# 3GPP_Release-2000

Schedule from MS Project, 1999-04-27 to 2010-09-10, A marks actual dates.

## Calendars

- Standard: Mon-Fri 08:00-12:00, 13:00-17:00; Sat-Sun off. Exceptions (off unless hours are given): 2000-01-15 08:00-12:00, 13:00-17:00, 2009-05-30 08:00-12:00, 13:00-17:00.

## Resources

| Resource |
| --- |
| NP |
| N1 |
| N2 |
| N3 |
| N4 |
| N5 |
| TP |
| T1 |
| T2 |
| T3 |
| RP |
| R1 |
| R2 |
| R3 |
| R4 |
| SP |
| S1 |
| S2 |
| S3 |
| S4 |
| S5 |
| PCG |
| GP |
| No |
| CN4 |
| ? |
| WG G2 |
| G2 |
| G1 |
| G4 |
| G3 |
| All |
| Generic |
| MLST |
| G5 |
| S3, G2 |
| WG T2 |
| GP,G1 |
| G4,G5 |
| OMA |
| GP-G2 |
| Yes |
| GP, |
| N4, |
| GP, N1 |
| CT5 |
| C5 |
| C1 |
| C4 |
| C3 |
| C6 |
| G1, |
| 4 |
| ct |
| c,s,r |
| CT,RAN,SA |
| G2, |
| G1, G3 |
| CT6 |
| CT1 |
| CT1, CT3, CT4 |
| C1, C3, C4 |
| CP |
| R5 |
| C |
| Rel-8 |
| GP, G2 |
| R1,R4 |
| S5,C1 |
| CT,RAN,SA,GERAN |
| S3,C1,C4 |
| 5 |
| S1,C1,C3,C4,S5 |
| S1,C1,C3,C5 |
| S1,C1,C3,C4 |
| S1,S5 |
| S2,S3 |
| RAN,SA |
| RP,S5 |
| S2,CT |
| S1,CT |
| S1,CT,GERAN |
| S1,C5 |
| S3,CT |
| S4,CT |
| C1,SA |
| S1,S2 |
| S1,S4 |
| S2,S2,S3,CT |
| S2,S3,CT |
| S1,CT,GX |
| S1,S4,CT |
| S2,S2,S3,S5,CT |
| S1,S2,CT |
| S1,S2,S3,CT |
| S1,S2,S3,S5CT |
| S1,S2,S3,S5,CT |
| S2,S5,CT |
| S4,S3 |
| S1,C1 |
| CP,C1 |
| C1,C3 |
| C1,C3,C4 |
| S1,S5,CT |
| C4,C3 |
| CP,RAN,SA,GERAN |
| S1,S2,S3,S5,CP |
| S2,S3,CP |
| S2,CP |
| S1,CP,GX |
| S1,CP |
| S1,S4,CP |
| S1,S2,CP |
| S1,S2,S3,CP |
| S2,S5,CP |
| S3,CP |
| S1,S5,CP |
| RAN,SA,GERAN |
| S1,S2,S3,S5,C1,C3,C4,C6 |
| S2,S3,C1,C3,C4 |
| S2,C4 |
| S2,C1,C3,C4 |
| S2,C1,C4 |
| S2,S3,C1,C4 |
| S1,C1,C4,G2 |
| C1,C4 |
| S1,C1,C3 |
| S1,S4,C1,C3,C4 |
| S1,S2,S3,C1,C3,C4 |
| S2,S5,C3 |
| S1,S2,C1,C4 |
| S2,C1 |
| S2,C1,C3 |
| S3,C1,C3,C4 |
| S1,S5,C1,C3,C4 |
| S2,C3,C4 |
| C3,C1 |
| R2,R4 |
| R2,R5 |
| RP,R5 |
| RP,S5,R5 |
| R1,R5 |
| S1,C1,R5 |
| S1,C1,S4,R5 |
| GERAN |
| G3new |
| G1, G3new |
| C4,C1,C3 |
| R1.R4 |
| R1, R4 |
| R2,R3 |
| C3,C4 |
| S4,C3 |
| S4,C3,C1,C4 |
| S1,S2,C1 |
| S1,S2<C1,C3,C4 |
| S1,S2,C1,C3,C4 |
| S5,C1,C3,C4 |
| GP,C4 |
| C4,C1 |
| S2,S1 |
| RP,SP,GP |
| RP,SP,CP,GP |
| CP,GP,RP,SP |
| GP,C4,S4 |
| S1,C1,C4 |
| S1,S2,C3,C1 |
| R2,R4,R3 |
| CP,GP, RP,SP |
| S2,S1,C1,S5 |
| S2,S1,C1 |
| S1,C1,S4 |
| S1,S2,GP,C4,R2 |
| S1,GP,R2 |
| S1,C6 |
| S1,S2,C1,S4 |
| S2,S3,S5,C1,C3,C4 |
| S2,S5,C1 |
| S2,S3,S5 |
| CP,GP, RP,SP,TP |
| S2,C4,C1 |
| S1,C1,C4,S3 |
| S2,S5 |
| S3,C1 |
| S3,C4 |
| S1,C4 |
| S2,S5,C3,C1 |
| S2,S1,S5,C1,C4 |
| S1,R1,C3 |
| S1,C1,R2 |
| S2,S1,C1,C4 |
| S1,C1,C6 |
| GP,S4,C4,C1,C3 |
| C3,C1,C4 |
| S1,C4,C1 |
| S1,S3 |
| S1,S2,S5,C3,C4 |
| R4,G1 |
| G1,R4 |
| RP,GP |
| R4,GP |
| R3,R2 |
| C6,RP,SP |
| R5,C6 |
| CP,RP,SP |
| RP,SP,CP |
| R3,S5 |
| S1,S2,RP |
| S1,S2,S5,RP |
| S2,S1,RP |
| Rel-9 |
| S3,C6 |
| S1,S2,S3,S5,RP |
| S2,S1,S3 |
| S1,S2,S3 |
| S1,S2,S3,S5 |
| C6,R5 |
| S1,S2,RP,GP |
| S1,S2,S4,S5,RP,GP |
| GP,G2 |
| GP,GP, N1 |
| GP,S2,G1,G2 |
| GP,R2,R3,S2,G1,G2 |
| GP,S2,S5,R2,R3,G2,G1 |
| GP,R3 |
| N4,S2 |
| GP,RP |
| GP,S2,RP |
| G5,G4 |
| G4,R3 |
| S2,R2,R4 |
| S1,S2,R2,R4 |
| GP,S5 |
| S1,S2,S5 |
| R4,R5 |
| R4,R2,R3,R5 |
| S2,S5,N4,RP |
| S1,S2,S3,S5,NP |
| S2,S4,S5 |
| T2,S1,S4,S5 |
| SP,RP |
| S2,RP |
| S1,S2,CP,G2 |
| CP,SP |
| S1,G2 |
| SP,CP |
| S1,S2,S5,C3 |
| S1,C1,S3 |
| G1,G3new |
| C4, C3, C1C4 |
| C4,C3,C1 |
| S1,S2,S3,S5,R2,R3,R4 |
| S1,S2,S3,R2 |
| S2,S3,S5,C4,R2 |
| S1,S5,C1 |
| S1,S2,S3,C1,C3,C4,R2 |
| Ggp |
| S3,S2,C1,C4,G2 G3new |
| R1,R2,R3,R4 |
| R4,R1,R2,R3 |
| R4,R2,R3 |
| S1,C1,C4,R2 |
| R4,R2 |
| S2,C4,R2,R4 |
| S2,C4,R2 |
| S2,S3,S5,C3,C4,R2 |
| S1,S2,S4,T2 |
| S1,S2,S4 |
| S1,S2,S4,R5 |
| S3,S2,C1,C4,G2,G3new |
| GP,C1 |

## Schedule

| ID | WBS | Task | Type | Duration | Start | Finish | Complete | Remaining | Baseline start | Baseline finish | Baseline duration | Total slack | Constraint | Resources | Work | Actual work | Text6 | Text1 | Text2 | Text4 | Text7 | Text8 |
| --- | --- | --- | --- | --- | --- | --- | --- | --- | --- | --- | --- | --- | --- | --- | --- | --- | --- | --- | --- | --- | --- | --- |
| 1 | 1 | Version 2009 Jun 12 |  | 2660d? | 2000-01-03 | 2010-03-10 |  |  | 2000-01-03 | 2010-03-10 | 2660d? | 132d | start no earlier than 2000-01-03 |  |  |  |  |  |  |  |  |  |
| 2 | 2 | SA2,SA3 Rel-9 Stage 2 exceptions to 09/2009 |  | 1d? | 2000-01-03 | 2000-01-03 |  |  | 2000-01-03 | 2000-01-03 | 1d? | 2791d |  |  |  |  |  |  |  |  |  |  |
| 3 | 3 | "CTRL + a" to display all the 3GPP fields |  | 1d | 2000-01-03 | 2000-01-03 |  |  | 2000-01-03 | 2000-01-03 | 1d | 2791d |  |  |  |  |  |  |  |  |  |  |
| 5 | 4 | Gantt: dark blue=done; light blue=to be done; grey: previous values; black=summary |  | 1d? | 2000-01-03 | 2000-01-03 |  |  | 2000-01-03 | 2000-01-03 | 1d? | 2791d | start no earlier than 2000-01-01 |  |  |  |  |  |  |  |  |  |
| 7 | 5 | Release 10 Features | milestone | 0d? | 2000-01-01 | 2000-01-01 |  |  | 2000-01-01 | 2000-01-01 | 0d? | 2792d |  | CP,SP |  |  | Rel-10 |  |  |  |  |  |
| 8 | 6 | **Network Selection for non-3GPP Access** |  | 526d? | 2007-12-07 | 2009-12-10 |  |  | 2007-12-07 | 2009-12-10 | 526d? | 196d |  | S1,C6 | 11740.8h |  | Rel-10 | N3GtoNSP | PCG-21 | Telefonica O2 | SP-38 | Alain |
| 9 | 6.1 | Stage 1 for N3GtoNSP |  | 526d? | 2007-12-07 | 2009-12-10 |  |  | 2007-12-07 | 2009-12-10 | 526d? | 196d | finish no earlier than 2009-12-10 | S1 | 4208h |  | Rel-10 | N3GtoNSP | PCG-21 | Telefonica O2 | SP-38 | Alain |
| 10 | 6.2 | CT6 issues for N3GtoNSP |  | 522d? | 2007-12-07 | 2009-12-04 |  |  | 2007-12-07 | 2009-12-04 | 522d? | 200d | finish no earlier than 2009-12-04 | C6 | 4176h |  | Rel-10 | N3GtoNSP | PCG-21 | Telefonica O2 | CP-38 | Xavier |
| 11 | 7 | **Network Improvements for Machine-type Communications** |  | 263d? | 2008-09-18 A | 2009-09-18 | 45% | 144.65d? | 2008-09-18 | 2009-09-18 | 263d? | 255d |  | S1 | 4208h | 1893.6h | Rel-10 | NIMTC | PCG-21 | KPN | SP-41 | Alain |
| 12 | 7.1 | Stage 1 for NIMTC |  | 263d? | 2008-09-18 A | 2009-09-18 | 45% | 144.65d? | 2008-09-18 | 2009-09-18 | 263d? | 255d | finish no earlier than 2009-09-18 | S1 | 2104h | 946.8h | Rel-10 | NIMTC | PCG-21 | KPN | SP-41 | Alain |
| 13 | 8 | **Registration in Densely-populated area (RED)** |  | 720d? | 2007-03-12 A | 2009-12-10 | 50% | 357.53d? | 2007-03-12 | 2009-12-10 | 720d? | 196d |  | S1,S2 | 10424h | 5247.76h | Rel-10 | RED |  | NTT DoCoMo | SP-35 | Alain |
| 14 | 8.1 | Stage 1 for RED |  | 4d? | 2007-03-12 A | 2007-03-15 A | 100% |  | 2007-03-12 | 2007-03-15 | 4d? |  | start no earlier than 2007-03-12 | S1 | 32h | 32h | Rel-10 | RED |  | NTT DoCoMo | SP-35 | Alain |
| 15 | 8.2 | Stage 2 for RED |  | 579d? | 2007-09-25 A | 2009-12-10 | 50% | 289.5d? | 2007-09-25 | 2009-12-10 | 579d? | 196d | finish no earlier than 2009-12-10 | S2 | 4632h | 2316h | Rel-10 | RED |  | NTT DoCoMo | SP-37 | Maurice |
| 16 | 9 | IMS Service Continuity – Inter Device Transfer enhancements |  | 136d? | 2009-06-04 | 2009-12-10 |  |  | 2009-06-04 | 2009-12-10 | 136d? | 196d | start no earlier than 2009-06-04 | S1 | 1088h |  | Rel-10 | IMS_SC_eIDT | PCG-23 | Huawei | SP-44 | Alain |
| 17 | 10 | **GTP-based S8 chaining** |  | 262d? | 2008-12-11 A | 2009-12-10 | 35% | 170.3d? | 2008-12-11 | 2009-12-10 | 262d? | 196d |  | S2 | 4192h | 1467.2h | Rel-10 | GTPchaining | PCG-22 | Huawei | SP-42 | Maurice |
| 18 | 10.1 | Stage 2 for GTPchaining |  | 262d? | 2008-12-11 A | 2009-12-10 | 35% | 170.3d? | 2008-12-11 | 2009-12-10 | 262d? | 196d | finish no earlier than 2009-12-10 | S2 | 2096h | 733.6h | Rel-10 | GTPchaining | PCG-22 | Huawei | SP-42 | Maurice |
| 19 | 11 | Multi Access PDN Connectivity |  | 196d? | 2009-03-13 | 2009-12-10 |  |  | 2009-03-13 | 2009-12-10 | 196d? | 196d | finish no earlier than 2009-12-10 | S2 | 1568h |  | Rel-10 | MAPCON | PCG-22 | Telecom Italia | SP-43 | Maurice |
| 20 | 12 | **Enhanced Home NodeB / eNodeB continuation of Rel-9** |  | 262d? | 2008-12-11 A | 2009-12-10 | 35% | 170.3d? | 2008-12-11 | 2009-12-10 | 262d? | 196d |  | S2 | 4184h | 1464.4h | Rel-10 | eEHNB | PCG-23 |  | SP-44 | Maurice |
| 21 | 12.1 | IMS aspects of Architecture for Home NodeB |  | 261d? | 2008-12-11 A | 2009-12-10 | 35% | 169.65d? | 2008-12-11 | 2009-12-10 | 261d? | 196d | finish no earlier than 2009-12-10 | S2 | 2088h | 730.8h | Rel-10 | EHNB-IMS | PCG-22 | Alcatel-Lucent | SP-42 | Maurice |
| 22 | 13 | EEA3 and EIA3 (new Encryption & Integrity EPS security algorithms) |  | 266d? | 2009-06-04 | 2010-06-10 |  |  | 2009-06-04 | 2010-06-10 | 266d? | 66d | finish no earlier than 2010-06-10 | S3 | 2128h |  | Rel-10 | EEA3_EIA3 | PCG-23 | CATR | SP-44 | Dionisio |
| 23 | 14 | (Small) Technical Enhancements and Improvements for Rel-10 |  | 136d? | 2009-06-04 | 2009-12-10 |  |  | 2009-06-04 | 2009-12-10 | 136d? | 196d | finish no earlier than 2009-12-10 | All | 1088h |  | Rel-10 | TEI10 | PCG-23 | ALL | SP-44 |  |
| 24 | 15 | Release 10 Feasibility Studies | milestone | 0d? | 2000-01-01 | 2000-01-01 |  |  | 2000-01-01 | 2000-01-01 | 0d? | 2792d | start no earlier than 2000-01-01 | SP |  |  | Rel-10 |  |  |  |  |  |
| 25 | 16 | Study on Mobile Haptic Services |  | 262d? | 2009-03-12 A | 2010-03-11 | 30% | 182.7d? | 2009-03-12 | 2010-03-11 | 262d? | 131d | finish no earlier than 2010-03-11 | S1 | 2088h | 626.4h | Rel-10 | FS_Haptics | PCG-22 | SK Telecom | SP-43 | Alain |
| 26 | 17 | Study on advanced requirements for IP interconnect |  | 528d? | 2007-12-04 A | 2009-12-10 | 60% | 211.2d? | 2007-12-04 | 2009-12-10 | 528d? | 196d | finish no earlier than 2009-12-10 | S1 | 4224h | 2534.4h | Rel-10 | FS_IPXS | PCG-21 | Telefonica O2 | SP-38 | Alain |
| 27 | 18 | Study on Unauthenticated PS Emergency Calls |  | 396d? | 2008-06-05 A | 2009-12-10 | 20% | 316.8d? | 2008-06-05 | 2009-12-10 | 396d? | 196d | finish no earlier than 2009-12-10 | S1 | 3168h | 633.6h | Rel-10 | FS_UAPSEC | PCG-21 | Nokia Siemens Networks | SP-40 | Alain |
| 28 | 19 | Study on Personal Broadcast Service |  | 322d? | 2008-09-18 A | 2009-12-10 | 75% | 80.25d? | 2008-09-18 | 2009-12-10 | 322d? | 196d | finish no earlier than 2009-12-10 | S1 | 2568h | 1926h | Rel-10 | FS_PBS | PCG-21 | ETRI | SP-41 | Alain |
| 29 | 20 | Study on LCS support in SAE for non-3GPP accesses |  | 322d? | 2008-09-18 A | 2009-12-10 | 70% | 96.3d? | 2008-09-18 | 2009-12-10 | 322d? | 196d | finish no earlier than 2009-12-10 | S1 | 2568h | 1797.6h | Rel-10 | FS_LCS_n3GPP | PCG-21 | SK Telecom | SP-41 | Alain |
| 30 | 21 | Study on System enhancements for the use of IMS services in local breakout and optimal routing of media |  | 575d? | 2007-10-01 A | 2009-12-10 | 60% | 230d? | 2007-10-01 | 2009-12-10 | 575d? | 196d | finish no earlier than 2009-12-10 | S2 | 4600h | 2760h | Rel-10 | FS_IMS_LBO_ORM |  | Telecom Italia, BT | SP-37 | Maurice |
| 31 | 22 | Study on Intra Domain Connection of RAN Nodes to Multiple CN Nodes |  | 458d? | 2008-03-12 A | 2009-12-10 | 50% | 229d? | 2008-03-12 | 2009-12-10 | 458d? | 196d | finish no earlier than 2009-12-10 | S2 | 3664h | 1832h | Rel-10 | FS_IDC | PCG-21 | China Mobile | SP-39 | Maurice |
| 32 | 23 | Study on IMS Evolution |  | 322d? | 2008-09-18 A | 2009-12-10 | 15% | 273.7d? | 2008-09-18 | 2009-12-10 | 322d? | 196d | finish no earlier than 2009-12-10 | S2 | 2576h | 386.4h | Rel-10 | FS_eIMS | PCG-21 | China Mobile | SP-41 | Maurice |
| 33 | 24 | Study on enhancements to IMS border functions for IMS Interconnection of services |  | 322d? | 2008-09-18 A | 2009-12-10 | 15% | 273.7d? | 2008-09-18 | 2009-12-10 | 322d? | 196d | finish no earlier than 2009-12-10 | S2 | 2576h | 386.4h | Rel-10 | FS_eIMS_IBCF | PCG-21 | Starent Networks | SP-41 | Maurice |
| 34 | 25 | Study on Policy solutions and enhancements |  | 136d? | 2009-06-04 | 2009-12-10 |  |  | 2009-06-04 | 2009-12-10 | 136d? | 196d | finish no earlier than 2009-12-10 | S2,S1 | 1088h |  | Rel-10 | FS_PP | PCG-23 | AT&T | SP-44 | Maurice |
| 35 | 26 | Study on IPv6 Migration |  | 206d? | 2009-06-04 | 2010-03-18 |  |  | 2009-06-04 | 2010-03-18 | 206d? | 126d | finish no earlier than 2010-03-18 | S2 | 1648h |  | Rel-10 | FS_IP6M | PCG-23 | China Mobile | SP-44 | Maurice |
| 36 | 27 | Study on SR-VCC Enhancements |  | 206d? | 2009-06-04 | 2010-03-18 |  |  | 2009-06-04 | 2010-03-18 | 206d? | 126d | finish no earlier than 2010-03-18 | S2 | 1648h |  | Rel-10 | FS_eSRVCC | PCG-23 | China Mobile | SP-44 | Maurice |
| 37 | 28 | Release 9 Features | milestone | 0d? | 2000-01-01 | 2000-01-01 |  |  | 2000-01-01 | 2000-01-01 | 0d? | 2792d |  | CP,GP,RP,SP |  |  | Rel-9 |  |  |  |  |  |

Notes:
- 8: SP#44 last chance before stopping the WI at SA#45 / Text5: chris.friel@O2.com
- 9: SP#44 last chance before stopping the WI at SA#45 / Text3: 22.011 / Text5: chris.friel@O2.com
- 10: SP#44 last chance before stopping the WI at SA#45 / Text3: 22.234, 21.111, 31.101, 31.102, 31.103 / Text5: chris.friel@O2.com
- 11: SA#42 moved to Rel-10 / Text5: Toon Norp (toon.norp AT tno.nl)
- 12: SA#42 moved to Rel-10 / Text3: 22.368 / Text5: Toon Norp (toon.norp AT tno.nl)
- 13: SA#35 Stage 1 completed. SA#40 SA2 moved to Rel-9. SA#43 moved to Rel-10. / Text3: WID identifies also impacted CT1 24.008, RAN2 25.331 / Text5: tanakai@nttdocomo.co.jp
- 14: SA#35 completed. / Text3: 22.101 CR#0207 / Text5: takakurat@s1.nttdocomo.co.jp
- 15: SA#40 SA2 moved to Rel-9. SA#43 moved to Rel-10. / Text3: 23.880, 23.002, 23.060, 23.221, 23.236 / Text5: tanakai@nttdocomo.co.jp
- 16: Rel-9 set Inter-Device Transfer requirements UID_410033 (IMS_SCC-IDT). Add additional scenarios and requirements for IDT. / Text3: 22.228 / Text5: Amar Deol (adeol@huawei.com)
- 17: SA#44 moved to Rel-10. Stage 1 in UID_320022 Rel-8 Requirements for evolution of the 3GPP system architecture (AIPN-SAE): 22.278, 22.011, 22.246 / Text5: Haining Wang (wanghaining@huawei.com)
- 18: SA#44 moved to Rel-10 / Text3: 23.402 (Chaining GTP-S8 based architecture and procedures) / Text5: Haining Wang (wanghaining@huawei.com)
- 19: SA#44 moved to Rel-10. Completion 06/09=>12/09. Triggered by UID_410043 Study on Multi Access PDN connectivity and IP flow mobility. Stage 1 in Rel-9 22.278 (6.2 - IP session control) / Text3: 23.401, 23.402 / Text5: ivano.guardini@telecomitalia.it
- 20: SA#44 Umbrella Feature created to host WIs moved out of Rel-9
- 21: SA#44 Moved from Rel-9 to Rel-10 / Text3: 23.832, TS 23.xyz (IMS Aspects of Architecture for Home NodeBs) / Text5: Nicolas Drevon
- 22: develop new EPS algorithms acceptable to regions such as China / Text3: 35.xxx (EEA3 & EIA3 Algorithm Specification, Implementors’ test data, Design and evaluation report, Final project report), 33.401 (SAE Security Architecture) / Text5: Yuan Qi, yuanqi@mail.ritt.com.cn
- 25: Haptic - human-machine tactile communication - could extend the service offerings and richness of mobile user experience beyond the current visual and auditory senses / Text3: 22.9xy / Text5: Donghee Shim
- 26: Text3: 22.893 / Text5: chris.friel@O2.com
- 27: SA#44 stagnating at 20% / Text3: 22.984 / Text5: Juergen Merkel
- 28: Text3: 22.947 / Text5: Jaihyung Cho
- 29: SA#44 TR 22.913 V100 for Information / Text3: 22.913 / Text5: Donghee Shim
- 30: SA#43 TR 23.894 for Information / Text3: 23.894 / Text5: mario.madella@telecomitalia.it, victor.kueh@bt.com
- 31: Linked to 23.236 / Text3: 23.823 / Text5: LIU HONG (liuhongyfw@chinamobile.com)
- 32: Text3: 23.812 / Text5: Li Gang (ligangyf@chinamobile.com), Yu Qing (yuqing@chinamobile.com)
- 33: Text3: 23.848 / Text5: Rajat Ghai (rghai@starentnetworks.com)
- 34: Study an evolved policy solution through enhancement of 3GPP policy framework (Stage 2). Consider aspects such as DPI, traffic steering, enhancing service policies. / Text3: 23.9yz (Study on policy solutions and enhancements) / Text5: farooq.bari@att.com
- 35: Study how to migrate from IPv4 to IPv6-only with the help of transition mechanisms defined in IETF, and how to handle scenarios where not all services are provided via IPv6. Some of these solutions may have impacts on 3GPP network elements and terminals. / Text3: 23.9xy (IPv6 migration guidelines) / Text5: Li Lianyuan (lilianyuan@chinamobile.com), Liu Hong (liuhongyfw@chinamobile.com)
- 36: Analyze current performance of SR-VCC solution in Rel-8 from E-UTRAN/HSPA to UTRAN/GERAN, and then evaluate additional mechanisms to improve user experience. Study if SR-VCC performance needs to be enhanced. / Text3: 23.8bc (Feasibility study of SR-VCC enhancements) / Text5: houzhiqiang@chinamobile.com, jiangyi@chinamobile.com

| ID | WBS | Task | Type | Duration | Start | Finish | Complete | Remaining | Baseline start | Baseline finish | Baseline duration | Total slack | Constraint | Resources | Work | Actual work | Text1 | Text4 | Text5 | Text6 | Text7 | Text8 | Text2 | Text3 |
| --- | --- | --- | --- | --- | --- | --- | --- | --- | --- | --- | --- | --- | --- | --- | --- | --- | --- | --- | --- | --- | --- | --- | --- | --- |
| 38 | 29 | **Services Alignment and Migration** |  | 467d? | 2006-12-06 A | 2008-09-18 A | 100% |  | 2006-12-06 | 2008-09-18 | 467d? |  |  | S1 | 7472h | 7472h | ServAl | China Mobile | fenglingjuan@chinamobile.com | Rel-9 | SP-33 | Alain |  |  |
| 39 | 29.1 | Stage 1 for ServAl |  | 467d? | 2006-12-06 A | 2008-09-18 A | 100% |  | 2006-12-06 | 2008-09-18 | 467d? |  | finish no earlier than 2008-12-11 | S1 | 3736h | 3736h | ServAl | China Mobile | fenglingjuan@chinamobile.com | Rel-9 | SP-33 | Alain | PCG-21 | 22.182 |
| 40 | 30 | **Value-Added Services for Short Message Service** |  | 586d? | 2007-09-10 A | 2009-12-04 | 46% | 315.13d? | 2007-09-10 | 2009-12-04 | 586d? | 200d |  | S1,C4,C1 | 10888h | 3925.6h | VAS4SMS | China Mobile | Wu Bin (wubin@chinamobile.com) | Rel-9 | SP-37 | Alain |  |  |
| 41 | 30.1 | Stage 1 for VAS4SMS |  | 133d? | 2007-09-10 A | 2008-03-12 A | 100% |  | 2007-09-10 | 2008-03-12 | 133d? |  | finish no earlier than 2008-03-21 | S1 | 1064h | 1064h | VAS4SMS | China Mobile | Wu Bin (wubin@chinamobile.com) | Rel-9 | SP-37 | Alain |  | 22.142 |
| 42 | 30.2 | VAS4SMS Interface and Signalling Flow - CT4 aspects |  | 322d? | 2008-09-12 A | 2009-12-04 | 70% | 96.3d? | 2008-09-12 | 2009-12-04 | 322d? | 200d | finish no earlier than 2009-12-04 | C4 | 2568h | 1797.6h | VAS4SMS | China Mobile | Wu Bin (wubin@chinamobile.com) | Rel-9 | CP-41 | Kimmo | PCG-21 | 23.142, 29.002 |
| 43 | 30.3 | VAS4SMS Interface and Signalling Flow - CT1 aspects |  | 321d? | 2008-09-09 | 2009-12-04 |  |  | 2008-09-09 | 2009-12-04 | 321d? | 200d | finish no earlier than 2009-12-04 | C1 | 2568h |  | VAS4SMS | China Mobile | Wu Bin (wubin@chinamobile.com) | Rel-9 | CP-41 | Frederic | PCG-21 | 23.040 |
| 44 | 31 | **End-User Identity** |  | 334d? | 2007-09-03 A | 2008-12-11 A | 100% |  | 2007-09-03 | 2008-12-11 | 334d? |  |  | S1 | 5344h | 5344h | EUI | Nokia Siemens Networks | Juergen.Merkel@NSN.com | Rel-9 | SP-38 | Alain |  |  |
| 45 | 31.1 | Definition of EUI |  | 334d? | 2007-09-03 A | 2008-12-11 A | 100% |  | 2007-09-03 | 2008-12-11 | 334d? |  | finish no earlier than 2008-12-11 | S1 | 2672h | 2672h | EUI | Nokia Siemens Networks | Juergen.Merkel@NSN.com | Rel-9 | SP-38 | Alain | PCG-21 | 21.905 |
| 46 | 32 | **Customized Ringing Signal** |  | 522d? | 2007-12-06 A | 2009-12-03 | 66% | 176.6d? | 2007-12-06 | 2009-12-03 | 522d? | 201d |  | S1,C1 | 7120h | 4256h | CRS | SK Telecom, China Mobile | Donghee Shim (SK Telecom), Jianping Zheng (China Mobile) | Rel-9 | SP-38 | Alain | PCG-21 |  |
| 47 | 32.1 | Stage 1 for CRS |  | 266d? | 2007-12-06 A | 2008-12-11 A | 100% |  | 2007-12-06 | 2008-12-11 | 266d? |  | finish no earlier than 2008-12-11 | S1 | 2128h | 2128h | CRS | SK Telecom, China Mobile | Donghee Shim (SK Telecom), Jianping Zheng (China Mobile) | Rel-9 | SP-38 | Alain | PCG-21 | 22.183, 22.173 |
| 48 | 32.2 | Stage 3 for IMS CRS Service |  | 136d? | 2009-05-29 | 2009-12-03 |  |  | 2009-05-29 | 2009-12-03 | 136d? | 201d | start no earlier than 2009-05-29 | C1 | 816h |  | CRS | China Mobile | wangzhao | Rel-9 | CP-44 | Frederic | PCG-23 | 24.173, 24.abc (IMS Customized Ringing Signal Service) |
| 49 | 33 | **Public Warning System** |  | 523d? | 2007-12-06 A | 2009-12-04 | 50% | 263.44d? | 2007-12-06 | 2009-12-04 | 523d? | 200d |  | S1,C1,C4,R2 | 10672h | 5018.42h | PWS | T-Mobile | Mark.Younge@t-mobile.com | Rel-9 | SP-38 | Alain | PCG-21 |  |
| 50 | 33.1 | Stage 1 for PWS |  | 266d? | 2007-12-06 A | 2008-12-11 A | 100% |  | 2007-12-06 | 2008-12-11 | 266d? |  | finish no earlier than 2008-12-11 | S1 | 2128h | 2128h | PWS | T-Mobile | Mark.Younge@t-mobile.com | Rel-9 | SP-38 | Alain | PCG-21 | 22.268 |
| 51 | 33.2 | **Stage 3 for PWS** |  | 137d? | 2009-05-29 A | 2009-12-04 | 25% | 102.37d? | 2009-05-29 | 2009-12-04 | 137d? | 200d |  | C1,C4 | 3272h | 821.01h | PWS-St3 | Qualcomm | Ramachandran Subramanian (rsubrama@qualcomm.com) | Rel-9 | CP-44 | Frederic | PCG-23 |  |
| 52 | 33.2.1 | CT1 aspects of PWS-St3 |  | 137d? | 2009-05-29 A | 2009-12-04 | 50% | 68d? | 2009-05-29 | 2009-12-04 | 137d? | 200d | finish no earlier than 2009-12-04 | C1 | 1088h | 544h | PWS-St3 | Qualcomm | Ramachandran Subramanian (rsubrama@qualcomm.com) | Rel-9 | CP-44 | Frederic | PCG-23 | 23.041 |
| 53 | 33.2.2 | CT4 aspects of PWS-St3 |  | 136d? | 2009-05-30 | 2009-12-04 |  |  | 2009-05-30 | 2009-12-04 | 136d? | 200d | finish no earlier than 2009-12-04 | C4 | 1088h |  | PWS-St3 | Qualcomm | Ramachandran Subramanian (rsubrama@qualcomm.com) | Rel-9 | CP-44 | Kimmo | PCG-23 | 29.168 |
| 54 | 33.3 | RAN aspects of PWS |  | 136d? | 2009-05-30 | 2009-12-04 |  |  | 2009-05-30 | 2009-12-04 | 136d? | 200d | finish no earlier than 2009-12-04 | R2 | 1088h |  | PWS-RAN | AT&T | Don Zelmer (dz1069@att.com) | Rel-9 | RP-44 | Joern | PCG-23 | 36.300, 36.331, 36.413 |
| 55 | 34 | **Enhancements to Multimedia Priority Service** |  | 584d? | 2006-03-13 A | 2008-06-05 A | 100% |  | 2006-03-13 | 2008-06-05 | 584d? |  |  | S1 | 4672h | 4672h | ePRIOR | Telcordia | jgarraha@telcordia.com | Rel-9 | SP-39 | Alain | PCG-21 |  |
| 56 | 34.1 | Stage 1 for ePRIOR |  | 584d? | 2006-03-13 A | 2008-06-05 A | 100% |  | 2006-03-13 | 2008-06-05 | 584d? |  | start no earlier than 2006-03-12 | S1 | 4672h | 4672h | ePRIOR | Telcordia | jgarraha@telcordia.com | Rel-9 | SP-39 | Alain | PCG-21 | 22.153, 22.278 |
| 57 | 35 | **Support of Personal Area Networks and Enhancements to Personal Network Management** |  | 393d? | 2008-06-05 A | 2009-12-04 | 2% | 384.78d? | 2008-06-05 | 2009-12-04 | 393d? | 200d |  | S1,C1 | 5840h | 122.17h | PAN_EPNM | Vodafone | armin.toepfer@vodafone.com | Rel-9 | SP-40 | Alain | PCG-21 |  |
| 58 | 35.1 | Stage 1 for PAN_EPNM | milestone | 0d? | 2008-06-05 A | 2008-06-05 A | 100% |  | 2008-06-05 | 2008-06-05 | 0d? |  | finish no earlier than 2008-06-05 | S1 |  |  | PAN_EPNM | Vodafone | armin.toepfer@vodafone.com | Rel-9 | SP-40 | Alain | PCG-21 | 22.259 |
| 59 | 35.2 | Stage 2 for PAN_EPNM |  | 141d? | 2009-03-06 A | 2009-09-18 | 5% | 133.95d? | 2009-03-06 | 2009-09-18 | 141d? | 255d | finish no earlier than 2009-09-18 | C1 | 1128h | 56.4h | PAN_EPNM | Huawei | Lili Yang (kadyyang@huawei.com) | Rel-9 | CP-43 | Frederic | PCG-22 | 23.259 |
| 60 | 35.3 | Stage 3 for PAN_EPNM |  | 196d? | 2009-03-09 | 2009-12-04 |  |  | 2009-03-09 | 2009-12-04 | 196d? | 200d | finish no earlier than 2009-12-04 | C1 | 1568h |  | PAN_EPNM | Huawei | Lili Yang (kadyyang@huawei.com) | Rel-9 | CP-43 | Frederic | PCG-22 | 24.259 |
| 61 | 36 | **Multi-Media Telephony Service enhancements** |  | 397d? | 2008-06-05 A | 2009-12-10 | 43% | 227.45d? | 2008-06-05 | 2009-12-10 | 397d? | 196d |  | S1,S5,C1 | 8488h | 3620.37h | eMMTel | France Telecom | Philippe Lottin | Rel-9 | SP-40 | Alain | PCG-21 |  |
| 62 | 36.1 | Stage 1 for eMMTel |  | 136d? | 2008-06-05 A | 2008-12-11 A | 100% |  | 2008-06-05 | 2008-12-11 | 136d? |  | start no earlier than 2008-06-05 | S1 | 1088h | 1088h | eMMTel | France Telecom | Philippe Lottin | Rel-9 | SP-40 | Alain | PCG-21 | 22.173 |
| 63 | 36.2 | Multimedia Telephony (MMTel) Service and Supplementary Services - Online Charging and completion for Offline Charging (all supplementary services) |  | 197d? | 2009-03-12 A | 2009-12-10 | 50% | 98d? | 2009-03-12 | 2009-12-10 | 197d? | 196d | finish no earlier than 2009-12-10 | S5 | 1568h | 784h | eMMTel-SS-CH | Alcatel-Lucent | Maryse.Gardella@alcatel-lucent.fr | Rel-9 | SP-43 | Dionisio | PCG-22 | 32.275, 32.298, 32.299 |
| 64 | 36.3 | Support of Real-time Transfer of Tariff Information (RTTI) in IMS charging |  | 196d? | 2009-03-12 A | 2009-12-10 | 25% | 147d? | 2009-03-12 | 2009-12-10 | 196d? | 196d | finish no earlier than 2009-12-10 | S5 | 1568h | 392h | IMSTSS-RTTI-CH | Orange | Jean-Luc Garcia (jl.garcia@orange-ftgroup.com) | Rel-9 | SP-43 | Dionisio | PCG-22 | 32.27x, 32.240, 32.280, 32.298, 32.299 |
| 65 | 36.4 | Stage 3 - Enhancements for Completion of Communications Supplementary service |  | 136d? | 2009-05-30 | 2009-12-04 |  |  | 2009-05-30 | 2009-12-04 | 136d? | 200d | finish no earlier than 2009-12-04 | C1 | 1088h |  | eMMTel-CC | France Telecom | Youssef.chadli@orange-ftgroup.com | Rel-9 | CP-44 | Frederic | PCG-23 | 24.642 |

Notes:
- 38: SA#41 Stage 1 completed. Triggered by Study UID_370086 (FSServAl).
- 39: SA#41 completed
- 40: SA#43 Feature moved to Rel-9. Stage 1 TS 22.142 promoted to Rel-9 and dismissed the Rel-8 version.
- 41: SA#39 completed. SA#43 Feature moved to Rel-9. Stage 1 TS 22.142 promoted to Rel-9 and dismissed the Rel-8 version.
- 42: CT#43 moved to Rel-9. WID updated CP-080721=>CP-090021
- 43: CT#43 moved to Rel-9. WID updated CP-080721=>CP-090021
- 44: SP#44 WID updated SP-070651=>SP-090380 (reduced scope of the work)
- 45: SP#44 WID updated SP-070651=>SP-090380 (reduced scope of the work)
- 46: SA#42 Stage 1 completed (need for Input in SA2). SA#41 WID updated SP-070875=>SP-080502
- 47: SA#42 completed.
- 49: SA#42 Stage 1 completed. Larger scope than Rel-8 Feature UID_370051 (ETWS). Triggered by TR 22.968 Study UID_320025 (FS_PWS).
- 50: SA#42 completed.
- 54: Extend Warning System support of E-UTRA/E-UTRAN beyond Rel-8 ETWS by providing support for multiple parallel Warning Notifications, etc.
- 55: SA#40 Stage 1 completed. Continuation of Rel-8 Feature PRIOR UID_340044.
- 56: SA#40 completed
- 57: SA#40 WID approved & Stage 1 completed
- 58: SA#40 Stage 1 completed
- 59: CP#44 WID updated CP-090113=>CP-090435 Removed: Mechanism for a PNE without a (U)SIM capable of discovering PNEs with a (U)SIM in its proximity
- 60: CP#44 WID updated CP-090113=>CP-090435 Removed: Mechanism for a PNE without a (U)SIM capable of discovering PNEs with a (U)SIM in its proximity
- 61: SA#42 Stage 1 completed. SA#41 WID updated SP-080324=>SP-080503
- 62: SA#42 completed. SA#41 WID updated SP-080324=>SP-080503
- 64: SA#44 WID updated SP-090055=>SP-090306. Linked to SA5 Rel-8 UID_380042 AoC support in IMS Charging (IMSTSS). SA3/CT3 coordination need on 29.658 (SIP transfer of tariff information)

| ID | WBS | Task | Duration | Start | Finish | Complete | Remaining | Baseline start | Baseline finish | Baseline duration | Total slack | Constraint | Resources | Work | Actual work | Text1 | Text2 | Text4 | Text5 | Text6 | Text7 | Text8 | Text11 |
| --- | --- | --- | --- | --- | --- | --- | --- | --- | --- | --- | --- | --- | --- | --- | --- | --- | --- | --- | --- | --- | --- | --- | --- |
| 66 | 37 | **User Data Convergence** | 403d? | 2008-06-05 A | 2009-12-18 | 26% | 300.22d? | 2008-06-05 | 2009-12-18 | 403d? | 190d |  | S1,C4 | 8136h | 1252.8h | UDC | PCG-21 | China Mobile | lansizhong@chinamobile.com | Rel-9 | SP-40 | Alain |  |
| 67 | 37.1 | Stage 1 for UDC | 136d? | 2008-06-05 A | 2008-12-11 A | 100% |  | 2008-06-05 | 2008-12-11 | 136d? |  | start no earlier than 2008-06-05 | S1 | 1088h | 1088h | UDC | PCG-21 | China Mobile | lansizhong@chinamobile.com | Rel-9 | SP-40 | Alain |  |
| 68 | 37.2 | UDC Technical Realization (Stage 2) | 206d? | 2009-03-06 A | 2009-12-18 | 10% | 185.4d? | 2009-03-06 | 2009-12-18 | 206d? | 190d | finish no earlier than 2009-12-18 | C4 | 1648h | 164.8h | UDC-CN | PCG-22 | Ericsson | Emiliano Merino (emiliano.merino@ericsson.com) | Rel-9 | CP-43 | Kimmo |  |
| 69 | 37.3 | **User Data Convergence - Modelling and Management** | 136d? | 2009-06-04 | 2009-12-10 |  |  | 2009-06-04 | 2009-12-10 | 136d? | 196d |  | S5 | 3264h |  | UDC-MMAN | PCG-23 | T-Mobile, China Mobile, Ericsson | Istvan Aba, Lan Si Zhong, Miguel Garcia | Rel-9 | SP-44 | Dionisio |  |
| 70 | 37.3.1 | UDC – Common Baseline Information Model | 136d? | 2009-06-04 | 2009-12-10 |  |  | 2009-06-04 | 2009-12-10 | 136d? | 196d | start no earlier than 2009-06-04 | S5 | 1088h |  | UDC-MMAN-CBIM | PCG-23 | China Mobile, Ericsson | Istvan Aba, Lan Si Zhong, Miguel Garcia | Rel-9 | SP-44 | Dionisio |  |
| 71 | 37.3.2 | UDC – Framework for Model Handling and Management | 136d? | 2009-06-04 | 2009-12-10 |  |  | 2009-06-04 | 2009-12-10 | 136d? | 196d | start no earlier than 2009-06-04 | S5 | 1088h |  | UDC-MMAN-MFRM | PCG-23 | T-Mobile | istvan.aba <at> t-mobile.at | Rel-9 | SP-44 | Dionisio |  |
| 72 | 38 | **Enhanced Home NodeB / eNodeB** | 397d? | 2008-06-05 A | 2009-12-10 | 35% | 256.99d? | 2008-06-05 | 2009-12-10 | 397d? | 196d |  | S1,S2,S3,S5,R2,R3,R4 | 21784h | 7677.26h | EHNB | PCG-21 | T-Mobile | michael.kurz@t-mobile.at | Rel-9 | SP-40 | Alain |  |
| 73 | 38.1 | Stage 1 for EHNB | 261d? | 2008-06-05 A | 2009-06-04 A | 100% |  | 2008-06-05 | 2009-06-04 | 261d? |  | finish no earlier than 2009-06-04 | S1 | 2088h | 2088h | EHNB | PCG-21 | T-Mobile | michael.kurz@t-mobile.at | Rel-9 | SP-40 | Alain |  |
| 74 | 38.2 | Architecture aspects of EHNB | 266d? | 2008-09-18 A | 2009-09-24 | 75% | 66.5d? | 2008-09-18 | 2009-09-24 | 266d? | 251d | finish no earlier than 2009-09-24 | S2 | 2128h | 1596h | EHNB | PCG-21 | T-Mobile | Sebastian Speicher | Rel-9 | SP-41 | Maurice |  |
| 75 | 38.3 | Security aspects of Enhanced Home NodeB / eNodeB | 207d? | 2008-12-11 A | 2009-09-24 | 50% | 103.5d? | 2008-12-11 | 2009-09-24 | 207d? | 251d | finish no earlier than 2009-09-24 | S3 | 1656h | 828h | EHNB-Sec | PCG-22 | Huawei | Marcus Wong (mwong@huawei.com) | Rel-9 | SP-42 | Dionisio |  |
| 76 | 38.4 | 3G HNB Gateway and LTE HeNB Gateway OAM&P | 261d? | 2008-12-11 A | 2009-12-10 | 25% | 195.75d? | 2008-12-11 | 2009-12-10 | 261d? | 196d | finish no earlier than 2009-12-10 | S5 | 2088h | 522h | HNB-OAM_GW | PCG-22 | China Mobile | GangChen (chengang@chinamobile.com) | Rel-9 | SP-42 | Dionisio |  |
| 77 | 38.5 | 3G HNB and LTE HeNB OAM&P Type 1 Interface | 197d? | 2009-03-12 A | 2009-12-10 | 30% | 137.2d? | 2009-03-12 | 2009-12-10 | 197d? | 196d | finish no earlier than 2009-12-10 | S5 | 1568h | 470.4h | HNB_eHNB-OAM_Type1 | PCG-22 | Huawei | Zou Lan (zlan@huawei.com) | Rel-9 | SP-43 | Dionisio |  |
| 78 | 38.6 | 3G HNB and LTE HeNB OAM&P Type 2 Interface | 150d? | 2009-05-15 A | 2009-12-10 | 5% | 142.5d? | 2009-05-15 | 2009-12-10 | 150d? | 196d | finish no earlier than 2009-12-10 | S5 | 1200h | 60h | HNB_eHNB-OAM_Type2 | PCG-23 | Ericsson | edwin.tse@ericsson.com | Rel-9 | SP-44 | Dionisio |  |
| 79 | 38.7 | LTE FDD Home eNodeB RF Requirements | 261d? | 2008-12-05 A | 2009-12-04 | 10% | 234.9d? | 2008-12-05 | 2009-12-04 | 261d? | 200d | finish no earlier than 2009-12-04 | R4 | 2088h | 208.8h | HeNB-RF_FDD | PCG-22 | Motorola | Ying Cai (yingcai@motorola.com) | Rel-9 | RP-42 | Stefania | RP-090627 |
| 80 | 38.8 | LTE TDD Home eNodeB RF Requirements | 196d? | 2009-03-06 A | 2009-12-04 | 10% | 176.4d? | 2009-03-06 | 2009-12-04 | 196d? | 200d | finish no earlier than 2009-12-04 | R4 | 1568h | 156.8h | HeNB-RF_TDD | PCG-22 | China Mobile | Nan Li (linan@chinamobile.com) | Rel-9 | RP-43 | Stefania | RP-090407 |
| 81 | 38.9 | Home NB and Home eNB enhancements - RAN3 aspects | 196d? | 2009-03-06 A | 2009-12-04 | 20% | 156.8d? | 2009-03-06 | 2009-12-04 | 196d? | 200d | finish no earlier than 2009-12-04 | R3 | 1568h | 313.6h | EHNB-RAN3 | PCG-22 | Alcatel-Lucent | Martin Warner (mw15@alcatel-lucent.com) | Rel-9 | RP-43 | Juha | RP-090409 |
| 82 | 38.10 | Home NB and Home eNB enhancements - RAN2 aspects | 196d? | 2009-03-06 A | 2009-12-04 | 20% | 156.8d? | 2009-03-06 | 2009-12-04 | 196d? | 200d | finish no earlier than 2009-12-04 | R2 | 1568h | 313.6h | EHNB-RAN2 | PCG-22 | Huawei | Yang Xudong (yangxudong@huawei.com) | Rel-9 | RP-43 | Joern | RP-090592 |
| 83 | 38.11 | Home NB and Home eNB enhancements - GERAN aspects | 136d? | 2009-05-18 | 2009-11-20 |  |  | 2009-05-18 | 2009-11-20 | 136d? | 210d | finish no earlier than 2009-11-20 | GP | 1088h |  | EHNB-GERAN | PCG-23 | Nokia Siemens Networks | Leonardo Provvedi | Rel-9 | GP-42 | Paolo |  |
| 84 | 39 | **Protection against Unsolicited Communication for IMS (PUCI)** | 267d? | 2008-09-18 A | 2009-09-24 | 59% | 108.67d? | 2008-09-18 | 2009-09-24 | 267d? | 251d |  | S1,S3 | 4760h | 2822.62h | PUCI | PCG-21 | NEC | Anand R. Prasad (anand@bq.jp.nec.com) | Rel-9 | SP-41 | Alain |  |
| 85 | 39.1 | Stage 1 for PUCI | 61d? | 2008-09-18 A | 2008-12-11 A | 100% |  | 2008-09-18 | 2008-12-11 | 61d? |  | finish no earlier than 2009-06-18 | S1 | 488h | 488h | PUCI | PCG-21 | NEC | Anand R. Prasad (anand@bq.jp.nec.com) | Rel-9 | SP-41 | Alain |  |
| 86 | 39.2 | SA3 work on PUCI | 267d? | 2008-09-18 A | 2009-09-24 | 50% | 133.5d? | 2008-09-18 | 2009-09-24 | 267d? | 251d | finish no earlier than 2009-09-24 | S3 | 2136h | 1068h | PUCI | PCG-21 | NEC | Anand R. Prasad (anand@bq.jp.nec.com) | Rel-9 | SP-41 | Dionisio |  |
| 87 | 40 | **IMS Services Centralization and Continuity** | 318d? | 2008-09-18 A | 2009-12-04 | 56% | 139.19d? | 2008-09-18 | 2009-12-04 | 318d? | 200d |  | S1,S2,C1 | 9752h | 4363.2h | IMS_SCC | PCG-21 | NEC | Joerg Swetina (joerg.swetina@nw.neclab.eu) | Rel-9 | SP-41 | Alain |  |
| 88 | 40.1 | Stage 1 - Inter-Device Transfer – Requirements | 61d? | 2008-09-18 A | 2008-12-11 A | 100% |  | 2008-09-18 | 2008-12-11 | 61d? |  | finish no earlier than 2009-06-18 | S1 | 488h | 488h | IMS_SCC-IDT | PCG-21 | NEC | Joerg Swetina (joerg.swetina@nw.neclab.eu) | Rel-9 | SP-41 | Alain |  |
| 89 | 40.2 | Stage 2 - IMS Service Continuity Enhancements: Service, Policy and Interactions | 186d? | 2008-09-18 A | 2009-06-04 A | 100% |  | 2008-09-18 | 2009-06-04 | 186d? |  | finish no earlier than 2009-06-04 | S2 | 1488h | 1488h | IMS_SCC-SPI | PCG-21 | Huawei | HengLiang Zhang (hl_zhang@huawei.com) | Rel-9 | SP-41 | Maurice |  |
| 90 | 40.3 | Stage 3 - IMS Service Continuity Enhancements: Service, Policy, Interactions and Inter UE Transfer | 136d? | 2009-05-29 | 2009-12-03 |  |  | 2009-05-29 | 2009-12-03 | 136d? | 201d | start no earlier than 2009-05-29 | C1 | 1088h |  | IMS_SCC-SPI | PCG-23 | Qualcomm | Roozbeh Atarius (ratarius@qualcomm.com) | Rel-9 | CP-44 | Frederic |  |
| 91 | 40.4 | Stage 2 - IMS Centralized Services | 186d? | 2008-09-18 A | 2009-06-04 A | 100% |  | 2008-09-18 | 2009-06-04 | 186d? |  | finish no earlier than 2009-06-04 | S2 | 1488h | 1488h | IMS_SCC-ICS | PCG-21 | Alcatel-Lucent | Andy Bennett (andybennett@alcatel-lucent.com) | Rel-9 | SP-41 | Maurice |  |
| 92 | 40.5 | Stage 3 - Enhancements to IMS Centralized Services | 137d? | 2009-05-29 A | 2009-12-04 | 26% | 102d? | 2009-05-29 | 2009-12-04 | 137d? | 200d | start no earlier than 2009-05-29 | C1 | 1088h | 272h | IMS_SCC-ICS | PCG-23 | Nokia Siemens Networks | Peter.Leis@nsn.com | Rel-9 | CP-44 | Frederic |  |
| 93 | 40.6 | Stage 3 - IMS Centralized Services support via I1 interface | 196d? | 2009-03-06 A | 2009-12-04 | 20% | 156.8d? | 2009-03-06 | 2009-12-04 | 196d? | 200d | finish no earlier than 2009-12-04 | C1 | 1568h | 313.6h | IMS_SCC-ICS_I1 | PCG-22 | Huawei | Lili Yang(kadyyang@huawei.com) | Rel-9 | CP-43 | Frederic |  |

Notes:
- 66: SA#42 Stage 1 completed
- 67: SA#42 completed / Text3: 22.985, 22.101
- 68: Text3: TS 23.335 (User Data Convergence (UDC); Technical Realization and Information Flows)
- 69: develop UDC information models
- 70: develop UDC information models) / Text3: 32.172
- 71: Text3: 32.bcd (User Data Convergence; Framework for Model Handling and Management), 32.172
- 72: SA#43 WID updated SP-080791=>SP-090197 to include RAN items/BBs
- 73: SA#44 completed / Text3: 22.220, 22.011
- 74: SA#44 exception to 09/09 see SP-090413(SA2_Rel9_status) / Text3: 23.830, 23.401, 23.402, 23.060
- 75: SA#44 exception to 09/09 / Text3: 33.xyz (Security Aspects of Home NodeB / eNodeB)
- 76: SP#44: updated SP-080794=>SP-090305 (WI Title changed from "3G HNB GW OAM&P" to "3G HNB GW and LTE HeNB GW OAM&P") / Text3: 32.771, 32.772, 32.773, 32.775, 32.781, 32.782, 32.783, 32.785, 32.452, 32.453, 32.632, 32.633, 32.635
- 77: Network Manager to Element Manager for H(e)NB / Text3: 32.591, 32.592, 32.593, 32.594, 32.581, 32.582, 32.583, 32.584
- 78: Network Manager to Element Manager for H(e)NB / Text3: 32.xxx Home NB and Home eNB OAM&P concepts and requirements (for interface Type 2), 32.xxy Home NB and Home eNB OAM&P Stage 2 (for interface Type 2)
- 79: Text3: 36.104, 36.141
- 80: Text3: 36.9xx (LTE TDD Home eNodeB RF Requirements Work Item Technical Report), 36.104, 36.141
- 81: Text3: new TS (UTRAN Iuh Interface: User Plane Protocols), 25.413, 25.467, 25.467, 25.468, 25.469, 25.469, 36.401, 36.413
- 82: Text3: 25.304, 25.331, 25.367, 36.300, 36.304, 36.331
- 83: GP#42 WID approved / Text3: 43.055, 43.129, 44.018, 44.060, 45.008, 48.008, 48.018
- 84: SA#42 Stage 1 completed. SA#41 SA3 WID approved (Stage 1 commitment in SA1 LS in SP-080523). Check related work in OMA Categorization Based Content Screening
- 85: SA#42 completed / Text3: 22.228
- 86: SA#44 TR 33.837 v100 for Information. No TS started yet. Bring revised WID reflecting only Rel-9 and New WID for TS work / Text3: 33.837
- 87: SA#42 Stage 1 completed.
- 88: SA#42 completed / Text3: 22.101, 22.228
- 89: SA#44 completed. TR 23.838 for Approval / Text3: 23.838, 23.237, 23.292, 23.216
- 90: Text3: 24.216, 24.229, 24.237
- 91: SA#44 completed. TR 23.883 for Information + Approval / Text3: 23.883, 23.292
- 92: Text3: 24.292, 24.604, 24.605, 24.606, 24.607, 24.608, 24.610, 24.611, 24.615, 24.616, 24.623, 24.629, 24.642
- 93: Text3: 24.294

| ID | WBS | Task | Duration | Start | Finish | Complete | Remaining | Baseline start | Baseline finish | Baseline duration | Total slack | Constraint | Resources | Work | Actual work | Text1 | Text2 | Text4 | Text5 | Text6 | Text7 | Text8 | Text11 |
| --- | --- | --- | --- | --- | --- | --- | --- | --- | --- | --- | --- | --- | --- | --- | --- | --- | --- | --- | --- | --- | --- | --- | --- |
| 94 | 41 | **Service Specific Access Control in EPS** | 257d? | 2008-12-11 A | 2009-12-03 | 1% | 255.12d? | 2008-12-11 | 2009-12-03 | 257d? | 201d |  | S1,C1 | 3152h | 16h | SSAC | PCG-22 | NTT DoCoMo | Frederic Thepot (thepot@docomolab-euro.com) | Rel-9 | SP-42 | Alain |  |
| 95 | 41.1 | Stage 1 for SSAC | 1d? | 2008-12-11 A | 2008-12-11 A | 100% |  | 2008-12-11 | 2008-12-11 | 1d? |  | start no earlier than 2008-12-11 | S1 | 8h | 8h | SSAC | PCG-22 | NTT DoCoMo | Frederic Thepot (thepot@docomolab-euro.com) | Rel-9 | SP-42 | Alain |  |
| 96 | 41.2 | Stage 3 for SSAC | 136d? | 2009-05-29 | 2009-12-03 |  |  | 2009-05-29 | 2009-12-03 | 136d? | 201d | start no earlier than 2009-05-29 | C1 | 1088h |  | SSAC | PCG-23 | NTT DoCoMo | Hideyuki Yamashita (yamashitahi@s1.nttdocomo.co.jp) | Rel-9 | CP-44 | Frederic |  |
| 97 | 42 | **Support for IMS Emergency Calls over GPRS and EPS** | 500d? | 2008-01-14 A | 2009-12-10 | 50% | 251.42d? | 2008-01-14 | 2009-12-10 | 500d? | 196d |  | S1,S2,S3,C1,C3,C4,R2 | 23768h | 10985h | IMS_EMER_GPRS_EPS | PCG-21 | Alcatel-Lucent | Deborah Barclay | Rel-9 | SP-38 | Maurice |  |
| 98 | 42.1 | Stage 1 of IMS_EMER_GPRS_EPS | 239d? | 2008-01-14 A | 2008-12-11 A | 100% |  | 2008-01-14 | 2008-12-11 | 239d? |  | finish no earlier than 2008-12-11 | S1 | 1912h | 1912h | IMS_EMER_GPRS_EPS | PCG-21 | Alcatel-Lucent | Deborah Barclay | Rel-9 | SP-38 | Alain |  |
| 99 | 42.2 | Stage 2 of IMS_EMER_GPRS_EPS | 364d? | 2008-01-14 A | 2009-06-04 A | 100% |  | 2008-01-14 | 2009-06-04 | 364d? |  | finish no earlier than 2009-06-04 | S2 | 2912h | 2912h | IMS_EMER_GPRS_EPS | PCG-21 | Alcatel-Lucent | Deborah Barclay | Rel-9 | SP-38 | Maurice |  |
| 100 | 42.3 | **Stage 3 of IMS_EMER_GPRS_EPS** | 137d? | 2009-05-29 A | 2009-12-04 | 4% | 132.11d? | 2009-05-29 | 2009-12-04 | 137d? | 200d |  | C1,C3,C4 | 4360h | 145.07h | IMS_EMER_GPRS_EPS | PCG-23 | Alcatel-Lucent | Frank Alfano (falfano@alcatel-lucent.com) | Rel-9 | CP-44 | Frederic |  |
| 101 | 42.3.1 | CT1 aspects - Stage 3 of IMS_EMER_GPRS_EPS | 136d? | 2009-05-29 | 2009-12-03 |  |  | 2009-05-29 | 2009-12-03 | 136d? | 201d | start no earlier than 2009-05-29 | C1 | 1088h |  | IMS_EMER_GPRS_EPS | PCG-23 | Alcatel-Lucent | Frank Alfano (falfano@alcatel-lucent.com) | Rel-9 | CP-44 | Frederic |  |
| 102 | 42.3.2 | CT3 aspects - Stage 3 of IMS_EMER_GPRS_EPS | 137d? | 2009-05-29 A | 2009-12-04 | 11% | 122.4d? | 2009-05-29 | 2009-12-04 | 137d? | 200d | start no earlier than 2009-05-29 | C3 | 1088h | 108.8h | IMS_EMER_GPRS_EPS | PCG-23 | Alcatel-Lucent | Frank Alfano (falfano@alcatel-lucent.com) | Rel-9 | CP-44 | Gwiho |  |
| 103 | 42.3.3 | CT4 aspects - Stage 3 of IMS_EMER_GPRS_EPS | 136d? | 2009-05-29 | 2009-12-03 |  |  | 2009-05-29 | 2009-12-03 | 136d? | 201d | start no earlier than 2009-05-29 | C4 | 1088h |  | IMS_EMER_GPRS_EPS | PCG-23 | Alcatel-Lucent | Frank Alfano (falfano@alcatel-lucent.com) | Rel-9 | CP-44 | Kimmo |  |
| 104 | 42.4 | Security aspects of IMS_EMER_GPRS_EPS | 261d? | 2008-12-12 | 2009-12-10 |  |  | 2008-12-12 | 2009-12-10 | 261d? | 196d | finish no earlier than 2009-12-10 | S3 | 2088h |  | IMS_EMER_GPRS_EPS-Sec | PCG-22 | Alcatel-Lucent | Deborah Barclay | Rel-9 | SP-42 | Dionisio |  |
| 105 | 42.5 | Support for IMS Emergency Calls over LTE | 206d? | 2008-12-05 A | 2009-09-18 | 90% | 20.6d? | 2008-12-05 | 2009-09-18 | 206d? | 255d | finish no earlier than 2009-09-18 | R2 | 1648h | 1483.2h | IMS_EMER_LTE | PCG-22 | Alcatel-Lucent | Sudeep Palat (spalat@alcatel-lucent.com) | Rel-9 | RP-42 | Joern | RP-090400 |
| 106 | 42.6 | **SRVCC support for IMS Emergency Calls** | 317d? | 2008-09-18 A | 2009-12-03 | 37% | 199.23d? | 2008-09-18 | 2009-12-03 | 317d? | 201d |  | S2,C1,C4 | 6848h | 2544.18h | IMS_EMER_GPRS_EPS-SRVCC | PCG-21 | China Mobile | Yu Qing (Yuqing@chinamobile.com) | Rel-9 | SP-41 | Maurice |  |
| 107 | 42.6.1 | SRVCC support for IMS Emergency Calls | 267d? | 2008-09-18 A | 2009-09-24 | 75% | 66.75d? | 2008-09-18 | 2009-09-24 | 267d? | 251d | finish no earlier than 2009-09-24 | S2 | 2136h | 1602h | IMS_EMER_GPRS_EPS-SRVCC | PCG-21 | China Mobile | Yu Qing (Yuqing@chinamobile.com) | Rel-9 | SP-41 | Maurice |  |
| 108 | 42.6.2 | CT1 aspects of SRVCC support for IMS Emergency Calls | 136d? | 2009-05-29 | 2009-12-03 |  |  | 2009-05-29 | 2009-12-03 | 136d? | 201d | start no earlier than 2009-05-29 | C1 | 1088h |  | IMS_EMER_GPRS_EPS-SRVCC | PCG-23 | China Mobile | jiangyi@chinamobile.com | Rel-9 | CP-44 | Frederic |  |
| 109 | 42.6.3 | CT4 aspects of SRVCC support for IMS Emergency Calls | 136d? | 2009-05-29 | 2009-12-03 |  |  | 2009-05-29 | 2009-12-03 | 136d? | 201d | start no earlier than 2009-05-29 | C4 | 1088h |  | IMS_EMER_GPRS_EPS-SRVCC | PCG-23 | China Mobile | jiangyi@chinamobile.com | Rel-9 | CP-44 | Kimmo |  |
| 110 | 43 | **LCS for LTE and EPS** | 393d? | 2008-06-05 A | 2009-12-04 | 44% | 220.34d? | 2008-06-05 | 2009-12-04 | 393d? | 200d |  | S2,C4,R2 | 10606.4h | 3001.6h | LCS_LTE_EPS | PCG-22 |  |  | Rel-9 | SP-43 | Maurice |  |
| 111 | 43.1 | **LCS Control Plane Solution for EPS** | 392d? | 2008-06-05 A | 2009-12-03 | 66% | 134.29d? | 2008-06-05 | 2009-12-03 | 392d? | 201d |  | S2,C4 | 5059.2h | 2088h | LCS_EPS-CPS | PCG-21 | Polaris Wireless | Robert Gross | Rel-9 | SP-40 | Maurice |  |
| 112 | 43.1.1 | Stage 2 for LCS_CPS_EPS | 261d? | 2008-06-05 A | 2009-06-04 A | 100% |  | 2008-06-05 | 2009-06-04 | 261d? |  | finish no earlier than 2009-06-04 | S2 | 2088h | 2088h | LCS_EPS-CPS | PCG-21 | Polaris Wireless | Robert Gross | Rel-9 | SP-40 | Maurice |  |
| 113 | 43.1.2 | Control Plane LCS in the EPC | 136d? | 2009-05-29 | 2009-12-03 |  |  | 2009-05-29 | 2009-12-03 | 136d? | 201d | start no earlier than 2009-05-29 | C4 | 1088h |  | LCS_EPS-CPS | PCG-23 | Polaris Wireless | Robert Gross | Rel-9 | CP-44 | Kimmo |  |
| 114 | 43.2 | Positioning Support for LTE | 261d? | 2008-07-11 A | 2009-12-04 | 40% | 156.6d? | 2008-07-11 | 2009-12-04 | 261d? | 200d | finish no earlier than 2009-12-04 | R2 | 2088h | 835.2h | LCS_LTE | PCG-22 | Qualcomm | Nathan Tenny (ntenny@qualcomm.com) | Rel-9 | RP-42 | Joern | RP-090401 |
| 115 | 43.3 | Network-Based Positioning Support in LTE | 196d? | 2009-03-06 A | 2009-12-04 | 5% | 186.2d? | 2009-03-06 | 2009-12-04 | 196d? | 200d | finish no earlier than 2009-12-04 | R2 | 1568h | 78.4h | LCS_LTE-NBPS | PCG-22 | TruePosition | Terry Brooks (terri.brooks@trueposition.com) | Rel-9 | RP-43 | Joern | RP-090402 |
| 116 | 44 | **MBMS support in EPS** | 397d? | 2008-06-05 A | 2009-12-10 | 43% | 224.36d? | 2008-06-05 | 2009-12-10 | 397d? | 196d |  | S2,S3,S5,C3,C4,R2 | 11525.2h | 3944h | MBMS_EPS | PCG-21 | China Mobile | Liu Hong (liuhongyfw@chinamobile.com) | Rel-9 | SP-40 | Maurice |  |
| 117 | 44.1 | Stage 2 for MBMS_EPS | 261d? | 2008-06-05 A | 2009-06-04 A | 100% |  | 2008-06-05 | 2009-06-04 | 261d? |  | finish no earlier than 2009-06-04 | S2 | 2088h | 2088h | MBMS_EPS | PCG-21 | China Mobile | Liu Hong (liuhongyfw@chinamobile.com) | Rel-9 | SP-40 | Maurice |  |
| 118 | 44.2 | Security for MBMS_EPS | 206d? | 2008-12-11 A | 2009-09-24 | 50% | 103d? | 2008-12-11 | 2009-09-24 | 206d? | 251d | finish no earlier than 2009-09-24 | S3 | 1648h | 824h | MBMS_EPS | PCG-22 | China Mobile | Liu Hong (liuhongyfw@chinamobile.com) | Rel-9 | SP-42 | Dionisio |  |
| 119 | 44.3 | MBMS Charging in EPS | 201d? | 2009-03-06 A | 2009-12-10 | 40% | 120d? | 2009-03-06 | 2009-12-10 | 201d? | 196d | finish no earlier than 2009-12-10 | S5 | 1600h | 640h | MBMS_EPS | PCG-22 | ZTE | guo.wenjie1@zte.com.cn | Rel-9 | SP-43 | Dionisio |  |
| 120 | 44.4 | CT4 aspects of MBMS support in EPS | 136d? | 2009-05-29 | 2009-12-03 |  |  | 2009-05-29 | 2009-12-03 | 136d? | 201d | start no earlier than 2009-05-29 | C4 | 1088h |  | MBMS_EPS | PCG-23 | China Mobile, ZTE | wangjingyf@chinamobile.com, lu.fei1@zte.com.cn | Rel-9 | CP-44 | Kimmo |  |
| 121 | 44.5 | CT3 aspects of MBMS support in EPS | 136d? | 2009-05-29 | 2009-12-03 |  |  | 2009-05-29 | 2009-12-03 | 136d? | 201d | start no earlier than 2009-05-29 | C3 | 1088h |  | MBMS_EPS | PCG-23 | ZTE, China Mobile | zhou.xiaoyun@zte.com.cn, wangjingyf@chinamobile.com | Rel-9 | CP-44 | Gwiho |  |
| 122 | 44.6 | MBMS support in LTE | 196d? | 2009-03-06 A | 2009-12-04 | 25% | 147d? | 2009-03-06 | 2009-12-04 | 196d? | 200d | finish no earlier than 2009-12-04 | R2 | 1568h | 392h | MBMS_LTE | PCG-22 | Huawei | arnaud.meylan@huawei.com | Rel-9 | RP-43 | Joern | RP-090403 |

Notes:
- 94: SA#42 Stage 1 completed (need for SA2 input). Triggered by Study UID_400036 on Service Specific Access Control in EPS (FS_SSAC)
- 95: SA#42 completed / Text3: 22.011 CR0136
- 96: Text3: 23.122, 24.173?
- 97: SA#42 Stage 1 completed. WID updated SP-070820=>SP-080352=>SP-080844 (Add SA3 task).
- 98: SA#42 completed / Text3: 22.101
- 99: SA#44 completed / Text3: 23.869, 23.060, 23.167, 23.203, 23.221, 23.228, 23.271, 23.401, 23.402
- 101: Text3: 23.122, 24.008, 24.229, 24.301, 24.302
- 102: Text3: 29.212, 29.213, 29.214, 29.215
- 103: Text3: 23.003, 29.060, 29.274, 29.275, 29.276
- 104: SA#42 WID updated SP-080352=>SP-080844 (Add SA3 task) / Text3: 33.401, 33.402
- 105: Text3: 36.331, 36.413
- 106: SA#43 TR 23.870 for Information. WID updated SP-080562=>SP-090099 (added location continuity aspects)
- 107: SA#44 exception to 09/09 (Work still needed on SR-VCC Emergency for CDMA 1x). TR 23.870 for Approval / Text3: 23.870, 23.216, 23.237
- 108: Stage 3 / Text3: 24.237
- 109: Stage 3 / Text3: 29.280
- 111: Triggered by abandoned Study UID_380068 (FS_LCS_EPS). Linked to UID_380064 Feature IMS_EMER_GPRS_EPS.
- 112: SA#44 completed (Some alignments might be needed later on based on RAN progress) / Text3: 23.891, 23.271, 23.401, 23.402
- 113: Supports stage 3 definition of SLs and SLg interfaces. Supports transport of positioning messages between the E-SMLC and MME in the scope of UID_420006 (Positioning Support for LTE) / Text3: 29.002, 3 New TSs 29.xxx: Definition of SLs interface for Control Plane LCS, Definition of SLg interface for Control Plane LCS, Definition of Diameter-based Lh interface for Control Plane LCS
- 114: RP#44 TS 36.305-100 for Information. UID_400038 (LCS Control Plane Solution for EPS) depends on this WI / Text3: 36.300, 36.331, 36.413, 36.133, 36.214, new 36.305
- 115: Text3: Possible new TS on Performance Requirements for LMU, 36.300, 36.331, 36.413
- 116: SA#42 WID updated SP-080442=>SP-080737 (add SA3 task)
- 117: SA#44 completed / Text3: 23.246
- 118: SA#44 exception to 09/09 / Text3: 33.246
- 119: Text3: 32.273, 32.251, 32.298, 32.299
- 120: Stage 3 / Text3: 29.274, 29.281, 23.007, 23.008
- 121: Stage 3 / Text3: 29.061
- 122: RP#44 updated WID RP-090350=>RP-090619. Stage 2/3 / Text3: 36.101, 36.104, 36.141, 36.300, 36.304, 36.321, 36.322, 36.323, 36.331, 36.440, 36.441, 36.442, 36.444, 36.445, 36.446

| ID | WBS | Task | Duration | Start | Finish | Complete | Remaining | Baseline start | Baseline finish | Baseline duration | Total slack | Constraint | Resources | Work | Actual work | Text1 | Text2 | Text4 | Text5 | Text6 | Text7 | Text8 |
| --- | --- | --- | --- | --- | --- | --- | --- | --- | --- | --- | --- | --- | --- | --- | --- | --- | --- | --- | --- | --- | --- | --- |
| 123 | 45 | **Access Network Discovery and Selection Function enhancements** | 127d? | 2008-12-11 A | 2009-06-04 A | 100% |  | 2008-12-11 | 2009-06-04 | 127d? |  |  | S2 | 1368.8h | 1368.8h | eANDSF | PCG-22 | Motorola | Apostolis Salkintzis (salki@motorola.com) | Rel-9 | SP-42 | Maurice |
| 124 | 45.1 | Stage 2 for eANDSF | 126d? | 2008-12-11 A | 2009-06-04 A | 100% |  | 2008-12-11 | 2009-06-04 | 126d? |  | finish no earlier than 2009-06-04 | S2 | 1008h | 1008h | eANDSF | PCG-22 | Motorola | Apostolis Salkintzis (salki@motorola.com) | Rel-9 | SP-42 | Maurice |
| 125 | 46 | Multiple PDN Connection to the Same APN for PMIP-based Interfaces | 61d? | 2009-03-13 A | 2009-06-04 A | 100% |  | 2009-03-13 | 2009-06-04 | 61d? |  | finish no earlier than 2009-06-04 | S2 | 488h | 488h | MUPSAP | PCG-22 | Samsung | erik.guttman@partner.samsung.com | Rel-9 | SP-43 | Maurice |
| 126 | 47 | Access Security Enhancements | 505d? | 2007-07-02 A | 2009-06-04 A | 100% |  | 2007-07-02 | 2009-06-04 | 505d? |  | finish no earlier than 2009-06-03 | S3 | 4040h | 4040h | ACCSEC2 |  | Ericsson | Bengt.Sahlin@ericsson.com | Rel-9 | SP-26 | Dionisio |
| 127 | 48 | **GBAPush enhancements (Generic push layer)** | 403d? | 2008-03-12 A | 2009-09-24 | 70% | 120.9d? | 2008-03-12 | 2009-09-24 | 403d? | 251d |  | S3 | 6448h | 4513.6h | eGBAPush | PCG-23 | Ericsson | Rolf Blom | Rel-9 | SP-44 | Dionisio |
| 128 | 48.1 | SA3 part of eGBAPush (Generic push layer) | 403d? | 2008-03-12 A | 2009-09-24 | 70% | 120.9d? | 2008-03-12 | 2009-09-24 | 403d? | 251d | finish no earlier than 2009-09-24 | S3 | 3224h | 2256.8h | eGBAPush | PCG-21 | Ericsson | Rolf Blom | Rel-9 | SP-39 | Dionisio |
| 129 | 49 | IMS Media Plane Security | 196d? | 2009-03-13 A | 2009-12-10 | 50% | 98d? | 2009-03-13 | 2009-12-10 | 196d? | 196d | finish no earlier than 2009-12-10 | S3 | 1568h | 784h | MEDIASEC | PCG-22 | Vodafone | Peter.Howard@vodafone.com | Rel-9 | SP-43 | Dionisio |
| 130 | 50 | Lawful Interception in the 3GPP Rel-9 | 81d? | 2009-06-04 | 2009-09-24 |  |  | 2009-06-04 | 2009-09-24 | 81d? | 251d | finish no earlier than 2009-09-24 | S3 | 648h |  | LI9 | PCG-23 |  | bernhard.spalt@siemens.com | Rel-9 | SP-44 | Dionisio |
| 131 | 51 | Extended Identity Management | 136d? | 2009-06-04 | 2009-12-10 |  |  | 2009-06-04 | 2009-12-10 | 136d? | 196d | finish no earlier than 2009-12-10 | S3,C4 | 1088h |  | GBA-IdM | PCG-23 | Nokia | Silke.Holtmanns at nokia.com | Rel-9 | SP-44 | Dionisio |
| 132 | 52 | **Network Domain Security (NDS) enhancements to support backhaul security** | 136d? | 2009-06-04 | 2009-12-10 |  |  | 2009-06-04 | 2009-12-10 | 136d? | 196d |  | S3,C4 | 3264h |  | NDS_Backhaul | PCG-23 | Vodafone | Peter Howard | Rel-9 | SP-44 | Dionisio |
| 133 | 52.1 | SA3 part of NDS_Backhaul | 136d? | 2009-06-04 | 2009-12-10 |  |  | 2009-06-04 | 2009-12-10 | 136d? | 196d | finish no earlier than 2009-12-10 | S3 | 1088h |  | NDS_Backhaul | PCG-23 | Vodafone | Peter Howard | Rel-9 | SP-44 | Dionisio |
| 134 | 52.2 | CT4 part of NDS_Backhaul | 136d? | 2009-06-04 | 2009-12-10 |  |  | 2009-06-04 | 2009-12-10 | 136d? | 196d | finish no earlier than 2009-12-10 | C4 | 1088h |  | NDS_Backhaul | PCG-23 | Vodafone | Peter Howard | Rel-9 | SP-44 | Dionisio |
| 135 | 53 | **128 bit encryption for GSM and GPRS** | 136d? | 2009-06-04 | 2009-12-10 |  |  | 2009-06-04 | 2009-12-10 | 136d? | 196d |  | S3,S2,C1,C4,G2,G3new | 7616h |  | A5/4-GEA4 | PCG-23 | Ericsson | Karl Norrman | Rel-9 | SP-44 | Dionisio |
| 136 | 53.1 | SA3 part of A5/4-GEA4 | 136d? | 2009-06-04 | 2009-12-10 |  |  | 2009-06-04 | 2009-12-10 | 136d? | 196d | start no earlier than 2009-06-04 | S3 | 1088h |  | A5/4-GEA4 | PCG-23 | Ericsson | Karl Norrman | Rel-9 | SP-44 | Dionisio |
| 137 | 53.2 | SA2 part of A5/4-GEA4 | 136d? | 2009-06-04 | 2009-12-10 |  |  | 2009-06-04 | 2009-12-10 | 136d? | 196d | start no earlier than 2009-06-04 | S2 | 1088h |  | A5/4-GEA4 | PCG-23 | Ericsson | Karl Norrman | Rel-9 | SP-44 | Maurice |
| 138 | 53.3 | CT1 part of A5/4-GEA4 | 136d? | 2009-06-04 | 2009-12-10 |  |  | 2009-06-04 | 2009-12-10 | 136d? | 196d | start no earlier than 2009-06-04 | C1 | 1088h |  | A5/4-GEA4 | PCG-23 | Ericsson | Karl Norrman | Rel-9 | SP-44 | Frederic |
| 139 | 53.4 | CT4 part of A5/4-GEA4 | 136d? | 2009-06-04 | 2009-12-10 |  |  | 2009-06-04 | 2009-12-10 | 136d? | 196d | start no earlier than 2009-06-04 | C4 | 1088h |  | A5/4-GEA4 | PCG-23 | Ericsson | Karl Norrman | Rel-9 | SP-44 | Kimmo |
| 140 | 53.5 | GERAN2 part of A5/4-GEA4 | 136d? | 2009-06-04 | 2009-12-10 |  |  | 2009-06-04 | 2009-12-10 | 136d? | 196d | start no earlier than 2009-06-04 | G2 | 1088h |  | A5/4-GEA4 | PCG-23 | Ericsson | Karl Norrman | Rel-9 | SP-44 | Gert |
| 141 | 53.6 | GERAN3new (testing) part of A5/4-GEA4 | 136d? | 2009-06-04 | 2009-12-10 |  |  | 2009-06-04 | 2009-12-10 | 136d? | 196d | start no earlier than 2009-06-04 | G3new | 1088h |  | A5/4-GEA4 | PCG-23 | Ericsson | Karl Norrman | Rel-9 | SP-44 | Ingbert |
| 142 | 54 | **Timed Graphics** | 262d? | 2008-12-11 A | 2009-12-10 | 20% | 209.6d? | 2008-12-11 | 2009-12-10 | 262d? | 196d |  | S4 | 4184h | 836.8h | TG | PCG-22 | Ericsson | clinton.priddle@ericsson.com | Rel-9 | SP-42 | Paolo |
| 143 | 54.1 | SA4 part of Timed Graphics | 261d? | 2008-12-11 A | 2009-12-10 | 20% | 208.8d? | 2008-12-11 | 2009-12-10 | 261d? | 196d | finish no earlier than 2009-12-10 | S4 | 2088h | 417.6h | TG | PCG-22 | Ericsson | clinton.priddle@ericsson.com | Rel-9 | SP-42 | Paolo |
| 144 | 55 | Managing MTSI Media Adaptation | 196d? | 2009-03-12 A | 2009-12-10 | 25% | 147d? | 2009-03-12 | 2009-12-10 | 196d? | 196d | finish no earlier than 2009-12-10 | S4 | 1568h | 392h | M3A | PCG-22 | Samsung | kyunghun.jung@samsung.com | Rel-9 | SP-43 | Paolo |
| 145 | 56 | **PSS and MBMS Aspects** | 197d? | 2009-03-12 A | 2009-12-10 | 8% | 182.22d? | 2009-03-12 | 2009-12-10 | 197d? | 196d |  | S4 | 4712h | 353.4h | PMA | PCG-23 | Ericsson, Nokia | Clinton.Priddle@ericsson.com, imed.bouazizi@nokia.com | Rel-9 | SP-44 | Paolo |
| 146 | 56.1 | PSS and MBMS extensions | 196d? | 2009-03-12 A | 2009-12-10 | 5% | 186.2d? | 2009-03-12 | 2009-12-10 | 196d? | 196d | finish no earlier than 2009-12-10 | S4 | 1568h | 78.4h | PMA-MBS_Ext | PCG-22 | Ericsson | Clinton.Priddle@ericsson.com | Rel-9 | SP-43 | Paolo |
| 147 | 56.2 | Improved Video Support for PSS and MBMS | 196d? | 2009-03-12 A | 2009-12-10 | 10% | 176.4d? | 2009-03-12 | 2009-12-10 | 196d? | 196d | finish no earlier than 2009-12-10 | S4 | 1568h | 156.8h | PMA-IVS | PCG-22 | Nokia | imed.bouazizi@nokia.com | Rel-9 | SP-43 | Paolo |
| 148 | 57 | IMS based PSS and MBMS User Service extensions | 196d? | 2009-03-12 A | 2009-12-09 | 15% | 166.6d? | 2009-03-12 | 2009-12-09 | 196d? | 197d | start no earlier than 2009-03-12 | S4 | 1568h | 235.2h | IMS_PSS_MBMS_US_EXT | PCG-22 | Ericsson | Markus Kampmann | Rel-9 | SP-43 | Paolo |
| 149 | 58 | Syndicated Feed Reception within 3GPP environments | 136d? | 2009-06-04 | 2009-12-10 |  |  | 2009-06-04 | 2009-12-10 | 136d? | 196d | start no earlier than 2009-06-04 | S4 | 1088h |  | SFR | PCG-23 | Ericsson | Thorsten.Lohmar@ericsson.com | Rel-9 | SP-44 | Paolo |

Notes:
- 123: SA#44 Stage 2 completed. No new Rel-9 use cases defined. Expected to implement service requirements not covered in Rel-8
- 124: SA#44 completed / Text3: 23.402, 23.002
- 125: SA#44 completed. Continues Rel-8 SAES Stage 2 UID_320005. Stage 1 in 22.278 (EPS Service requirements) / Text3: 23.060, 23.203, 23.401, 23.402
- 126: SA#44 completed. Stopped TR 33.801. CRs 33.102,43.020 on A5/2 removal done long time ago. A5/4 introduction CRs will be done under UID_440057 128 bit encryption for GSM and GPRS. SA#26 approved WID (improved GERAN security) / Text3: 33.102, 43.020, Stopped TR 33.801 “Access security review” (Reason: draft contained useful material for planning A5/2 removal and A5/4 introduction. Completion would require significant effort)
- 127: SA#44 exception to 09/09. WID approved. Develop a generic push layer using GAA protection. SA#43 Umbrella Feature created to host 33.224, moved from Rel-8 to Rel-9
- 128: SA#44 exception to 09/09. WID approved. Develop a generic push layer using GAA protection. SA#42 TS 33.224 moved to Rel-9 (33.223 completed as Rel-8 under UID_390146) / Text3: 33.224
- 129: SA#44 exception to 09/09 both TR/TS. Bring TS for Information at SA#45. TR 33.828 2nd time for Information. SA#43 Stage 1 to be defined by SA3 in consultation with SA1 / Text3: 33.828, 33.xxx (Solutions for IMS media plane security)
- 130: SA#44 exception to 09/09. Bring WID at SA#45 / Text3: 33.106, 33.107, 33.108
- 131: SA#44 exception to 09/09. Stage 2 (Stage 1 not identified: GBA Liberty Interworking has been outlined and GBAOpenID interworking is analogous. New TR will enhance security and interoperability btw. 3GPP security and latest identity management systems. / Text3: TR 33.9xx (Identity Management and 3GPP Security Interworking; Identity Management and Generic Authentication Architecture (GAA) Interworking), CT4 29.109 (Add service code)
- 132: SA#44 exception to 09/09. Continuation of Rel-8 UID_390044 SAE security architecture. Covers gaps in backhaul security in SAE (also applicable to UTRAN and GERAN backhaul)
- 133: SA#44 exception to 09/09. Continuation of Rel-8 UID_390044 SAE security architecture. Covers gaps in backhaul security in SAE (also applicable to UTRAN and GERAN backhaul) / Text3: 33.102, 33.210, 33.310, 33.401, 33.402
- 134: SA#44 exception to 09/09. Continuation of Rel-8 UID_390044 SAE security architecture. Covers gaps in backhaul security in SAE (also applicable to UTRAN and GERAN backhaul) / Text3: 29.060, 29.274, 29.281 (Applicability of NDS/IP and NDS/AF to GTP, GTPv2-C and GTPv1-U)
- 135: SA#44 exception to 09/09 (Stage 2). Allow 128 as an alternative to 64 bit keys (Stage 2/3 + Test spec)
- 136: SA#44 exception to 09/09 (Stage 2) / Text3: 55.226 (A5/4 encryption algorithms for GSM and ECSD, and GEA4 encryption algorithm for GPRS; Document 1: A5/4 and GEA4 spec),33.102,43.020
- 137: Text3: 23.060
- 138: Text3: 24.008,44.064
- 139: Text3: 29.002,29.060
- 140: Text3: 44.018,48.008,48.018,48.058
- 141: Text3: 51.010
- 142: Provide graphics in parallel to a video stream (without requiring an umbrella scene descriptor such as 3GPP DIMS in TS 26.142)
- 143: Text3: 26.xyz (Timed Graphics), 26.114, 26.140, 26.234, 26.244, 26.245, 26.346
- 144: Work to extend Rel-8 UID_34041 MTSI Video - Dynamic Rate Adaptation/Signalling of Image Size. Update speech/video adaptation algorithms used by network to control MTSI client terminal in congestion or poor transmission conditions. / Text3: 26.114
- 145: Umbrella WI: Evolved radio access technologies (HSPA, LTE) provide higher data rates allowing provision of services with higher quality. PSS and MBMS User Services are important for evolved mobile networks
- 146: SA#44 WID updated SP-090022=>SP-090262 (Feature=>BB). Work to extend Rel-8 UID_34043 PSS_MBMS_OMTV (Extending PSS and MBMS User Services for optimized Mobile TV) & ensure compatibility with UID_34046 (IMS_PSS_MBMS_US) / Text3: 26.234, 26.346
- 147: SA#44 WID updated SP-090023=>SP-090263 (Feature=>BB. Add support for more advanced H.264 profiles and levels to match PSS and MBMS capabilities and larger screen sizes (e.g. H.264 Scalable Baseline Profile) / Text3: 26.9xx (Study on improved video for PSS and MBMS), 26.234, 26.244, 26.346
- 148: Work to extend Rel-8 UID_34046 (IMS_PSS_MBMS_US), SA2 UID_410034 IMSSCC-SPI (IMS Service Continuity Enhancements: Service, Policy and Interactions) / Text3: 26.237 (IMS based PSS and MBMS User Service; Protocols)
- 149: RSS optimized for mobile use. Reuse/reference OMA's enabler DCD client server transactions and metadata. Syndicated feeds, using Atom & Really Simple Syndication (RSS), are widely used on Internet for various scheduled pull applications such as podcasts. / Text3: TS 26.yyy (Syndicated Feed Reception within 3GPP environments; Protocols and codecs)

| ID | WBS | Task | Duration | Start | Finish | Complete | Remaining | Baseline start | Baseline finish | Baseline duration | Total slack | Constraint | Resources | Work | Actual work | Text1 | Text2 | Text6 | Text7 | Text8 | Text4 |
| --- | --- | --- | --- | --- | --- | --- | --- | --- | --- | --- | --- | --- | --- | --- | --- | --- | --- | --- | --- | --- | --- |
| 150 | 59 | **OAM&P 9** | 471d? | 2008-02-22 A | 2009-12-10 | 24% | 360.24d? | 2008-02-22 | 2009-12-10 | 471d? | 196d |  | S5 | 26760h | 7362.37h | OAM9 | PCG-22 | Rel-9 | SP-42 | Dionisio |  |
| 151 | 59.1 | **Network Infrastructure Management** | 262d? | 2008-12-11 A | 2009-12-10 | 16% | 221.04d? | 2008-12-11 | 2009-12-10 | 262d? | 196d |  | S5 | 7008h | 1095.71h | OAM9-NIM | PCG-22 | Rel-9 | SP-42 | Dionisio |  |
| 152 | 59.1.1 | Software Management for Network Elements | 206d? | 2008-12-11 A | 2009-09-24 | 40% | 123.6d? | 2008-12-11 | 2009-09-24 | 206d? | 251d | finish no earlier than 2009-09-24 | S5 | 1648h | 659.2h | OAM9-NE_SWM | PCG-22 | Rel-9 | SP-42 | Dionisio | Huawei, Nokia Siemens Networks |
| 153 | 59.1.2 | Service Oriented Architecture (SOA) for IRP | 136d? | 2009-06-04 A | 2009-12-10 | 5% | 129.2d? | 2009-06-04 | 2009-12-10 | 136d? | 196d | finish no earlier than 2009-12-10 | S5 | 1088h | 54.4h | OAM9 | PCG-23 | Rel-9 | SP-44 | Dionisio | Ericsson, Nokia Siemens Networks |
| 154 | 59.1.3 | IRP SOAP Solution Sets continuation from Rel-8 | 136d? | 2009-06-04 A | 2009-12-10 | 5% | 129.2d? | 2009-06-04 | 2009-12-10 | 136d? | 196d | start no earlier than 2009-06-04 | S5 | 1088h | 54.4h | OAM9 | PCG-23 | Rel-9 | SP-44 | Dionisio | Ericsson |
| 155 | 59.1.4 | Automatic Radio Network Configuration Data Preparation | 136d? | 2009-06-04 | 2009-12-10 |  |  | 2009-06-04 | 2009-12-10 | 136d? | 196d | finish no earlier than 2009-12-10 | S5 | 1088h |  | OAM9 | PCG-23 | Rel-9 | SP-44 | Dionisio | Nokia Siemens Networks |
| 156 | 59.2 | **Performance Management** | 197d? | 2009-03-12 A | 2009-12-10 | 15% | 167.43d? | 2009-03-12 | 2009-12-10 | 197d? | 196d |  | S5 | 5800h | 863.75h | OAM9-PM | PCG-22 | Rel-9 | SP-42 | Dionisio |  |
| 157 | 59.2.1 | Enhancement of E-UTRAN Performance Measurements | 196d? | 2009-03-12 A | 2009-12-09 | 10% | 176.4d? | 2009-03-12 | 2009-12-09 | 196d? | 197d | start no earlier than 2009-03-12 | S5 | 1568h | 156.8h | OAM9 | PCG-22 | Rel-9 | SP-43 | Dionisio | Motorola, Huawei |
| 158 | 59.2.2 | Enhancement of EPC Performance Measurements | 197d? | 2009-03-12 A | 2009-12-10 | 30% | 137.2d? | 2009-03-12 | 2009-12-10 | 197d? | 196d | start no earlier than 2009-03-12 | S5 | 1568h | 470.4h | OAM9 | PCG-22 | Rel-9 | SP-43 | Dionisio | China Mobile |
| 159 | 59.2.3 | Enhancement of UTRAN Performance Measurements | 136d? | 2009-06-04 | 2009-12-10 |  |  | 2009-06-04 | 2009-12-10 | 136d? | 196d | start no earlier than 2009-06-04 | S5 | 1088h |  | OAM9 | PCG-23 | Rel-9 | SP-44 | Dionisio | China Mobile |
| 160 | 59.3 | Trace | 196d? | 2009-03-13 | 2009-12-10 |  |  | 2009-03-13 | 2009-12-10 | 196d? | 196d | finish no earlier than 2009-12-10 | S5 | 1568h |  | OAM9-Trace | PCG-22 | Rel-9 | SP-42 | Dionisio |  |
| 161 | 59.4 | **Self-Organizing Networks (SON) - OAM aspects** | 471d? | 2008-02-22 A | 2009-12-10 | 60% | 188.4d? | 2008-02-22 | 2009-12-10 | 471d? | 196d |  | S5 | 7528h | 4516.8h | OAM9-SON | PCG-22 | Rel-9 | SP-43 | Dionisio |  |
| 162 | 59.4.1 | SON Self-Optimization & Self-Healing handling | 470d? | 2008-02-22 A | 2009-12-10 | 60% | 188d? | 2008-02-22 | 2009-12-10 | 470d? | 196d | finish no earlier than 2009-12-10 | S5 | 3760h | 2256h | LTE_SON-OAM | PCG-21 | Rel-9 | SP-39 | Dionisio | Huawei, ZTE |
| 163 | 59.5 | Subscription Management (SuM) evolution | 136d? | 2009-06-04 | 2009-12-10 |  |  | 2009-06-04 | 2009-12-10 | 136d? | 196d | finish no earlier than 2009-12-10 | S5 | 1088h |  | OAM9-SuM | PCG-23 | Rel-9 | SP-44 | Dionisio | Ericsson |
| 164 | 60 | **Charging Management small Enhancements** | 136d? | 2009-06-04 | 2009-12-10 |  |  | 2009-06-04 | 2009-12-10 | 136d? | 196d |  | S5 | 2176h |  | CH9 | PCG-23 | Rel-9 | SP-44 | Dionisio |  |
| 165 | 60.1 | IWLAN mobility charging | 136d? | 2009-06-04 | 2009-12-10 |  |  | 2009-06-04 | 2009-12-10 | 136d? | 196d | finish no earlier than 2009-12-10 | S5 | 1088h |  | eIWLAN_Mob | PCG-23 | Rel-9 | SP-44 | Dionisio | Orange |
| 166 | 61 | Definition of 3GPP UICC services over the new high-speed interface | 520d? | 2007-12-10 A | 2009-12-04 | 15% | 441.25d? | 2007-12-10 | 2009-12-04 | 520d? | 200d | finish no earlier than 2009-12-04 | C6 | 4160h | 630h | UICCHS | PCG-21 | Rel-9 | CP-38 | Xavier | Gemalto |
| 167 | 62 | **Enhancements of IMS Customized Alerting Tone (CAT) Service** | 262d? | 2008-12-05 A | 2009-12-04 | 35% | 170.3d? | 2008-12-05 | 2009-12-04 | 262d? | 200d |  | C1 | 3766.4h | 730.8h | eCAT | PCG-22 | Rel-9 | CP-42 | Frederic | China Mobile |
| 168 | 62.1 | Stage 3 Enhancements of IMS CAT Supplementary Service | 261d? | 2008-12-05 A | 2009-12-04 | 35% | 169.65d? | 2008-12-05 | 2009-12-04 | 261d? | 200d | finish no earlier than 2009-12-04 | C1 | 2088h | 730.8h | eCAT-SS | PCG-22 | Rel-9 | CP-42 | Frederic | China Mobile |
| 169 | 63 | **CS-IBCF and CS-TrGW definition in 3GPP specifications** | 397d? | 2008-05-30 A | 2009-12-04 | 48% | 207.11d? | 2008-05-30 | 2009-12-04 | 397d? | 200d |  | C3,C4 | 9072h | 4335.14h | CS-IBCF | PCG-21 | Rel-9 | CP-40 | Gwiho | Telecom Italia |
| 170 | 63.1 | CT3 aspects of CS-IBCF | 342d? | 2008-05-30 A | 2009-09-18 | 80% | 68.2d? | 2008-05-30 | 2009-09-18 | 342d? | 255d | finish no earlier than 2009-09-18 | C3 | 2728h | 2182.4h | CS-IBCF | PCG-21 | Rel-9 | CP-40 | Gwiho | Telecom Italia |
| 171 | 63.2 | CT4 aspects of CS-IBCF | 396d? | 2008-05-30 A | 2009-12-04 | 20% | 316.8d? | 2008-05-30 | 2009-12-04 | 396d? | 200d | finish no earlier than 2009-12-04 | C4 | 3168h | 633.6h | CS-IBCF | PCG-21 | Rel-9 | CP-40 | Kimmo | Telecom Italia |
| 172 | 64 | **IMS – Interconnection Border Control Function (IBCF) – Transition Gateway (TrGW); Ix Interface; Stage 3** | 322d? | 2008-09-12 A | 2009-12-04 | 45% | 177.09d? | 2008-09-12 | 2009-12-04 | 322d? | 200d |  | C4,C3 | 6418.4h | 2022.56h | IMS_IBCF | PCG-21 | Rel-9 | CP-41 | Kimmo | Alcatel-Lucent |
| 173 | 64.1 | CT4 part of IMS_IBCF | 321d? | 2008-09-12 A | 2009-12-04 | 30% | 224.7d? | 2008-09-12 | 2009-12-04 | 321d? | 200d | finish no earlier than 2009-12-04 | C4 | 2568h | 770.4h | IMS_IBCF | PCG-21 | Rel-9 | CP-41 | Kimmo | Alcatel-Lucent |
| 174 | 64.2 | CT3 part of IMS_IBCF | 240.8d? | 2008-09-12 A | 2009-09-18 | 65% | 84.28d? | 2008-09-12 | 2009-09-18 | 240.8d? | 255d | finish no earlier than 2009-09-18 | C3 | 1926.4h | 1252.16h | IMS_IBCF | PCG-21 | Rel-9 | CP-41 | Gwiho | Alcatel-Lucent |
| 175 | 65 | IMS Application Level Gateway Control Function (ALGCF) – IMS Access Media Gateway (IMA-MGW); Iq Interface; Stage 2 and Stage 3 | 321d? | 2008-09-12 A | 2009-12-04 | 25% | 240.75d? | 2008-09-12 | 2009-12-04 | 321d? | 200d | finish no earlier than 2009-12-04 | C4 | 2568h | 642h | IMS_AGCF | PCG-21 | Rel-9 | CP-41 | Kimmo | Alcatel-Lucent |

Notes:
- 150: SA#42 umbrella Feature created to host OAM WIs
- 151: SA#42 umbrella BB created to host OAM WIs
- 152: 02/09: WI Title changed on SA5 request from "Management of software entities residing in Network Elements" to "Software Management for Network Elements". The WI states: Telecommunication Management; Software Management (SWM) / Text3: 32.531, 32.532, 32.533, 32.537 / Text5: Bidipta Das (bidipta@huawei.com), Clemens Suerbaum (clemens.suerbaum@nsn.com)
- 153: Triggered by UID_400029 Study on Service Oriented Architecture (SOA) for IRP (TR 32.824) / Text3: 32.101, 32.102, 32.150 / Text5: Edwin Tse (Ericsson), Joerg Schmidt (NSN)
- 154: Contination of Rel-8 UID_400030 IRP SOAP Solution Sets / Text3: 32.127, 32.327, 32.337, 32.357, 32.387, 32.397, 32.447, 32.121, 32.122, 32.123, 32.321, 32.322, 32.323, 32.325, 32.331, 32.332, 32.333, 32.335, 32.351, 32.352, 32.353, 32.381, 32.382, 32.383, 32.385, 32.391, 32.392, 32.393, 32.395, 32.441, 32.442, 32.443, / Text5: John Power
- 155: Text3: 32.501, 32.502, 32.503 / Text5: clemens.suerbaum@nsn.com
- 156: SA#42 umbrella BB created to host OAM WIs
- 157: Text3: 32.425 / Text5: Yizhi Yao (yzyao@motorola.com),Lan Zou (zlan@huawei.com)
- 158: Text3: 32.426 / Text5: Li Jian (lijian@chinamobile.com), Liang Shuangchun (liangshuangchun@cmdi.chinamobile.com)
- 159: Text3: 32.405 / Text5: Liang Shuangchun, Li Jian, Bao Haitao
- 160: SA#42 umbrella BB created to host OAM WIs
- 161: SA#43 umbrella BB created to host OAM WIs
- 162: SA#43 WID updated SP-080067=>SP-090054. SA#42 moved to Rel-9 / Text3: 32.521, 32.522, 32.523 (SON Self-Optimization OAM), 32.541, 32.542, 32.543 (SON Self-Healing OAM) / Text5: Yizhi Yao (yzyao@motorola.com),Lan Zou (zlan@huawei.com)
- 163: Expand the scope of SuM to better include the service layer / Text3: 32.140, 32.141, 32.152, 32.172, 32.175 / Text5: frode.nergard@ericsson.com
- 165: Radio Access Technology differentiation for charging. Completes Rel-8 Feature IWLAN_Mob UID_370049 Mobility between 3GPP-WLAN Interworking and 3GPP Systems / Text3: 32.240, 32.252, 32.298, 32.299 / Text5: Jean-Luc Garcia
- 166: CT#42 moved to Rel-9 / Text3: 31.xyz / Text5: jacques.seif@gemalto.com
- 167: CT#42 umbrella Feature created to host CT1 CAT WI (Stage 1 in 22.182) / Text5: Jiang Yi
- 168: Enhance IMS CAT Supplementary Service as defined in 22.182 and TR 23.872 / Text3: 24.182 / Text5: Jiang Yi
- 169: CT#43 moved to Rel-9. WID updated CP-080577=>CP-090073. Rel-8 UID_380061 (Ipinterc) covers Stage 1 in SA1 22.101, 22.228. CT#42 Rel-8 exception to 03/09 / Text5: mauro.ficaccio@telecomitalia.it
- 170: CT#43 moved to Rel-9. WID updated CP-080577=>CP-090073. CT#42 Rel-8 exception to 03/09 / Text3: 29.235 / Text5: mauro.ficaccio@telecomitalia.it
- 171: CT#43 moved to Rel-9. WID updated CP-080577=>CP-090073. CT#42 Rel-8 exception to 03/09 / Text3: 29.238, 23.231, 29.232 / Text5: mauro.ficaccio@telecomitalia.it
- 172: CT#42 Rel-8 exception to 03/09. CT#43 moved to Rel-9. WID updated CP-080746=>CP-090019 / Text5: Bruno.Landais@alcatel-lucent.fr
- 173: CT#42 Rel-8 exception to 03/09. CT#43 moved to Rel-9. WID updated CP-080746=>CP-090019 / Text3: 29.238 / Text5: Bruno.Landais@alcatel-lucent.fr
- 174: CT#42 Rel-8 exception to 03/09. CT#43 moved to Rel-9. WID updated CP-080746=>CP-090019 / Text3: 29.162, 29.235 / Text5: Bruno.Landais@alcatel-lucent.fr
- 175: CT#42 Rel-8 exception to 03/09. CT#43 moved to Rel-9. WID updated CP-080723=>CP-090020 / Text3: 23.334, 29.334 / Text5: bruno.landais@alcatel-lucent.fr

| ID | WBS | Task | Duration | Start | Finish | Complete | Remaining | Baseline start | Baseline finish | Baseline duration | Total slack | Constraint | Resources | Work | Actual work | Text1 | Text2 | Text4 | Text5 | Text6 | Text7 | Text8 | Text11 |
| --- | --- | --- | --- | --- | --- | --- | --- | --- | --- | --- | --- | --- | --- | --- | --- | --- | --- | --- | --- | --- | --- | --- | --- |
| 176 | 66 | **Completion of IMS Restoration Procedures** | 136d? | 2009-05-29 | 2009-12-03 |  |  | 2009-05-29 | 2009-12-03 | 136d? | 201d |  | C4,C1 | 3264h |  | eIMS_RP | PCG-23 | Ericsson | Emiliano Merino (emiliano.merino@ericsson.com) | Rel-9 | CP-44 | Kimmo |  |
| 177 | 66.1 | CT4 aspects of eIMS_RP | 136d? | 2009-05-29 | 2009-12-03 |  |  | 2009-05-29 | 2009-12-03 | 136d? | 201d | start no earlier than 2009-05-29 | C4 | 1088h |  | eIMS_RP | PCG-23 | Ericsson | Emiliano Merino (emiliano.merino@ericsson.com) | Rel-9 | CP-44 | Kimmo |  |
| 178 | 66.2 | CT1 aspects of eIMS_RP | 136d? | 2009-05-29 | 2009-12-03 |  |  | 2009-05-29 | 2009-12-03 | 136d? | 201d | start no earlier than 2009-05-29 | C1 | 1088h |  | eIMS_RP | PCG-23 | Ericsson | Emiliano Merino (emiliano.merino@ericsson.com) | Rel-9 | CP-44 | Kimmo |  |
| 179 | 67 | Operational description of the Inter-IMS Network to Network Interface (II-NNI) | 136d? | 2009-05-29 | 2009-12-03 |  |  | 2009-05-29 | 2009-12-03 | 136d? | 201d | start no earlier than 2009-05-29 | C3 | 1088h |  | II-NNI | PCG-23 | Orange | sebastien.daudet@orange-ftgroup.com | Rel-9 | CP-44 | Gwiho |  |
| 180 | 68 | IMS Stage 3 - IETF Protocol Alignment | 137d? | 2009-05-29 | 2009-12-04 |  |  | 2009-05-29 | 2009-12-04 | 137d? | 200d | finish no earlier than 2009-12-04 | C1 | 1096h |  | IMSProtoc3 | PCG-23 | Alcatel-Lucent | Keith Drage (drage@alcatel-lucent.com) | Rel-9 | CP-44 | Frederic |  |
| 181 | 69 | **Rel-9 Improvements of the Radio Interface** | 586d? | 2007-12-17 A | 2010-03-12 | 37% | 367.89d? | 2007-12-17 | 2010-03-12 | 586d? | 130d |  | RP,GP | 22771.6h | 8195.87h | RInImp9 | PCG-21 |  |  | Rel-9 | RP-41 | Stefania |  |
| 182 | 69.1 | UMTS/LTE 3500 MHz | 515d? | 2007-12-17 A | 2009-12-04 | 40% | 309d? | 2007-12-17 | 2009-12-04 | 515d? | 200d | finish no earlier than 2009-12-04 | R4 | 4120h | 1648h | RInImp8-UMTSLTE3500 | PCG-21 | Ericsson | Jjohan.skold@ericsson.com | Rel Indep | RP-38 | Stefania | RP-090387 |
| 183 | 69.2 | LCR TDD UE OTA Performance Requirements | 186d? | 2008-09-12 A | 2009-05-29 A | 100% |  | 2008-09-12 | 2009-05-29 | 186d? |  | finish no earlier than 2009-05-29 | R4 | 1488h | 1488h | RInImp9-RFLCROTA | PCG-21 | RITT | Wu Xiang (wuxiang@chinattl.com) | Rel-9 | RP-41 | Stefania | RP-090389 |
| 184 | 69.3 | **RF requirements for Multicarrier and Multi-RAT BS** | 392d? | 2008-09-12 A | 2010-03-12 | 28% | 282.25d? | 2008-09-12 | 2010-03-12 | 392d? | 130d |  | R4,G1 | 8195.6h | 2294.64h | RInImp9-RFmulti | PCG-21 | Ericsson | Johan.skold@ericsson.com | Rel-9 | RP-41 | Stefania | RP-090388 |
| 185 | 69.3.1 | RAN4 part of RF requirements for Multicarrier and Multi RAT BS | 391d? | 2008-09-12 A | 2010-03-12 | 30% | 273.7d? | 2008-09-12 | 2010-03-12 | 391d? | 130d | finish no earlier than 2010-03-12 | R4 | 3128h | 938.4h | RInImp9-RFmulti | PCG-22 | Ericsson | Johan.skold@ericsson.com | Rel-9 | RP-42 | Stefania | RP-090388 |
| 186 | 69.3.2 | GERAN part of RF requirements for Multicarrier and Multi RAT BS | 261d? | 2008-11-21 A | 2009-11-20 | 25% | 195.75d? | 2008-11-21 | 2009-11-20 | 261d? | 210d | finish no earlier than 2009-11-20 | G1 | 2088h | 522h | RInImp9-RFmulti-GERAN | PCG-22 | Ericsson | mats.y.samuelsson@ericsson.com | Rel-9 | GP-40 | Paolo |  |
| 187 | 69.4 | Extended UMTS/LTE 800 MHz | 202d? | 2008-05-07 A | 2009-09-11 | 75% | 50.25d? | 2008-05-07 | 2009-09-11 | 202d? | 260d | finish no earlier than 2009-09-11 | R4 | 1608h | 1206h | RInImp9-UMTSLTE800 | PCG-22 | NTT DoCoMo | Shingo Suwa (suwas@nttdocomo.co.jp) | Rel-9 | RP-42 | Stefania | RP-090390 |
| 188 | 69.5 | UMTS/LTE 800 MHz for Europe | 196d? | 2009-03-06 A | 2009-12-04 | 5% | 186.2d? | 2009-03-06 | 2009-12-04 | 196d? | 200d | finish no earlier than 2009-12-04 | R4 | 1568h | 78.4h | RInImp9-UMTSLTE800EU | PCG-22 | Ericsson | Olav Queseth (olav.queseth@ericsson.com) | Rel-9 | RP-43 | Stefania | RP-090391 |
| 189 | 69.6 | Performance requirement for LCR TDD with UE speeds up to 350 kph | 196d? | 2009-03-06 A | 2009-12-04 | 20% | 156.8d? | 2009-03-06 | 2009-12-04 | 196d? | 200d | finish no earlier than 2009-12-04 | R4 | 1568h | 313.6h | RInImp9-LCRTDD350 | PCG-22 | CATT | Yuexia Song (songyuexia@datangmobile.cn) | Rel-9 | RP-43 | Stefania | RP-090392 |
| 190 | 69.7 | Extended UMTS/LTE 1500 MHz | 136d? | 2009-05-30 | 2009-12-04 |  |  | 2009-05-30 | 2009-12-04 | 136d? | 200d | finish no earlier than 2009-12-04 | R4 | 1088h |  | UMTSLTE1500 | PCG-23 | NTT DoCoMo | Shingo Suwa (suwas@nttdocomo.co.jp) | Rel-9 | RP-44 | Stefania |  |
| 191 | 70 | **Rel-9 Improvements of the Radio Interface - UE Conformance Testing** | 332d? | 2008-12-05 A | 2010-03-12 | 1% | 330.02d? | 2008-12-05 | 2010-03-12 | 332d? | 130d |  | R5 | 9640h | 57.64h | RInImp-UEConTest | PCG-23 |  |  | Rel-9 | RP-44 | Ingbert |  |
| 192 | 70.1 | Conformance Test Aspects – LTE 3500 | 261d? | 2008-12-05 A | 2009-12-04 | 1% | 258.39d? | 2008-12-05 | 2009-12-04 | 261d? | 200d | finish no earlier than 2009-12-04 | R5 | 2088h | 20.88h | LTE-UEConTest_LTE3500 | PCG-22 | Ericsson | fredrik.sundstrom@ericsson.com | Rel Indep | RP-42 | Ingbert | RP-090418 |
| 193 | 70.2 | Conformance Test Aspects – UMTS 3500 | 261d? | 2008-12-05 A | 2009-12-04 | 1% | 258.39d? | 2008-12-05 | 2009-12-04 | 261d? | 200d | finish no earlier than 2009-12-04 | R5 | 2088h | 20.88h | RInImp-UEConTest_UMTS3500 | PCG-22 | Nokia | jukka.vikstedt@nokia.com | Rel Indep | RP-42 | Ingbert | RP-090419 |
| 194 | 70.3 | Conformance Test Aspects – UMTS/LTE in 800 MHz for Europe | 215d? | 2009-05-19 | 2010-03-12 |  |  | 2009-05-19 | 2010-03-12 | 215d? | 130d | finish no earlier than 2010-03-12 | R5 | 1720h |  | UMTSLTE800EU_UEConTest | PCG-23 | Ericsson | fredrik.sundstrom@ericsson.com | Rel-9 | RP-44 | Ingbert |  |
| 195 | 70.4 | TDD UE over the Air (Antenna) conformance testing methodology | 136d? | 2009-05-30 | 2009-12-04 |  |  | 2009-05-30 | 2009-12-04 | 136d? | 200d | finish no earlier than 2009-12-04 | R5 | 1088h |  | UEAnt_TDDTest | PCG-23 | CATR | Qu Yan (quyan@emcite.com) | Rel-9 | RP-44 | Ingbert |  |
| 196 | 71 | **Rel-9 RAN improvements** | 525d? | 2007-12-04 A | 2009-12-04 | 32% | 359.57d? | 2007-12-04 | 2009-12-04 | 525d? | 200d |  | RP | 14696h | 4615.97h | RANimp | PCG-22 |  |  | Rel-9 | RP-43 | Stefania |  |
| 197 | 71.1 | 1.28 Mcps TDD Repeater | 524d? | 2007-12-04 A | 2009-12-04 | 40% | 312.4d? | 2007-12-04 | 2009-12-04 | 524d? | 200d | finish no earlier than 2009-12-04 | R4 | 4192h | 1692.8h | RANimp-Repeaters1.28TDD | PCG-21 | RITT | qinyan@chinattl.com | Rel-9 | RP-38 | Stefania | RP-090393 |
| 198 | 71.2 | Dual-Cell HSUPA | 197d? | 2009-03-06 A | 2009-12-04 | 45% | 107.8d? | 2009-03-06 | 2009-12-04 | 197d? | 200d | finish no earlier than 2009-12-04 | R1 | 1568h | 705.6h | RANimp-DC_HSUPA | PCG-22 | Nokia Siemens Networks | Karri Ranta-aho (karri.ranta-aho@nsn.com) | Rel-9 | RP-43 | Patrick | RP-090395 |
| 199 | 71.3 | Support for different bands for Dual-Cell HSDPA | 196d? | 2009-03-06 A | 2009-12-04 | 25% | 147d? | 2009-03-06 | 2009-12-04 | 196d? | 200d | finish no earlier than 2009-12-04 | R4 | 1568h | 392h | RANimp-MultiBand_DC_HSDPA | PCG-22 | Nokia Siemens Networks | Tuomo.saynajakangas@nsn.com | Rel-9 | RP-43 | Stefania | RP-090396 |
| 200 | 71.4 | Combination of DC-HSDPA with MIMO | 197d? | 2008-06-05 A | 2009-12-04 | 50% | 98d? | 2008-06-05 | 2009-12-04 | 197d? | 200d | finish no earlier than 2009-12-04 | R1 | 1568h | 784h | RANimp-DC_MIMO | PCG-22 | Ericsson | johan.bergman@ericsson.com | Rel-9 | RP-43 | Patrick | RP-090397 |
| 201 | 71.5 | UTRAN 2 ms TTI uplink range improvement | 196d? | 2009-03-06 A | 2009-12-04 | 5% | 186.2d? | 2009-03-06 | 2009-12-04 | 196d? | 200d | finish no earlier than 2009-12-04 | R1 | 1568h | 78.4h | RANimp-2mTTI_ULimp | PCG-22 | Nokia Siemens Networks | Karri Ranta-aho (karri.ranta-aho@nsn.com) | Rel-9 | RP-43 | Patrick | RP-090398 |
| 202 | 71.6 | TxAA extension for non-MIMO UEs | 196d? | 2009-03-06 A | 2009-12-04 | 30% | 137.2d? | 2009-03-06 | 2009-12-04 | 196d? | 200d | finish no earlier than 2009-12-04 | R1 | 1568h | 470.4h | RANimp-TxAA_nonMIMO | PCG-22 | Nokia | Arto Lehti (arto.lehti@nokia.com) | Rel-9 | RP-43 | Patrick | RP-090399 |
| 203 | 71.7 | Cell Portion for 1.28 Mcps TDD | 136d? | 2009-05-30 | 2009-12-04 |  |  | 2009-05-30 | 2009-12-04 | 136d? | 200d | finish no earlier than 2009-12-04 | R3 | 1088h |  | CP_LCRTDD | PCG-23 | CATT | Ying Zhang (zhangying2@datangmobile.cn) | Rel-9 | RP-44 | Juha |  |

Notes:
- 176: Continuation (Stage 2/3) of Rel-8 Feature IMS Restoration Procedures UID_400012
- 177: Text3: 23.380, 23.820
- 178: Text3: 24.229
- 179: Text3: 29.165
- 180: Text3: 23.218, 24.229, 24.940
- 181: RP#41 umbrella Feature created to host Rel-9 WIs
- 182: RP#44 completion target 05/09=>12/09. Testing in UID_420013 & UID_420014 / Text3: 25.101, 25.104, 25.113, 25.133, 25.141, 34.124, 25.307, 25.331, 25.461, 25.463, 36.101, 36.104, 36.141, 25.307, 36.331
- 183: RP#43 Completion target 03/09=>09/09 / Text3: Produced no TR 25.8xy (LCR TDD UE OTA performance requirements)
- 184: RP#42 WID updated RP-080758=>RP-081098
- 185: RP#42 WID updated RP-080758=>RP-081098 / Text3: 25.104, 25.105, 36.104, XX.YYa (E-UA, UA and GSM/EDGE; Multi-Standard Radio (MSR) BS radio transmission and reception), XX.Yybb (BS conformance testing), XX.Yyc (RF requirements for Multicarrier and Multi-RAT BS)
- 186: GP#40 WID approved / Text3: 45.005, 51.021
- 187: RP#44 completion target 05/09=>09/09. TR 36.800-100 for Information / Text3: 36.800 (Extended UMTS/LTE 800 Work Item Technical Report), 25.101, 25.104, 25.113, 25.133, 25.141, 25.306, 25.307, 25.331, 25.461, 25.466, 34.124, 36.101, 36.104, 36.113, 36.124, 36.133, 36.141, 36.331
- 188: Text3: 25.101, 25.104, 25.113, 25.133, 25.141, 25.306, 25.307, 25.331, 25.461, 25.466, 34.124, 36.101, 36.104, 36.113, 36.124, 36.133, 36.141, 36.331
- 189: Text3: 25.102, 25.105, 25.142
- 190: for potential deployment in Japan / Text3: 25.101, 25.104, 25.113, 25.133, 25.141, 34.124, 25.306, 25.307, 25.331, 25.461, 25.466, 36.101, 36.104, 36.113, 36.124, 36.133, 36.141, 36.331
- 192: RP#42 WID approved. Testing for UID_380073 / Text3: 36.508, 36.521-1, 36.521-2, 36.521-3
- 193: Testing for UID_380073 / Text3: 34.108, 34.121-1, 34.121-2
- 194: Testing for UID_430009 UMTS/LTE 800 MHz for Europe / Text3: 34.108, 34.121-1, 34.121-2, 34.123-1, 34.123-2, 34.123-3, 36.508, 36.521-1, 36.521-2, 36.521-3, 36.523-1, 36.523-2, 36.523-3
- 195: Finalize TDD UE test methodology based on R4 TR 25.914 (UE and MS antenna performance evaluation method) and TS 25.144 Over the Air (Antenna) minimum performance requirements for the speech mode (terminal close to head) / Text3: 34.114 Conformance Testing for UE/MS OTA Performance
- 197: RP#44 decided it should be Rel-9. RP#43 Completion target 09/09=>12/09 / Text3: TS 25.xyz LCR TDD Repeater; Radio transmission and reception, TS 25.abc LCR TDD Repeater; Conformance testing, 25.113
- 198: Text3: 25.211, 25.212, 25.213, 25.214, 25.215, 25.319, 25.306, 25.321, 25.331, 25.423, 25.433, 25.101, 25.104, 25.133
- 199: Text3: 25.101, 25.104, 25.133, 25.306, 25.308, 25.331, 25.423, 25.433
- 200: Text3: 25.101, 25.104, 25.211, 25.212, 25.213, 25.214, 25.215, 25.308, 25.321, 25.331, 25.423, 25.433, 26.306, 25.133
- 201: Text3: 25.212, 25.214, 25.321, 25.331, 25.133
- 202: Transmit Antenna Array (TxAA) / Text3: 25.211, 25.212, 25.213, 25.214, 25.215, 25.308, 25.306, 25.321, 25.331, 25.423, 25.433, 25.101, 25.104
- 203: Text3: 25.225, 25.423, 25.433, 25.102, 25.105, 25.123

| ID | WBS | Task | Duration | Start | Finish | Complete | Remaining | Baseline start | Baseline finish | Baseline duration | Total slack | Constraint | Resources | Work | Actual work | Text1 | Text2 | Text6 | Text7 | Text8 | Text4 | Text5 | Text11 | Text9 | Text12 |
| --- | --- | --- | --- | --- | --- | --- | --- | --- | --- | --- | --- | --- | --- | --- | --- | --- | --- | --- | --- | --- | --- | --- | --- | --- | --- |
| 204 | 72 | **LTE improvements** | 262d? | 2009-03-06 A | 2010-03-05 | 9% | 238.91d? | 2009-03-06 | 2010-03-05 | 262d? | 135d |  | RP | 6840h | 602.68h | LTEimp | PCG-22 | Rel-9 | RP-42 | Stefania |  |  |  |  |  |
| 205 | 72.1 | LTE Pico NodeB RF Requirements | 261d? | 2009-03-06 A | 2010-03-05 | 5% | 247.95d? | 2009-03-06 | 2010-03-05 | 261d? | 135d | finish no earlier than 2010-03-05 | R4 | 2088h | 104.4h | LTEimp-Pico_eNB-RF | PCG-22 | Rel-9 | RP-43 | Stefania | Huawei | Liyan Yin (yinliyan@huawei.com) | RP-090404 |  |  |
| 206 | 72.2 | Enhanced Dual-Layer transmission for LTE | 196d? | 2009-03-06 A | 2009-12-04 | 20% | 156.8d? | 2009-03-06 | 2009-12-04 | 196d? | 200d | finish no earlier than 2009-12-04 | R1 | 1568h | 313.6h | LTEimp-eDL | PCG-22 | Rel-9 | RP-43 | Patrick | China Mobile | Xu Xiaodong (xuxiaodong@chinamobile.com) | RP-090405 |  |  |
| 207 | 72.3 | Vocoder rate adaptation for LTE | 136d? | 2009-05-30 | 2009-12-04 |  |  | 2009-05-30 | 2009-12-04 | 136d? | 200d | finish no earlier than 2009-12-04 | R2 | 1088h |  | LTEimp-Vocoder | PCG-23 | Rel-9 | RP-44 | Joern | Alcatel-Lucent | Sudeep Palat |  |  |  |
| 208 | 73 | **Self-Organizing Networks (SON)** | 197d? | 2009-03-06 A | 2009-12-04 | 35% | 127.4d? | 2009-03-06 | 2009-12-04 | 197d? | 200d |  | R3 | 3144h | 1105.6h | SON | PCG-22 | Rel-9 | SP-42 | Juha | Nokia Siemens Networks | Krzysztof Kordybach | RP-090410 |  |  |
| 209 | 73.1 | SON | 197d? | 2009-03-06 A | 2009-12-04 | 35% | 127.4d? | 2009-03-06 | 2009-12-04 | 197d? | 200d | finish no earlier than 2009-12-04 | R3 | 1568h | 548.8h | SON | PCG-22 | Rel-9 | RP-43 | Juha | Nokia Siemens Networks | Krzysztof Kordybach (krzysztof.kordybach@nsn.com) | RP-090410 |  |  |
| 210 | 74 | **Voice services over Adaptive Multi-user channels on One Slot** | 262d? | 2008-11-21 A | 2009-11-20 | 35% | 169.52d? | 2008-11-21 | 2009-11-20 | 262d? | 210d |  | GP | 7480h | 2635.02h | VAMOS | PCG-22 | Rel-9 | SP-42 | Paolo | Nokia Siemens Networks, China Mobile | juergen.hofmann@nsn.com, liuxiaoyu@chinamobile.com |  |  |  |
| 211 | 74.1 | VAMOS Stage 2 | 207d? | 2008-11-21 A | 2009-09-04 | 80% | 41.2d? | 2008-11-21 | 2009-09-04 | 207d? | 265d | finish no earlier than 2009-09-04 | GP | 1648h | 1318.4h | VAMOS | PCG-22 | Rel-9 | GP-40 | Paolo | Nokia Siemens Networks, China Mobile | juergen.hofmann@nsn.com, liuxiaoyu@chinamobile.com |  |  |  |
| 212 | 74.2 | VAMOS Stage 3 | 206d? | 2008-11-21 A | 2009-09-04 | 35% | 133.9d? | 2008-11-21 | 2009-09-04 | 206d? | 265d | finish no earlier than 2009-09-04 | GP | 1648h | 576.8h | VAMOS | PCG-22 | Rel-9 | GP-40 | Paolo | Nokia Siemens Networks, China Mobile | juergen.hofmann@nsn.com, liuxiaoyu@chinamobile.com |  |  |  |
| 213 | 74.3 | VAMOS Radio Performance Requirements | 261d? | 2008-11-24 | 2009-11-20 |  |  | 2008-11-24 | 2009-11-20 | 261d? | 210d | finish no earlier than 2009-11-20 | GP | 2088h |  | VAMOS | PCG-22 | Rel-9 | GP-40 | Paolo | Nokia Siemens Networks, China Mobile | juergen.hofmann@nsn.com, liuxiaoyu@chinamobile.com |  |  |  |
| 214 | 75 | **Local Call Local Switch** | 206d? | 2009-02-20 A | 2009-12-03 | 10% | 185.95d? | 2009-02-20 | 2009-12-03 | 206d? | 201d |  | GP | 7568h | 630.83h | LCLS | PCG-22 | Rel-9 | GP-41 | Paolo | Huawei | Xing Zhu |  |  |  |
| 215 | 75.1 | Local Call Local Switch | 196d? | 2009-02-20 A | 2009-11-20 | 30% | 137.2d? | 2009-02-20 | 2009-11-20 | 196d? | 210d | finish no earlier than 2009-11-20 | GP | 1568h | 470.4h | LCLS | PCG-22 | Rel-9 | GP-41 | Paolo | Huawei | Xing Zhu |  |  |  |
| 216 | 75.2 | **CN aspects of Local Call Local Switch** | 136d? | 2009-05-29 | 2009-12-03 |  |  | 2009-05-29 | 2009-12-03 | 136d? | 201d |  | C4,C3,C1 | 4352h |  | LCLS-CN | PCG-23 | Rel-9 | CP-44 | Kimmo | Vodafone | David Hutton |  |  |  |
| 217 | 75.2.1 | CT4 aspects of LCLS | 136d? | 2009-05-29 | 2009-12-03 |  |  | 2009-05-29 | 2009-12-03 | 136d? | 201d | start no earlier than 2009-05-29 | C4 | 1088h |  | LCLS-CN | PCG-23 | Rel-9 | CP-44 | Kimmo | Vodafone | David Hutton |  |  |  |
| 218 | 75.2.2 | CT3 aspects of LCLS | 136d? | 2009-05-29 | 2009-12-03 |  |  | 2009-05-29 | 2009-12-03 | 136d? | 201d | start no earlier than 2009-05-29 | C3 | 1088h |  | LCLS-CN | PCG-23 | Rel-9 | CP-44 | Kimmo | Vodafone | David Hutton |  |  |  |
| 219 | 75.2.3 | CT1 aspects of LCLS | 136d? | 2009-05-29 | 2009-12-03 |  |  | 2009-05-29 | 2009-12-03 | 136d? | 201d | start no earlier than 2009-05-29 | C1 | 1088h |  | LCLS-CN | PCG-23 | Rel-9 | CP-44 | Kimmo | Vodafone | David Hutton |  |  |  |
| 220 | 76 | **Cell Broadcast protocol Base Station Controller – Cell Broadcast Centre (BSC-CBC)** | 147d? | 2009-05-15 | 2009-12-04 |  |  | 2009-05-15 | 2009-12-04 | 147d? | 200d |  | GP,C1 | 3440h |  | CEBRO | PCG-23 | Rel-9 | GP-42 | Paolo | Ericsson | Claes-Göran Persson |  |  |  |
| 221 | 76.1 | Cell Broadcast protocol Base Station Controller – Cell Broadcast Centre (BSC-CBC) | 136d? | 2009-05-15 | 2009-11-19 |  |  | 2009-05-15 | 2009-11-19 | 136d? | 211d | start no earlier than 2009-05-15 | GP | 1088h |  | CEBRO | PCG-23 | Rel-9 | GP-42 | Paolo | Ericsson | Claes-Göran Persson |  |  |  |
| 222 | 76.2 | Cell Broadcast protocol Base Station Controller – Cell Broadcast Centre (BSC-CBC) | 147d? | 2009-05-15 | 2009-12-04 |  |  | 2009-05-15 | 2009-12-04 | 147d? | 200d | finish no earlier than 2009-12-04 | C1 | 1176h |  | CEBRO | PCG-23 | Rel-9 | GP-42 | Frederic | Ericsson | Claes-Göran Persson |  |  |  |
| 223 | 77 | Hybrid Location | 81d? | 2009-05-18 | 2009-09-04 |  |  | 2009-05-18 | 2009-09-04 | 81d? | 265d | finish no earlier than 2009-09-04 | GP | 648h |  | HILT | PCG-23 | Rel-9 | GP-42 | Paolo | TruePosition | Matt Ward (mward@trueposition.com) |  |  |  |
| 224 | 78 | (Small) Technical Enhancements and Improvements for Rel-9 | 391d? | 2008-09-15 | 2010-03-12 |  |  | 2008-09-15 | 2010-03-12 | 391d? | 130d | finish no earlier than 2010-03-12 | All | 3128h |  | TEI9 | PCG-22 | Rel-9 | SP-42 |  | ALL |  |  |  |  |
| 225 | 79 | **Deleted - SAES Enhancements (non RAN aspects)** | 381d? | 2007-06-25 A | 2008-12-08 A | 100% |  | 2007-06-25 | 2008-12-08 | 381d? |  |  | S2 | 11664h | 11664h | SAES_Ph2 | PCG-21 | Rel-9 | SP-39 | Maurice | Nokia Siemens Networks |  |  | PCG-21 | SP-39 |
| 226 | 79.1 | Deleted - Functions and procedures for SAE to support LTE MBMS | 381d? | 2007-06-25 A | 2008-12-08 A | 100% |  | 2007-06-25 | 2008-12-08 | 381d? |  | finish no earlier than 2008-12-08 | S2 | 3048h | 3048h | SAES_Ph2 |  | Rel-9 | SP-35 | Maurice |  |  |  | PCG-21 | SP-39 |
| 227 | 79.2 | Deleted - CS over EPS | 194d? | 2008-03-12 A | 2008-12-08 A | 100% |  | 2008-03-12 | 2008-12-08 | 194d? |  | finish no earlier than 2008-12-08 | S2 | 1552h | 1552h | SAES_Ph2 | PCG-21 | Rel-9 | SP-39 | Maurice |  |  |  | PCG-21 | SP-39 |

Notes:
- 205: Text3: 36.8xy (RF requirements for LTE Pico NodeB), 36.104, 36.141
- 206: RP#44 WID updated RP-090359=>RP-090648. Evolve Rel-8 single layer Dedicated Reference Symbols (DRS) based beamforming technology to multi-layer beamforming increasing cell throughput especially at cell edge in LCR TDD network / Text3: 36.101, 36.104, 36.106, 36.133, 36.211, 36.212, 36.213, 36.321, 36.331
- 207: Allow operator's trade-off between voice quality and capacity in LTE. SA2/SA4 impacted. Goal could be satisfied with a reduced set of requirements. SA2/SA4 to analyze impact of these restricted requirements. / Text3: 36.300
- 209: TR 36.902 v100 for Information / Text3: 36.300, 36.423, 36.902
- 210: GP#40 WID approved. Triggered by UID_50590 (MUROS) Study on Multi-User Reusing-One-Slot
- 211: GP#42 completion 05/09=>09/09. GP#40 WID approved / Text3: 45.001 (Overview of VAMOS solution)
- 212: GP#40 WID approved / Text3: 24.008, 44.018, 45.002, 45.003, 45.004, 45.008, 48.008, 48.058
- 213: GP#40 WID approved / Text3: 45.005 (Test Scenarios for VAMOS Performance requirements)
- 214: CP#44 WID approved. GP#41 WID approved
- 215: GP#41 WID approved / Text3: 48.008 (MSC-BSS interface; Layer 3 specification)
- 216: Stage 2/3
- 217: Text3: 23.8xx, 23.205, 23.153, 23.231, 29.232
- 218: Text3: 29.007
- 219: Text3: 23.009
- 220: GP#42 WID approved
- 221: GP#42 WID approved / Text3: TS XX.XXX (Base Station Controller – Cell Broadcast Centre (BSC - CBC) Interface Specification)
- 222: GP#42 WID approved / Text3: 23.041
- 223: GP#42 WID approved (Hybrid Integrated Location Technology=HILT) / Text3: 43.059, 48.071
- 225: SA#39 created to host Rel-9 Wis. BUT no agreed WID
- 226: SA#39 SAE functionality moved to Rel-9. WID returned to SA2 for re-consideration & remove MBMS for EPS from Rel 8
- 227: SA#39 SAE functionality moved to Rel-9. BUT no agreed WID

| ID | WBS | Task | Type | Duration | Start | Finish | Predecessors | Complete | Remaining | Baseline start | Baseline finish | Baseline duration | Total slack | Constraint | Resources | Work | Actual work | Text1 | Text2 | Text6 | Text7 | Text8 | Text9 | Text12 | Text4 | Text5 | Text11 |
| --- | --- | --- | --- | --- | --- | --- | --- | --- | --- | --- | --- | --- | --- | --- | --- | --- | --- | --- | --- | --- | --- | --- | --- | --- | --- | --- | --- |
| 228 | 79.3 | **Deleted - SAE for generic support for non-3GPP accesses** |  | 251d? | 2007-06-25 A | 2008-06-09 A |  | 100% |  | 2007-06-25 | 2008-06-09 | 251d? |  |  | S2 | 4016h | 4016h | SAES_Ph2 | PCG-21 | Rel-9 | SP-39 | Maurice | PCG-21 | SP-39 |  |  |  |
| 229 | 79.3.1 | Deleted - Single Radio Aspects of SAE for Optimized Handover with WiMAX |  | 251d? | 2007-06-25 A | 2008-06-09 A |  | 100% |  | 2007-06-25 | 2008-06-09 | 251d? |  | finish no earlier than 2008-06-09 | S2 | 2008h | 2008h | SAES_Ph2 | PCG-21 | Rel-9 | SP-39 | Maurice | PCG-21 | SP-39 |  |  |  |
| 230 | 80 | Deleted - Harmonization of Gq'/Rx for Common IMS |  | 304d? | 2008-01-14 A | 2009-03-12 A |  | 100% |  | 2008-01-14 | 2009-03-12 | 304d? |  | finish no earlier than 2009-03-12 | S2 | 2432h | 2432h | IMS_Comm_GqRx_Harm | PCG-21 | Rel-9 | SP-38 | Maurice | PCG-22 | SP-43 | Alcatel-Lucent | geoffrey.cristallo@alcatel-lucent.be |  |
| 231 | 81 | Deleted - Support of WiMAX - LTE Mobility |  | 407d? | 2008-06-06 A | 2009-12-25 A |  | 100% |  | 2008-06-06 | 2009-12-25 | 407d? |  | start no earlier than 2008-06-06 | R2 | 3248h | 3248h | WiMAX_LTE_Mobility | PCG-21 | Rel-9 | RP-38 | Joern | PCG-21 | SP-39 | Samsung |  |  |
| 232 | 82 | Deleted - Support of WiMAX - UMTS Mobility |  | 407d? | 2008-06-06 A | 2009-12-25 A |  | 100% |  | 2008-06-06 | 2009-12-25 | 407d? |  | start no earlier than 2008-06-06 | R2 | 3248h | 3248h | WiMAX_UMTS_Mobility | PCG-21 | Rel-9 | RP-38 | Joern | PCG-21 | SP-39 | Intel |  |  |
| 233 | 83 | Release 9 Feasibility Studies | milestone | 0d? | 2000-01-01 | 2000-01-01 |  |  |  | 2000-01-01 | 2000-01-01 | 0d? | 2792d |  | CP,GP,RP,SP |  |  |  |  | Rel-9 |  |  |  |  |  |  |  |
| 234 | 84 | **Study on enhanced voice service requirements for the EPS** |  | 540d? | 2007-09-03 A | 2009-09-24 |  | 63% | 200.04d? | 2007-09-03 | 2009-09-24 | 540d? | 251d |  | S1,S4 | 11304h | 7116.47h | FS_EV_EPS |  | Rel-9 | SP-37 | Alain |  |  | Orange | tim.haysom@orange-ftgroup.com |  |
| 235 | 84.1 | Use cases definition and service and system requirements |  | 334d? | 2007-09-03 A | 2008-12-11 A |  | 100% |  | 2007-09-03 | 2008-12-11 | 334d? |  | finish no earlier than 2008-12-11 | S1 | 2672h | 2672h | FS_EV_EPS-S1 |  | Rel-9 | SP-37 | Alain |  |  | Orange | tim.haysom@orange-ftgroup.com |  |
| 236 | 84.2 | Codec specific part of FSEV_EPS |  | 539d? | 2007-09-03 A | 2009-09-24 |  | 40% | 323.4d? | 2007-09-03 | 2009-09-24 | 539d? | 251d | finish no earlier than 2009-09-24 | S4 | 4312h | 1724.8h | FS_EV_EPS-S4 |  | Rel-9 | SP-37 | Paolo |  |  | Orange | tim.haysom@orange-ftgroup.com |  |
| 237 | 85 | Study on Service Specific Access Control in EPS |  | 136d? | 2008-06-05 A | 2008-12-11 A |  | 100% |  | 2008-06-05 | 2008-12-11 | 136d? |  | start no earlier than 2008-06-05 | S1 | 1088h | 1088h | FS_SSAC | PCG-21 | Rel-9 | SP-40 | Alain |  |  | NTT DoCoMo | Frederic Thepot (thepot@docomolab-euro.com) |  |
| 238 | 86 | Study on CS Domain Services over EPS access |  | 492d? | 2007-04-25 A | 2009-03-12 A |  | 100% |  | 2007-04-25 | 2009-03-12 | 492d? |  | finish no earlier than 2009-03-12 | S2 | 3936h | 3936h | FS_CSoPS |  | Rel-9 | SP-35 | Maurice |  |  | T-Mobile | sabine.demel@t-mobile.at |  |
| 239 | 87 | Study on Extended Support of IMS Emergency Calls |  | 319d? | 2007-09-24 A | 2008-12-11 A |  | 100% |  | 2007-09-24 | 2008-12-11 | 319d? |  | finish no earlier than 2009-06-18 | S2 | 2552h | 2552h | FS_IMS-eCall |  | Rel-9 | SP-37 | Maurice |  |  | Qualcomm | Stephen Edge |  |
| 240 | 88 | Study on Multi Access PDN connectivity and IP flow Mobility |  | 267d? | 2008-09-18 A | 2009-09-24 |  | 85% | 40.05d? | 2008-09-18 | 2009-09-24 | 267d? | 251d | finish no earlier than 2009-09-24 | S2,S1 | 2136h | 1815.6h | FS_MAPIM | PCG-21 | Rel-9 | SP-41 | Maurice |  |  | Qualcomm | Gerardo Giaretta (gerardog@qualcomm.com) |  |
| 241 | 89 | Study on Service Continuity for Emergency Voice Calls |  | 721d? | 2006-06-08 A | 2009-03-12 A |  | 100% |  | 2006-06-08 | 2009-03-12 | 721d? |  | finish no earlier than 2009-03-12 | S2 | 5768h | 5768h | FS_VCCEm |  | Rel-9 | SP-32 | Maurice |  |  | Nortel | Ricky Kaura (rkaura@nortel.com) |  |
| 242 | 90 | Study on Protection against SMS and MMS spam |  | 916d? | 2006-06-08 A | 2009-12-10 |  | 30% | 641.2d? | 2006-06-08 | 2009-12-10 | 916d? | 196d | finish no earlier than 2009-12-10 | S3 | 7328h | 2198.4h | FS_CPSMal |  | Rel-9 | SP-32 | Dionisio |  |  | Orange | eric.gauthier@orange.ch |  |
| 243 | 91 | Study on Security Aspects of Remote Provisioning and Change of Subscription for M2M Equipment |  | 527d? | 2004-04-06 A | 2009-09-24 |  | 70% | 158.1d? | 2004-04-06 | 2009-09-24 | 527d? | 251d | finish no earlier than 2009-09-24 | S3,C6 | 4216h | 2951.2h | FS_UM2M |  | Rel-9 | SP-37 | Dionisio |  |  | Ericsson | vesa.lehtovirta@ericsson.com |  |
| 244 | 92 | Study on UTRAN key management enhancements |  | 517d? | 2007-12-20 A | 2009-12-10 |  | 30% | 361.9d? | 2007-12-20 | 2009-12-10 | 517d? | 196d | finish no earlier than 2009-12-10 | S3 | 4136h | 1240.8h | FS_UKM | PCG-21 | Rel-9 | SP-38 | Dionisio |  |  | Ericsson | Karl Norrman |  |
| 245 | 93 | Study on Surround Sound codec extension for PSS and MBMS |  | 132d? | 2009-03-12 A | 2009-09-11 |  | 5% | 125.4d? | 2009-03-12 | 2009-09-11 | 132d? | 260d | finish no earlier than 2009-09-11 | S4 | 1056h | 52.8h | FS_SS_PSS_MBMS | PCG-22 | Rel-9 | SP-43 | Paolo |  |  | Fraunhofer Gesellschaft | jan.plogsties@iis.franhofer.de |  |
| 246 | 94 | Study on System Maintenance over Itf-N |  | 657d? | 2007-06-07 A | 2009-12-10 |  | 80% | 131.2d? | 2007-06-07 | 2009-12-10 | 657d? | 196d | finish no earlier than 2009-12-10 | S5 | 5248h | 4198.4h | FS_OAM-Maint-Itf-N |  | Rel-9 | SP-36 | Dionisio |  |  | ZTE | HUANG, Shuqiang |  |
| 247 | 95 | Study on Self-Organizing Networks (SON) related OAM interfaces for Home NodeB |  | 522d? | 2007-06-07 A | 2009-06-04 A |  | 100% |  | 2007-06-07 | 2009-06-04 | 522d? |  | finish no earlier than 2009-12-10 | S5 | 4168h | 4168h | FS_OAM-SON-HNB |  | Rel-9 | SP-36 | Dionisio |  |  | Huawei | Zou Lan (zlan@huawei.com) |  |
| 248 | 96 | Study on Self-healing of Self-Organizing Networks (SON) |  | 471d? | 2008-02-22 A | 2009-12-10 |  | 90% | 47d? | 2008-02-22 | 2009-12-10 | 471d? | 196d | finish no earlier than 2009-12-10 | S5 | 3760h | 3384h | FS_OAM-SON-SH | PCG-21 | Rel-9 | SP-39 | Dionisio |  |  | ZTE | zhu.weihong@zte.com.cn |  |
| 249 | 97 | Study on Service Oriented Architecture (SOA) for IRP |  | 262d? | 2008-06-05 A | 2009-06-04 A |  | 100% |  | 2008-06-05 | 2009-06-04 | 262d? |  | finish no earlier than 2009-05-20 | S5 | 2088h | 2088h | FS_OAM_SOA_IRP | PCG-21 | Rel-9 | SP-40 | Dionisio |  |  | Ericsson | edwin.tse@ericsson.com |  |
| 250 | 98 | Study on Rc Reference Point Functionalities and Message Flows |  | 322d? | 2008-09-18 A | 2009-12-10 |  | 65% | 112.35d? | 2008-09-18 | 2009-12-10 | 322d? | 196d | finish no earlier than 2009-12-10 | S5 | 2568h | 1669.2h | FS_OAM_Rc | PCG-21 | Rel-9 | SP-41 | Dionisio |  |  | Huawei | shan.mingjun@huawei.com |  |
| 251 | 99 | Study on Telecommunication Management; Energy Savings Management (ESM) |  | 196d? | 2009-03-12 A | 2009-12-10 |  | 15% | 166.6d? | 2009-03-12 | 2009-12-10 | 196d? | 196d | finish no earlier than 2009-12-10 | S5 | 1568h | 235.2h | FS_OAM_ESM | PCG-22 | Rel-9 | SP-43 | Dionisio |  |  | Orange, Vodafone | Jean-Michel Cornilly (Orange) |  |
| 252 | 100 | Study on Integration of Device Management Information with Itf-N |  | 136d? | 2009-06-04 | 2009-12-10 | 477 |  |  | 2009-06-04 | 2009-12-10 | 136d? | 196d | finish no earlier than 2009-12-10 | S5 | 1088h |  | FS_IDMI_Itf-N | PCG-23 | Rel-9 | SP-44 | Dionisio |  |  | Motorola | Yizhi Yao (yzyao@motorola.com) |  |
| 253 | 101 | Study on EPC Charging enhancement |  | 136d? | 2009-06-04 | 2009-12-10 |  |  |  | 2009-06-04 | 2009-12-10 | 136d? | 196d | start no earlier than 2009-06-04 | S5 | 1088h |  | FS_EPCcharg | PCG-23 | Rel-9 | SP-44 | Dionisio |  |  | Nokia Siemens Networks | Gerald.Goermer@nsn.com |  |
| 254 | 102 | Study on Evaluation of the inclusion of Path Loss Based Technology in the UTRAN |  | 456d? | 2007-12-17 A | 2009-09-11 |  | 95% | 22.75d? | 2007-12-17 | 2009-09-11 | 456d? | 260d | finish no earlier than 2009-09-11 | R4 | 3640h | 3458h | FS_RAN-Pathloss | PCG-21 | Rel-9 | RP-38 | Stefania |  |  | Polaris Wireless | Norman Shaw (nshaw@polariswireless.com) | RP-090423 |
| 255 | 103 | Study on LTE-Advanced |  | 386d? | 2008-06-13 A | 2009-12-04 |  | 60% | 154.4d? | 2008-06-13 | 2009-12-04 | 386d? | 200d | finish no earlier than 2009-12-04 | R1 | 3088h | 1852.8h | FS_RAN_LTEA | PCG-21 | Rel-9 | RP-39 | Patrick |  |  | NTT DoCoMo | Takehiro Nakamura (nakamurata@nttdocomo.co.jp) | RP-090424 |
| 256 | 104 | Study on 1.28 Mcps TDD Home NodeB |  | 326d? | 2008-02-20 A | 2009-09-11 |  | 60% | 130.4d? | 2008-02-20 | 2009-09-11 | 326d? | 260d | finish no earlier than 2009-09-11 | R4 | 2608h | 1564.8h | FS_RAN-HNBLCRTDD | PCG-21 | Rel-9 | RP-41 | Stefania |  |  | TD Tech | Li Rong (lirong@td-tech.com) | RP-090425 |
| 257 | 105 | Study on E-UTRAN Mobility Evaluation and Enhancement |  | 126d? | 2008-12-05 A | 2009-05-29 A |  | 100% |  | 2008-12-05 | 2009-05-29 | 126d? |  | finish no earlier than 2009-05-29 | R1 | 1008h | 1008h | FS_EUTRAN_mob | PCG-22 | Rel-9 | RP-42 | Patrick |  |  | Qualcomm | Rajat Prakash (rprakash@qualcomm.com) | RP-090426 |
| 258 | 106 | Study on Measurement of Radiated Performance for MIMO and multi-antenna reception for HSPA and LTE terminals |  | 196d? | 2009-03-06 A | 2009-12-04 |  | 15% | 166d? | 2009-03-06 | 2009-12-04 | 196d? | 200d | finish no earlier than 2009-12-04 | R4 | 1568h | 240h | FS_HSPA_LTE_measRP_MIMO_multi-antenna | PCG-22 | Rel-9 | RP-43 | Stefania |  |  | Vodafone | SoonLeh Ling (soonleh.ling@vodafone.com) | RP-090427 |
| 259 | 107 | Study on Minimization of drive-tests in Next Generation Networks |  | 136d? | 2009-03-06 A | 2009-09-11 |  | 30% | 95.2d? | 2009-03-06 | 2009-09-11 | 136d? | 260d | finish no earlier than 2009-09-11 | R2 | 1088h | 326.4h | FS_NGN_min_drive-tests | PCG-22 | Rel-9 | RP-43 | Joern |  |  | Qualcomm | Masato Kitazoe (mkitazoe@qualcomm.com) | RP-090428 |
| 260 | 108 | Study on Enhanced Interference Management for HNBs |  | 61d? | 2009-03-06 A | 2009-05-29 A |  | 100% |  | 2009-03-06 | 2009-05-29 | 61d? |  | start no earlier than 2009-03-06 | R4 | 488h | 488h | FS_eInterfMgmt_HNB | PCG-22 | Rel-9 | RP-43 | Stefania |  |  | Qualcomm | Farhad Meshkati (fmeshkat@qualcomm.com) | RP-090429 |
| 261 | 109 | Study on Enhanced Interference Management Mechanisms for HNBs |  | 136d? | 2009-05-30 | 2009-12-04 |  |  |  | 2009-05-30 | 2009-12-04 | 136d? | 200d | finish no earlier than 2009-12-04 | R3 | 1088h |  | FS_eInterfMgmtMchsm_HNB | PCG-23 | Rel-9 | RP-44 | Juha |  |  | Qualcomm | Farhad Meshkati |  |
| 262 | 110 | Study on Extending 850 MHz |  | 136d? | 2009-05-30 | 2009-12-04 |  |  |  | 2009-05-30 | 2009-12-04 | 136d? | 200d | finish no earlier than 2009-12-04 | R4 | 1088h |  | FS_e850 | PCG-23 | Rel-9 | RP-44 | Stefania |  |  | Ericsson | Christian Bergljung (christian.bergljung@stericsson.com) |  |
| 263 | 111 | Release 8 Features | milestone | 0d? | 2000-01-03 | 2000-01-03 |  |  |  | 2000-01-03 | 2000-01-03 | 0d? | 2791d | start no earlier than 2000-01-03 | CP,GP,RP,SP |  |  |  |  | Rel-8 |  |  |  |  |  |  |  |

Notes:
- 228: SA#39 SAE functionality moved to Rel-9. BUT no agreed WID
- 229: SA#39 SAE functionality moved to Rel-9. BUT no agreed WID
- 230: SA#43 stopped. LS_out to TISPAN informs about stopping this activity / Text3: 23.822, 23.203
- 231: RP#39: No agreed WID / Text3: 36.306, 36.331, 36.413, 36.300, 36.214, 36.133, 36.304
- 232: RP#39: No agreed WID / Text3: 25.306, 25.331, 25.413
- 234: SA#42 SA1 part completed
- 235: SA#42 completed / Text3: 22.813
- 237: SA#42 completed. Spinn-off Feature UID_420020 (SSAC) / Text3: 22.986
- 238: SA#43 completed / Text3: 23.879
- 239: SA#42 completed / Text3: 23.868
- 240: SA#44 completion 06/09=>09/09. SA#43 TR 23.861 for Information / Text3: 23.861
- 241: SA#43 completed / Text3: 23.826
- 242: SA#42 moved to Rel-9 / Text3: 33.9xx
- 243: SA#44 WI Title alligned with TR (SP-090267). SA#43 TR 33.812 for Information. Triggered by SA1 Study UID_7027 (FS_M2M) TR 22.868 / Text3: 33.812
- 244: SA#44 SID updated SP-070782=>SP-090283 (removed UTRAN/E-UTRAN IRAT signalling cases from Study scope (while IRAT handling is left as specified by 33.401). Study also focuses on support for a key hierarchy locally in UTRAN and intra-UTRAN mobility cases.) / Text3: 33.8xy
- 245: Work to extend Rel-8 UID_34043 PSS_MBMS_OMTV (Extending PSS and MBMS User Services for optimized Mobile TV) / Text3: 26.9xx (Study on Surround Sound for PSS and MBMS)
- 246: SA#44 for SA Information / Text3: 32.822
- 247: SA#44 completed / Text3: 32.821
- 248: SA#44 for SA Information / Text3: 32.823
- 249: SA#44 completed. Spin-off implementation WI UID_440000Service Oriented Architecture (SOA) for IRP / Text3: 32.824
- 250: SA#44 for SA Information / Text3: 32.825
- 251: Study result might impact Feature UID_420011 Self Organising Networks (SON) / Text3: 32.826
- 252: Study the missing Itf-N part in the Framework. Study changes to Itf-N to utilize UE based measurements / Text3: 32.8xy Study on User Equipment Management (UEM)
- 253: Text3: It has to be decided whether it will be a new TR or Rel-9 CRs on TR 32.820
- 254: RP#44 completion target 03/09=>05/09=>-9/09 / Text3: 25.9xx
- 255: RP#44 completion target 09/09=>12/09. WID updated RP-080599=>RP-090665 (Added: Support of heterogeneous network deployments i.e. mix deployments consisting of macro, pico, femto and relay nodes). RP#43 TR 36.814 for Information. RP#40 TR 36.913 completed / Text3: 36.913 (Reqs for further advancements for E-UTRA (LTE-Advanced), 36.814 (Further advancements for E-UTRA Physical layer aspects)
- 256: RP#44 completion target 05/09=>09/09 / Text3: 25.866
- 257: RP#44 completed (RP-090452 R1 LS to RAN on Conclusions for LTE Mobility Study Item - no further Rel-9 action/TR needed
- 258: Text3: New TR (25/36) on Measurements of radiated performance for MIMO and multi-antenna reception for HSPA and LTE terminals
- 259: RP#44 TR 36.805-100 for Information / Text3: 36.805
- 260: RP#44 completed. Spin-off RAN3 UID_440015 Study on Enhanced Interference Management Mechanisms for HNBs / Text3: 25.967
- 261: Triggered by RAN4 UID_430027 Study on Enhanced Interference Management for HNBs / Text3: TR ab.xyz
- 262: Text3: TR xx.yyy (Extending 850 study Item Technical report)

| ID | WBS | Task | Duration | Start | Finish | Complete | Remaining | Baseline start | Baseline finish | Baseline duration | Total slack | Constraint | Resources | Work | Actual work | Text1 | Text4 | Text5 | Text6 | Text8 | Text7 | Text2 |
| --- | --- | --- | --- | --- | --- | --- | --- | --- | --- | --- | --- | --- | --- | --- | --- | --- | --- | --- | --- | --- | --- | --- |
| 264 | 112 | **3GPP System Architecture Evolution Specification - Evolved Packet System (non RAN aspects)** | 899d? | 2006-04-12 A | 2009-09-18 | 99% | 2.8d? | 2006-04-12 | 2009-09-18 | 899d? | 255d |  | SP,CP | 256980h | 251624h | SAES | T-Mobile | michael.kurz@t-mobile.at | Rel-8 | Alain |  |  |
| 265 | 112.1 | Requirements for evolution of the 3GPP system architecture | 395d? | 2006-06-08 A | 2007-12-12 A | 100% |  | 2006-06-08 | 2007-12-12 | 395d? |  | finish no earlier than 2007-11-30 | S1 | 3160h | 3160h | AIPN-SAE | T-Mobile | michael.kurz@t-mobile.at | Rel-8 | Alain |  |  |
| 266 | 112.2 | **High level and common (for all accesses) functions** | 629d? | 2007-01-02 A | 2009-05-29 A | 100% |  | 2007-01-02 | 2009-05-29 | 629d? |  |  | SP,CP | 42536h | 42536h | EPS-ComF | Nokia Siemens Networks | balazs.bertenyi@nsn.com | Rel-8 | Maurice | SP-37 |  |
| 267 | 112.2.1 | Stage 2 for High level functions | 370d? | 2007-01-02 A | 2008-06-02 A | 100% |  | 2007-01-02 | 2008-06-02 | 370d? |  | finish no earlier than 2008-06-02 | S2 | 2960h | 2960h | SAES-SA-HLF | Motorola | Irfan.Ali@motorola.com | Rel-8 | Maurice |  |  |
| 268 | 112.2.2 | Stage 2 Security Architecture | 197d? | 2008-03-12 A | 2008-12-11 A | 100% |  | 2008-03-12 | 2008-12-11 | 197d? |  | finish no earlier than 2008-12-11 | S3 | 1576h | 1576h | SAES | Nokia Siemens Networks | marc.blommaert.ext@nsn.com | Rel-8 | Dionisio | SP-39 | PCG-21 |
| 269 | 112.2.3 | Stage 3 (CT1) for SAE impact on services, network functions and capabilities | 545d? | 2007-02-05 A | 2009-03-06 A | 100% |  | 2007-02-05 | 2009-03-06 | 545d? |  | finish no earlier than 2009-03-06 | C1 | 4360h | 4360h | SAES | Nokia Siemens Networks | robert.zaus@nsn.com | Rel-8 | Frederic |  |  |
| 270 | 112.2.4 | Stage 3 SAE impact on existing capabilities | 480d? | 2007-02-05 A | 2008-12-05 A | 100% |  | 2007-02-05 | 2008-12-05 | 480d? |  | finish no earlier than 2008-12-12 | C3 | 3840h | 3840h | SAES | Huawei | Wei Weihua (weiwh@huawei.com) | Rel-8 | Gwiho |  |  |
| 271 | 112.2.5 | Stage 3 (CT4) of SAE impact on existing capabilities | 545d? | 2007-02-05 A | 2009-03-06 A | 100% |  | 2007-02-05 | 2009-03-06 | 545d? |  | finish no earlier than 2009-03-06 | C4 | 4360h | 4360h | SAES | Huawei | shahab.lavasani@huawei.com | Rel-8 | Kimmo |  |  |
| 272 | 112.2.6 | Stage 2/3 for Network selection procedures | 480d? | 2007-02-05 A | 2008-12-05 A | 100% |  | 2007-02-05 | 2008-12-05 | 480d? |  | finish no earlier than 2009-03-06 | C1 | 3840h | 3840h | SAES | Nokia Siemens Networks | robert.zaus@nsn.com | Rel-8 | Frederic |  |  |
| 273 | 112.2.7 | Stage 3 EPC interworking with external PDNs (SGi) | 605d? | 2007-02-05 A | 2009-05-29 A | 100% |  | 2007-02-05 | 2009-05-29 | 605d? |  | finish no earlier than 2009-05-29 | C3 | 4840h | 4840h | SAES-St3-intwk | Huawei | Wei Weihua (weiwh@huawei.com) | Rel-8 | Gwiho |  |  |
| 274 | 112.2.8 | Stage 3 PCC within SAE | 605d? | 2007-02-05 A | 2009-05-29 A | 100% |  | 2007-02-05 | 2009-05-29 | 605d? |  | finish no earlier than 2009-05-29 | C3 | 4840h | 4840h | SAES-St3-PCC | Ericsson | j.javier.pastor@ericsson.com | Rel-8 | Gwiho |  |  |
| 275 | 112.2.9 | Stage 3 for SAE / LTE identities | 545d? | 2007-02-05 A | 2009-03-06 A | 100% |  | 2007-02-05 | 2009-03-06 | 545d? |  | finish no earlier than 2009-03-06 | C4 | 4360h | 4360h | SAES | Huawei | shahab.lavasani@huawei.com | Rel-8 | Kimmo |  |  |
| 276 | 112.2.10 | Unified guidelines for Diameter usage within 3GPP | 316d? | 2007-09-21 A | 2008-12-05 A | 100% |  | 2007-09-21 | 2008-12-05 | 316d? |  | finish no earlier than 2008-12-05 | C3 | 2528h | 2528h | SAES-DIAM | Huawei | Javier Gonzalez Gallego | Rel-8 | Gwiho | CP-37 |  |
| 277 | 112.3 | **SAE for LTE access** | 569d? | 2007-01-02 A | 2009-03-06 A | 100% |  | 2007-01-02 | 2009-03-06 | 569d? |  |  | S2,C1,C3,C4 | 57824h | 57824h | SAES-LTE | Motorola | Irfan.Ali@motorola.com | Rel-8 | Maurice |  |  |
| 278 | 112.3.1 | CT4 Stage 3 for protocol between EPCs | 545d? | 2007-02-05 A | 2009-03-06 A | 100% |  | 2007-02-05 | 2009-03-06 | 545d? |  | finish no earlier than 2009-03-06 | C4 | 4360h | 4360h | SAES | Huawei | shahab.lavasani@huawei.com | Rel-8 | Kimmo |  |  |
| 279 | 7.2.2.1 | **SAES-SA-FP_LTE with GTP variant** | 569d? | 2007-01-02 A | 2009-03-06 A | 100% |  | 2007-01-02 | 2009-03-06 | 569d? |  |  | S2,C4 | 11896h | 11896h | SAES-SA-FP_LTE-GTP | Nokia Siemens Networks | balazs.bertenyi@nsn.com | Rel-8 | Maurice |  |  |
| 280 | 112.3.2.1 | Stage 2 for SAES-SA-FP_LTE with GTP variant | 373d? | 2007-01-02 A | 2008-06-05 A | 100% |  | 2007-01-02 | 2008-06-05 | 373d? |  | finish no earlier than 2008-06-02 | S2 | 2984h | 2984h | SAES-SA-FP_LTE-GTP-St2 | Nokia Siemens Networks | balazs.bertenyi@nsn.com | Rel-8 | Maurice |  |  |
| 281 | 112.3.2.2 | CT4 Stage 3 for GTP v2 protocol | 545d? | 2007-02-05 A | 2009-03-06 A | 100% |  | 2007-02-05 | 2009-03-06 | 545d? |  | finish no earlier than 2009-03-06 | C4 | 4360h | 4360h | SAES | Huawei | shahab.lavasani@huawei.com | Rel-8 | Kimmo |  |  |
| 282 | 7.2.2.2 | **SAES-SA-FP_LTE with PMIP variant** | 569d? | 2007-01-02 A | 2009-03-06 A | 100% |  | 2007-01-02 | 2009-03-06 | 569d? |  |  | S2,C4 | 15736h | 15736h | SAES-SA-FP_LTE-IETF | Nokia Siemens Networks | balazs.bertenyi@nsn.com | Rel-8 | Maurice |  |  |
| 283 | 112.3.3.1 | Stage 2 for SAES-SA-FP_LTE with PMIP variant | 373d? | 2007-01-02 A | 2008-06-05 A | 100% |  | 2007-01-02 | 2008-06-05 | 373d? |  | finish no earlier than 2008-06-02 | S2 | 2984h | 2984h | SAES-SA-FP_LTE-IETF-St2 | Nokia Siemens Networks | balazs.bertenyi@nsn.com | Rel-8 | Maurice |  |  |
| 284 | 112.3.3.2 | CT4 Stage 3 for PMIP protocol within EPC | 545d? | 2007-02-05 A | 2009-03-06 A | 100% |  | 2007-02-05 | 2009-03-06 | 545d? |  | finish no earlier than 2009-03-06 | C4 | 4360h | 4360h | SAES | Huawei | shahab.lavasani@huawei.com | Rel-8 | Kimmo | CP-37 |  |
| 285 | 112.3.3.3 | Mobile IPv4 (MIPv4) based Mobility protocols | 480d? | 2007-02-05 A | 2008-12-05 A | 100% |  | 2007-02-05 | 2008-12-05 | 480d? |  | finish no earlier than 2008-12-05 | C4 | 3840h | 3840h | SAES | Motorola | Lewis Milton | Rel-8 | Kimmo | CP-41 |  |
| 286 | 112.3.4 | Stage 3 for UE NAS mobility procedures in idle and active mode | 545d? | 2007-02-05 A | 2009-03-06 A | 100% |  | 2007-02-05 | 2009-03-06 | 545d? |  | finish no earlier than 2009-03-06 | C1 | 4360h | 4360h | SAES | Nokia Siemens Networks | robert.zaus@nsn.com | Rel-8 | Frederic |  |  |
| 287 | 112.3.5 | Stage 3 for Session management, bearer control and QoS aspects | 545d? | 2007-02-05 A | 2009-03-06 A | 100% |  | 2007-02-05 | 2009-03-06 | 545d? |  | finish no earlier than 2009-03-06 | C1 | 4360h | 4360h | SAES | Nokia Siemens Networks | robert.zaus@nsn.com | Rel-8 | Frederic |  |  |
| 288 | 112.3.6 | Stage 3 for security aspects of LTE Access | 545d? | 2007-02-05 A | 2009-03-06 A | 100% |  | 2007-02-05 | 2009-03-06 | 545d? |  | finish no earlier than 2009-03-06 | C1 | 4360h | 4360h | SAES | Nokia Siemens Networks | robert.zaus@nsn.com | Rel-8 | Frederic |  |  |
| 289 | 112.3.7 | Stage 3 for QoS mechanisms | 480d? | 2007-02-05 A | 2008-12-05 A | 100% |  | 2007-02-05 | 2008-12-05 | 480d? |  | finish no earlier than 2008-12-12 | C3 | 3840h | 3840h | SAES | Ericsson | j.javier.pastor@ericsson.com | Rel-8 | Gwiho |  |  |
| 290 | 112.3.8 | Stage 3 for EPC - HSS interface | 545d? | 2007-02-05 A | 2009-03-06 A | 100% |  | 2007-02-05 | 2009-03-06 | 545d? |  | finish no earlier than 2009-03-06 | C4 | 4360h | 4360h | SAES | Huawei | shahab.lavasani@huawei.com | Rel-8 | Kimmo |  |  |

Notes:
- 264: SA#39 WID updated SP-070933=>SP-080132
- 265: SA#38 completed / Text3: 22.278, 22.011, 22.246
- 266: CT#43 exception 03/09=>05/09 (no exception sheet needed). SA#39 WID updated SP-070933=>SP-080132
- 267: SA#40 completed / Text3: 23.402
- 268: SA#42 completed. SA#39 WID updated SP-070933=>SP-080132 / Text3: 33.401, 33.210, 33.310
- 269: CT#43 completed. CT#42 Rel-8 exception to 03/09 / Text3: 24.229, 24.305, 27.007
- 270: CT#42 completed. WID updated CP-080056=>CP-080772 / Text3: 29.061
- 271: CT#43 completed. WID updated CP-080724=>CP-090247. CT#42 Rel-8 exception to 03/09. Network sharing, etc, MBMS removed / Text3: 29.274, 29.275
- 272: CT#42 completed. CT#41 WID updated CP-080075=>CP-080493. / Text3: 23.122, 24.302
- 273: CT#44 completed / Text3: 29.061
- 274: CT#44 completed / Text3: 29.212, 29.213, 29.214, 29.215
- 275: CT#43 completed. WID updated CP-080724=>CP-090247. CT#42 Rel-8 exception to 03/09 / Text3: 23.003
- 276: CT#42 completed / Text3: 29.909
- 277: CT#43 completed. SA#39 WID updated SP-070933=>SP-080132
- 278: CT#43 completed. WID updated CP-080724=>CP-090247. CT#42 Rel-8 exception to 03/09. PMIP and GTP based S8 interface (EPC-EPC). / Text3: 29.274, 29.275
- 279: CT#43 completed. SA#39 WID updated SP-070933=>SP-080132
- 280: SA#40 completed / Text3: 23.401, 23.060, 23.002, 23.246, 23.203, 23.107, 23.234, 23.271
- 281: CT#43 completed. WID updated CP-080724=>CP-090247. CT#42 Rel-8 exception to 03/09 / Text3: 29.274
- 282: CT#43 completed. SA#39 WID updated SP-070933=>SP-080132
- 283: SA#40 completed. Multiple PDN related alignments, 23.060-derived changes.
- 284: CT#43 completed. WID updated CP-080724=>CP-090247. CT#42 Rel-8 exception to 03/09. PMIP based S5 interface. / Text3: 29.275, 29.282
- 285: CT#42 completed. CT#43 WID updated CP-080724=>CP-090247 / Text3: 29.279
- 286: CT#43 completed. CT#42 Rel-8 exception to 03/09 / Text3: 24.007, 24.301
- 287: CT#43 completed. CT#42 Rel-8 exception to 03/09 / Text3: 24.007, 24.301
- 288: CT#43 completed. CT#42 Rel-8 exception to 03/09 / Text3: 24.008, 24.301
- 289: CT#42 completed. CT#41 updated WID CP-080057=>CP-080576. / Text3: 29.213
- 290: CT#43 completed. WID updated CP-080724=>CP-090247. CT#42 Rel-8 exception to 03/09. S6a, S6d, S13, S13' interface / Text3: 29.272

| ID | WBS | Task | Type | Duration | Start | Finish | Complete | Baseline start | Baseline finish | Baseline duration | Constraint | Resources | Work | Actual work | Text1 | Text4 | Text5 | Text6 | Text8 | Text3 | Text7 | Text2 | Text12 |
| --- | --- | --- | --- | --- | --- | --- | --- | --- | --- | --- | --- | --- | --- | --- | --- | --- | --- | --- | --- | --- | --- | --- | --- |
| 291 | 112.4 | **SAE for Interoperation between LTE and legacy cellular PS accesses** |  | 545d? | 2007-02-05 A | 2009-03-06 A | 100% | 2007-02-05 | 2009-03-06 | 545d? |  | S2,C1,C4 | 40152h | 40152h | SAES-SA-FP_3GPP | Motorola | Irfan.Ali@motorola.com | Rel-8 | Maurice |  |  |  |  |
| 292 | 112.4.1 | Stage 2 for Interoperation between LTE and 2G/3G |  | 424d? | 2007-02-05 A | 2008-09-18 A | 100% | 2007-02-05 | 2008-09-18 | 424d? | finish no earlier than 2008-09-11 | S2 | 3392h | 3392h | EPSto2_3G | Motorola | Irfan.Ali@motorola.com | Rel-8 | Maurice | 23.401, 23.402 | SP-37 |  |  |
| 293 | 112.4.2 | Stage 3 for Inter-system mobility between E-UTRAN and 2G/3G |  | 545d? | 2007-02-05 A | 2009-03-06 A | 100% | 2007-02-05 | 2009-03-06 | 545d? | finish no earlier than 2009-03-06 | C1 | 4360h | 4360h | SAES | Nokia Siemens Networks | robert.zaus@nsn.com | Rel-8 | Frederic | 24.008, 24.301 | CP-38 | PCG-21 |  |
| 294 | 112.4.3 | Stage 2 GPRS enhancements for LTE access |  | 272d? | 2007-09-04 A | 2008-09-18 A | 100% | 2007-09-04 | 2008-09-18 | 272d? | start no earlier than 2007-09-04 | S2 | 2176h | 2176h | SAES-GPRS_LTE | Vodafone | chris.pudney@vodafone.com | Rel-8 | Maurice | 23.401 |  |  |  |
| 295 | 112.4.4 | Stage 2 GPRS for EPC (23.060, etc.) |  | 179d? | 2008-01-14 A | 2008-09-18 A | 100% | 2008-01-14 | 2008-09-18 | 179d? | finish no earlier than 2008-09-18 | S2 | 1432h | 1432h | SAES | Nokia Siemens Networks | balazs.bertenyi@nsn.com | Rel-8 | Maurice | 23.060 | SP-39 | PCG-21 |  |
| 296 | 112.4.5 | Stage 3 for EPC - GPRS |  | 545d? | 2007-02-05 A | 2009-03-06 A | 100% | 2007-02-05 | 2009-03-06 | 545d? | finish no earlier than 2009-03-06 | C4 | 4360h | 4360h | SAES | Huawei | shahab.lavasani@huawei.com | Rel-8 | Kimmo | 29.274, 29.275, 29.281 |  |  |  |
| 297 | 112.4.6 | Stage 3 for EPC to UTRAN |  | 545d? | 2007-02-05 A | 2009-03-06 A | 100% | 2007-02-05 | 2009-03-06 | 545d? | finish no earlier than 2009-03-06 | C4 | 4360h | 4360h | SAES | Huawei | shahab.lavasani@huawei.com | Rel-8 | Kimmo | 29.274, 29.275, 29.281 | CP-38 | PCG-21 |  |
| 298 | 112.4.7 | Stage 3 for EPC to 3GPP2 |  | 545d? | 2007-02-05 A | 2009-03-06 A | 100% | 2007-02-05 | 2009-03-06 | 545d? | finish no earlier than 2009-03-06 | C4 | 4360h | 4360h | SAES | Huawei | shahab.lavasani@huawei.com | Rel-8 | Kimmo | 29.277, 29.276 | CP-38 | PCG-21 |  |
| 299 | 112.4.8 | Stage 2 for Interoperation between LTE and CDMA2000 |  | 329d? | 2007-06-18 A | 2008-09-18 A | 100% | 2007-06-18 | 2008-09-18 | 329d? | finish no earlier than 2008-04-25 | S2 | 2632h | 2632h | EPStoC2k | Motorola, Vodafone | Irfan.Ali@motorola.com, chris.pudney@vodafone.com | Rel-8 | Maurice | 23.401, 23.402 | CP-37 |  |  |
| 300 | 112.4.9 | Stage 3 for Inter-system mobility between E-UTRAN and CDMA2000 |  | 545d? | 2007-02-05 A | 2009-03-06 A | 100% | 2007-02-05 | 2009-03-06 | 545d? | finish no earlier than 2009-03-06 | C1 | 4360h | 4360h | SAES | Nokia Siemens Networks | robert.zaus@nsn.com | Rel-8 | Frederic | 24.301, 24.302 |  |  |  |
| 301 | 112.4.10 | Stage 3 for MME - SGSN "signalling free" protocol |  | 545d? | 2007-02-05 A | 2009-03-06 A | 100% | 2007-02-05 | 2009-03-06 | 545d? | finish no earlier than 2009-03-06 | C4 | 4360h | 4360h | SAES | Huawei | shahab.lavasani@huawei.com | Rel-8 | Kimmo | 29.272, 29.274 |  |  |  |
| 302 | 112.5 | **SAE for support for non-3GPP accesses** |  | 569d? | 2007-01-02 A | 2009-03-06 A | 100% | 2007-01-02 | 2009-03-06 | 569d? |  | S2,S3,C1,C4 | 53872h | 53872h | SAES-SA-FP_n3GPP | Motorola | Irfan.Ali@motorola.com | Rel-8 | Maurice |  |  |  |  |
| 303 | 7.2.4.1 | Stage 2 for Host-based Mobility aspects |  | 373d? | 2007-01-02 A | 2008-06-05 A | 100% | 2007-01-02 | 2008-06-05 | 373d? | finish no earlier than 2008-04-11 | S2 | 2984h | 2984h | SAES-SA-FP_n3GPP-HBMob | Motorola | Irfan.Ali@motorola.com | Rel-8 | Maurice | 23.402 |  |  |  |
| 304 | 7.2.4.2 | Stage 2 for Network-based Mobility aspects |  | 448d? | 2007-01-02 A | 2008-09-18 A | 100% | 2007-01-02 | 2008-09-18 | 448d? | finish no earlier than 2008-09-18 | S2 | 3584h | 3584h | SAES-SA-FP_n3GPP-NBMob | Motorola | Irfan.Ali@motorola.com | Rel-8 | Maurice | 23.402 |  |  |  |
| 305 | 112.5.3 | Stage 3 for Mobility management based on DSMIP v6 |  | 480d? | 2007-02-05 A | 2008-12-05 A | 100% | 2007-02-05 | 2008-12-05 | 480d? | finish no earlier than 2008-12-05 | C1 | 3840h | 3840h | SAES | Nokia Siemens Networks | robert.zaus@nsn.com | Rel-8 | Frederic | 24.303 |  |  |  |
| 306 | 112.5.4 | Stage 3 for Mobility management based on MIP v4 |  | 480d? | 2007-02-05 A | 2008-12-05 A | 100% | 2007-02-05 | 2008-12-05 | 480d? | start no earlier than 2007-02-05 | C1 | 3840h | 3840h | SAES | Nokia Siemens Networks | robert.zaus@nsn.com | Rel-8 | Frederic | 24.304 | CP-39 | PCG-21 |  |
| 307 | 112.5.5 | Stage 3 for Inter-system mobility between E-UTRAN and non 3GPP accesses |  | 545d? | 2007-02-05 A | 2009-03-06 A | 100% | 2007-02-05 | 2009-03-06 | 545d? | finish no earlier than 2009-03-06 | C1 | 4360h | 4360h | SAES | Nokia Siemens Networks | robert.zaus@nsn.com | Rel-8 | Frederic | 24.008, 24.301 | CP-38 | PCG-21 |  |
| 308 | 112.5.6 | Stage 2 for Optimized Dual-Radio Handover with WiMAX |  | 249d? | 2007-06-25 A | 2008-06-05 A | 100% | 2007-06-25 | 2008-06-05 | 249d? | finish no earlier than 2008-06-09 | S2 | 1992h | 1992h | SAES-SA-FP_n3GPP-OptWIMAX | Motorola | Irfan.Ali@motorola.com | Rel-8 | Maurice | 23.402 |  |  |  |
| 309 | 112.5.7 | Stage 2 Security aspects for non-3GPP Access |  | 197d? | 2008-03-12 A | 2008-12-11 A | 100% | 2008-03-12 | 2008-12-11 | 197d? | finish no earlier than 2008-12-11 | S3 | 1576h | 1576h | SAES | Nokia Siemens Networks | marc.blommaert.ext@nsn.com | Rel-8 | Dionisio | 33.402, 33.210, 33.310 | SP-39 | PCG-21 |  |
| 310 | 112.5.8 | Stage 3 security aspects for DSMIP v6 Access |  | 480d? | 2007-02-05 A | 2008-12-05 A | 100% | 2007-02-05 | 2008-12-05 | 480d? | finish no earlier than 2008-12-05 | C1 | 3840h | 3840h | SAES | Nokia Siemens Networks | robert.zaus@nsn.com | Rel-8 | Frederic | 24.303 | CP-37 |  |  |
| 311 | 112.5.9 | Stage 3 security aspects for MIPv4 Access |  | 480d? | 2007-02-05 A | 2008-12-05 A | 100% | 2007-02-05 | 2008-12-05 | 480d? | finish no earlier than 2008-12-05 | C1 | 3840h | 3840h | SAES | Nokia Siemens Networks | robert.zaus@nsn.com | Rel-8 | Frederic | 24.304 | CP-39 | PCG-21 |  |
| 312 | 112.5.10 | Stage 3 for Access to the EPC via non-3GPP access networks |  | 545d? | 2007-02-05 A | 2009-03-06 A | 100% | 2007-02-05 | 2009-03-06 | 545d? | finish no earlier than 2009-03-06 | C1 | 4360h | 4360h | SAES | Nokia Siemens Networks | robert.zaus@nsn.com | Rel-8 | Frederic | 24.302, 24.312 |  |  |  |
| 313 | 112.5.11 | Stage 3 for interfaces within EPC |  | 383d? | 2007-09-19 A | 2009-03-06 A | 100% | 2007-09-19 | 2009-03-06 | 383d? | finish no earlier than 2009-03-06 | C4 | 3064h | 3064h | SAES | Huawei | shahab.lavasani@huawei.com | Rel-8 | Kimmo | 29.274, 29.281 | CP-37 |  |  |
| 314 | 112.5.12 | Stage 3 for Interfaces EPC - non-3GPP IP access |  | 545d? | 2007-02-05 A | 2009-03-06 A | 100% | 2007-02-05 | 2009-03-06 | 545d? | finish no earlier than 2009-03-06 | C4 | 4360h | 4360h | SAES | Huawei | shahab.lavasani@huawei.com | Rel-8 | Kimmo | 29.273, 29.275 |  |  |  |
| 315 | 112.5.13 | Stage 3 for AAA/HSS related |  | 480d? | 2007-02-05 A | 2008-12-05 A | 100% | 2007-02-05 | 2008-12-05 | 480d? | finish no earlier than 2008-12-05 | C4 | 3840h | 3840h | SAES | Huawei | shahab.lavasani@huawei.com | Rel-8 | Kimmo | 29.273 |  |  |  |
| 316 | 112.5.14 | Stage 3 for EPC - AAA interface |  | 480d? | 2007-02-05 A | 2008-12-05 A | 100% | 2007-02-05 | 2008-12-05 | 480d? | finish no earlier than 2008-12-05 | C4 | 3840h | 3840h | SAES | Huawei | shahab.lavasani@huawei.com | Rel-8 | Kimmo | 29.273 |  |  |  |
| 317 | 112.5.15 | Deleted (already covered) SAES-SA-FP_n3GPP Optimized Handover with CDMA | milestone | 0d? | 2007-06-25 A | 2007-06-25 A | 100% | 2007-06-25 | 2007-06-25 | 0d? | finish no earlier than 2007-06-25 | S2 |  |  | SAES-SA-FP_n3GPP-OptCDMA | Nokia Siemens Networks |  | Rel-8 | Maurice |  |  |  | SP-37 |

Notes:
- 291: CT#43 completed. SA#39 WID updated SP-070933=>SP-080132
- 292: SA#41 completed. SA#40 exception to Sep 2008 (default bearer issue).
- 293: CT#43 completed. CT#42 Rel-8 exception to 03/09
- 294: SA#41 completed. 25/03/08 claimed as SA#34 stopped. Resurrected. WID updated SP-060926 => SP-080132
- 295: SA#41 completed. SA#40 exception to Sep 2008 (QoS mapping related changes, Interoperation between Gn/Gp and S4 SGSN).
- 296: CT#43 completed. WID updated CP-080724=>CP-090247. CT#42 Rel-8 exception to 03/09.S3, S4 Interface
- 297: CT#43 completed. WID updated CP-080724=>CP-090247. CT#42 Rel-8 exception to 03/09
- 298: CT#43 completed. WID updated CP-080724=>CP-090247. CT#42 Rel-8 exception to 03/09. S101, S103 Interface MME - HRPD access S102, Interface to CDMA2000 1x RTT
- 299: SA#40 exception to Sep 2008 (Handover of multiple PDNs, Handling of multiple BBERFs). SA#41 completed (except: Handover of multiple PDNs=>Rel-9)
- 300: CT#43 completed. CT#42 Rel-8 exception to 03/09
- 301: CT#43 completed. WID updated CP-080724=>CP-090247. CT#42 Rel-8 exception to 03/09
- 302: CT#43 completed. SA#39 retained in Rel-8 (in addition to the essential functionality defined in SP-070699). Replaces UID_340037
- 303: SA#40 completed
- 304: SA#40 exception to Sep 2008 (Multiple PDN connections to the same APN using PMIP). SA#41 completed
- 305: CT#41 WID updated CP-080075=>CP-080493. CT#42 completed
- 306: CT#41 WID updated CP-080075=>CP-080493. CT#42 completed
- 307: CT#43 completed. CT#42 Rel-8 exception to 03/09
- 308: SA#40 completed
- 309: SA#42 completed. SA#39 WID updated SP-070933=>SP-080132. WP record created. SA#41 exception granted to Stage 2 UE-ANDSF security (Access Network Discovery and Selection Function)
- 310: CT#42 completed. post-CT#39: split into DSMIP v6 and MIPv4 Access. CT#41 WID updated CP-080075=>CP-080493.
- 311: CT#42 completed. post-CT#39: split into DSMIP v6 and MIPv4 Access. UID_390072->390172. CT#41 WID updated CP-080075=>CP-080493.
- 312: CT#43 completed. CT#42 Rel-8 exception to 03/09
- 313: CT#43 completed. WID updated CP-080724=>CP-090247. CT#42 Rel-8 exception to 03/09. S10, S11. GTP based S5 Interface
- 314: CT#43 completed. WID updated CP-080724=>CP-090247. CT#42 Rel-8 exception to 03/09. S2a, S2b, SWa, STa, SWn (Untrusted IP access - ePDG) interface
- 315: CT#42 completd. CT#43 WID updated CP-080724=>CP-090247
- 316: CT#42 completd. CT#43 WID updated CP-080724=>CP-090247
- 317: SA#37 stopped

| ID | WBS | Task | Type | Duration | Start | Finish | Complete | Remaining | Baseline start | Baseline finish | Baseline duration | Total slack | Constraint | Resources | Work | Actual work | Text1 | Text4 | Text5 | Text6 | Text8 | Text2 | Text7 | Text9 | Text12 |
| --- | --- | --- | --- | --- | --- | --- | --- | --- | --- | --- | --- | --- | --- | --- | --- | --- | --- | --- | --- | --- | --- | --- | --- | --- | --- |
| 318 | 112.6 | **Single Radio Voice Call Continuity for 3GPP (SRVCC)** |  | 569d? | 2007-01-02 A | 2009-03-06 A | 100% |  | 2007-01-02 | 2009-03-06 | 569d? |  |  | S2,C1,C4 | 10752h | 10752h | SAES-SRVCC | Nokia Siemens Networks | curt.c.wong@nokia.com | Rel-8 | Maurice |  |  |  |  |
| 319 | 112.6.1 | Stage 2 for 2G/3G SRVCC |  | 448d? | 2007-01-02 A | 2008-09-18 A | 100% |  | 2007-01-02 | 2008-09-18 | 448d? |  | finish no earlier than 2008-09-15 | S2 | 3584h | 3584h | SAES-SRVCC | Nokia Siemens Networks | curt.c.wong@nokia.com | Rel-8 | Maurice |  |  |  |  |
| 320 | 112.6.2 | Stage 3 for SRVCC in EPS |  | 201d? | 2008-05-30 A | 2009-03-06 A | 100% |  | 2008-05-30 | 2009-03-06 | 201d? |  | finish no earlier than 2009-03-06 | C1 | 1608h | 1608h | SAES-SRVCC | Nokia Siemens Networks | robert.zaus@nsn.com | Rel-8 | Frederic | PCG-21 | CP-41 |  |  |
| 321 | 112.6.3 | MME to MSC interface for SRVCC |  | 126d? | 2008-09-12 A | 2009-03-06 A | 100% |  | 2008-09-12 | 2009-03-06 | 126d? |  | finish no earlier than 2009-03-06 | C4 | 1008h | 1008h | SAES-SRVCC | Nokia Siemens Networks | Giorgi Gulbani | Rel-8 | Kimmo | PCG-21 | CP-41 |  |  |
| 322 | 112.7 | Voice Call Continuity for CDMA2000 1X |  | 249d? | 2007-06-25 A | 2008-06-05 A | 100% |  | 2007-06-25 | 2008-06-05 | 249d? |  | finish no earlier than 2008-06-13 | S2 | 1992h | 1992h | SAES-VCC_1X | Nokia Siemens Networks | balazs.bertenyi@nsn.com | Rel-8 | Maurice |  |  |  |  |
| 323 | 112.8 | SAE impacts on IMS |  | 373d? | 2007-01-02 A | 2008-06-05 A | 100% |  | 2007-01-02 | 2008-06-05 | 373d? |  | finish no earlier than 2008-06-13 | S2 | 2984h | 2984h | SAES-SA_IMS | Nokia Siemens Networks | balazs.bertenyi@nsn.com | Rel-8 | Maurice |  |  |  |  |
| 324 | 112.9 | **CS Fallback in EPS** |  | 258d? | 2008-03-12 A | 2009-03-06 A | 100% |  | 2008-03-12 | 2009-03-06 | 258d? |  |  | S2,C1,C4 | 4800h | 4800h | SAES-CSFB | T-Mobile, Vodafone | sabine.demel@t-mobile.at, chris.pudney@vodafone.com | Rel-8 | Maurice | PCG-21 | SP-39 |  |  |
| 325 | 112.9.1 | Stage 2 for CS Fallback in EPS |  | 62d? | 2008-03-12 A | 2008-06-05 A | 100% |  | 2008-03-12 | 2008-06-05 | 62d? |  | finish no earlier than 2008-12-05 | S2 | 496h | 496h | SAES-CSFB | T-Mobile, Vodafone | sabine.demel@t-mobile.at, chris.pudney@vodafone.com | Rel-8 | Maurice | PCG-21 | SP-40 |  |  |
| 326 | 112.9.2 | Stage 3 for CS Fallback in EPS |  | 201d? | 2008-05-30 A | 2009-03-06 A | 100% |  | 2008-05-30 | 2009-03-06 | 201d? |  | finish no earlier than 2009-03-06 | C1 | 1608h | 1608h | SAES-CSFB | NEC | yannick.lair@nectech.fr | Rel-8 | Frederic | PCG-21 | CP-40 |  |  |
| 327 | 112.9.3 | Stage 3 for CS Fallback in EPS |  | 136d? | 2008-05-30 A | 2008-12-05 A | 100% |  | 2008-05-30 | 2008-12-05 | 136d? |  | finish no earlier than 2008-12-05 | C4 | 1088h | 1088h | SAES-CSFB | NEC | yannick.lair@nectech.fr | Rel-8 | Kimmo | PCG-21 | CP-40 |  |  |
| 328 | 112.10 | System enhancements for the use of IMS services in local breakout |  | 62d? | 2008-03-12 A | 2008-06-05 A | 100% |  | 2008-03-12 | 2008-06-05 | 62d? |  | finish no earlier than 2008-06-05 | S2 | 496h | 496h | SAES-IMS_LBO | Telecom Italia | mario.madella@telecomitalia.it | Rel-8 | Maurice | PCG-21 | SP-39 |  |  |
| 329 | 112.11 | **EPC Data Definitions** |  | 309d? | 2008-01-07 A | 2009-03-12 A | 100% |  | 2008-01-07 | 2009-03-12 | 309d? |  |  | S5 | 7144h | 7144h | EPC-OAM |  |  | Rel-8 | Dionisio | PCG-21 | SP-39 |  |  |
| 330 | 112.11.1 | EPC Network Resource Model (NRM) Integration Reference Point (IRP) |  | 309d? | 2008-01-07 A | 2009-03-12 A | 100% |  | 2008-01-07 | 2009-03-12 | 309d? |  | finish no earlier than 2009-03-12 | S5 | 2472h | 2472h | EPC-OAM | Huawei | WANG, Xuelong | Rel-8 | Dionisio | PCG-21 | SP-38 |  |  |
| 331 | 112.11.2 | Performance measurements for EPC |  | 275d? | 2008-02-22 A | 2009-03-12 A | 100% |  | 2008-02-22 | 2009-03-12 | 275d? |  | finish no earlier than 2009-03-12 | S5 | 2200h | 2200h | EPC-OAM | China Mobile | Li Jian, Liang Shuangchun | Rel-8 | Dionisio | PCG-21 | SP-39 |  |  |
| 332 | 112.12 | EPC Charging |  | 309d? | 2008-01-07 A | 2009-03-12 A | 100% |  | 2008-01-07 | 2009-03-12 | 309d? |  | finish no earlier than 2009-03-12 | S5 | 2472h | 2472h | EPC-CH | Nokia Siemens Networks | GÖRMER, Gerald | Rel-8 | Dionisio | PCG-21 | SP-38 |  |  |
| 333 | 112.13 | Issues for CT1 TR 24.801 |  | 420d? | 2007-01-04 A | 2008-12-05 A | 100% |  | 2007-01-04 | 2008-12-05 | 420d? |  | finish no earlier than 2008-12-05 | C1 | 3360h | 3360h | SAES | Nokia Siemens Networks | robert.zaus@nsn.com | Rel-8 | Frederic | PCG-21 | CP-39 |  |  |
| 334 | 112.14 | Issues for CT3 TR 29.804 |  | 420d? | 2007-02-05 A | 2008-09-12 A | 100% |  | 2007-02-05 | 2008-09-12 | 420d? |  | finish no earlier than 2008-12-12 | C3 | 3360h | 3360h | SAES | Ericsson | j.javier.pastor@ericsson.com | Rel-8 | Gwiho | PCG-21 | CP-39 |  |  |
| 335 | 112.15 | Deleted - Issues for CT4 TR 29.803 |  | 420d? | 2007-01-04 A | 2008-09-12 A | 100% |  | 2007-01-04 | 2008-09-12 | 420d? |  | finish no earlier than 2008-12-11 | C4 | 3360h | 3360h | SAES | Huawei |  | Rel-8 | Kimmo | PCG-21 | CP-39 | PCG-21 | CP-41 |
| 336 | 112.16 | Domain Name System Procedures for Evolved Packet System (DEPS) |  | 179.75d? | 2008-05-30 A | 2009-03-06 A | 100% |  | 2008-05-30 | 2009-03-06 | 179.75d? |  | finish no earlier than 2009-03-06 | C4 | 1438h | 1438h | SAES-DEPS | TeliaSonera | jouni.korhonen@teliasonera.com | Rel-8 | Kimmo | PCG-21 | CP-40 |  |  |
| 337 | 112.17 | InterWorking Function (IWF) between MAP based and Diameter based interfaces |  | 126d? | 2008-09-12 A | 2009-03-06 A | 100% |  | 2008-09-12 | 2009-03-06 | 126d? |  | finish no earlier than 2009-03-06 | C4 | 1008h | 1008h | SAES-MAP2Diam | Huawei | liming49985@huawei.com | Rel-8 | Kimmo | PCG-21 | CP-41 |  |  |
| 338 | 112.18 | **CT6 aspects of SAE** |  | 402d? | 2008-03-07 A | 2009-09-18 | 84% | 62.86d? | 2008-03-07 | 2009-09-18 | 402d? | 255d |  | C6 | 5872h | 5204.8h | SAES | Nokia | Rune Lindholm | Rel-8 | Xavier | PCG-21 | SP-39 |  |  |
| 339 | 112.18.1 | CT6 aspects of SAE |  | 321d? | 2008-03-07 A | 2009-05-29 A | 100% |  | 2008-03-07 | 2009-05-29 | 321d? |  | finish no earlier than 2009-05-29 | C6 | 2568h | 2568h | SAES | Nokia | Rune Lindholm | Rel-8 | Xavier | PCG-21 | CP-39 |  |  |
| 340 | 112.18.2 | Test interworking of LTE Terminals with the USIM |  | 206d? | 2008-12-05 A | 2009-09-18 | 60% | 82.4d? | 2008-12-05 | 2009-09-18 | 206d? | 255d | finish no earlier than 2009-09-18 | C6 | 1648h | 988.8h | SAES-USIM_LTE-Test | Comprion | Udo Willenbrink | Rel-8 | Xavier | PCG-22 | CP-42 |  |  |
| 341 | 112.19 | Deleted (covered by 380068): Functions and procedures for SAE to support LCS | milestone | 0d? | 2008-03-03 A | 2008-03-03 A | 100% |  | 2008-03-03 | 2008-03-03 | 0d? |  | finish no earlier than 2008-03-03 | S2 |  |  | SAES-SA-FP_LCS | Nokia Siemens Networks |  | Rel-8 | Maurice |  |  |  | SP-37 |
| 342 | 112.20 | Deleted (covered by 380064): SAE aspects of Emergency Calls | milestone | 0d? | 2008-03-03 A | 2008-03-03 A | 100% |  | 2008-03-03 | 2008-03-03 | 0d? |  | start no earlier than 2008-03-03 | S2 |  |  | SAES-SA-EmCall | Nokia Siemens Networks |  | Rel-8 | Maurice |  |  |  | SP-37 |
| 343 | 112.21 | Deleted - CT1 aspects of SAES |  | 16.7d? | 2007-09-04 A | 2007-09-27 A | 100% |  | 2007-09-04 | 2007-09-27 | 16.7d? |  | start no earlier than 2007-09-04 | CP,C1 | 133.62h | 133.62h | SAES-St3 |  |  | Rel-8 | Frederic |  |  |  | SP-37 |
| 344 | 112.22 | Deleted - CT1 aspects of SAES | milestone | 0d? | 2007-09-04 A | 2007-09-04 A | 100% |  | 2007-09-04 | 2007-09-04 | 0d? |  | start no earlier than 2007-09-04 | C1 |  |  | SAES-St3 |  |  | Rel-8 | Frederic |  |  |  | SP-37 |
| 345 | 112.23 | Deleted - Interoperability | milestone | 0d? | 2008-03-14 A | 2008-03-14 A | 100% |  | 2008-03-14 | 2008-03-14 | 0d? |  | start no earlier than 2008-03-14 | C1 |  |  | SAES-St3-interop |  |  | Rel-8 | Frederic |  |  |  | SP-37 |
| 346 | 112.24 | Deleted - CT3 aspects of SAES | milestone | 0d? | 2007-09-04 A | 2007-09-04 A | 100% |  | 2007-09-04 | 2007-09-04 | 0d? |  | start no earlier than 2007-09-04 | C3 |  |  | SAES-St3 |  |  | Rel-8 | Gwiho |  |  |  | SP-37 |
| 347 | 112.25 | Deleted - CT4 aspects of SAES | milestone | 0d? | 2007-09-04 A | 2007-09-04 A | 100% |  | 2007-09-04 | 2007-09-04 | 0d? |  | start no earlier than 2007-09-04 | C4 |  |  | SAES-St3 |  |  | Rel-8 | Kimmo |  |  |  | SP-37 |
| 348 | 112.26 | Deleted - UE to EPC NAS signalling (incl. MBMS and QoS aspects) | milestone | 0d? | 2008-03-14 A | 2008-03-14 A | 100% |  | 2008-03-14 | 2008-03-14 | 0d? |  | start no earlier than 2008-03-14 | C1 |  |  | SAES-St3-sig |  |  | Rel-8 | Frederic |  |  |  | SP-37 |
| 349 | 112.27 | Deleted -User and Control plane protocols | milestone | 0d? | 2007-09-21 A | 2007-09-21 A | 100% |  | 2007-09-21 | 2007-09-21 | 0d? |  | start no earlier than 2007-09-21 | C4 |  |  | SAES-St3-prot |  |  | Rel-8 | Kimmo |  |  |  | SP-37 |
| 350 | 112.28 | Deleted - Architecture enhancements for non-3GPP accesses | milestone | 0d? | 2007-09-04 A | 2007-09-04 A | 100% |  | 2007-09-04 | 2007-09-04 | 0d? |  | start no earlier than 2007-09-04 | S2 |  |  | SAES-non_3GPP | Motorola | Irfan.Ali@motorola.com | Rel-8 | Maurice |  |  |  | SP-34 |
| 351 | 112.29 | Deleted: Stage 2 of architecture for the 3GPP System Architecture Evolution | milestone | 0d? | 2007-10-02 A | 2007-10-02 A | 100% |  | 2007-10-02 | 2007-10-02 | 0d? |  | start no earlier than 2007-10-02 | S2 |  |  | SAES-St2 | Vodafone | chris.pudney@vodafone.com | Rel-8 | Maurice |  |  |  | SP-34 |
| 352 | 112.30 | Deleted - SA aspects of System Architecture Evolution |  | 384d? | 2006-04-12 A | 2007-10-01 A | 100% |  | 2006-04-12 | 2007-10-01 | 384d? |  | finish no earlier than 2007-10-02 | S2 | 3072h | 3072h | SAES-SA |  |  | Rel-8 | Maurice |  |  |  | SP-34 |

Notes:
- 318: CT#43 completed. CT#42 Rel-8 exception to 03/09. SA#41 Stage 2 completed. SA#38 WID approved (extract from SAE WID SP-070817).
- 319: SA#41 completed. SA#38 WID approved. SA#40 exception to Sep 2008 for Single Radio VCC: incorporating of results of the RAN HSPA VoIP to CS alignment work. / Text3: 23.216
- 320: CT#43 completed. CT#42 Rel-8 exception to 03/09 / Text3: 23.009, 24.008, 24.301
- 321: CT#43 completed. CT#42 Rel-8 exception to 03/09 / Text3: 29.274, 29.277, 23.003, 23.008, 29.280
- 322: SA#40 completed
- 323: SA#40 completed
- 324: CT#43 completed. CT#42 Rel-8 exception to 03/09. SA#40 Stage 2 completed.
- 325: SA#40 completed / Text3: 23.272, 23.401
- 326: CT#43 completed. CT#42 Rel-8 exception to 03/09 / Text3: 24.301, 24.801, 24.007, 24.008, 24.011, 29.018, 29.118 [Mobility Management Entity (MME) – Visitor Location Register (VLR) SGs interface specification]
- 327: CT#42 completed. WID updated CP-080321=>CP-080495=>CP-080791 / Text3: 23.007, 23.008, 29.274, 29.277
- 328: SA#40 completed / Text3: 23.228, 23.221, 23.203
- 329: SA#43 completed
- 330: SA#43 completed. SA#42 Rel-8 exception to 03/09 / Text3: 32.751, 32.752, 32.753, 32.755
- 331: SA#43 completed. SA#42 Rel-8 exception to 03/09 / Text3: 32.426
- 332: SA#43 completed. SA#42 Rel-8 exception to 03/09 / Text3: 32.240/296/251/252/298/299
- 333: CT#43 completed / Text3: 24.801
- 334: CT#41 completed / Text3: 29.804
- 335: CT#41 Work stopped and continued in Normative specifications / Text3: 29.803
- 336: CT#43 completed. CT#42 Rel-8 exception to 03/09 / Text3: 23.003, 29.303
- 337: CT#43 completed. CT#42 Rel-8 exception to 03/09. Triggered by UID_380023 (FS_MAP2Diam) / Text3: 29.305
- 338: CT#44 completed core specification. Testing ongoing
- 339: CT#44 completed (Network Measurement Results collection via USAT are now specified) / Text3: 31.102, 31.111
- 340: CT#44: CRs agreed. Testing for UID_390021 (BB: Rel-8 CT6 aspects of SAE) / Text3: 31.121, 31.xyz (USIM application interworking with E-UTRA/EPC test specification)
- 341: SA#37 stopped
- 342: SA#37 stopped
- 343: SA#37 stopped
- 344: SA#37 stopped
- 345: SA#37 stopped
- 346: SA#37 stopped
- 347: SA#37 stopped / Text3: 29.803
- 348: SA#37 stopped
- 349: SA#37 stopped
- 350: SA#34 stopped. Replaced by UID_350027 and its children / Text3: 23.402
- 351: SA#34 stopped. Replaced by UIDs 340018 and 340037. (SA#34 report discussion of SP-060917.) / Text3: 23.002, 23.060, 23.107, 23.203, 23.228, 23.234, 23.246, 23.271, 23.279
- 352: SA#34 stopped

| ID | WBS | Task | Duration | Start | Finish | Complete | Baseline start | Baseline finish | Baseline duration | Constraint | Resources | Work | Actual work | Text1 | Text4 | Text5 | Text6 | Text7 | Text8 | Text2 | Text9 | Text12 |
| --- | --- | --- | --- | --- | --- | --- | --- | --- | --- | --- | --- | --- | --- | --- | --- | --- | --- | --- | --- | --- | --- | --- |
| 353 | 113 | **IMS Centralized Service Control (ICSRA)** | 395d? | 2007-09-03 A | 2009-03-06 A | 100% | 2007-09-03 | 2009-03-06 | 395d? |  | S1,S2,C1,C3,C4 | 9072h | 9072h | ICSRA | AT&T | Randolph Wohlert (rwohlert@tri.sbc.com) | Rel-8 | SP-37 | Alain |  |  |  |
| 354 | 113.1 | Stage 1 for ICSRA | 138d? | 2007-09-03 A | 2008-03-12 A | 100% | 2007-09-03 | 2008-03-12 | 138d? | finish no earlier than 2007-12-14 | S1 | 1104h | 1104h | ICSRA | AT&T | Randolph Wohlert (rwohlert@tri.sbc.com) | Rel-8 | SP-38 | Alain | PCG-21 |  |  |
| 355 | 113.2 | Stage 2 for ICSRA | 125d? | 2007-12-14 A | 2008-06-05 A | 100% | 2007-12-14 | 2008-06-05 | 125d? | start no earlier than 2007-12-14 | S2 | 1000h | 1000h | ICSRA-St2 | Alcatel-Lucent |  | Rel-8 | SP-38 | Maurice | PCG-21 |  |  |
| 356 | 113.3 | Stage 3 for ICSRA – Protocol, Addressing, Subscriber Data | 201d? | 2008-05-30 A | 2009-03-06 A | 100% | 2008-05-30 | 2009-03-06 | 201d? | finish no earlier than 2009-03-06 | C1 | 1608h | 1608h | ICSRA | Ericsson | Sean Schneyer | Rel-8 | CP-40 | Frederic | PCG-21 |  |  |
| 357 | 113.4 | Deleted - Stage 3 for ICSRA – I1 interface | 76d? | 2008-05-30 A | 2008-09-12 A | 100% | 2008-05-30 | 2008-09-12 | 76d? | finish no earlier than 2008-09-12 | C1 | 608h | 608h | ICSRA | Huawei | xupeili@huawei.com | Rel-8 | CP-40 | Frederic | PCG-21 | PCG-21 | CP-41 |
| 358 | 113.5 | Stage 3 for ICSRA – Protocol, Addressing, Subscriber Data | 201d? | 2008-05-30 A | 2009-03-06 A | 100% | 2008-05-30 | 2009-03-06 | 201d? | finish no earlier than 2009-03-06 | C3 | 1608h | 1608h | ICSRA | Mavenir | Brett Wallis | Rel-8 | CP-40 | Gwiho | PCG-21 |  |  |
| 359 | 113.6 | Stage 3 for ICSRA – Protocol, Addressing, Subscriber Data | 136d? | 2008-05-30 A | 2008-12-05 A | 100% | 2008-05-30 | 2008-12-05 | 136d? | start no earlier than 2008-05-30 | C4 | 1088h | 1088h | ICSRA | Ericsson | Sean Schneyer | Rel-8 | CP-40 | Kimmo | PCG-21 |  |  |
| 360 | 114 | **IMS Multimedia Telephony and Supplementary Services** | 487d? | 2007-05-02 A | 2009-03-12 A | 100% | 2007-05-02 | 2009-03-12 | 487d? |  | S1,S5,C1,C3,C4 | 46006.4h | 46006.4h | IMSTSS |  |  | Rel-8 | SP-37 | Alain |  |  |  |
| 361 | 114.1 | **General aspects of IMS Sup Services** | 395d? | 2007-09-03 A | 2009-03-06 A | 100% | 2007-09-03 | 2009-03-06 | 395d? |  | S1,C1,C3,C4 | 9752h | 9752h | IMSSS-Gal | Ericsson | Susana Sabater | Rel-8 | SP-37 | Alain |  |  |  |
| 362 | 114.1.1 | Service and Capability for Core IMS - inclusion of TISPAN requirements | 75d? | 2007-09-03 A | 2007-12-14 A | 100% | 2007-09-03 | 2007-12-14 | 75d? | finish no earlier than 2007-12-14 | S1 | 600h | 600h | TISCAPR8 | Ericsson | Susana Sabater | Rel-8 | SP-37 | Alain |  |  |  |
| 363 | 114.1.2 | Documentation of TISPAN R1 and R2 in CT1 | 208d? | 2007-11-28 A | 2008-09-12 A | 100% | 2007-11-28 | 2008-09-12 | 208d? | finish no earlier than 2008-09-12 | C1 | 1664h | 1664h | REDOC_TIS-C1 | Nokia Siemens Networks | peter.leis@nsn.com | Rel-8 | CP-38 | Frederic | PCG-21 |  |  |
| 364 | 114.1.3 | Documentation of TISPAN R1 and R2 in CT3 | 333d? | 2007-11-28 A | 2009-03-06 A | 100% | 2007-11-28 | 2009-03-06 | 333d? | finish no earlier than 2009-03-06 | C3 | 2664h | 2664h | REDOC_TIS-C3 | Nokia Siemens Networks | peter.leis@nsn.com | Rel-8 | CP-38 | Gwiho | PCG-21 |  |  |
| 365 | 114.1.4 | Documentation of TISPAN R1 and R2 in CT4 | 208d? | 2007-11-28 A | 2008-09-12 A | 100% | 2007-11-28 | 2008-09-12 | 208d? | finish no earlier than 2008-09-12 | C4 | 1664h | 1664h | REDOC_TIS-C4 | Nokia Siemens Networks | peter.leis@nsn.com | Rel-8 | CP-38 | Kimmo | PCG-21 |  |  |
| 366 | 114.2 | **IMS Multimedia Telephony Service** | 394d? | 2007-09-10 A | 2009-03-12 A | 100% | 2007-09-10 | 2009-03-12 | 394d? |  | S1,S5 | 5096h | 5096h | IMS-MMTel |  |  | Rel-8 | SP-37 | Alain |  |  |  |
| 367 | 114.2.1 | Merging TISPAN MMTel [requirements] for Common IMS | 65d? | 2007-09-10 A | 2007-12-07 A | 100% | 2007-09-10 | 2007-12-07 | 65d? | finish no earlier than 2007-12-07 | S1 | 520h | 520h | TMMTEL | Nokia Siemens Networks |  | Rel-8 | SP-37 | Alain |  |  |  |
| 368 | 114.2.2 | Multimedia Telephony Service and Supplementary Services (MMTel) offline Charging | 309d? | 2008-01-07 A | 2009-03-12 A | 100% | 2008-01-07 | 2009-03-12 | 309d? | finish no earlier than 2009-03-12 | S5 | 2472h | 2472h | MMTel-CH | Alcatel-Lucent | GARDELLA, Maryse | Rel-8 | SP-38 | Dionisio | PCG-21 |  |  |
| 369 | 114.3 | **Call Completion on Busy Subscriber (CCBS)/Call Completion on Non-Reachable (CCNR) on IMS** | 483d? | 2007-05-02 A | 2009-03-06 A | 100% | 2007-05-02 | 2009-03-06 | 483d? |  | C1,C3 | 11072h | 11072h | CCBS_CCNR | Deutsche Telekom | martin.huelsemann@telekom.de | Rel-8 | SP-38 | Frederic | PCG-21 |  |  |
| 370 | 114.3.1 | Stage 3 CCBS_CCNR | 483d? | 2007-05-02 A | 2009-03-06 A | 100% | 2007-05-02 | 2009-03-06 | 483d? | finish no earlier than 2009-03-06 | C1 | 3864h | 3864h | CCBS_CCNR | Deutsche Telekom | martin.huelsemann@telekom.de | Rel-8 | CP-38 | Frederic | PCG-21 |  |  |
| 371 | 114.3.2 | Stage 3 CCBS_CCNR | 418d? | 2007-05-02 A | 2008-12-05 A | 100% | 2007-05-02 | 2008-12-05 | 418d? | finish no earlier than 2008-12-05 | C3 | 3344h | 3344h | CCBS_CCNR | Deutsche Telekom | martin.huelsemann@telekom.de | Rel-8 | CP-38 | Gwiho | PCG-21 |  |  |
| 372 | 114.4 | **Flexible Alerting** | 288d? | 2008-01-30 A | 2009-03-06 A | 100% | 2008-01-30 | 2009-03-06 | 288d? |  | S1,C1 | 5278.4h | 5278.4h | FA | Nortel | milanpa@nortel.com | Rel-8 | SP-39 | Alain | PCG-21 |  |  |
| 373 | 114.4.1 | Stage 1 FA | 92d? | 2008-01-30 A | 2008-06-05 A | 100% | 2008-01-30 | 2008-06-05 | 92d? |  | S1 | 670.4h | 670.4h | FA | Telecom Italia |  | Rel-8 | SP-39 | Alain | PCG-21 |  |  |
| 374 | 114.4.2 | Stage 3 FA | 288d? | 2008-01-30 A | 2009-03-06 A | 100% | 2008-01-30 | 2009-03-06 | 288d? | finish no earlier than 2009-03-06 | C1 | 2304h | 2304h | FA | Nortel | milanpa@nortel.com | Rel-8 | CP-39 | Frederic | PCG-21 |  |  |
| 375 | 114.5 | **Communication Wait on IMS** | 331d? | 2007-11-30 A | 2009-03-06 A | 100% | 2007-11-30 | 2009-03-06 | 331d? |  | C1,C3 | 7416h | 7416h | CW_IMS | Deutsche Telekom | martin.huelsemann@telekom.de | Rel-8 | SP-38 | Frederic | PCG-21 |  |  |
| 376 | 114.5.1 | Stage 3 CW-IMS | 331d? | 2007-11-30 A | 2009-03-06 A | 100% | 2007-11-30 | 2009-03-06 | 331d? | finish no earlier than 2009-03-06 | C1 | 2648h | 2648h | CW_IMS | Deutsche Telekom | martin.huelsemann@telekom.de | Rel-8 | CP-38 | Frederic | PCG-21 |  |  |
| 377 | 114.5.2 | Stage 3 CW-IMS | 265d? | 2007-11-30 A | 2008-12-04 A | 100% | 2007-11-30 | 2008-12-04 | 265d? | finish no earlier than 2008-12-05 | C3 | 2120h | 2120h | CW_IMS | Deutsche Telekom | martin.huelsemann@telekom.de | Rel-8 | CP-38 | Gwiho | PCG-21 |  |  |
| 378 | 114.6 | Advice of Charge (AoC) support in IMS Charging | 309d? | 2008-01-07 A | 2009-03-12 A | 100% | 2008-01-07 | 2009-03-12 | 309d? | finish no earlier than 2009-03-12 | S5 | 2472h | 2472h | IMSTSS | Nokia Siemens Networks | GÖRMER, Gerald | Rel-8 | SP-38 | Dionisio | PCG-21 |  |  |
| 379 | 114.7 | Add Interconnection Border Control Function (IBCF) to IMS Charging | 128d? | 2007-09-17 A | 2008-03-12 A | 100% | 2007-09-17 | 2008-03-12 | 128d? | finish no earlier than 2008-03-12 | S5 | 1024h | 1024h | IMSTSS | Alcatel-Lucent | GARDELLA, Maryse | Rel-8 | SP-37 | Dionisio |  |  |  |

Notes:
- 353: CT#43 completed. SA#40 SA1/2 completed. CT#40 WID approved.
- 354: SA#38 WID approved. SA#39 completed / Text3: 22.101
- 355: SA#38 WID approved. SA#40 completed / Text3: 23.292, 23.206
- 356: CT#43 completed. CT#42 Rel-8 exception to 03/09 / Text3: 24.292, 24.229
- 357: 23/07/08 Line created at CT1 Zagreb request. CT#41 WID updated CP-080319=>CP-080492. CT#41 work stopped / Text3: 24.293
- 358: CT#43 completed. CT#42 Rel-8 exception to 03/09 / Text3: 29.292
- 359: CT#42 completed. CT#41 WID updated CP-080319=>CP-080492. / Text3: 23.003, 29.232, 23.018, 29.002
- 360: SA#43 completed
- 361: CT#43 completed
- 362: SA#39 completed / Text3: 22.228, 22.115, 22.101
- 363: CT#41 completed / Text3: 24.141, 24.147, 24.173, 24.229, 24.247, 24.341, 24.604, 24.605, 24.606, 24.607, 24.608, 24.610, 24.611, 24.616, 24.623, 24.628, 24.629, 24.647, 24.654
- 364: CT#43 completed. CT#42 Rel-8 exception to 03/09 / Text3: 29.162, 29.163, 29.658
- 365: CT#41 completed / Text3: 29.228, 29.229
- 366: SA#43 completed
- 367: SA#38 completed / Text3: 22.173
- 368: SA#43 completed. SA#42 Rel-8 exception to 03/09 / Text3: 32.275, 32.298/299
- 369: CT#43 completed
- 370: CT#43 completed. CT#42 Rel-8 exception to 03/09 / Text3: 24.642, 24.229, 24.173
- 371: CT#42 completed / Text3: 29.163
- 372: CT#43 completed
- 373: SA#40 completed / Text3: 22.173
- 374: CT#43 completed. CT#42 Rel-8 exception to 03/09 / Text3: 24.239, 24.173
- 375: CT#43 completed
- 376: CT#43 completed. CT#42 Rel-8 exception to 03/09 / Text3: 24.615, 24.229, 24.173
- 377: CT#42 completed / Text3: 29.163
- 378: SA#43 completed. SA#42 Rel-8 exception to 03/09 / Text3: 32.280, 32.240/260/296/298/299
- 379: SA#39 completed / Text3: 32.260, 32.298

| ID | WBS | Task | Duration | Start | Finish | Complete | Remaining | Baseline start | Baseline finish | Baseline duration | Total slack | Constraint | Resources | Work | Actual work | Text1 | Text2 | Text4 | Text5 | Text6 | Text7 | Text8 |
| --- | --- | --- | --- | --- | --- | --- | --- | --- | --- | --- | --- | --- | --- | --- | --- | --- | --- | --- | --- | --- | --- | --- |
| 380 | 115 | **3GPP2 Input to Common IMS** | 200d? | 2008-03-07 A | 2008-12-11 A | 100% |  | 2008-03-07 | 2008-12-11 | 200d? |  |  | S1,S2,S3,C1,C3,C4 | 8653.2h | 8653.2h | CIMS_3GPP2 | PCG-21 | Nortel | Amar Deol (deola@nortelnetworks.com) | Rel-8 | SP-39 | Alain |
| 381 | 115.1 | Stage 1 CIMS_3GPP2 (SA1) | 30.65d? | 2008-03-12 A | 2008-06-05 A | 100% |  | 2008-03-12 | 2008-06-05 | 30.65d? |  | finish no earlier than 2008-06-12 | S1 | 245.2h | 245.2h | CIMS_3GPP2 | PCG-21 | Nortel | Amar Deol (deola@nortelnetworks.com) | Rel-8 | SP-39 | Alain |
| 382 | 115.2 | Stage 2 CIMS_3GPP2 (SA2) | 62d? | 2008-03-12 A | 2008-06-05 A | 100% |  | 2008-03-12 | 2008-06-05 | 62d? |  | finish no earlier than 2008-09-11 | S2 | 496h | 496h | IMS_Common | PCG-21 | Nortel | Amar Deol (deola@nortelnetworks.com) | Rel-8 | SP-39 | Maurice |
| 383 | 115.3 | Security CIMS_3GPP2 (SA3) | 197d? | 2008-03-12 A | 2008-12-11 A | 100% |  | 2008-03-12 | 2008-12-11 | 197d? |  | finish no earlier than 2008-12-11 | S3 | 1576h | 1576h | IMS_Common | PCG-21 | Nortel | Amar Deol (deola@nortelnetworks.com) | Rel-8 | SP-39 | Dionisio |
| 384 | 115.4 | Stage 3 CIMS_3GPP2 (CT1) | 196d? | 2008-03-07 A | 2008-12-05 A | 100% |  | 2008-03-07 | 2008-12-05 | 196d? |  | finish no earlier than 2008-12-11 | C1 | 1568h | 1568h | REDOC_3GPP2 | PCG-21 | Alcatel-Lucent | orsic@alcatel-lucent.com | Rel-8 | CP-39 | Frederic |
| 385 | 115.5 | Stage 3 CIMS_3GPP2 (CT3) | 196d? | 2008-03-07 A | 2008-12-05 A | 100% |  | 2008-03-07 | 2008-12-05 | 196d? |  | finish no earlier than 2008-12-05 | C3 | 1568h | 1568h | REDOC_3GPP2 | PCG-21 | Alcatel-Lucent | orsic@alcatel-lucent.com | Rel-8 | CP-39 | Gwiho |
| 386 | 115.6 | Stage 3 CIMS_3GPP2 (CT4) | 200d? | 2008-03-07 A | 2008-12-11 A | 100% |  | 2008-03-07 | 2008-12-11 | 200d? |  | finish no earlier than 2008-12-11 | C4 | 1600h | 1600h | REDOC_3GPP2 | PCG-21 | Alcatel-Lucent | orsic@alcatel-lucent.com | Rel-8 | CP-39 | Kimmo |
| 387 | 116 | **IMS Enhancements for support of Packet Cable access** | 388d? | 2006-12-06 A | 2008-05-30 A | 100% |  | 2006-12-06 | 2008-05-30 | 388d? |  |  | S2,S3,C1,C3,C4 | 27448h | 27448h | PktCbl |  | Cablelabs | Bernie McKibben | Rel-8 |  | Maurice |
| 388 | 116.1 | **IMS Enhancements for Cable Client Types and Deployment Models** | 345d? | 2007-02-05 A | 2008-05-30 A | 100% |  | 2007-02-05 | 2008-05-30 | 345d? |  |  | S2,C1 | 6992h | 6992h | PktCbl-Deploy |  | Cablelabs | Bernie McKibben | Rel-8 |  | Maurice |
| 389 | 116.1.1 | Architecture aspects of PktCbl-Deploy | 219d? | 2007-02-05 A | 2007-12-06 A | 100% |  | 2007-02-05 | 2007-12-06 | 219d? |  | finish no earlier than 2007-12-03 | S2 | 1752h | 1752h | PktCbl-Deploy |  | Cablelabs | Bernie McKibben | Rel-8 |  | Maurice |
| 390 | 116.1.2 | CT1 aspects of PktCbl-Deploy | 310d? | 2007-03-26 A | 2008-05-30 A | 100% |  | 2007-03-26 | 2008-05-30 | 310d? |  | finish no earlier than 2008-06-15 | C1 | 2480h | 2480h | PktCbl-Deploy |  | Cablelabs | D.Hancock@ CableLabs.com | Rel-8 |  | Frederic |
| 391 | 116.2 | **IMS Inter-working aspects in Support of Cable Regulatory requirements** | 290d? | 2007-02-05 A | 2008-03-14 A | 100% |  | 2007-02-05 | 2008-03-14 | 290d? |  |  | S2,C1,C3 | 5640h | 5640h | PktCbl-Intw |  | Cablelabs | B.McKibben@CableLabs.com | Rel-8 |  | Maurice |
| 392 | 116.2.1 | Architecture PktCbl-Interwork | 160d? | 2007-02-05 A | 2007-09-14 A | 100% |  | 2007-02-05 | 2007-09-14 | 160d? |  | start no earlier than 2007-02-05 | S2 | 1280h | 1280h | PktCbl-Intw |  | Cablelabs | B.McKibben@CableLabs.com | Rel-8 |  | Maurice |
| 393 | 116.2.2 | CT1,CT3 PktCbl-Interwork | 255d? | 2007-03-26 A | 2008-03-14 A | 100% |  | 2007-03-26 | 2008-03-14 | 255d? |  | finish no earlier than 2008-03-15 | C1,C3 | 2040h | 2040h | PktCbl-Intw |  | Cablelabs | D.Hancock@ CableLabs.com | Rel-8 |  | Frederic |
| 394 | 116.3 | **IMS Enhancements for Security Requirements in Support of Cable Deployments** | 388d? | 2006-12-06 A | 2008-05-30 A | 100% |  | 2006-12-06 | 2008-05-30 | 388d? |  |  | S3,C1,C3,C4 | 11712h | 11712h | PktCbl-Sec |  | Cablelabs | s.dotson@cablelabs.com | Rel-8 |  | Dionisio |
| 395 | 116.3.1 | SA3 Aspects of PktCbl-Sec | 331d? | 2006-12-06 A | 2008-03-12 A | 100% |  | 2006-12-06 | 2008-03-12 | 331d? |  | finish no earlier than 2007-12-20 | S3 | 2648h | 2648h | PktCbl-Sec |  | Cablelabs | s.dotson@cablelabs.com | Rel-8 |  | Dionisio |
| 396 | 116.3.2 | CT1 Aspects of PktCbl-Sec | 310d? | 2007-03-26 A | 2008-05-30 A | 100% |  | 2007-03-26 | 2008-05-30 | 310d? |  | finish no earlier than 2008-06-06 | C1 | 2480h | 2480h | PktCbl-Sec |  | Cablelabs | D.Hancock@ CableLabs.com | Rel-8 |  | Frederic |
| 397 | 116.3.3 | CT3 Aspects of PktCbl-Sec | 180d? | 2007-03-26 A | 2007-11-30 A | 100% |  | 2007-03-26 | 2007-11-30 | 180d? |  | finish no earlier than 2008-03-15 | C3 | 1440h | 1440h | PktCbl-Intw | PCG-21 | Cablelabs | D.Hancock@ CableLabs.com | Rel-8 | CP-38 | Gwiho |
| 398 | 116.3.4 | CT4 Aspects of PktCbl-Sec | 255d? | 2007-03-26 A | 2008-03-14 A | 100% |  | 2007-03-26 | 2008-03-14 | 255d? |  | finish no earlier than 2008-03-14 | C4 | 2040h | 2040h | PktCbl-Sec |  | Cablelabs | D.Hancock@ CableLabs.com | Rel-8 |  | Kimmo |
| 399 | 117 | **IMS System enhancements for corporate network access** | 582d? | 2007-06-22 A | 2009-09-11 | 96% | 24.54d? | 2007-06-22 | 2009-09-11 | 582d? | 260d |  | S2,S1,C1,C4 | 12179.9h | 11666.9h | IMS_Corp |  | Orange | Delphin Barankanira | Rel-8 |  | Maurice |
| 400 | 117.1 | SA1 aspects of IMS_Corp | 23.6d? | 2008-03-12 A | 2008-06-05 A | 100% |  | 2008-03-12 | 2008-06-05 | 23.6d? |  | finish no earlier than 2008-06-05 | S1 | 188.8h | 188.8h | IMS_Corp | PCG-21 | Telecom Italia |  | Rel-8 | SP-39 | Alain |
| 401 | 117.2 | SA2 aspects of IMS_Corp | 325d? | 2007-06-22 A | 2008-09-18 A | 100% |  | 2007-06-22 | 2008-09-18 | 325d? |  | finish no earlier than 2008-12-25 | S2 | 2600h | 2600h | IMS_Corp |  | Orange | Delphin Barankanira | Rel-8 |  | Maurice |
| 402 | 117.3 | CT1 aspects of IMS_Corp | 397d? | 2008-03-07 A | 2009-09-11 | 90% | 39.7d? | 2008-03-07 | 2009-09-11 | 397d? | 260d | finish no earlier than 2009-06-01 | C1 | 3167.11h | 2850.4h | IMS_Corp | PCG-21 | Alcatel-Lucent | Keith Drage (drage@alcatel-lucent.com) | Rel-8 | CP-39 | Frederic |
| 403 | 117.4 | CT4 aspects of IMS_Corp | 196d? | 2008-02-26 A | 2008-12-05 A | 100% |  | 2008-02-26 | 2008-12-05 | 196d? |  | finish no earlier than 2008-12-11 | C4 | 1568h | 1568h | IMS_Corp | PCG-21 | Alcatel-Lucent | Keith Drage (drage@alcatel-lucent.com) | Rel-8 | CP-39 | Kimmo |

Notes:
- 380: TSG#42 completed
- 381: SA#40 completed / Text3: 22.228, 22.173, 22.101, 22.153
- 382: SA#40 completed / Text3: 23.002, 23.141, 23.203, 23.167, 23.228
- 383: SA#42 completed [issues addressed under UID_370078 (IMS-Sec)] / Text3: 33.141, 33.203, 33.210
- 384: CT#42 completed. WID updated CP-080218=>CP-080494=>CP-080795 / Text3: 23.218, 24.141, 24.147, 24.173, 24.229, 24.238, 24.247, 24.604, 24.605, 24.606, 24.607, 24.608, 24.610, 24.611, 24.629, 24.930
- 385: CT#42 completed. WID updated CP-080218=>CP-080494=>CP-080795 / Text3: 29.163, 29.212, 29.213, 29.214
- 386: CT#42 completed. WID updated CP-080218=>CP-080494=>CP-080795 / Text3: 29.228, 29.229, 29.328, 29.329
- 387: CT#40 completed
- 388: CT#40 completed
- 389: SA#38 completed / Text3: 23.228
- 390: CT#40 completed
- 391: CT#39 completed
- 392: SA#37 completed / Text3: 23.228
- 393: CT#39 completed / Text3: 24.229
- 394: CT#40 completed
- 395: SA#39 completed / Text3: 33.203, 33.210, 33.220
- 396: CT#40 completed / Text3: 24.229
- 397: CT#38 completed / Text3: 29.163
- 398: CT#39 completed / Text3: 29.228, 29.229, 23.008
- 399: CT#43 Rel-8 further exception 03/09=>05/09 (no exception sheet needed). SA#41 work completed (No Stage 2 impacts identified by Joint Workshop)
- 400: SA#40 completed
- 401: SA#41 completed / Text3: 23.228
- 402: CT#44 exception 05/09=>09/09 (CT1 to solve open issues; if not possible=> remove incomplete tasks from Rel-8) / Text3: 24.229, 24.503
- 403: CT#42 completed / Text3: 29.228, 29.229, 23.003, 23.008, 29.433

| ID | WBS | Task | Duration | Start | Finish | Complete | Baseline start | Baseline finish | Baseline duration | Constraint | Resources | Work | Actual work | Text1 | Text2 | Text7 | Text8 | Text4 | Text5 | Text6 |
| --- | --- | --- | --- | --- | --- | --- | --- | --- | --- | --- | --- | --- | --- | --- | --- | --- | --- | --- | --- | --- |
| 404 | 118 | **Maintenance of TISPAN documentation** | 244d? | 2007-07-02 A | 2008-06-05 A | 100% | 2007-07-02 | 2008-06-05 | 244d? |  | S2,C1,C3,C4 | 5984h | 5984h | MAINTISP | PCG-21 | SP-38 | Maurice |  |  |  |
| 405 | 118.1 | Maintenance of TISPAN R1 | 86d? | 2007-11-09 A | 2008-03-07 A | 100% | 2007-11-09 | 2008-03-07 | 86d? | start no earlier than 2007-11-09 | C1,C3,C4 | 688h | 688h | MAINT_R1 | PCG-21 | CP-38 | Frederic | Alcatel-Lucent | Keith Drage (drage@alcatel-lucent.com) | Rel-7 |
| 406 | 118.2 | Maintenance of TISPAN R2 | 86d? | 2007-11-09 A | 2008-03-07 A | 100% | 2007-11-09 | 2008-03-07 | 86d? | start no earlier than 2007-11-09 | C1,C3,C4 | 688h | 688h | MAINT_R2 | PCG-21 | CP-38 | Frederic | Alcatel-Lucent | Keith Drage (drage@alcatel-lucent.com) | Rel-8 |
| 407 | 118.3 | Documentation of TISPAN NGN R1 and R2 in 3GPP SA2 | 104d? | 2008-01-14 A | 2008-06-05 A | 100% | 2008-01-14 | 2008-06-05 | 104d? | finish no earlier than 2008-06-20 | S2 | 832h | 832h | IMS_Comm_Doc | PCG-21 | SP-38 | Maurice | Nokia Siemens Networks | jozsef.varga@nsn.com | Rel-8 |
| 408 | 118.4 | Maintenance of TISPAN release 1 common IMS | 114d? | 2007-07-02 A | 2007-12-06 A | 100% | 2007-07-02 | 2007-12-06 | 114d? | finish no earlier than 2007-12-06 | S2,S1 | 912h | 912h | IMS_Comm_Mtce7 | PCG-21 | SP-38 | Maurice | BT, Ericsson | Dick Knight, Raymond Forbes | Rel-7 |
| 409 | 118.5 | Maintenance of TISPAN release 2 common IMS | 114d? | 2007-07-02 A | 2007-12-06 A | 100% | 2007-07-02 | 2007-12-06 | 114d? | finish no earlier than 2007-12-06 | S2 | 912h | 912h | IMS_Comm_Mtce8 | PCG-21 | SP-38 | Maurice | Telecom Italia | antonio.ascolese@telecomitalia.it | Rel-8 |
| 410 | 119 | **IMS Service Continuity** | 318d? | 2008-03-12 A | 2009-05-29 A | 100% | 2008-03-12 | 2009-05-29 | 318d? |  | S2,S1,C1 | 5624h | 5624h | IMS-Cont | PCG-21 | SP-39 | Maurice | LG Electronics | JaeSeung SONG (anthonys@lge.com) | Rel-8 |
| 411 | 119.1 | Stage 1 IMS Service Continuity | 62d? | 2008-03-12 A | 2008-06-05 A | 100% | 2008-03-12 | 2008-06-05 | 62d? | start no earlier than 2008-03-12 | S1 | 496h | 496h | IMS-Cont | PCG-21 | SP-39 | Alain | LG Electronics | JaeSeung SONG (anthonys@lge.com) | Rel-8 |
| 412 | 119.2 | Stage 2 IMS Service Continuity | 62d? | 2008-03-12 A | 2008-06-05 A | 100% | 2008-03-12 | 2008-06-05 | 62d? | finish no earlier than 2008-06-05 | S2 | 496h | 496h | IMS-Cont | PCG-21 | SP-39 | Maurice | LG Electronics | JaeSeung SONG (anthonys@lge.com) | Rel-8 |
| 413 | 119.3 | Stage 3 IMS Service Continuity | 261d? | 2008-05-30 A | 2009-05-29 A | 100% | 2008-05-30 | 2009-05-29 | 261d? | finish no earlier than 2009-05-29 | C1 | 2088h | 2088h | IMS-Cont | PCG-21 | CP-40 | Frederic | Huawei | Lili Yang (kadyyang@huawei.com) | Rel-8 |
| 414 | 120 | **Security Enhancements for IMS** | 643.3d? | 2006-09-19 A | 2009-03-06 A | 100% | 2006-09-19 | 2009-03-06 | 643.3d? |  | S3,C1,C4 | 18624h | 18624h | IMS-Sec |  | SP-37 | Dionisio | Ericsson | Bengt.Sahlin@ericsson.com | Rel-8 |
| 415 | 120.1 | Stage 2 for IMS-Sec | 466d? | 2007-03-01 A | 2008-12-11 A | 100% | 2007-03-01 | 2008-12-11 | 466d? | finish no earlier than 2008-12-11 | S3 | 3728h | 3728h | IMS-Sec |  |  | Dionisio | Ericsson | Bengt.Sahlin@ericsson.com | Rel-8 |
| 416 | 120.2 | CT1 part of Stage 3 for IMS-Sec | 392d? | 2006-09-19 A | 2008-12-05 A | 100% | 2006-09-19 | 2008-12-05 | 392d? | finish no earlier than 2008-12-05 | C1 | 3136h | 3136h | IMS-Sec | PCG-21 | CP-39 | Frederic | Ericsson |  | Rel-8 |
| 417 | 120.3 | CT4 part of Stage 3 for IMS-Sec | 457d? | 2007-06-07 A | 2009-03-06 A | 100% | 2007-06-07 | 2009-03-06 | 457d? | finish no earlier than 2009-03-06 | C4 | 3656h | 3656h | IMS-Sec | PCG-21 | CP-39 | Kimmo | Ericsson |  | Rel-8 |
| 418 | 120.4 | CT1 part of NASS Bundled Authentication | 343d? | 2007-11-14 A | 2009-03-06 A | 100% | 2007-11-14 | 2009-03-06 | 343d? | finish no earlier than 2009-03-06 | C1 | 2744h | 2744h | NBA | PCG-21 | CP-39 | Frederic | Alcatel-Lucent | Keith Drage (drage@alcatel-lucent.com) | Rel-8 |
| 419 | 120.5 | CT4 part of NASS Bundled Authentication | 143d? | 2007-11-14 A | 2008-05-30 A | 100% | 2007-11-14 | 2008-05-30 | 143d? | start no earlier than 2007-11-14 | C4 | 1144h | 1144h | NBA-CT4 | PCG-21 | CP-39 | Kimmo | Alcatel-Lucent |  | Rel-8 |
| 420 | 121 | IMS initiated and controlled PSS and MBMS User Service | 262d? | 2008-03-12 A | 2009-03-12 A | 100% | 2008-03-12 | 2009-03-12 | 262d? | finish no earlier than 2009-03-12 | S4,S3 | 1003.2h | 1003.2h | IMS_PSS_MBMS_US |  |  | Paolo | FT, Ericsson | olle.franceschi@ericsson.com | Rel-8 |
| 421 | 122 | **Multimedia interworking between IMS and CS networks** | 836d? | 2005-09-23 A | 2008-12-05 A | 100% | 2005-09-23 | 2008-12-05 | 836d? |  | C3,C4 | 16112h | 16112h | MIW-IMS |  |  | Gwiho | Vodafone | nico.gabriele@vodafone.com | Rel-8 |
| 422 | 122.1 | Note: Stages 1 and 2 defined in earlier Release | 49d? | 2005-09-23 A | 2005-11-30 A | 100% | 2005-09-23 | 2005-11-30 | 49d? | start no earlier than 2005-09-23 | S2 | 392h | 392h | MIW-IMS |  |  | Maurice | Vodafone | nico.gabriele@vodafone.com | Rel-8 |
| 423 | 122.2 | Stage 3 of MW-IMS | 571d? | 2005-09-23 A | 2007-11-30 A | 100% | 2005-09-23 | 2007-11-30 | 571d? | finish no earlier than 2007-09-14 | C3 | 4568h | 4568h | MIW-IMS-St3 |  |  | Gwiho | Vodafone | nico.gabriele@vodafone.com | Rel-8 |
| 424 | 122.3 | Stage 3 for MW-IMS, MONA extension | 285d? | 2007-11-05 A | 2008-12-05 A | 100% | 2007-11-05 | 2008-12-05 | 285d? | finish no earlier than 2008-12-05 | C3 | 2280h | 2280h | MIW-IMS | PCG-21 | CP-38 | Gwiho | Vodafone | Christer.Holmberg@ericsson.com | Rel-8 |
| 425 | 122.4 | Mn interface (MGCF – IM MGW) | 273d? | 2007-11-21 A | 2008-12-05 A | 100% | 2007-11-21 | 2008-12-05 | 273d? | finish no earlier than 2008-12-19 | C4 | 2184h | 2184h | MIW-IMS | PCG-21 | CP-38 | Kimmo | Vodafone | Christer.Holmberg@ericsson.com | Rel-8 |
| 426 | 123 | IMS Stage 3 IETF Protocol Alignment | 446d? | 2007-06-22 A | 2009-03-06 A | 100% | 2007-06-22 | 2009-03-06 | 446d? | finish no earlier than 2009-03-06 | C1 | 3568h | 3568h | IMSProtoc2 |  |  | Frederic | Alcatel-Lucent | Keith Drage (drage@alcatel-lucent.com) | Rel-8 |
| 427 | 124 | **Interworking between User-to-User Signalling (UUS) and SIP** | 335d? | 2007-11-30 A | 2009-03-12 A | 100% | 2007-11-30 | 2009-03-12 | 335d? |  | C1,C3 | 7488h | 7488h | UUSIW | PCG-21 | CP-38 | Kimmo | Huawei | Lili Yang (kadyyang@huawei.com) | Rel-8 |
| 428 | 124.1 | Stage 3 MGCF UUSIW | 266d? | 2007-11-30 A | 2008-12-05 A | 100% | 2007-11-30 | 2008-12-05 | 266d? | finish no earlier than 2008-12-05 | C1 | 2128h | 2128h | UUSIW | PCG-21 | CP-38 | Frederic | Huawei | Lili Yang (kadyyang@huawei.com) | Rel-8 |
| 429 | 124.2 | Stage 3 MGCF UUSIW | 335d? | 2007-11-30 A | 2009-03-12 A | 100% | 2007-11-30 | 2009-03-12 | 335d? | finish no earlier than 2009-03-12 | C3 | 2680h | 2680h | UUSIW | PCG-21 | CP-38 | Gwiho | Huawei | Lili Yang (kadyyang@huawei.com) | Rel-8 |

Notes:
- 404: SA#40 completed
- 405: CT#39 completed / Text3: 24.404, 24.405, 24.406, 24.407, 24.408, 24.410, 24.411, 24.416, 29.421, 24.423, 24.428, 24.429, 29.433, 24.441, 24.403, 29.427, 24.430, 29.412
- 406: CT#39 completed / Text3: 24.406, 24.407, 24.410, 24.411, 24.423, 24.430, 24.447, 24.451, 24.454, 24.503, 24.505, 24.508, 24.516, 24.528, 24.529, 29.412, 29.421, 29.433, 29.458, 29.527
- 407: WID approved SA#38. per OPs & ETSI GA 39. This is a joint effort of SA WG2 and TISPAN WG2. SA#40 completed / Text3: 23.228, 23.204, 23.167
- 408: SA#38 WID and TSs approved. SA#40 WID updated SP-070915=>SP-080315. SA#41 WID updated SP-080315=>SP-080501 / Text3: 22.273, 22.401, 23.406, 23.417, 23.508, 23.509, 23.511, 22.401, 22.173
- 409: SA#38 approved WID and TSs / Text3: 23.506, 23.507,23.517, 23.521
- 410: CT#43 Rel-8 further exception 03/09=>05/09 (no exception sheet needed). SA#40 Stage 1/2 completed
- 411: SA#40 completed
- 412: SA#40 completed / Text3: 23.237, 23.292
- 413: CT#44 completed / Text3: 24.237, 24.229, 24.216
- 414: CT#43 completed. SA#36 WID approved
- 415: SA#42 completed. SA#39 SA3 to remove Stage 3 from 33.178-100 for CTx work. SA#40 withdrawn 33.178-100. / Text3: 33.203, 33.141, 33.978, 33.803
- 416: CT#42 completed. SA#39 SA3 to remove Stage 3 from 33.178-100 for CT1 work
- 417: CT#43 completed. CT#42 Rel-8 exception to 03/09
- 418: CT#43 completed. CT#42 Rel-8 exception to 03/09 / Text3: 24.229
- 419: CT#40 completed / Text3: 29.229, 29.228, 23.008
- 420: SA#43 completed. SA#42 Rel-8 exception to 03/09. SA#39 WID approved. / Text3: 26.237, 26.234, 26.346, 33.246
- 421: CT#42 completed
- 422: SA#31 Moved from FS section Feb 2006
- 423: Moved from R7 WP because it is part of Feature UID_713024. This feature was extended to R8 by the inclusion (at Nov 2007 CT3 meeting) of Stage 3 exception covering MONA (WI 380021) / Text3: 29.863, 29.163
- 424: CT#42 completed / Text3: 29.863, 29.163
- 425: CT#42 completed / Text3: 29.332
- 426: CT#43 completed. CT#42 Rel-8 exception to 03/09 / Text3: 23.218, 24.229, 24.930
- 427: CT#43 completed
- 428: CT#42 completed / Text3: 24.279, 24.229
- 429: Depending on IETF draft. CT#43 completed / Text3: 29.163

| ID | WBS | Task | Type | Duration | Start | Finish | Complete | Remaining | Baseline start | Baseline finish | Baseline duration | Total slack | Constraint | Resources | Work | Actual work | Text1 | Text2 | Text4 | Text5 | Text6 | Text7 | Text8 | Text3 |
| --- | --- | --- | --- | --- | --- | --- | --- | --- | --- | --- | --- | --- | --- | --- | --- | --- | --- | --- | --- | --- | --- | --- | --- | --- |
| 430 | 125 | **Support of Overlap signalling** |  | 331d? | 2007-11-30 A | 2009-03-06 A | 100% |  | 2007-11-30 | 2009-03-06 | 331d? |  |  | C3,C1,C4 | 10008.2h | 10008.2h | Overlap | PCG-21 | Deutsche Telekom | r.jesske@telekom.de | Rel-8 | CP-38 | Gwiho |  |
| 431 | 125.1 | Stage 3 Overlap (CT1) |  | 331d? | 2007-11-30 A | 2009-03-06 A | 100% |  | 2007-11-30 | 2009-03-06 | 331d? |  | finish no earlier than 2009-03-06 | C1 | 2648h | 2648h | Overlap | PCG-21 | Deutsche Telekom | r.jesske@telekom.de | Rel-8 | CP-38 | Frederic | 24.229 |
| 432 | 125.2 | Stage 3 Overlap (CT3) |  | 331d? | 2007-11-30 A | 2009-03-06 A | 100% |  | 2007-11-30 | 2009-03-06 | 331d? |  | finish no earlier than 2009-03-06 | C3 | 2648h | 2648h | Overlap | PCG-21 | Deutsche Telekom | r.jesske@telekom.de | Rel-8 | CP-38 | Gwiho | 29.163 |
| 433 | 125.3 | Stage 3 Overlap (CT4) |  | 258.02d? | 2007-11-30 A | 2008-12-05 A | 100% |  | 2007-11-30 | 2008-12-05 | 258.02d? |  | start no earlier than 2007-11-30 | C4 | 2064.16h | 2064.16h | Overlap | PCG-21 | Deutsche Telekom | r.jesske@telekom.de | Rel-8 | CP-38 | Kimmo | 29.228, 29.229 |
| 434 | 126 | AS/MRFC Stage 2 and 3 |  | 278d? | 2007-11-14 A | 2008-12-05 A | 100% |  | 2007-11-14 | 2008-12-05 | 278d? |  | finish no earlier than 2008-12-05 | C1 | 2224h | 2224h | MRFC_TS | PCG-21 | HP | mark.syrett@hp.com | Rel-8 | CP-38 | Frederic | 23.218, 24.229, 24.147, 24.247 |
| 435 | 127 | **IMS Restoration Procedures** |  | 201d? | 2008-05-30 A | 2009-03-06 A | 100% |  | 2008-05-30 | 2009-03-06 | 201d? |  |  | C4,C1 | 4824h | 4824h | IMS_RP | PCG-21 | Ericsson | german.blanco@ericsson.com | Rel-8 | SP-40 | Kimmo |  |
| 436 | 127.1 | IMS Restoration Procedures |  | 201d? | 2008-05-30 A | 2009-03-06 A | 100% |  | 2008-05-30 | 2009-03-06 | 201d? |  | finish no earlier than 2009-03-06 | C4 | 1608h | 1608h | IMS_RP | PCG-21 | Ericsson | german.blanco@ericsson.com | Rel-8 | SP-40 | Kimmo | 23.380, 29.228, 29.229, 29.230, 23.008 |
| 437 | 127.2 | IMS Restoration Procedures |  | 201d? | 2008-05-30 A | 2009-03-06 A | 100% |  | 2008-05-30 | 2009-03-06 | 201d? |  | finish no earlier than 2009-03-06 | C1 | 1608h | 1608h | IMS_RP | PCG-21 | Ericsson | german.blanco@ericsson.com | Rel-8 | SP-40 | Frederic | 24.229 |
| 438 | 128 | IMS Application Server Service Data Descriptions for AS interoperability |  | 125d? | 2008-09-12 A | 2009-03-06 A | 100% |  | 2008-09-12 | 2009-03-06 | 125d? |  | finish no earlier than 2009-03-06 | C4 | 1000h | 1000h | IMS_ASIO | PCG-21 | Alcatel-Lucent | nhberry@alcatel-lucent.com | Rel-8 | CP-41 | Kimmo | 29.328, 29.329, 29.364 |
| 439 | 129 | **I-WLAN Network Selection Principle (NSP)** |  | 451d? | 2007-06-14 A | 2009-03-06 A | 100% |  | 2007-06-14 | 2009-03-06 | 451d? |  |  | S1,C1,C6 | 6643.2h | 6643.2h | IWLANNSP |  | Telefonica O2 | chris.friel@o2.com | Rel-8 |  | Alain |  |
| 440 | 129.1 | Stage 1 for I-WLAN NSP | milestone | 0d? | 2007-06-14 A | 2007-06-14 A | 100% |  | 2007-06-14 | 2007-06-14 | 0d? |  |  | S1 |  |  | IWLANNSP | PCG-21 | Telefonica O2 | chris.friel@o2.com | Rel-8 | SP-39 | Alain | 22.234 |
| 441 | 129.2 | Stage 3 for I-WLAN NSP |  | 261d? | 2008-03-07 A | 2009-03-06 A | 100% |  | 2008-03-07 | 2009-03-06 | 261d? |  | finish no earlier than 2008-12-05 | C1 | 2088h | 2088h | IWLANNSP | PCG-21 | RIM | Adrian Buckley (abuckley@rim.com) | Rel-8 | CP-39 | Frederic | 24.234 |
| 442 | 129.3 | Stage 3 for I-WLAN NSP |  | 118.4d? | 2008-03-07 A | 2008-12-11 A | 100% |  | 2008-03-07 | 2008-12-11 | 118.4d? |  | finish no earlier than 2008-12-11 | C6 | 947.2h | 947.2h | IWLANNSP | PCG-21 | RIM | Adrian Buckley (abuckley@rim.com) | Rel-8 | CP-39 | Xavier | 31.102, 31.111 |
| 443 | 130 | **Mobility between 3GPP-WLAN Interworking and 3GPP Systems** |  | 386d? | 2007-09-14 A | 2009-03-06 A | 100% |  | 2007-09-14 | 2009-03-06 | 386d? |  |  | S2,C1 | 6216h | 6216h | IWLAN_Mob |  | Orange | xiaobao.chen@orange-ftgroup.com | Rel-8 | SP-37 | Maurice |  |
| 444 | 130.1 | Stage 2: I-WLAN Mobility |  | 190d? | 2007-09-14 A | 2008-06-05 A | 100% |  | 2007-09-14 | 2008-06-05 | 190d? |  | finish no earlier than 2008-09-08 | S2 | 1520h | 1520h | IWLAN_Mob | PCG-21 | Orange | xiaobao.chen@orange-ftgroup.com | Rel-8 | SP-38 | Maurice | 23.327 |
| 445 | 130.2 | CT1 aspects of I-WLAN Mobility |  | 201d? | 2008-05-30 A | 2009-03-06 A | 100% |  | 2008-05-30 | 2009-03-06 | 201d? |  | finish no earlier than 2009-03-06 | C1 | 1608h | 1608h | IWLAN_Mob | PCG-21 | Orange | reina.nader@orange-ftgroup.com | Rel-8 | CP-40 | Frederic | 24.327, 24.303 |
| 446 | 131 | **Enhancements for VGCS Applications (EVA)** |  | 914d? | 2006-03-15 A | 2009-09-11 | 96% | 38.87d? | 2006-03-15 | 2009-09-11 | 914d? | 260d |  | S1,C1,C4,G2 | 23423.6h | 22427.8h | EVA |  | Nortel | Amar Deol (deola@nortelnetworks.com) | Rel-8 |  | Alain |  |
| 447 | 131.1 | SA1 aspects of EVA |  | 191d? | 2006-03-15 A | 2006-12-06 A | 100% |  | 2006-03-15 | 2006-12-06 | 191d? |  | finish no earlier than 2006-12-06 | S1 | 1528h | 1528h | EVA-s1 |  | Nortel | Amar Deol (deola@nortelnetworks.com) | Rel-8 |  | Alain | 42.068 |
| 448 | 131.2 | VGCS/VBS and GPRS Interactions |  | 145d? | 2007-09-03 A | 2008-03-21 A | 100% |  | 2007-09-03 | 2008-03-21 | 145d? |  | finish no earlier than 2008-03-21 | S1 | 1160h | 1160h | EVA |  | Huawei | Ling Liu | Rel-8 | SP-37 | Alain | 42.068, 42.069 |
| 449 | 131.3 | CT1 aspects of EVA |  | 857d? | 2006-06-02 A | 2009-09-11 | 90% | 85.7d? | 2006-06-02 | 2009-09-11 | 857d? | 260d | finish no earlier than 2009-06-01 | C1 | 6847.58h | 6162.82h | EVA |  | Nortel | milanpa@nortel.com | Rel-8 |  | Frederic | 43.068, 44.068 |
| 450 | 131.4 | CT4 aspects of EVA |  | 391d? | 2006-06-02 A | 2007-11-30 A | 100% |  | 2006-06-02 | 2007-11-30 | 391d? |  | finish no earlier than 2007-06-01 | C4 | 3128h | 3128h | EVA |  | Nortel |  | Rel-8 |  | Kimmo | 29.002 |
| 451 | 131.5 | GERAN2 aspects of EVA |  | 431d? | 2006-06-30 A | 2008-02-22 A | 100% |  | 2006-06-30 | 2008-02-22 | 431d? |  | finish no earlier than 2008-02-22 | G2 | 3448h | 3448h | EVA-EVGCSA |  | Nortel | frank.billenkamp@nortel.com | Rel-8 |  | Gert | 44.018, 48.008 |
| 452 | 132 | **Personal Network Management** |  | 955d? | 2005-07-11 A | 2009-03-06 A | 100% |  | 2005-07-11 | 2009-03-06 | 955d? |  |  | S1,C1,S3 | 27008h | 27008h | PNM |  | Vodafone | armin.toepfer@vodafone.com | Rel-8 |  | Alain |  |
| 453 | 132.1 | Stage 1 for PNM |  | 276d? | 2005-07-11 A | 2006-07-31 A | 100% |  | 2005-07-11 | 2006-07-31 | 276d? |  | start no earlier than 2005-07-11 | S1 | 2208h | 2208h | PNM |  | Vodafone | armin.toepfer@vodafone.com | Rel-8 |  | Alain | 22.259 |
| 454 | 132.2 | Stage 2 for PNM |  | 445d? | 2007-03-26 A | 2008-12-05 A | 100% |  | 2007-03-26 | 2008-12-05 | 445d? |  | finish no earlier than 2008-12-05 | C1 | 3560h | 3560h | PNM |  | Vodafone | yang.lu@vodafone.com | Rel-8 |  | Frederic | 23.259 |

Notes:
- 430: CT#43 completed. CT#42 Rel-8 exception to 03/09
- 431: CT#43 completed. CT#42 Rel-8 exception to 03/09
- 432: CT#43 completed. CT#42 Rel-8 exception to 03/09
- 433: CT#42 completed
- 434: CT#42 completed. Triggered by Study UID_7048 (MRFC)
- 435: CT#43 completed. CT#42 Rel-8 exception to 03/09. CT#41 WID updated CP-080281=>CP-080447. Triggered by Study TR 23.820 (FS_IMS_RP) UID_350018
- 436: CT#43 completed. CT#42 Rel-8 exception to 03/09
- 437: CT#43 completed. CT#42 Rel-8 exception to 03/09
- 438: CT#43 completed. CT#42 Rel-8 exception to 03/09. Triggered by UID_360030 (FS_IMS_ASIO)
- 439: CT#43 completed. SA#36 Stage 1 completed
- 440: SA#36 completed
- 441: CT#43 completed
- 442: CT#42 completed
- 443: CT#43 completed. SA#40 Stage 2 completed
- 444: SA#40 completed
- 445: CT#43 completed
- 446: Stage 1/2 completed
- 447: SA#38 completed
- 448: SA#39 completed
- 449: CT#44: Need for SA1 42.068 alignment CR removing functionality that could not be realized in CT1 Rel-8
- 450: CT#38 completed
- 451: GP#37 completed
- 452: CT#43 completed. Feb 06 moved FS=>Feature. SA#31 Stage 1 completed. SA#40 WID updated with reduced scope SP-060574=>SP-080327
- 453: SA#31 completed. SA#40 WID updated SP-060574=>SP-080327
- 454: CT#42 completed

| ID | WBS | Task | Type | Duration | Start | Finish | Complete | Remaining | Baseline start | Baseline finish | Baseline duration | Total slack | Constraint | Resources | Work | Actual work | Text1 | Text4 | Text5 | Text6 | Text8 | Text3 | Text12 | Text7 | Text2 |
| --- | --- | --- | --- | --- | --- | --- | --- | --- | --- | --- | --- | --- | --- | --- | --- | --- | --- | --- | --- | --- | --- | --- | --- | --- | --- |
| 455 | 132.3 | **Stage 3 for PNM** |  | 510d? | 2007-03-26 A | 2009-03-06 A | 100% |  | 2007-03-26 | 2009-03-06 | 510d? |  |  | C1,C4 | 11720h | 11720h | PNM | Vodafone | yang.lu@vodafone.com | Rel-8 | Frederic |  |  |  |  |
| 456 | 132.3.1 | CT1 aspects of Stage 3 PNM |  | 510d? | 2007-03-26 A | 2009-03-06 A | 100% |  | 2007-03-26 | 2009-03-06 | 510d? |  | finish no earlier than 2008-12-05 | C1 | 4080h | 4080h | PNM | Vodafone | yang.lu@vodafone.com | Rel-8 | Frederic | 24.259, 24.229 |  |  |  |
| 457 | 132.3.2 | CT4 aspects of Stage 3 PNM |  | 445d? | 2007-03-26 A | 2008-12-05 A | 100% |  | 2007-03-26 | 2008-12-05 | 445d? |  | finish no earlier than 2008-12-11 | C4 | 3560h | 3560h | PNM | Vodafone | yang.lu@vodafone.com | Rel-8 | Kimmo |  |  |  |  |
| 458 | 132.4 | Key establishment between a UICC hosting device and a remote device |  | 235d? | 2006-12-06 A | 2007-10-30 A | 100% |  | 2006-12-06 | 2007-10-30 | 235d? |  | finish no earlier than 2007-10-30 | S3 | 1880h | 1880h | PNM | Ericsson | Vesa.Lehtovirta@ericsson.com | Rel-8 | Dionisio | 33.259 |  |  |  |
| 459 | 132.5 | Deleted - Actual Requirements of PNM | milestone | 0d? | 2007-03-26 A | 2007-03-26 A | 100% |  | 2007-03-26 | 2007-03-26 | 0d? |  | finish no earlier than 2007-03-26 | C1 |  |  | PNM | Ericsson |  | Rel-8 | Frederic |  | SP-37 |  |  |
| 460 | 133 | **eCall Data Transfer** |  | 637d? | 2006-09-28 A | 2009-03-06 A | 100% |  | 2006-09-28 | 2009-03-06 | 637d? |  |  | S1,C1 | 9744h | 9744h | EData | Airbiquity | rrobinson@airbiquity.com | Rel-8 | Alain |  |  |  |  |
| 461 | 133.1 | eData Requirements |  | 380d? | 2006-09-28 A | 2008-03-12 A | 100% |  | 2006-09-28 | 2008-03-12 | 380d? |  | finish no earlier than 2006-12-07 | S1 | 3040h | 3040h | EData | Airbiquity | rrobinson@airbiquity.com | Rel-8 | Alain | 22.101, 22.105 |  | SP-37 |  |
| 462 | 133.2 | Transfer of data during an emergency call |  | 201d? | 2008-05-30 A | 2009-03-06 A | 100% |  | 2008-05-30 | 2009-03-06 | 201d? |  | finish no earlier than 2009-03-06 | C1 | 1608h | 1608h | EData | T-Mobile | Dieter Jacobsohn | Rel-8 | Frederic | 24.008 |  | SP-40 | PCG-21 |
| 463 | 134 | eCall data transfer Phase 2: Comparison of alternative in-band modem solutions and standardization of one in-band modem solution |  | 463d? | 2007-12-06 A | 2009-09-11 | 95% | 23.15d? | 2007-12-06 | 2009-09-11 | 463d? | 260d | finish no earlier than 2009-09-11 | S4 | 3696h | 3510.95h | eCall_Phase2 | Airbiquity | lhong@airbiquity.com & rrobinson@airbiquity.com | Rel-8 | Paolo | 26.267, 26.268, 26.269, 26.967, 26.969 |  |  |  |
| 464 | 135 | **IP Interconnection of Services** |  | 668d? | 2006-08-16 A | 2009-03-06 A | 100% |  | 2006-08-16 | 2009-03-06 | 668d? |  |  | S1,S2,S5,C3 | 17520h | 17520h | IPinterc | Telefonica O2 | chris.friel@O2.com | Rel-8 | Alain |  |  | SP-38 | PCG-21 |
| 465 | 135.1 | Stage 1 for IPinterc |  | 70d? | 2007-12-06 A | 2008-03-12 A | 100% |  | 2007-12-06 | 2008-03-12 | 70d? |  | start no earlier than 2007-12-06 | S1 | 560h | 560h | IPinterc | Telefonica O2 | chris.friel@O2.com | Rel-8 | Alain | 22.101, 22.228 |  | SP-38 | PCG-21 |
| 466 | 135.2 | **System enhancements for interconnection interfaces between two IMSs** |  | 668d? | 2006-08-16 A | 2009-03-06 A | 100% |  | 2006-08-16 | 2009-03-06 | 668d? |  |  | S2,S5,C3 | 11616h | 11616h | IMS_NNI | Telecom Italia | Mario Madella (mario.madella@telecomitalia.it) | Rel-8 | Maurice |  |  |  |  |
| 467 | 135.2.1 | Stage 2 for IMS_NNI |  | 120d? | 2007-06-22 A | 2007-12-06 A | 100% |  | 2007-06-22 | 2007-12-06 | 120d? |  | finish no earlier than 2007-12-21 | S2 | 960h | 960h | IMS_NNI | Telecom Italia | Mario Madella (mario.madella@telecomitalia.it) | Rel-8 | Maurice | 23.002, 23.228 |  |  |  |
| 468 | 135.2.2 | IMS inter-operator service interconnection interface |  | 461d? | 2007-06-01 A | 2009-03-06 A | 100% |  | 2007-06-01 | 2009-03-06 | 461d? |  | finish no earlier than 2009-03-06 | C3 | 3688h | 3688h | FBI2-IOPSI | Telecom Italia | antonio.ascolese@telecomitalia.it | Rel-8 | Gwiho | 29.865, 29.165 |  |  |  |
| 469 | 135.2.3 | Charging harmonization for NGN between 3GPP and ATIS-TMOC |  | 51d? | 2006-09-28 A | 2006-12-07 A | 100% |  | 2006-09-28 | 2006-12-07 | 51d? |  | finish no earlier than 2006-12-07 | S5 | 408h | 408h | FBI2-TISP2-CH | Amdocs | Brown, Yishai | Rel-8 | Dionisio | 32.297 |  |  |  |
| 470 | 135.2.4 | Deleted - Protocol impact of FBI for TISPAN R2 |  | 152d? | 2006-08-16 A | 2007-03-15 A | 100% |  | 2006-08-16 | 2007-03-15 | 152d? |  | finish no earlier than 2007-03-15 | C1 | 1216h | 1216h | FBI2-TISP2-c1 | Ericsson |  | Rel-8 | Frederic |  | SP-38 |  |  |
| 471 | 135.2.5 | Deleted (never approved) - Stage 2 of FBI for TISPAN R2 - Rel 8 | milestone | 0d? | 2007-11-30 A | 2007-11-30 A | 100% |  | 2007-11-30 | 2007-11-30 | 0d? |  | finish no earlier than 2007-11-30 | S2 |  |  | FBI2-TISP2-s2 | Nokia Siemens Networks |  | Rel-8 | Maurice |  | SP-36 |  |  |
| 472 | 136 | **Support of (G)MSC-S – (G)MSC-S Nc Interface based on the SIP-I protocol** |  | 386d? | 2007-09-14 A | 2009-03-06 A | 100% |  | 2007-09-14 | 2009-03-06 | 386d? |  |  | C4,C3 | 11872h | 11872h | SIP_Nc | Vodafone | David.Hutton@vodafone.com | Rel-8 | Kimmo |  |  |  |  |
| 473 | 136.1 | Stage 1 for SIP_Nc (covered by Feature IPinterc) |  | 70d? | 2007-12-06 A | 2008-03-12 A | 100% |  | 2007-12-06 | 2008-03-12 | 70d? |  | start no earlier than 2007-12-06 | S1 | 560h | 560h | IPinterc | Telefonica O2 | chris.friel@O2.com | Rel-8 | Alain | 22.101, 22.228 |  | CP-41 | PCG-21 |
| 474 | 136.2 | SIP-I based circuit-switched core network; Stage 2 |  | 321d? | 2007-09-14 A | 2008-12-05 A | 100% |  | 2007-09-14 | 2008-12-05 | 321d? |  | finish no earlier than 2008-12-11 | C4 | 2568h | 2568h | SIP_Nc-St2 | Vodafone | David.Hutton@vodafone.com | Rel-8 | Kimmo | 23.231, 23.153, 23.205 |  |  |  |
| 475 | 136.3 | Application of SIP-I Protocols to Circuit Switched (CS) core network architecture; Stage 3 |  | 321d? | 2007-09-14 A | 2008-12-05 A | 100% |  | 2007-09-14 | 2008-12-05 | 321d? |  | finish no earlier than 2008-12-11 | C4 | 2568h | 2568h | SIP_Nc-St3 | Vodafone | David.Hutton@vodafone.com | Rel-8 | Kimmo | 29.231, 29.232, 29.332 |  |  |  |
| 476 | 136.4 | Interworking between the 3GPP CS domain with SIP-I as signalling protocol and other networks |  | 386d? | 2007-09-14 A | 2009-03-06 A | 100% |  | 2007-09-14 | 2009-03-06 | 386d? |  | finish no earlier than 2009-03-06 | C3 | 3088h | 3088h | SIP_Nc | Nokia Siemens Networks | Thomas.Belling@nsn.com | Rel-8 | Gwiho | 29.235, 23.172, 23.202, 29.007, 29.163, 29.414 |  |  |  |
| 477 | 137 | **Earthquake and Tsunami Warning System** |  | 440d? | 2007-09-10 A | 2009-05-15 A | 100% |  | 2007-09-10 | 2009-05-15 | 440d? |  |  | S1,S2,CP,G2 | 6136h | 6136h | ETWS | NTT DoCoMo | kitaharar@nttdocomo.co.jp | Rel-8 | Alain |  |  | SP-37 |  |
| 478 | 137.1 | Stage 1 for ETWS |  | 133d? | 2007-09-10 A | 2008-03-12 A | 100% |  | 2007-09-10 | 2008-03-12 | 133d? |  | finish no earlier than 2008-03-12 | S1 | 1064h | 1064h | ETWS | NTT DoCoMo | kitaharar@nttdocomo.co.jp | Rel-8 | Alain | 22.168 |  | SP-37 |  |
| 479 | 137.2 | SA2 aspects of ETWS |  | 179d? | 2008-01-14 A | 2008-09-18 A | 100% |  | 2008-01-14 | 2008-09-18 | 179d? |  | finish no earlier than 2008-09-08 | S2 | 1432h | 1432h | ETWS | NTT DoCoMo | tanakai@nttdocomo.co.jp | Rel-8 | Maurice | 23.828, 23.401 |  | SP-38 | PCG-21 |
| 480 | 137.3 | CT1 aspects of ETWS |  | 50.5d? | 2008-05-30 A | 2008-12-05 A | 100% |  | 2008-05-30 | 2008-12-05 | 50.5d? |  | finish no earlier than 2008-12-05 | C1 | 404h | 404h | ETWS | NTT DoCoMo | yamashitahi@s1.nttdocomo.co.jp | Rel-8 | Frederic | 23.041 |  | CP-40 | PCG-21 |
| 481 | 137.4 | CT4 aspects of ETWS |  | 50.5d? | 2008-09-26 A | 2008-12-05 A | 100% |  | 2008-09-26 | 2008-12-05 | 50.5d? |  | finish no earlier than 2008-12-05 | C4 | 404h | 404h | ETWS | NTT DoCoMo | yamashitahi@s1.nttdocomo.co.jp | Rel-8 | Kimmo | 29.168 |  | CP-40 | PCG-21 |
| 482 | 137.5 | ETWS primary notification message definition in GERAN |  | 47d? | 2009-03-12 A | 2009-05-15 A | 100% |  | 2009-03-12 | 2009-05-15 | 47d? |  | finish no earlier than 2009-05-15 | G2 | 376h | 376h | ETWS | Ericsson | claes-goran.persson@ericsson.com | Rel-8 | Gert | 44.018, 44.060 |  | SP-43 | PCG-22 |
| 483 | 138 | Conformance Test Aspects – UMTS Earthquake and Tsunami Warning System (ETWS) FDD |  | 207d? | 2009-05-29 | 2010-03-12 |  |  | 2009-05-29 | 2010-03-12 | 207d? | 130d | finish no earlier than 2010-03-12 | R5 | 1656h |  | ETWS_UMTS_UEConTestFDD | NTT DoCoMo | Makoto Ito (itohm@nttdocomo.co.jp) | Rel-8 |  | 34.108, 34.123-1, 34.123-2, 34.123-3 |  | RP-44 | PCG-23 |

Notes:
- 455: CT#43 completed. Moved from FS section Feb 06: SP-33: Create new section to capture the PNM stage 2 aspects and identify any impacts to existing stage 2 specifications.
- 456: CT#43 completed
- 457: CT#42 No impact to CT4 specifications
- 458: 07/08: Moved from Rel-7 to Rel-8 WP; Feature=>BB as per SA3/SA WID in SP-060839, keeping the same UID
- 459: SA#37 stopped
- 460: SA#39 completed. Linked to SA4 Feature UID_34042 (eCall_Phase2). CT#40 approved Stage 3 WID.
- 461: SA4 to select a suitable in-band modem. SA#39 completed
- 462: CT#43 completed. CT#42 Rel-8 exception to 03/09
- 463: SA#44 exception 06/09=>09/09 (SP-090254). Triggered by Study UID_360015 (eCALLIBMS). Linked to SA1 Feature UID_330005 (EData).
- 464: SA#43 completed. CT#42 Rel-8 exception to 03/09. Covers Stage 1 for IMS_NNI (UID_360024),SIP_Nc (UID_360026),CS-IBCF (UID_400008). SA#41 WID updated SP-070871=>SP-080565 [Moved under it as BBs 2 existing Features: CS-IBCF, IMS_NNI]
- 465: SA#39 completed.
- 466: CT#43 completed. CT#42 Rel-8 exception to 03/09. SA#36 Name changed from "System enhancements for TISPAN Rel2". Stage 1 in Feature UID_380060 (IPinterc). CT#41 updated WID CP-080054=>CP-080578 (Feature IMS_NNI=>BB under Ipinterc)
- 467: SA#38 completed. SA#41 WID updated SP-070490=>SP-080554
- 468: CT#43 completed. CT#42 Rel-8 exception to 03/09
- 469: SA#34 completed
- 470: SA#38 stopped
- 471: SA#36 stopped
- 472: CT#43 completed. Stage 1 in Feature UID_380060 (IPinterc). CT#40 updated WID CP-070517=>CP-080282
- 473: 22/07/08 Created. Stage 1 for SIP_Nc (covered by SA1 Feature UID_380060 Ipinterc)
- 474: CT#42 completed
- 475: CT#42 completed
- 476: CT#43 completed. CT#42 target 12/08=>03/09
- 477: SA#43 GERAN task included. Larger scope Feature UID_380057 (PWS) moved to Rel-9
- 478: SA#39 completed
- 479: SA#41 completed . SA#40 exception to Sep 2008 on impacts of adding the CBC to MME interface.
- 480: CT#42 completed. WID updated CP-080318=>CP-080659=>CP-080951
- 481: CT#42 completed. WID updated CP-080318=>CP-080659=>CP-080951
- 482: SA#44 completed with CT1 help (GERAN2 LS_in SP-090154)

| ID | WBS | Task | Type | Duration | Start | Finish | Complete | Remaining | Baseline start | Baseline finish | Baseline duration | Total slack | Constraint | Resources | Work | Actual work | Text1 | Text2 | Text4 | Text5 | Text6 | Text7 | Text8 | Text3 | Text12 |
| --- | --- | --- | --- | --- | --- | --- | --- | --- | --- | --- | --- | --- | --- | --- | --- | --- | --- | --- | --- | --- | --- | --- | --- | --- | --- |
| 484 | 139 | **In Case of Emergency numbers storage and easy access on UICC** |  | 519d? | 2007-03-13 A | 2009-03-06 A | 100% |  | 2007-03-13 | 2009-03-06 | 519d? |  |  | S1,C6 | 8864h | 8864h | ICE | PCG-21 | Vodafone | armin.toepfer@vodafone.com | Rel-8 | SP-38 | Alain |  |  |
| 485 | 139.1 | Stage 1 for ICE |  | 262d? | 2007-03-13 A | 2008-03-12 A | 100% |  | 2007-03-13 | 2008-03-12 | 262d? |  | finish no earlier than 2008-03-12 | S1 | 2096h | 2096h | ICE | PCG-21 | Vodafone | armin.toepfer@vodafone.com | Rel-8 | SP-38 | Alain | 22.030, 22.101 |  |
| 486 | 139.2 | CT6 aspects of ICE |  | 519d? | 2007-03-13 A | 2009-03-06 A | 100% |  | 2007-03-13 | 2009-03-06 | 519d? |  | finish no earlier than 2009-03-06 | C6 | 4152h | 4152h | ICE | PCG-21 | Vodafone | armin.toepfer@vodafone.com | Rel-8 | SP-38 | Xavier | 31.102 |  |
| 487 | 140 | Local Charging Zone Requirements |  | 380d? | 2006-09-28 A | 2008-03-12 A | 100% |  | 2006-09-28 | 2008-03-12 | 380d? |  | finish no earlier than 2006-12-07 | S1 | 3040h | 3040h | LCZR |  | China Mobile | liuhongyfw@chinamobile.com | Rel-8 |  | Alain | 22.115 |  |
| 488 | 141 | **Customized Alerting Tone (CAT) Service** |  | 724d? | 2006-12-06 A | 2009-09-11 | 66% | 248.07d? | 2006-12-06 | 2009-09-11 | 724d? | 260d |  | S1,C1,C3,C4 | 12222h | 5315.44h | CAT |  | China Mobile | fenglingjuan@chinamobile.com | Rel-8 |  | Alain |  |  |
| 489 | 141.1 | Stage 1 for CAT |  | 207d? | 2006-12-06 A | 2007-09-20 A | 100% |  | 2006-12-06 | 2007-09-20 | 207d? |  | start no earlier than 2006-12-06 | S1 | 1656h | 1656h | CAT |  | China Mobile | fenglingjuan@chinamobile.com | Rel-8 | SP-37 | Alain | 22.182 |  |
| 490 | 141.2 | TISPAN requirements for customized multimedia information services |  | 71d? | 2007-09-03 A | 2007-12-10 A | 100% |  | 2007-09-03 | 2007-12-10 | 71d? |  | finish no earlier than 2007-12-10 | S1 | 568h | 568h | TISCMI |  | China Mobile | fenglingjuan@chinamobile.com | Rel-8 | SP-37 | Alain | 22.182 |  |
| 491 | 141.3 | IMS CAT Supplementary Service |  | 164d? | 2008-04-21 A | 2008-12-04 A | 100% |  | 2008-04-21 | 2008-12-04 | 164d? |  | finish no earlier than 2008-12-05 | C1 | 1312h | 1312h | CAT-SS | PCG-21 | Nortel | milanpa@nortel.com | Rel-8 | CP-39 | Frederic | 24.182 |  |
| 492 | 141.4 | CAT solution for voice and video call in CS domain |  | 384.8d? | 2008-03-12 A | 2009-09-11 | 10% | 346.32d? | 2008-03-12 | 2009-09-11 | 384.8d? | 260d | finish no earlier than 2009-09-11 | C3 | 3078.4h | 307.84h | CAT-SS | PCG-21 | Nortel | milanpa@nortel.com | Rel-8 | CP-39 | Gwiho | 29.163 |  |
| 493 | 141.5 | CAT Service in 3GPP CS domain |  | 126d? | 2008-09-12 A | 2009-03-06 A | 100% |  | 2008-09-12 | 2009-03-06 | 126d? |  | finish no earlier than 2009-03-06 | C4 | 1008h | 1008h | CAT-3G_CS | PCG-21 | China Mobile | zhaoyuyi@chinamobile.com | Rel-8 | CP-41 | Kimmo | 23.205, 23.231, 29.002 |  |
| 494 | 141.6 | CAT Service in 3GPP CS domain |  | 57.95d? | 2008-09-12 A | 2008-12-05 A | 100% |  | 2008-09-12 | 2008-12-05 | 57.95d? |  | start no earlier than 2008-09-12 | C1 | 463.6h | 463.6h | CAT-3G_CS | PCG-21 | China Mobile | zhaoyuyi@chinamobile.com | Rel-8 | CP-41 | Frederic | 24.008, 23.014 |  |
| 495 | 142 | **Service-Level Interworking for Messaging Services** |  | 509d? | 2007-03-26 A | 2009-03-06 A | 100% |  | 2007-03-26 | 2009-03-06 | 509d? |  |  | S1,S2,C3,C1 | 8584h | 8584h | MESSIW |  | Huawei | ling.liu@huawei.com; duanxiaoqin@huawei.com | Rel-8 |  | Alain |  |  |
| 496 | 142.1 | Stage 1 for MESSIW | milestone | 0d? | 2007-03-26 A | 2007-03-26 A | 100% |  | 2007-03-26 | 2007-03-26 | 0d? |  | finish no earlier than 2007-12-01 | S1 |  |  | MESSIW |  | Huawei | ling.liu@huawei.com | Rel-8 |  | Alain | 22.105, 22.340 |  |
| 497 | 142.2 | Stage 2 for MESSIW |  | 227d? | 2007-04-26 A | 2008-03-07 A | 100% |  | 2007-04-26 | 2008-03-07 | 227d? |  | finish no earlier than 2008-03-07 | S2 | 1816h | 1816h | MESSIW |  | Huawei | patrice.hede@huawei.com | Rel-8 |  | Maurice | 23.811, 23.204 |  |
| 498 | 142.3 | Stage 3 for MESSIW |  | 201d? | 2008-05-30 A | 2009-03-06 A | 100% |  | 2008-05-30 | 2009-03-06 | 201d? |  | finish no earlier than 2008-12-05 | C3 | 1608h | 1608h | MESSIW | PCG-21 | Huawei | xupeili@huawei.com | Rel-8 | CP-40 | Gwiho | 29.311 |  |
| 499 | 142.4 | Stage 3 for MESSIW |  | 136d? | 2008-05-30 A | 2008-12-05 A | 100% |  | 2008-05-30 | 2008-12-05 | 136d? |  | finish no earlier than 2008-12-12 | C1 | 1088h | 1088h | MESSIW | PCG-21 | Huawei | xupeili@huawei.com | Rel-8 | CP-40 | Frederic | 24.229 |  |
| 500 | 143 | **Multimedia Priority Service** |  | 853d? | 2006-06-08 A | 2009-09-11 | 81% | 159.69d? | 2006-06-08 | 2009-09-11 | 853d? | 260d |  | S1,C1,C3,C4 | 22336h | 18154.5h | PRIOR |  | Telcordia | jgarraha@telcordia.com | Rel-8 | SP-34 | Alain |  |  |
| 501 | 143.1 | Service Requirements for PRIOR |  | 391d? | 2006-06-08 A | 2007-12-06 A | 100% |  | 2006-06-08 | 2007-12-06 | 391d? |  | finish no earlier than 2007-11-30 | S1 | 3128h | 3128h | PRIOR-EMR |  | Telcordia | jgarraha@telcordia.com | Rel-8 | SP-32 | Alain | 22.153 |  |
| 502 | 143.2 | Stage 3 for PRIOR |  | 726d? | 2006-12-01 A | 2009-09-11 | 50% | 363d? | 2006-12-01 | 2009-09-11 | 726d? | 260d | finish no earlier than 2009-09-11 | C1 | 5808h | 2904h | PRIOR |  | Alcatel-Lucent | Keith Drage (drage@alcatel-lucent.com) | Rel-8 | CP-34 | Frederic | 24.229 |  |
| 503 | 143.3 | Deleted - Stage 3 for PRIOR |  | 441d? | 2007-09-21 A | 2009-05-29 A | 100% |  | 2007-09-21 | 2009-05-29 | 441d? |  | finish no earlier than 2009-05-29 | C3 | 3528h | 3528h | PRIOR |  | Alcatel-Lucent | Keith Drage (drage@alcatel-lucent.com) | Rel-8 | CP-37 | Gwiho | 29.212, 29.213, 29.214, 29.163 | CP-44 |
| 504 | 143.4 | Stage 3 for PRIOR |  | 381d? | 2007-09-21 A | 2009-03-06 A | 100% |  | 2007-09-21 | 2009-03-06 | 381d? |  | finish no earlier than 2009-03-06 | C4 | 3048h | 3048h | PRIOR |  | Alcatel-Lucent | Keith Drage (drage@alcatel-lucent.com) | Rel-8 | CP-37 | Kimmo | 23.008, 29.228, 29.229 |  |
| 505 | 144 | **OSA Rel-8** |  | 202d? | 2007-08-23 A | 2008-05-30 A | 100% |  | 2007-08-23 | 2008-05-30 | 202d? |  |  | S1,C5 | 23552h | 23552h | OSA8 |  | Orange | Song Dong | Rel-8 |  | Alain |  |  |
| 506 | 144.1 | OSA Stage 1 - Service Requirements |  | 145d? | 2007-08-23 A | 2008-03-12 A | 100% |  | 2007-08-23 | 2008-03-12 | 145d? |  | finish no earlier than 2007-12-04 | S1 | 1160h | 1160h | OSA8 |  | Orange, AePONA | Song Dong | Rel-8 |  | Alain | 22.127 |  |
| 507 | 144.2 | OSA Stage 1 - NGN Service Requirement |  | 140d? | 2007-09-03 A | 2008-03-14 A | 100% |  | 2007-09-03 | 2008-03-14 | 140d? |  | finish no earlier than 2008-03-14 | S1 | 1120h | 1120h | OSA8-IMS |  | Orange | Song Dong | Rel-8 | SP-37 | Alain | 22.127 |  |

Notes:
- 484: CT#43 completed (ICE Graphics not included in Rel-8)
- 485: SA#39 Stage 1 completed
- 486: CT#43 completed (ICE Graphics not in Rel-8 / not explicitly in SA1 WID either). CT#42 Rel-8 exception to 03/09 (add ICE Graphics as per SA1 request)
- 487: SA#39 Stage 1 completed
- 488: SA#40 SA2 exception to Sep 2008 (Forking, Early session model)
- 490: SA#38 completed
- 491: CT#42 completed. CT#41 WID updated CP-080074=>CP-080496.
- 492: CT#44: sent LS to ITU-T (CP-090501) request to specify explicit parameter for CAT signalling and APM container for 3GPP to define the contents. CT3 CRs at CT#45. Triggered by Study UID_360031 (FS_CAT_VVC_CS) TR 29.882
- 493: CT#43 completed. CT#42 Rel-8 exception to 03/09. Triggered by Study UID_360031 (FS_CAT_VVC_CS) TR 29.882.
- 494: Triggered by Study UID_360031 (FS_CAT_VVC_CS) TR 29.882. CT#42 completed
- 495: CT#43 completed. SA#39 Stage 2 completed
- 496: SA#35 completed
- 497: SA#39 completed
- 498: CT#43 completed
- 499: CT#42 completed. WID updated CP-080391=>CP-080575=>CP-080773
- 500: CP#44 exception to 09/09. Define split between Rel-8 and Rel-9 at CP#45 (Reason: delay of IETF dependency). SA#38 Stage 1 completed. No Stage 2 identified
- 501: SA#38 completed
- 502: CP#44: define split between Rel-8 and Rel-9 at CP#45 (Reason: delay of IETF dependency)
- 503: CP#44 closed (Reason: No Rel-8 solution expected (LS sent to SA2, but not prioritized in SA2)
- 504: CT#43 completed
- 505: TSG#40 completed. New OSA work in OMA. SA1 need to remove unfulfilled Requirements to align with CT5 Stage 2/3 reality.
- 506: TSG#40 New OSA work in OMA. SA1 to remove non-fulfilled Requirements.
- 507: TSG#40 New OSA work in OMA. SA1 to remove non-fulfilled Requirements.

| ID | WBS | Task | Duration | Start | Finish | Complete | Baseline start | Baseline finish | Baseline duration | Constraint | Resources | Work | Actual work | Text1 | Text3 | Text4 | Text5 | Text6 | Text8 | Text2 | Text7 | Text9 | Text12 |
| --- | --- | --- | --- | --- | --- | --- | --- | --- | --- | --- | --- | --- | --- | --- | --- | --- | --- | --- | --- | --- | --- | --- | --- |
| 508 | 144.3 | **OSA Stage 2/3 enhancements** | 157d? | 2007-10-25 A | 2008-05-30 A | 100% | 2007-10-25 | 2008-05-30 | 157d? |  | C5 | 20016h | 20016h | OSA8 | 23.198, 29.198, 29.199 | Alcatel-Lucent | unmehopa@alcatel-lucent.com | Rel-8 | Kimmo |  |  |  |  |
| 509 | 144.3.1 | Delete - Ensure Parlay-X composable with identity management frameworks, in particular Liberty Alliance | 157d? | 2007-10-25 A | 2008-05-30 A | 100% | 2007-10-25 | 2008-05-30 | 157d? | finish no earlier than 2008-12-25 | C5 | 1256h | 1256h | OSA8 | existing 29.199-xy | Ericsson, FT/Orange, Sprint, Telecom Italia | catherine.mulligan@ericsson.com | Rel-8 | Kimmo | PCG-21 | CP-37 | PCG-21 | CP-40 |
| 510 | 144.3.2 | Parlay-X Content Management web service (store/manage meta-data) | 157d? | 2007-10-25 A | 2008-05-30 A | 100% | 2007-10-25 | 2008-05-30 | 157d? | finish no earlier than 2008-12-04 | C5 | 1256h | 1256h | OSA8 | 29.199-21 | Alcatel-Lucent | unmehopa@alcatel-lucent.com | Rel-8 | Kimmo |  | CP-37 |  |  |
| 511 | 144.3.3 | Parlay-X Policy web service | 157d? | 2007-10-25 A | 2008-05-30 A | 100% | 2007-10-25 | 2008-05-30 | 157d? | finish no earlier than 2008-12-04 | C5 | 1256h | 1256h | OSA8 | 29.199-22 | Alcatel-Lucent | unmehopa@alcatel-lucent.com | Rel-8 | Kimmo |  | CP-37 |  |  |
| 512 | 144.3.4 | Parlay-X Terminal status web service | 157d? | 2007-10-25 A | 2008-05-30 A | 100% | 2007-10-25 | 2008-05-30 | 157d? | finish no earlier than 2008-05-30 | C5 | 1256h | 1256h | OSA8 | 29.199-08 | Alcatel-Lucent | unmehopa@alcatel-lucent.com | Rel-8 | Kimmo |  | CP-37 |  |  |
| 513 | 144.3.5 | Delete - Identify communication format used by a particular application | 157d? | 2007-10-25 A | 2008-05-30 A | 100% | 2007-10-25 | 2008-05-30 | 157d? | finish no earlier than 2008-05-30 | C5 | 1256h | 1256h | OSA8 | existing 29.199-xy | Ericsson | catherine.mulligan@ericsson.com | Rel-8 | Kimmo | PCG-21 | CP-37 | PCG-21 | CP-40 |
| 514 | 144.3.6 | Delete - Security on User Profile Management - reuse GUP API (22.127 CR 0084 S1-071794) | 128d? | 2007-12-05 A | 2008-05-30 A | 100% | 2007-12-05 | 2008-05-30 | 128d? | finish no earlier than 2008-12-25 | C5 | 1024h | 1024h | OSA8 | PXWS Framework | Telecom Italia | vincenzo.amorino@telecomitalia.it | Rel-8 | Kimmo | PCG-21 | CP-38 | PCG-21 | CP-40 |
| 515 | 144.3.7 | Delete - Privacy on Subscriber Identity (Liberty Alliance, OASIS) (22.127 CR 0085 S1-071835) | 128d? | 2007-12-05 A | 2008-05-30 A | 100% | 2007-12-05 | 2008-05-30 | 128d? | finish no earlier than 2008-12-25 | C5 | 1024h | 1024h | OSA8 | PXWS Framework | Telecom Italia | vincenzo.amorino@telecomitalia.it | Rel-8 | Kimmo | PCG-21 | CP-38 | PCG-21 | CP-40 |
| 516 | 144.3.8 | Delete - Topology Hiding (22.127 CR 0086 S1-071838) | 128d? | 2007-12-05 A | 2008-05-30 A | 100% | 2007-12-05 | 2008-05-30 | 128d? | finish no earlier than 2008-12-25 | C5 | 1024h | 1024h | OSA8 | PXWS Framework | Telecom Italia | vincenzo.amorino@telecomitalia.it | Rel-8 | Kimmo | PCG-21 | CP-38 | PCG-21 | CP-40 |
| 517 | 144.3.9 | Delete - Subscriber event notification (22.127 CR 0087 S1-071836) | 128d? | 2007-12-05 A | 2008-05-30 A | 100% | 2007-12-05 | 2008-05-30 | 128d? | finish no earlier than 2008-12-25 | C5 | 1024h | 1024h | OSA8 | PXWS Framework | Telecom Italia | vincenzo.amorino@telecomitalia.it | Rel-8 | Kimmo | PCG-21 | CP-38 | PCG-21 | CP-40 |
| 518 | 144.3.10 | Delete - Event notification (22.127 CR 0088 S1-071762) | 128d? | 2007-12-05 A | 2008-05-30 A | 100% | 2007-12-05 | 2008-05-30 | 128d? | finish no earlier than 2008-12-25 | C5 | 1024h | 1024h | OSA8 | PXWS Framework | Telecom Italia | vincenzo.amorino@telecomitalia.it | Rel-8 | Kimmo | PCG-21 | CP-38 | PCG-21 | CP-40 |
| 519 | 144.3.11 | Delete - Access policy (22.127 CR 0089 S1-071763) | 128d? | 2007-12-05 A | 2008-05-30 A | 100% | 2007-12-05 | 2008-05-30 | 128d? | finish no earlier than 2008-12-25 | C5 | 1024h | 1024h | OSA8 | PXWS Framework | Telecom Italia | vincenzo.amorino@telecomitalia.it | Rel-8 | Kimmo | PCG-21 | CP-38 | PCG-21 | CP-40 |
| 520 | 144.3.12 | Delete - API usage accounting (22.127 CR 0090 S1-071792) | 128d? | 2007-12-05 A | 2008-05-30 A | 100% | 2007-12-05 | 2008-05-30 | 128d? | finish no earlier than 2008-12-25 | C5 | 1024h | 1024h | OSA8 | PXWS Framework | Telecom Italia | vincenzo.amorino@telecomitalia.it | Rel-8 | Kimmo | PCG-21 | CP-38 | PCG-21 | CP-40 |
| 521 | 144.3.13 | Presence alignment with OMA and IETF (22.127 CR 0092 S1-071764) | 128d? | 2007-12-05 A | 2008-05-30 A | 100% | 2007-12-05 | 2008-05-30 | 128d? | finish no earlier than 2008-05-30 | C5 | 1024h | 1024h | OSA8 | 29.199-14/13 | Alcatel-Lucent | unmehopa@alcatel-lucent.com | Rel-8 | Kimmo | PCG-21 | CP-38 |  |  |
| 522 | 144.3.14 | Delete - Service identification (22.127 CR 0095 S1-071837) | 128d? | 2007-12-05 A | 2008-05-30 A | 100% | 2007-12-05 | 2008-05-30 | 128d? | finish no earlier than 2008-05-30 | C5 | 1024h | 1024h | OSA8 | existing 29.199-xy | Ericsson | catherine.mulligan@ericsson.com | Rel-8 | Kimmo | PCG-21 | CP-38 | PCG-21 | CP-40 |
| 523 | 144.3.15 | Framework Enterprise Operator (Service Subscription function) | 102d? | 2008-01-10 A | 2008-05-30 A | 100% | 2008-01-10 | 2008-05-30 | 102d? | finish no earlier than 2008-05-30 | C5 | 816h | 816h | OSA8 | 29.198-03 | Alcatel-Lucent | unmehopa@alcatel-lucent.com | Rel-8 | Kimmo | PCG-21 | CP-39 |  |  |
| 524 | 144.3.16 | Mobility Emergency Location | 102d? | 2008-01-10 A | 2008-05-30 A | 100% | 2008-01-10 | 2008-05-30 | 102d? | finish no earlier than 2008-05-30 | C5 | 816h | 816h | OSA8 | 29.198-06 | Alcatel-Lucent | unmehopa@alcatel-lucent.com | Rel-8 | Kimmo | PCG-21 | CP-39 |  |  |
| 525 | 144.3.17 | Connectivity Manager SCF | 102d? | 2008-01-10 A | 2008-05-30 A | 100% | 2008-01-10 | 2008-05-30 | 102d? |  | C5 | 816h | 816h | OSA8 | 29.198-10 | Alcatel-Lucent | unmehopa@alcatel-lucent.com | Rel-8 | Kimmo | PCG-21 | CP-39 |  |  |
| 526 | 144.3.18 | PAM Presence Agent | 102d? | 2008-01-10 A | 2008-05-30 A | 100% | 2008-01-10 | 2008-05-30 | 102d? | finish no earlier than 2008-05-30 | C5 | 816h | 816h | OSA8 | 29.198-14 | Alcatel-Lucent | unmehopa@alcatel-lucent.com | Rel-8 | Kimmo | PCG-21 | CP-39 |  |  |
| 527 | 145 | **Paging Permission with Access Control (PPACR)** | 389d? | 2007-06-12 A | 2008-12-05 A | 100% | 2007-06-12 | 2008-12-05 | 389d? |  | S1,C1 | 5888h | 5888h | PPACR |  | NTT DoCoMo | Morita Takashi | Rel-8 | Alain |  |  |  |  |
| 528 | 145.1 | Stage 1 for PPACR | 69d? | 2007-06-12 A | 2007-09-14 A | 100% | 2007-06-12 | 2007-09-14 | 69d? | finish no earlier than 2007-09-14 | S1 | 552h | 552h | PPACR-S1 | 22.011 | NTT DoCoMo | Morita Takashi | Rel-8 | Alain |  | SP-37 |  |  |
| 529 | 145.2 | Stage 3 for PPACR (CT1) | 278d? | 2007-11-14 A | 2008-12-05 A | 100% | 2007-11-14 | 2008-12-05 | 278d? | finish no earlier than 2008-12-05 | C1 | 2224h | 2224h | PPACR-CT1 | 24.008, 23.122, 24.301 | NTT DoCoMo |  | Rel-8 | Frederic | PCG-21 | CP-38 |  |  |
| 530 | 146 | **Charging for multi-phases services** | 70d? | 2007-12-06 A | 2008-03-12 A | 100% | 2007-12-06 | 2008-03-12 | 70d? |  | S1 | 560h | 560h | CHRGMPH | 22.115 | Telecom Italia | Marco.DeLuca1@telecomitalia.it | Rel-8 | Alain | PCG-21 | SP-38 |  |  |
| 531 | 146.1 | Stage 1 for CHRGMPH | 70d? | 2007-12-06 A | 2008-03-12 A | 100% | 2007-12-06 | 2008-03-12 | 70d? | start no earlier than 2007-12-06 | S1 | 560h | 560h | CHRGMPH-s1 | 22.115 | Telecom Italia | Marco.DeLuca1@telecomitalia.it | Rel-8 | Alain | PCG-21 | SP-38 |  |  |

Notes:
- 508: CT#40 WID updated CP-070349=>CP-080252. Started work completed. Unfulfilled Rel-8 Stage 1 and New OSA work to be done in OMA. SA1 needs to remove non-fulfilled requirements in 22.127
- 509: CT#40: Work moved to OMA
- 510: CT#40 completed
- 511: CT#40 completed
- 512: CT#40 completed
- 513: CT#40: Work moved to OMA
- 514: SA#38 SP-070853 R8 CRs 22.127 OSA Stage 1. CT#40: Work moved to OMA
- 515: SA#38 SP-070853 R8 CRs 22.127 OSA Stage 1. CT#40: Work moved to OMA
- 516: SA#38 SP-070853 R8 CRs 22.127 OSA Stage 1. CT#40: Work moved to OMA
- 517: SA#38 SP-070853 R8 CRs 22.127 OSA Stage 1. CT#40: Work moved to OMA
- 518: SA#38 SP-070853 R8 CRs 22.127 OSA Stage 1. CT#40: Work moved to OMA
- 519: SA#38 SP-070853 R8 CRs 22.127 OSA Stage 1. CT#40: Work moved to OMA
- 520: SA#38 SP-070853 R8 CRs 22.127 OSA Stage 1. CT#40: Work moved to OMA
- 521: CT#40 completed
- 522: SA#38 SP-070853 R8 CRs 22.127 OSA Stage 1. CT#40: Work moved to OMA
- 523: CT#40 completed
- 524: CT#40 completed
- 525: CT#40 completed
- 526: CT#40 completed
- 527: CT#42 completed. Triggered by Study UID_330016 (PPAC).
- 528: SA#37 completed
- 529: CT#42 completed
- 530: SA#39 Stage 1 completed
- 531: SA#39 completed

| ID | WBS | Task | Duration | Start | Finish | Complete | Remaining | Baseline start | Baseline finish | Baseline duration | Total slack | Constraint | Resources | Work | Actual work | Text1 | Text2 | Text4 | Text6 | Text7 | Text8 | Text11 |
| --- | --- | --- | --- | --- | --- | --- | --- | --- | --- | --- | --- | --- | --- | --- | --- | --- | --- | --- | --- | --- | --- | --- |
| 532 | 147 | **Home NodeB / eNodeB** | 327d? | 2007-12-06 A | 2009-03-06 A | 100% |  | 2007-12-06 | 2009-03-06 | 327d? |  |  | S1,C1,C4 | 5720h | 5720h | HomeNB | PCG-21 | Vodafone | Rel-8 | SP-38 | Alain |  |
| 533 | 147.1 | Stage 1 for HNB_eHNB | 70d? | 2007-12-06 A | 2008-03-12 A | 100% |  | 2007-12-06 | 2008-03-12 | 70d? |  | start no earlier than 2007-12-06 | S1 | 560h | 560h | HomeNB-S1 | PCG-21 | Vodafone | Rel-8 | SP-38 | Alain |  |
| 534 | 147.2 | CSG and Idle Mode Mobility for LTE Home eNodeB | 126d? | 2008-09-12 A | 2009-03-06 A | 100% |  | 2008-09-12 | 2009-03-06 | 126d? |  | finish no earlier than 2009-03-06 | C1 | 1008h | 1008h | HomeNB-LTE | PCG-21 | Huawei | Rel-8 | CP-41 | Frederic |  |
| 535 | 147.3 | CSG and Idle Mode Mobility for 3G Home NodeB | 126d? | 2008-09-12 A | 2009-03-06 A | 100% |  | 2008-09-12 | 2009-03-06 | 126d? |  | finish no earlier than 2009-03-06 | C1 | 1008h | 1008h | HomeNB-3G | PCG-21 | Qualcomm | Rel-8 | CP-41 | Frederic |  |
| 536 | 147.4 | Support of Closed Subscriber Group (CSG) | 66d? | 2008-12-05 A | 2009-03-06 A | 100% |  | 2008-12-05 | 2009-03-06 | 66d? |  | finish no earlier than 2009-03-06 | C4 | 528h | 528h | HomeNB | PCG-22 | CT#42 | Rel-8 | CP-42 | Kimmo | CT#42 report |
| 537 | 148 | **UTRA HNB** | 326d? | 2008-03-07 A | 2009-06-04 A | 100% |  | 2008-03-07 | 2009-06-04 | 326d? |  |  | RP,S5 | 6832h | 6832h | HNB | PCG-21 |  | Rel-8 | SP-39 | Stefania |  |
| 538 | 148.1 | Support of UTRA HNB | 201d? | 2008-05-30 A | 2009-03-06 A | 100% |  | 2008-05-30 | 2009-03-06 | 201d? |  | finish no earlier than 2009-03-06 | R2 | 1608h | 1608h | HNB-supp | PCG-21 | Huawei | Rel-8 | SP-40 | Joern | RP-090040 |
| 539 | 148.2 | FDD Home NodeB RF requirements | 261d? | 2008-03-07 A | 2009-03-06 A | 100% |  | 2008-03-07 | 2009-03-06 | 261d? |  | finish no earlier than 2009-03-06 | R4 | 2088h | 2088h | HNB-RF | PCG-21 | Motorola | Rel-8 | SP-39 | Stefania | RP-090041 |
| 540 | 148.3 | UTRAN Architecture for 3G HNB | 136d? | 2008-05-30 A | 2008-12-05 A | 100% |  | 2008-05-30 | 2008-12-05 | 136d? |  | finish no earlier than 2008-12-05 | R3 | 1088h | 1088h | HNB-arch | PCG-21 | Alcatel-Lucent | Rel-8 | SP-40 | Juha | RP-090042 |
| 541 | 148.4 | 3G Home NodeB OAM&P Type 1 Management Interface | 127d? | 2008-12-11 A | 2009-06-04 A | 100% |  | 2008-12-11 | 2009-06-04 | 127d? |  | finish no earlier than 2009-06-04 | S5 | 1008h | 1008h | HNB-3G_OAM | PCG-22 | Huawei | Rel-8 | SP-42 | Dionisio |  |
| 542 | 149 | **UTRA HNB – UE Conformance Testing** | 197d? | 2009-03-06 A | 2009-12-04 | 5% | 187.15d? | 2009-03-06 | 2009-12-04 | 197d? | 200d |  | R5 | 3144h | 157.2h | HNB-UEConTest | PCG-22 |  | Rel-8 | RP-43 | Ingbert |  |
| 543 | 149.1 | Conformance Test Aspects – UTRA HNB (FDD) | 196d? | 2009-03-06 A | 2009-12-04 | 5% | 186.2d? | 2009-03-06 | 2009-12-04 | 196d? | 200d | finish no earlier than 2009-12-04 | R5 | 1568h | 78.4h | HNB-UEConTestFDD | PCG-22 | Huawei | Rel-8 | RP-43 | Ingbert | RP-090420 |
| 544 | 150 | Lawful Interception in the 3GPP Rel-8 | 524d? | 2007-03-12 A | 2009-03-12 A | 100% |  | 2007-03-12 | 2009-03-12 | 524d? |  | finish no earlier than 2009-03-12 | S3 | 4192h | 4192h | LI8 |  | BMWI, Verizon | Rel-8 |  | Dionisio |  |
| 545 | 151 | **Generic Bootstrapping Architecture Push Function** | 258d? | 2008-03-12 A | 2009-03-06 A | 100% |  | 2008-03-12 | 2009-03-06 | 258d? |  |  | S3,C1,C4 | 6468.8h | 6468.8h | GBAPush | PCG-21 | Ericsson | Rel-8 | SP-39 | Dionisio |  |
| 546 | 151.1 | SA3 part of GBAPush (33.223) | 193d? | 2008-03-12 A | 2008-12-05 A | 100% |  | 2008-03-12 | 2008-12-05 | 193d? |  | finish no earlier than 2008-12-05 | S3 | 1544h | 1544h | GBAPush | PCG-21 | Ericsson | Rel-8 | SP-39 | Dionisio |  |
| 547 | 151.2 | CT1 part of GBAPush | 178.8d? | 2008-03-12 A | 2009-03-06 A | 100% |  | 2008-03-12 | 2009-03-06 | 178.8d? |  | finish no earlier than 2009-03-06 | C1 | 1430.4h | 1430.4h | GBAPush | PCG-21 | Ericsson | Rel-8 | SP-39 | Frederic |  |
| 548 | 151.3 | CT4 part of GBAPush | 178.8d? | 2008-03-12 A | 2009-03-06 A | 100% |  | 2008-03-12 | 2009-03-06 | 178.8d? |  | finish no earlier than 2009-03-06 | C4 | 1430.4h | 1430.4h | GBAPush | PCG-21 | Ericsson | Rel-8 | SP-39 | Kimmo |  |
| 549 | 152 | Requirements and Test methods for Wideband Terminals | 197d? | 2008-03-12 A | 2008-12-11 A | 100% |  | 2008-03-12 | 2008-12-11 | 197d? |  | start no earlier than 2008-03-12 | S4 | 1576h | 1576h | RETEM_WB_T |  | FT, Ericsson | Rel-8 |  | Paolo |  |
| 550 | 153 | Extending PSS and MBMS User Services for optimized Mobile TV | 266d? | 2007-12-06 A | 2008-12-11 A | 100% |  | 2007-12-06 | 2008-12-11 | 266d? |  | finish no earlier than 2008-12-11 | S4 | 2128h | 2128h | PSS_MBMS_OMTV |  | Ericsson | Rel-8 |  | Paolo |  |
| 551 | 154 | **Encoding formats, transport formats and media description signalling for interworking, QoE, and other enhancements to MTSI-MHI** | 331d? | 2007-12-06 A | 2009-03-12 A | 100% |  | 2007-12-06 | 2009-03-12 | 331d? |  |  | S4,C3,C1,C4 | 9640h | 9640h | MTSI_eMHI | PCG-21 | Ericsson, Qualcomm | Rel-8 | SP-40 | Paolo |  |
| 552 | 154.1 | MTSI Video - Dynamic Rate Adaptation/Signalling of Image Size | 331d? | 2007-12-06 A | 2009-03-12 A | 100% |  | 2007-12-06 | 2009-03-12 | 331d? |  | finish no earlier than 2009-03-12 | S4 | 2648h | 2648h | MTSI_eMHI-DRASIS |  | Qualcomm, Samsung | Rel-8 |  | Paolo |  |
| 553 | 154.2 | CT3 part of Enhancement of interworking between MTSI and CS networks | 201d? | 2008-05-30 A | 2009-03-06 A | 100% |  | 2008-05-30 | 2009-03-06 | 201d? |  | finish no earlier than 2009-03-06 | C3 | 1608h | 1608h | MTSI_eMHI | PCG-21 | Huawei | Rel-8 | CP-40 | Gwiho |  |
| 554 | 154.3 | CT1 part of Enhancement of interworking between MTSI and CS networks | 141d? | 2008-05-30 A | 2008-12-12 A | 100% |  | 2008-05-30 | 2008-12-12 | 141d? |  | start no earlier than 2008-05-30 | C1 | 1128h | 1128h | MTSI_eMHI | PCG-21 | Huawei | Rel-8 | CP-40 | Frederic |  |
| 555 | 154.4 | CT4 part of Enhancement of interworking between MTSI and CS networks | 201d? | 2008-05-30 A | 2009-03-06 A | 100% |  | 2008-05-30 | 2009-03-06 | 201d? |  | finish no earlier than 2009-03-06 | C4 | 1608h | 1608h | MTSI_eMHI | PCG-21 | Huawei | Rel-8 | CP-40 | Kimmo |  |

Notes:
- 532: CT#43 completed. SA#39 Stage 1 completed / Text5: John Watson
- 533: SA#39 completed / Text3: 22.011, 22.115 / Text5: John Watson
- 534: CT#43 completed. CT#42 Rel-8 exception to 03/09 / Text3: 23.122, 24.301, 24.801, 24.285 / Text5: zhang.peng@huawei.com
- 535: CT#43 completed. CT#42 Rel-8 exception to 03/09 / Text3: 23.122, 24.008, 24.285 / Text5: Osok Song
- 536: CT#43 completed. CT#42 Rel-8 exception to 03/09. SA#42 SP-080874 22.011CR0141 confirmed Requirement to support roaming subscribers with CSG home network subscription but did NOT confirmed requirement for home network independent support of roamers in CSG / Text3: 29.002, 29.272, 23.008, 23.003 / Text5: Hannu Hietalahti
- 537: RP#43 completed. SA#43 Rel-8 further exception SA5 to 06/09.
- 538: RP#43 completed. RP#42 Rel-8 exception to 03/09. RP#41 WID updated RP-080483=>RP-080752. / Text3: 25.304, 25.306, 25.331, 25.367 / Text5: Yang Xudong (yangxudong@huawei.com)
- 539: RP#43 completed. RP#42 Rel-8 exception to 03/09 / Text3: 25.104, 25.141, 25.967 / Text5: Ying Cai (yingcai@motorola.com)
- 540: RP#42 completed / Text3: 25.401, 25.410, 25.412, 25.413, 25.414, 25.415, 25.467, 25.468, 25.469 / Text5: Martin Warner (mw15@alcatel-lucent.com)
- 541: SA#44 completed. Complements work in BroadBand Forum / Text3: 32.581, 32.582, 32.583, 32.584 / Text5: Zou Lan (zlan@huawei.com)
- 542: testing for Feature UID_390033 UTRA HNB
- 543: testing for Feature UID_390033 UTRA HNB / Text3: 34.108, 34.123-1, 34.123-2, 34.123-3 / Text5: Trica Li (trica_li@huawei.com)
- 544: SA#43 completed. SA#42 exception 12/08=>03/09. SA#40/41 each 3-months exceptions granted / Text3: 33.106, 33.107, 33.108 / Text5: berthold.wilhelm@bnetza.de, ron_ryan@verizon.net
- 545: CT#43 completed / Text5: Rolf Blom
- 546: SA#42 completed 33.223 as Rel-8. TS 33.224 moved to Rel-9 under new UID_420039 / Text3: 33.223 / Text5: Rolf Blom
- 547: CT#43 completed. WID updated SP-080133=>CP-090112. CT#42 Rel-8 exception to 03/09 / Text3: 24.109 / Text5: Rolf Blom
- 548: CT#43 completed. WID updated SP-080133=>CP-090112. CT#42 Rel-8 exception to 03/09 / Text3: 29.109 / Text5: Rolf Blom
- 549: SA#42 completed. SA#39 WID approved. / Text3: 26.131, 26.132 / Text5: stephane.ragot@orange-ftgroup.com, wanqing.shi@sonyericsson.com
- 550: SA#42 completed. SA#38 WID approved. / Text3: 26.234, 26.346, 26.946 / Text5: thorsten.lohmar@ericsson.com
- 551: TSG#43 completed. TSG#42 Rel-8 exception to 03/09 / Text5: olle.franceschi@ericsson.com, nleung@qualcomm.com
- 552: SA#43 completed. SA#42 Rel-8 exception to 03/09. SA#40 WID updated SP-070755=>SP-080246. [Feature=>BB under new Feature UID_400028 (MTSI)] / Text3: 26.114 / Text5: nleung@qualcomm.com & kyunghun.jung@samsung.com
- 553: CT#43 completed. CT#42 Rel-8 exception to 03/09 / Text3: 29.163 / Text5: Tingfang Tang (tagna_online@huawei.com)
- 554: CT#42 completed (No CT1-impact). WID updated CP-080422=>CP-080774 / Text5: Tingfang Tang (tagna_online@huawei.com)
- 555: CT#43 completed. CT#42 Rel-8 exception to 03/09 / Text3: 29.332 / Text5: Tingfang Tang (tagna_online@huawei.com)

| ID | WBS | Task | Duration | Start | Finish | Complete | Baseline start | Baseline finish | Baseline duration | Constraint | Resources | Work | Actual work | Text1 | Text6 | Text8 | Text4 | Text5 | Text7 | Text9 | Text12 | Text2 |
| --- | --- | --- | --- | --- | --- | --- | --- | --- | --- | --- | --- | --- | --- | --- | --- | --- | --- | --- | --- | --- | --- | --- |
| 556 | 155 | **OAM&P 8** | 461d? | 2007-06-07 A | 2009-03-12 A | 100% | 2007-06-07 | 2009-03-12 | 461d? |  | S5,C1 | 39739.2h | 39739.2h | OAM8 | Rel-8 | Dionisio |  |  |  |  |  |  |
| 557 | 155.1 | **Network Infrastructure Management** | 461d? | 2007-06-07 A | 2009-03-12 A | 100% | 2007-06-07 | 2009-03-12 | 461d? |  | S5 | 17512h | 17512h | OAM8-NIM | Rel-8 | Dionisio |  |  |  |  |  |  |
| 558 | 155.1.1 | Telecom Management Methodology | 461d? | 2007-06-07 A | 2009-03-12 A | 100% | 2007-06-07 | 2009-03-12 | 461d? | finish no earlier than 2009-03-12 | S5 | 3688h | 3688h | OAM8 | Rel-8 | Dionisio | Ericsson | thomas.tovinger@ericsson.com |  |  |  |  |
| 559 | 155.1.2 | Advanced Alarming on Itf-N | 266d? | 2007-06-07 A | 2008-06-12 A | 100% | 2007-06-07 | 2008-06-12 | 266d? | finish no earlier than 2008-12-11 | S5 | 2128h | 2128h | OAM8 | Rel-8 | Dionisio | Nokia Siemens Networks | SUERBAUM, Clemens |  |  |  |  |
| 560 | 155.1.3 | CN CS Bearer Transport Network (BTN) relative NRM | 266d? | 2007-06-07 A | 2008-06-12 A | 100% | 2007-06-07 | 2008-06-12 | 266d? | finish no earlier than 2008-12-11 | S5 | 2128h | 2128h | OAM8 | Rel-8 | Dionisio | China Mobile | LI, Jian |  |  |  |  |
| 561 | 155.1.4 | Deleted - End point modelling for reference point | 324d? | 2007-09-17 A | 2008-12-11 A | 100% | 2007-09-17 | 2008-12-11 | 324d? | finish no earlier than 2008-12-11 | S5 | 2592h | 2592h | OAM8 | Rel-8 | Dionisio | Motorola | YAO, Yizhi | SP-37 | PCG-21 | SP-41 |  |
| 562 | 155.1.5 | Alignment with eTOM and M.3060 architectural concepts | 210d? | 2008-02-22 A | 2008-12-11 A | 100% | 2008-02-22 | 2008-12-11 | 210d? | start no earlier than 2008-02-22 | S5 | 1680h | 1680h | OAM8 | Rel-8 | Dionisio | TeliaSonera | Berggren, Tommy | SP-39 |  |  | PCG-21 |
| 563 | 155.1.6 | IRP SOAP Solution Sets | 201d? | 2008-06-05 A | 2009-03-12 A | 100% | 2008-06-05 | 2009-03-12 | 201d? | finish no earlier than 2009-03-12 | S5 | 1608h | 1608h | OAM8 | Rel-8 | Dionisio | Ericsson | edwin.tse@ericsson.com | SP-40 |  |  | PCG-21 |
| 564 | 155.2 | **Performance Management** | 461d? | 2007-06-07 A | 2009-03-12 A | 100% | 2007-06-07 | 2009-03-12 | 461d? |  | S5 | 13712h | 13712h | OAM8-PM | Rel-8 | Dionisio |  |  |  |  |  |  |
| 565 | 155.2.1 | IP bearer network Performance measurement definitions | 396d? | 2007-06-07 A | 2008-12-11 A | 100% | 2007-06-07 | 2008-12-11 | 396d? | finish no earlier than 2008-12-11 | S5 | 3168h | 3168h | OAM8 | Rel-8 | Dionisio | China Mobile | lilianyuan@chinamobile.com |  |  |  |  |
| 566 | 155.2.2 | HSUPA performance measurements | 396d? | 2007-06-07 A | 2008-12-11 A | 100% | 2007-06-07 | 2008-12-11 | 396d? | finish no earlier than 2008-12-11 | S5 | 3168h | 3168h | OAM8 | Rel-8 | Dionisio | China Mobile | LI, Jian |  |  |  |  |
| 567 | 155.2.3 | Key Performance Indicators (KPIs) for UMTS and GSM | 461d? | 2007-06-07 A | 2009-03-12 A | 100% | 2007-06-07 | 2009-03-12 | 461d? | finish no earlier than 2009-03-12 | S5 | 3688h | 3688h | OAM8 | Rel-8 | Dionisio | China Mobile | Liang Shuangchun |  |  |  |  |
| 568 | 155.3 | **Trace Management** | 196d? | 2008-03-07 A | 2008-12-05 A | 100% | 2008-03-07 | 2008-12-05 | 196d? |  | S5,C1,C3,C4 | 5777.6h | 5777.6h | OAM8-Trace | Rel-8 | Dionisio |  |  |  |  |  |  |
| 569 | 155.3.1 | Service Level Tracing in IMS | 196d? | 2008-03-07 A | 2008-12-05 A | 100% | 2008-03-07 | 2008-12-05 | 196d? | finish no earlier than 2008-12-05 | C1 | 1568h | 1568h | OAM8-Trace | Rel-8 | Frederic | Vodafone | peter.dawes@vodafone.com |  |  |  |  |
| 570 | 155.3.2 | Service Level Tracing in IMS | 175.4d? | 2008-03-07 A | 2008-12-05 A | 100% | 2008-03-07 | 2008-12-05 | 175.4d? | finish no earlier than 2008-12-05 | C3 | 1403.2h | 1403.2h | OAM8-Trace | Rel-8 | Gwiho | Vodafone | peter.dawes@vodafone.com | CP-40 |  |  | PCG-21 |
| 571 | 155.3.3 | Service Level Tracing in IMS | 175.4d? | 2008-03-07 A | 2008-12-05 A | 100% | 2008-03-07 | 2008-12-05 | 175.4d? | finish no earlier than 2008-12-05 | C4 | 1403.2h | 1403.2h | OAM8-Trace | Rel-8 | Frederic | Vodafone | peter.dawes@vodafone.com | CP-40 |  |  | PCG-21 |
| 572 | 156 | **Charging Management small Enhancements** | 716d? | 2006-03-16 A | 2008-12-11 A | 100% | 2006-03-16 | 2008-12-11 | 716d? |  | S5 | 12544h | 12544h | CH8 | Rel-8 | Dionisio |  |  |  |  |  |  |
| 573 | 156.1 | Online charging correlation | 457d? | 2006-03-16 A | 2007-12-14 A | 100% | 2006-03-16 | 2007-12-14 | 457d? | start no earlier than 2006-03-16 | S5 | 3656h | 3656h | CH8 | Rel-8 | Dionisio | Orange | Chahine, Rony |  |  |  |  |
| 574 | 156.2 | SMS online charging | 137d? | 2007-06-07 A | 2007-12-14 A | 100% | 2007-06-07 | 2007-12-14 | 137d? | finish no earlier than 2007-12-14 | S5 | 1096h | 1096h | CH8 | Rel-8 | Dionisio | Vodafone | WONG, Gavin |  |  |  |  |
| 575 | 156.3 | Introduce Online Charging from SMS-SC into the SMS Charging Specifications | 61d? | 2008-09-18 A | 2008-12-11 A | 100% | 2008-09-18 | 2008-12-11 | 61d? | finish no earlier than 2008-12-11 | S5 | 488h | 488h | CH8 | Rel-8 | Dionisio | Acision | Gebler, Erik - Acision [erik.gebler (at) acision.com] | SP-41 |  |  | PCG-21 |
| 576 | 156.4 | Deleted - WLAN Offline Charging | 244d? | 2008-01-07 A | 2008-12-11 A | 100% | 2008-01-07 | 2008-12-11 | 244d? | finish no earlier than 2008-12-11 | S5 | 1952h | 1952h | CH8 | Rel-8 | Dionisio | Alcatel-Lucent | GARDELLA, Maryse | SP-38 | PCG-22 | SP-42 | PCG-21 |
| 577 | 157 | **Conferencing enhancements for Mp interface** | 266d? | 2007-11-30 A | 2008-12-05 A | 100% | 2007-11-30 | 2008-12-05 | 266d? |  | C4 | 6384h | 6384h | eMp | Rel-8 | Kimmo | Huawei | Chencheng@huawei.com |  |  |  | PCG-21 |
| 578 | 157.1 | Stage 2 for eMp | 266d? | 2007-11-30 A | 2008-12-05 A | 100% | 2007-11-30 | 2008-12-05 | 266d? | finish no earlier than 2008-12-11 | C4 | 2128h | 2128h | eMp | Rel-8 | Kimmo | Huawei | Chencheng@huawei.com | CP-38 |  |  | PCG-21 |
| 579 | 157.2 | Stage 3 for eMp | 266d? | 2007-11-30 A | 2008-12-05 A | 100% | 2007-11-30 | 2008-12-05 | 266d? | finish no earlier than 2008-12-05 | C4 | 2128h | 2128h | eMp | Rel-8 | Kimmo | Huawei | Chencheng@huawei.com | CP-38 |  |  | PCG-21 |

Notes:
- 558: SA#43 completed. SA#42 Rel-8 exception to 03/09 / Text3: 32.155, 32.153
- 559: SA#40 completed / Text3: 32.121, 32.122, 32.123
- 560: SA#40 completed / Text3: 32.632/3/5
- 561: SA#41 Work stopped. Contributions related to E-UTRAN/EPC to be submitted to UID_380036 E-UTRAN NRM IRP/ UID_380037 EPC NRM IRP / Text3: 32.152, 32.62/3/4x, 32.73x
- 562: SA#42 completed / Text3: 32.101/2, 32-series
- 563: SA#43 completed. WID updated SP-080276=>SP-090148. SA#42 Rel-8 exception to 03/09 / Text3: 32.111-7, 32.617, 32.417, 32.367, 32.347, 32.111-1, 32.111-2, 32.111-3, 32.111-5, 32.307, 32.317, 32.341, 32.342, 32.343, 32.345, 32.361, 32.362, 32.363, 32.365, 32.411, 32.412, 32.413, 32.415, 32.611, 32.612, 32.613, 32.615, 32.625
- 565: SA#42 completed. SA#36 WID updated SP-050319=>SP-070301 / Text3: 32.321/2/3/5
- 566: SA#42 completed / Text3: 32.405
- 567: SA#43 completed. SA#42 Rel-8 exception to 03/09 / Text3: 32.410
- 569: CT#42 completed. CT#40 WID updated CP-060521=>CP-080315. / Text3: 24.323, 24.229
- 570: CT#42 completed (No CT3-impact). CT#40 WID updated CP-060521=>CP-080315
- 571: CT#42 completed. CT#40 WID updated CP-060521=>CP-080315. / Text3: 29.228, 29.229
- 572: SA#42 completed.
- 573: SA#38 completed / Text3: 32.296
- 574: SA#38 completed / Text3: 32.274, 32.240/299
- 575: SA#42 completed. Linked to SA2 UID 32081 (Support of SMS over IP networks) and CT4 UID 340016 (Routeing of MT-SMS via the HPLMN). / Text3: 32.274, 32.299
- 576: SA#42 stopped / Text3: 32.252, 32.298, 32.299
- 577: CT#42 completed. WID updated CP-070868=>CP-080725
- 578: CT#42 completed. WID updated CP-070868=>CP-080725 / Text3: 23.333
- 579: CT#42 completed. WID updated CP-070868=>CP-080725 / Text3: 29.333

| ID | WBS | Task | Type | Duration | Start | Finish | Complete | Remaining | Baseline start | Baseline finish | Baseline duration | Total slack | Constraint | Resources | Work | Actual work | Text1 | Text4 | Text5 | Text6 | Text8 | Text7 | Text12 | Text2 | Text11 |
| --- | --- | --- | --- | --- | --- | --- | --- | --- | --- | --- | --- | --- | --- | --- | --- | --- | --- | --- | --- | --- | --- | --- | --- | --- | --- |
| 580 | 158 | **Contact Manager for 3GPP UICC applications** |  | 642d? | 2006-06-22 A | 2008-12-05 A | 100% |  | 2006-06-22 | 2008-12-05 | 642d? |  |  | C6 | 13352h | 13352h | eUPHBOOK | Gemalto | Jacques.seif@gemalto.com | Rel-8 | Xavier |  |  |  |  |
| 581 | 158.1 | Requirements for Contact Manager |  | 392d? | 2006-06-22 A | 2007-12-21 A | 100% |  | 2006-06-22 | 2007-12-21 | 392d? |  | finish no earlier than 2007-12-21 | C6 | 3136h | 3136h | eUPHBOOK-St1 | Gemalto | Jacques.seif@gemalto.com | Rel-8 | Xavier |  |  |  |  |
| 582 | 158.2 | External interface for eUPHBOOK |  | 220d? | 2007-05-07 A | 2008-03-07 A | 100% |  | 2007-05-07 | 2008-03-07 | 220d? |  | finish no earlier than 2008-03-07 | C6 | 1760h | 1760h | eUPHBOOK-Ext_Spec | Gemalto | Jacques.seif@gemalto.com | Rel-8 | Xavier |  |  |  |  |
| 583 | 158.3 | Internal interface for eUPHBOOK |  | 415d? | 2007-05-07 A | 2008-12-05 A | 100% |  | 2007-05-07 | 2008-12-05 | 415d? |  | finish no earlier than 2008-12-05 | C6 | 3320h | 3320h | eUPHBOOK-Int_Spec | Gemalto | Jacques.seif@gemalto.com | Rel-8 | Xavier | CP-37 |  |  |  |
| 584 | 158.4 | Deleted - Implementation of eUPHBOOK | milestone | 0d? | 2007-06-21 A | 2007-06-21 A | 100% |  | 2007-06-21 | 2007-06-21 | 0d? |  | start no earlier than 2007-06-21 | C6 |  |  | eUPHBOOK-St23 | Giesecke & Devrient | Claus Dietze | Rel-8 | Xavier |  | SP-33 |  |  |
| 585 | 159 | **Contact Manager Conformance Test specifications** |  | 396d? | 2008-06-02 | 2009-12-04 |  |  | 2008-06-02 | 2009-12-04 | 396d? | 200d |  | C6 | 9504h |  | eUPHBOOK-Test | Comprion, Gemalto | Udo Willenbrink, Jacques Seif | Rel-8 | Xavier | CP-40 |  | PCG-21 |  |
| 586 | 159.1 | Contact Manager for 3GPP UICC applications test specifications |  | 396d? | 2008-06-02 | 2009-12-04 |  |  | 2008-06-02 | 2009-12-04 | 396d? | 200d | finish no earlier than 2009-12-04 | C6 | 3168h |  | eUPHBOOK-Test | Comprion | Udo Willenbrink | Rel-8 | Xavier | CP-40 |  |  |  |
| 587 | 159.2 | Contact Manager API for Java™ Card test specification |  | 396d? | 2008-06-02 | 2009-12-04 |  |  | 2008-06-02 | 2009-12-04 | 396d? | 200d | finish no earlier than 2009-12-04 | C6 | 3168h |  | eUPHBOOK-Test | Gemalto | jacques.seif@gemalto.com | Rel-8 | Xavier | CP-40 |  |  |  |
| 588 | 160 | **Rel-8 LTE – 3G Long Term Evolution - Evolved Packet System RAN part** |  | 644d? | 2006-09-25 A | 2009-03-12 A | 100% |  | 2006-09-25 | 2009-03-12 | 644d? |  |  | RP,S5 | 44896h | 44896h | LTE | NTT DoCoMo | Takehiro Nakamura (nakamurata@nttdocomo.co.jp) | Rel-8 | Stefania |  |  |  | RP-080741 |
| 589 | 160.1 | LTE – Physical Layer |  | 380d? | 2006-09-25 A | 2008-03-07 A | 100% |  | 2006-09-25 | 2008-03-07 | 380d? |  | finish no earlier than 2007-09-14 | R1 | 3040h | 3040h | LTE-Phys | NTT DoCoMo | Sadayuki Abeta | Rel-8 | Patrick |  |  |  | RP-080741 |
| 590 | 160.2 | LTE – Radio Interface Layer 2 and 3 Protocol Aspect |  | 575d? | 2006-09-25 A | 2008-12-05 A | 100% |  | 2006-09-25 | 2008-12-05 | 575d? |  | finish no earlier than 2008-12-11 | R2 | 4600h | 4600h | LTE-L23 | Nokia Siemens Networks | benoist.sebire@nokia.com | Rel-8 | Joern |  |  |  | RP-080741 |
| 591 | 160.3 | LTE – eUTRAN Interfaces |  | 575d? | 2006-09-25 A | 2008-12-05 A | 100% |  | 2006-09-25 | 2008-12-05 | 575d? |  | finish no earlier than 2008-12-11 | R3 | 4600h | 4600h | LTE-interfaces | Ericsson | Martin Israelsson | Rel-8 | Juha |  |  |  | RP-080741 |
| 592 | 160.4 | LTE – Evolved UTRA and UTRAN RF Radio Transmission/Reception, System Performance Requirements and Conformance Testing |  | 575d? | 2006-09-25 A | 2008-12-05 A | 100% |  | 2006-09-25 | 2008-12-05 | 575d? |  | finish no earlier than 2008-12-11 | R4 | 4600h | 4600h | LTE-RF | Nokia Siemens Networks | Tuomo Saynajakangas | Rel-8 | Stefania |  |  |  | RP-080741 |
| 593 | 160.5 | LTE – FDD repeaters |  | 386d? | 2007-09-14 A | 2009-03-06 A | 100% |  | 2007-09-14 | 2009-03-06 | 386d? |  | finish no earlier than 2009-03-06 | R4 | 3088h | 3088h | LTE-Repeaters | Powerwave Technologies, Andrew Wireless | ralf.michanikl@andrew.com, Alf.Ahlstrom@pwav.com | Rel-8 | Stefania | RP-37 |  |  | RP-090037 |
| 594 | 160.6 | **E-UTRAN Data Definitions** |  | 389d? | 2007-09-17 A | 2009-03-12 A | 100% |  | 2007-09-17 | 2009-03-12 | 389d? |  |  | S5 | 13096h | 13096h | E-UTRAN-OAM |  |  | Rel-8 | Dionisio | SP-39 |  | PCG-21 |  |
| 595 | 160.6.1 | Subscriber and Equipment Trace for E-UTRAN and EPC |  | 389d? | 2007-09-17 A | 2009-03-12 A | 100% |  | 2007-09-17 | 2009-03-12 | 389d? |  | finish no earlier than 2009-03-12 | S5 | 3112h | 3112h | E-UTRAN-OAM | Ericsson | PETERSEN, Robert | Rel-8 | Dionisio | SP-37 |  |  |  |
| 596 | 160.6.2 | E-UTRAN Network Resource Model (NRM) Integration Reference Point (IRP) |  | 309d? | 2008-01-07 A | 2009-03-12 A | 100% |  | 2008-01-07 | 2009-03-12 | 309d? |  | finish no earlier than 2009-03-12 | S5 | 2472h | 2472h | E-UTRAN-OAM | Ericsson | ELMDAHL, Per | Rel-8 | Dionisio | SP-38 |  | PCG-21 |  |
| 597 | 160.6.3 | Performance measurements for E-UTRAN |  | 275d? | 2008-02-22 A | 2009-03-12 A | 100% |  | 2008-02-22 | 2009-03-12 | 275d? |  | finish no earlier than 2009-03-12 | S5 | 2200h | 2200h | E-UTRAN-OAM | Motorola, Huawei | YAO, Yizhi | Rel-8 | Dionisio | SP-39 |  | PCG-21 |  |
| 598 | 160.6.4 | Key Performance Indicators (KPIs) for E-UTRAN |  | 275d? | 2008-02-22 A | 2009-03-12 A | 100% |  | 2008-02-22 | 2009-03-12 | 275d? |  | finish no earlier than 2009-03-12 | S5 | 2200h | 2200h | E-UTRAN-OAM | Ericsson | HÜBINETTE, Ulf | Rel-8 | Dionisio | SP-39 |  | PCG-21 |  |
| 599 | 160.7 | **Self-Organizing Networks (SON)** |  | 210d? | 2008-02-22 A | 2008-12-11 A | 100% |  | 2008-02-22 | 2008-12-11 | 210d? |  |  | S5 | 6720h | 6720h | LTE_SON-OAM | Vodafone | GOMPAKIS, Panagiotis | Rel-8 | Dionisio | SP-39 |  | PCG-21 |  |
| 600 | 160.7.1 | SON Concepts and requirements |  | 210d? | 2008-02-22 A | 2008-12-11 A | 100% |  | 2008-02-22 | 2008-12-11 | 210d? |  |  | S5 | 1680h | 1680h | LTE_SON-OAM | Vodafone | GOMPAKIS, Panagiotis | Rel-8 | Dionisio | SP-39 |  | PCG-21 |  |
| 601 | 160.7.2 | Self-Establishment of eNBs, including automated Software Management |  | 210d? | 2008-02-22 A | 2008-12-11 A | 100% |  | 2008-02-22 | 2008-12-11 | 210d? |  | start no earlier than 2008-02-22 | S5 | 1680h | 1680h | LTE_SON-OAM | Nokia Siemens Networks | SUERBAUM, Clemens | Rel-8 | Dionisio | SP-39 |  | PCG-21 |  |
| 602 | 160.7.3 | SON Automatic Neighbour Relations (ANR) List Management |  | 210d? | 2008-02-22 A | 2008-12-11 A | 100% |  | 2008-02-22 | 2008-12-11 | 210d? |  | finish no earlier than 2008-12-11 | S5 | 1680h | 1680h | LTE_SON-OAM | Ericsson | edwin.tse@ericsson.com | Rel-8 | Dionisio | SP-39 |  | PCG-21 |  |
| 603 | 161 | **Rel-8 LTE – Terminal Conformance Test Specification** |  | 602d? | 2007-06-01 A | 2009-09-18 | 78% | 130.43d? | 2007-06-01 | 2009-09-18 | 602d? | 255d |  | R5 | 22624h | 17888h | LTE-UEConTest |  |  | Rel-8 | Ingbert |  |  |  |  |
| 604 | 161.1 | 3G LTE – Terminal Protocol Conformance Test Specifications |  | 601d? | 2007-06-01 A | 2009-09-18 | 70% | 180.3d? | 2007-06-01 | 2009-09-18 | 601d? | 255d | finish no earlier than 2009-09-18 | R5 | 4808h | 3365.6h | LTE-UEConTest_SIG | NEC, Motorola | david.lecompte@nectech.fr, Jacob.John@motorola.com | Rel-8 | Ingbert |  |  |  | RP-090385 |

Notes:
- 580: CT#42 completed. CT#40: WID updated CP-070622=>CP-080382. aka Enhanced USIM phonebook
- 581: CT#38 completed / Text3: 21.111
- 582: CT#39 completed / Text3: 31.220
- 583: CT#42 completed / Text3: 31.221
- 584: SA#33 stopped / Text3: 31.102
- 585: CT#44 work not started
- 586: CT#44 work not started / Text3: 31.320 (external interface for communication with the ME)
- 587: CT#44 work not started / Text3: 31.321 (internal interface (API))
- 588: RP#43 completed. RP#42 Rel-8 exception for UID_370046 (LTE FDD repeaters) to 03/09. / Text3: 36.300, 36.938
- 589: RP#39 completed. / Text3: 36.201, 36.211, 36.212, 36.213, 36.214, 25.215, 25.225
- 590: RP#42 completed. ASN.1 freezing target 03/09 / Text3: 36.302, 36.304, 36.306, 36.314, 36.321, 36.322, 36.323, 36.331, 25.302, 25.304, 25.331
- 591: RP#42 completed / Text3: 36.401, 36.410, 36.411, 36.412, 36.413, 36.414, 36.420, 36.421, 36.422, 36.423, 36.424, 25.413
- 592: RP#42 completed (closed at 95%) / Text3: 36.101, 36.104, 36.113, 36.124, 36.133, 36.141, 36.942, 25.123, 25.133
- 593: RP#43 completed. RP#42 Rel-8 exception to 03/09 / Text3: 36.106, 36.143, 25.113
- 594: SA#43 completed
- 595: SA#43 completed. SA#42 Rel-8 exception to 03/09 / Text3: 32.42x, 32.44x
- 596: SA#43 completed. SA#42 Rel-8 exception to 03/09 / Text3: 32.761, 32.762, 32.763, 32.765
- 597: SA#43 completed. SA#42 Rel-8 exception to 03/09 / Text3: 32.425
- 598: SA#43 completed. SA#42 Rel-8 exception to 03/09 / Text3: 32.450, 32.451
- 599: SA#42 completed (WT UID_390007 moved to Rel-9). SA#40 updated WID SP-080064=>SP-080275.
- 600: SA#42 completed. SA#40 updated WID SP-080064=>SP-080275. SA#41 UID_390004 split to monitor 32.500 progress. / Text3: 32.500
- 601: SA#42 completed. WID updated SP-080065=>SP-080849 / Text3: 32.501, 32.502, 32.531, 32.532, 32.533
- 602: SA#42 completed / Text3: 32.511, 32.761, 32.762, 32.763, 32.765
- 603: Testing for Feature UID_20068 (LTE)
- 604: RP#43 Completion target 03/09=>09/09 / Text3: 36.521-1, 36.521-2, 36.508, 36.509, 36.523-1, 36.523-2

| ID | WBS | Task | Duration | Start | Finish | Complete | Remaining | Baseline start | Baseline finish | Baseline duration | Total slack | Constraint | Resources | Work | Actual work | Text1 | Text2 | Text4 | Text5 | Text6 | Text7 | Text8 | Text11 | Text9 | Text12 |
| --- | --- | --- | --- | --- | --- | --- | --- | --- | --- | --- | --- | --- | --- | --- | --- | --- | --- | --- | --- | --- | --- | --- | --- | --- | --- |
| 605 | 161.2 | **LTE – Terminal Radio Transmission and Reception Conformance Test Specifications** | 602d? | 2007-06-01 A | 2009-09-18 | 83% | 105.35d? | 2007-06-01 | 2009-09-18 | 602d? | 255d |  | R5 | 14432h | 11906.4h | LTE-UEConTest_RF | PCG-23 | Agilent | andrea_leonardi@agilent.com | Rel-8 | RP-44 | Ingbert | RP-090386 |  |  |
| 606 | 161.2.1 | LTE – Terminal Radio Transmission and Reception Conformance Test Specifications (FDD) | 601d? | 2007-06-01 A | 2009-09-18 | 85% | 90.15d? | 2007-06-01 | 2009-09-18 | 601d? | 255d | finish no earlier than 2009-09-18 | R5 | 4808h | 4086.8h | LTE-UEConTest_RF_FDD |  | Agilent | andrea_leonardi@agilent.com | Rel-8 |  | Ingbert | RP-090386 |  |  |
| 607 | 161.2.2 | LTE – Terminal Radio Transmission and Reception Conformance Test Specifications (TDD) | 601d? | 2007-06-01 A | 2009-09-18 | 80% | 120.2d? | 2007-06-01 | 2009-09-18 | 601d? | 255d | finish no earlier than 2009-09-18 | R5 | 4808h | 3846.4h | LTE-UEConTest_RF_TDD | PCG-21 | Agilent | andrea_leonardi@agilent.com | Rel-8 | RP-41 | Ingbert | RP-090386 |  |  |
| 608 | 162 | **Rel-8 Improvements of the Radio Interface** | 525d? | 2007-03-05 A | 2009-03-06 A | 100% |  | 2007-03-05 | 2009-03-06 | 525d? |  |  | RP | 18152h | 18152h | RInImp8 |  |  |  | Rel-8 |  | Stefania |  |  |  |
| 609 | 162.1 | UMTS 1500 MHz | 140d? | 2007-03-05 A | 2007-09-14 A | 100% |  | 2007-03-05 | 2007-09-14 | 140d? |  | finish no earlier than 2007-09-14 | R4 | 1120h | 1120h | RInImp8-UMTS1500 |  | NTT DoCoMo | Takehiro Nakamura (nakamurata@nttdocomo.co.jp) | Rel-8 |  | Stefania | RP-070526 |  |  |
| 610 | 162.2 | UMTS 700 MHz FDD | 325d? | 2007-03-05 A | 2008-05-30 A | 100% |  | 2007-03-05 | 2008-05-30 | 325d? |  | finish no earlier than 2008-06-12 | R4 | 2600h | 2600h | RInImp8-UMTS700 |  | Nokia | Tuomo Saynajakangas | Rel-8 |  | Stefania | RP-080260 |  |  |
| 611 | 162.3 | UMTS 2300 MHz TDD LCR | 195d? | 2007-12-17 A | 2008-09-12 A | 100% |  | 2007-12-17 | 2008-09-12 | 195d? |  | finish no earlier than 2008-09-12 | R4 | 1560h | 1560h | RInImp8-UMTS2300TDD | PCG-21 | CATT | songyuexia@datangmobile.cn | Rel-8 | RP-38 | Stefania | RP-080517 |  |  |
| 612 | 162.4 | Further Improved Minimum Performance Requirements for HSDPA UE (FDD) - Two-Branch Interference Cancellation | 265d? | 2007-03-05 A | 2008-03-07 A | 100% |  | 2007-03-05 | 2008-03-07 | 265d? |  | finish no earlier than 2008-03-12 | R4 | 2120h | 2120h | RInImp8-2BIC |  | AT&T | Marc Grant | Rel-8 |  | Stefania | RP-080041 |  |  |
| 613 | 162.5 | CS Voice Service over HSPA | 167d? | 2007-07-19 A | 2008-03-07 A | 100% |  | 2007-07-19 | 2008-03-07 | 167d? |  |  | R2 | 1336h | 1336h | RInImp8-CsHspa |  | Nokia Siemens Networks | woonhee.hwang@nsn.com | Rel-8 | RP-37 | Joern | RP-080042 |  |  |
| 614 | 162.6 | Performance requirements for 15 code reception with 16QAM/QPSK (FDD) | 126d? | 2007-06-11 A | 2008-03-07 A | 100% |  | 2007-06-11 | 2008-03-07 | 126d? |  | finish no earlier than 2008-06-12 | R4 | 1008h | 1008h | RInImp8-Hsdpa15codes |  | Vodafone | tim.frost@vodafone.com | Rel-8 | RP-37 | Stefania | RP-080043 |  |  |
| 615 | 162.7 | UMTS 1880 MHz TDD | 126d? | 2008-09-12 A | 2009-03-06 A | 100% |  | 2008-09-12 | 2009-03-06 | 126d? |  | finish no earlier than 2009-03-09 | R4 | 1008h | 1008h | RInImp9-UMTS1880TDD | PCG-21 | CATT | Yuexia Song (songyuexia@datangmobile.cn) | Rel-8 | RP-41 | Stefania | RP-090044 |  |  |
| 616 | 162.8 | Deleted - UMTS 2300 MHz FDD/TDD | 400d? | 2007-03-05 A | 2008-09-12 A | 100% |  | 2007-03-05 | 2008-09-12 | 400d? |  | finish no earlier than 2008-12-11 | R4 | 3200h | 3200h | RInImp8-UMTS2300 |  | AT&T | Marc Grant | Rel-8 |  | Stefania | RP-080515 | PCG-21 | RP-41 |
| 617 | 163 | **Rel-8 Improvements of the Radio Interface - UE Conformance Testing** | 396d? | 2007-06-01 A | 2008-12-05 A | 100% |  | 2007-06-01 | 2008-12-05 | 396d? |  |  | R5 | 6256h | 6256h | RInImp-UEConTest |  |  |  | Rel-8 |  | Ingbert |  |  |  |
| 618 | 163.1 | Conformance Test Aspects – CS Voice Service over HSPA | 336d? | 2007-06-01 A | 2008-09-12 A | 100% |  | 2007-06-01 | 2008-09-12 | 336d? |  | finish no earlier than 2008-09-12 | R5 | 2688h | 2688h | RInImp8-CsHspa_UEConTest |  | Huawei | baoyi@huawei.com | Rel-8 |  | Ingbert | RP-080542 |  |  |
| 619 | 163.2 | Conformance Test Aspects – Performance requirements for 15 code reception with 16QAM/QPSK (FDD) | 195d? | 2008-03-07 A | 2008-12-05 A | 100% |  | 2008-03-07 | 2008-12-05 | 195d? |  | finish no earlier than 2008-12-05 | R5 | 1560h | 1560h | RInImp8-UEConTest_ Hsdpa15codes | PCG-21 | Ericsson | Mikael.Ziren@Ericsson.com | Rel-8 | RP-40 | Ingbert | RP-080818 |  |  |
| 620 | 164 | **Rel-8 RAN improvements** | 520d? | 2007-06-04 A | 2009-05-29 A | 100% |  | 2007-06-04 | 2009-05-29 | 520d? |  |  | RP | 29776h | 29776h | RANimp |  |  |  | Rel-8 |  | Stefania |  |  |  |
| 621 | 164.1 | Combination of 64QAM and MIMO for HSDPA (FDD) | 205d? | 2007-06-04 A | 2008-09-12 A | 100% |  | 2007-06-04 | 2008-09-12 | 205d? |  | finish no earlier than 2008-09-12 | R1 | 1640h | 1640h | RANimp-64QamMimoHsdpa |  | Ericsson | Johan.Bergman@ericsson.com | Rel-8 |  | Patrick | RP-080518 |  |  |
| 622 | 164.2 | Improved L2 for uplink | 186d? | 2007-09-14 A | 2008-05-30 A | 100% |  | 2007-09-14 | 2008-05-30 | 186d? |  | finish no earlier than 2008-05-30 | R2 | 1488h | 1488h | RANimp-UplinkL2dataRates |  | Ericsson | Janne.Peisa@ericsson.com | Rel-8 | RP-37 | Joern | RP-080265 |  |  |
| 623 | 164.3 | Enhanced Uplink for CELL_FACH State in FDD | 321d? | 2007-09-14 A | 2008-12-05 A | 100% |  | 2007-09-14 | 2008-12-05 | 321d? |  | finish no earlier than 2008-12-12 | R2 | 2568h | 2568h | RANimp-UplinkEnhState |  | Nokia Siemens Networks | markus.wimmer@nsn.com | Rel-8 | RP-37 | Joern | RP-080804 |  |  |
| 624 | 164.4 | Enhanced UE DRX for FDD | 261d? | 2007-09-14 A | 2008-09-12 A | 100% |  | 2007-09-14 | 2008-09-12 | 261d? |  | finish no earlier than 2008-09-12 | R2 | 2088h | 2088h | RANimp-DRX |  | Nokia | luis.barreto@nokia.com | Rel-8 | RP-37 | Joern | RP-080520 |  |  |
| 625 | 164.5 | Enhancements for SRNS Relocation Procedure | 261d? | 2007-09-14 A | 2008-09-12 A | 100% |  | 2007-09-14 | 2008-09-12 | 261d? |  | finish no earlier than 2008-09-12 | R3 | 2088h | 2088h | RANimp-SrnsReloc |  | Nokia Siemens Networks | masatoshi.nakamata@nsn.com | Rel-8 | RP-37 | Juha | RP-080521 |  |  |
| 626 | 164.6 | Enhancements for FDD HSPA Evolution | 321d? | 2007-09-14 A | 2008-12-05 A | 100% |  | 2007-09-14 | 2008-12-05 | 321d? |  | finish no earlier than 2008-12-05 | R3,R2 | 2568h | 2568h | RANimp-HSPAEvo |  | Nokia Siemens Networks | masatoshi.nakamata@nsn.com | Rel-8 | RP-37 | Juha | RP-080805 |  |  |
| 627 | 164.7 | 64QAM for 1.28 Mcps TDD HSDPA | 264d? | 2007-12-04 A | 2008-12-05 A | 100% |  | 2007-12-04 | 2008-12-05 | 264d? |  | finish no earlier than 2008-12-05 | R1 | 2112h | 2112h | RANimp-64Qam1.28TDD | PCG-21 | ZTE | zfmail@zte.com.cn | Rel-8 | RP-38 | Patrick | RP-080806 |  |  |
| 628 | 164.8 | Enhanced CELL_FACH state in 1.28 Mcps TDD | 264d? | 2007-12-04 A | 2008-12-05 A | 100% |  | 2007-12-04 | 2008-12-05 | 264d? |  | finish no earlier than 2008-12-12 | R2 | 2112h | 2112h | RANimp-EnhState1.28TDD | PCG-21 | ZTE | zhang.yincheng@zte.com.cn | Rel-8 | RP-38 | Joern | RP-080807 |  |  |
| 629 | 164.9 | Continuous Connectivity for packet data users for 1.28 Mcps TDD | 321d? | 2008-03-07 A | 2009-05-29 A | 100% |  | 2008-03-07 | 2009-05-29 | 321d? |  | finish no earlier than 2009-05-29 | R1 | 2568h | 2568h | RANimp-LCRCPC | PCG-21 | TD Tech | chenying@td-tech.com | Rel-8 | RP-39 | Patrick | RP-090394 |  |  |
| 630 | 164.10 | HSPA VoIP to WCDMA/GSM CS continuity | 261d? | 2008-03-07 A | 2009-03-06 A | 100% |  | 2008-03-07 | 2009-03-06 | 261d? |  | finish no earlier than 2009-03-06 | R2 | 2088h | 2088h | RANimp-HSPAVoIP | PCG-21 | Nokia | Simone.Provvedi@nokia.com | Rel-8 | RP-39 | Joern | RP-090050 |  |  |
| 631 | 164.11 | HS-DSCH Serving Cell Change Enhancements | 196d? | 2008-03-07 A | 2008-12-05 A | 100% |  | 2008-03-07 | 2008-12-05 | 196d? |  | finish no earlier than 2008-12-12 | R2 | 1568h | 1568h | RANimp-HSDSCH | PCG-21 | Ericsson | henrik.enbuske@ericsson.com | Rel-8 | RP-39 | Joern | RP-080811 |  |  |
| 632 | 164.12 | MIMO for 1.28 Mcps TDD | 201d? | 2007-11-01 A | 2009-03-06 A | 100% |  | 2007-11-01 | 2009-03-06 | 201d? |  | finish no earlier than 2009-05-29 | R1,R4 | 1608h | 1608h | RANimp-MIMOLCR | PCG-21 | CATT | wangke@datangmobile.cn | Rel-8 | RP-40 | Patrick | RP-090313 |  |  |
| 633 | 164.13 | Dual-Cell HSDPA operation on adjacent carriers | 140d? | 2008-05-30 A | 2008-12-11 A | 100% |  | 2008-05-30 | 2008-12-11 | 140d? |  | finish no earlier than 2009-05-29 | R1,R4 | 1120h | 1120h | RANimp-DCHSDPA | PCG-21 | Ericsson | johan.bergman@ericsson.com | Rel-8 | RP-40 | Patrick | RP-080814 |  |  |

Notes:
- 605: RP#44 Umbrella/virtual BB created. Reason: R5 insists on using WI code LTE-UEConTest_RF irrespective of FDD or TDD
- 606: RP#44 36.521-3 v200 for Approval. RP#43 Completion target 03/09=>09/09 / Text3: 36.521-1, 36.521-2, 36.521-3, 36.508, 36.509, 36.903
- 607: RP#44 36.521-3 v200 for Approval. RP#43 Completion target 03/09=>09/09 / Text3: 36.521-1, 36.521-2, 36.521-3, 36.508, 36.509, 36.903
- 609: SR in RP-070526 / Text3: 25.101, 25.104, 25.133, 25.141, 25.331, 25.942, 25.306, 25.307, 34.121
- 610: SR in RP-080260 / Text3: 25.101, 25.104, 25.133, 25.141, 25.331, 25.942, 25.306, 25.307, 34.121
- 611: SR in RP-080517. RP#41 completed / Text3: 25.102, 25.105, 25.113, 25.123, 25.142, 34.124, 25.306, 25.331, 34.122
- 612: SR in RP-080041.
- 613: SR in RP-080042. / Text3: 25.323, 25.331, 25.322
- 614: SR in RP-080043. / Text3: 25.101
- 615: RP#43 completed as Rel-8 / Text3: 25.102, 25.105, 25.113, 25.123, 25.142, 34.124, 25.307
- 616: SR in RP-080515. RP#41 stopped / Text3: 25.101, 25.104, 25.133, 25.141, 25.331, 25.942, 25.306, 25.307, 34.121
- 617: 05/08: Linked to Feature UID_20028 (RInImp)
- 618: SR in RP-080542. RP#41 completed. / Text3: 34.108, 34.123-1, 34.123-2, 34.123-3
- 619: RP#42 completed. SR in RP-080818. Linked to UID_370033. / Text3: 34.121-1, 34.121-2
- 621: SR in RP-080518. RP#41 completed / Text3: 25.308, 25.211, 25.212, 25.213, 25.306, 25.331, 25.433, 25.435, 25.423, 25.425, 25.101, 25.104, 25.141
- 622: SR in RP-080265. RP#40 completed / Text3: 25.319, 25.301, 25.306, 25.321, 25.331, 25.433, 25.435, 25.423, 25.425, 25.427
- 623: SR in RP-080804. RP#42 completed / Text3: 25.309, 25.211, 25.214, 25.321, 25.331, 25.423, 25.433
- 624: SR in RP-080520. RP#41 completed / Text3: 25.306, 25.308, 25.321, 25.331, 25.423
- 625: SR in RP-080521. RP#41 completed / Text3: 25.306, 25.308, 25.321, 25.331, 25.423, 25.433, 25.214, 25.133
- 626: SR in RP-080805. RP#42 completed. WID updated RP-070760=>RP-080830 / Text3: 25.401, 25.413, 25.420, 25.423, 25.427, 25.433, 25.446, 25.301, 25.346
- 627: SR in RP-080806. RP#42 completed / Text3: 25.102, 25.105, 25.123, 25.142, 25.201, 25.221, 25.222, 25.223, 25.224, 25.306, 25.308, 25.321, 25.331, 25.423, 25.433
- 628: SR in RP-080807. RP#42 completed / Text3: 25.123, 25.221, 25.222, 25.224, 25.301, 25.302, 25.304, 25.306, 25.308, 25.319, 25.321, 25.331, 25.401, 25.423, 25.425, 25.433, 25.435
- 629: RP#44 completed / Text3: 25.929, 25.308, 25.319
- 630: RP#43 completed. RP#42 Rel-8 exception to 03/09. (condition: ASN.1 available Jan 09 to RAN2/3. If not, shifted to Rel-9) / Text3: 25.331, 25.413
- 631: SR in RP-080811. RP#42 completed / Text3: 25.101, 25.104, 25.133, 25.212, 25.214, 25.308, 25.321, 25.331, 25.423, 25.433
- 632: RP#43 completed (part missing R4 performance part) / Text3: 25.201, 25.221, 25.222, 25.223, 25.224, 25.306, 25.308, 25.321, 25.331, 25.423, 25.433, 25.102, 25.105, 25.142
- 633: RP#42 completed except R4 performance part 05/09. Triggered by FS_RAN-DCHS UID_390032 / Text3: 25.101, 25.104, 25.133, 25.141, 25.211, 25.212, 25.213, 25.214, 25.215, 25.306, 25.308, 25.321, 25.331, 25.423, 25.433

| ID | WBS | Task | Duration | Start | Finish | Complete | Remaining | Baseline start | Baseline finish | Baseline duration | Total slack | Constraint | Resources | Work | Actual work | Text1 | Text6 | Text8 | Text2 | Text4 | Text7 | Text11 |
| --- | --- | --- | --- | --- | --- | --- | --- | --- | --- | --- | --- | --- | --- | --- | --- | --- | --- | --- | --- | --- | --- | --- |
| 634 | 165 | **Rel-8 RAN improvements - UE Conformance Testing** | 597d? | 2008-05-30 A | 2010-09-10 | 31% | 411.41d? | 2008-05-30 | 2010-09-10 | 597d? | 0d |  | R5 | 22679.2h | 5630.4h | RANimp-UEConTest | Rel-8 | Ingbert |  |  |  |  |
| 635 | 165.1 | Conformance Test Aspects – Combination of 64QAM and MIMO for HSDPA (FDD) | 266d? | 2008-09-12 A | 2009-09-18 | 60% | 106.4d? | 2008-09-12 | 2009-09-18 | 266d? | 255d | finish no earlier than 2009-09-18 | R5 | 2128h | 1276.8h | RANimp-UEConTest_64QamMimoHsdpa | Rel-8 | Ingbert | PCG-21 | Ericsson | RP-41 | RP-090414 |
| 636 | 165.2 | Conformance Test Aspects – Improved L2 for uplink | 341d? | 2008-05-30 A | 2009-09-18 | 60% | 136.4d? | 2008-05-30 | 2009-09-18 | 341d? | 255d | finish no earlier than 2009-09-18 | R5 | 2728h | 1636.8h | RANimp-UEConTest_UplinkL2dataRates | Rel-8 | Ingbert | PCG-21 | Ericsson | RP-40 | RP-090412 |
| 637 | 165.3 | Conformance Test Aspects – 64QAM for 1.28 Mcps TDD HSDPA | 261d? | 2008-05-30 A | 2009-05-29 A | 100% |  | 2008-05-30 | 2009-05-29 | 261d? |  | finish no earlier than 2009-05-29 | R5 | 2088h | 2088h | RANimp-UEConTest_64Qam1.28TDD | Rel-8 | Ingbert | PCG-21 | ZTE | RP-40 | RP-090415 |
| 638 | 165.4 | Conformance Test Aspects – Dual-Cell HSDPA operation on adjacent carriers | 261d? | 2008-12-05 A | 2009-12-04 | 10% | 234.9d? | 2008-12-05 | 2009-12-04 | 261d? | 200d | finish no earlier than 2009-12-04 | R5 | 2088h | 208.8h | RANimp-UEConTest_DCHSDPA | Rel-8 | Ingbert | PCG-22 | Qualcomm | RP-42 | RP-090417 |
| 639 | 165.5 | Conformance Test Aspects – Enhanced Uplink for CELL_FACH State in FDD | 266d? | 2009-03-06 A | 2010-03-12 | 5% | 252.7d? | 2009-03-06 | 2010-03-12 | 266d? | 130d | finish no earlier than 2010-03-12 | R5 | 2128h | 106.4h | RANimp-UEConTest_EnhancedRACHCellFACHState | Rel-8 | Ingbert | PCG-22 | Nokia | RP-43 | RP-090422 |
| 640 | 165.6 | Conformance Test Aspects – Receiver Type3i | 196d? | 2009-03-06 A | 2009-12-04 | 20% | 156.8d? | 2009-03-06 | 2009-12-04 | 196d? | 200d | finish no earlier than 2009-12-04 | R5 | 1568h | 313.6h | RANimp_UEConTest_ReceiverType3i | Rel-8 | Ingbert | PCG-22 | Qualcomm | RP-43 | RP-090421 |
| 641 | 165.7 | Conformance Test Aspects – Enhanced CELL_FACH State in LCR TDD | 336d? | 2009-05-30 | 2010-09-10 |  |  | 2009-05-30 | 2010-09-10 | 336d? | 0d | finish no earlier than 2010-09-10 | R5 | 2688h |  | EnhancedCellFACHStateLCRTDD_UEConTest | Rel-8 | Ingbert | PCG-23 | CATT | RP-44 |  |
| 642 | 165.8 | Conformance Test Aspects – 1.28 Mcps TDD Improved L2 support for high data rates | 337d? | 2009-05-29 | 2010-09-10 |  |  | 2009-05-29 | 2010-09-10 | 337d? | 0d | finish no earlier than 2010-09-10 | R5 | 2696h |  | ImprovedL2LCRTDD_UEConTest | Rel-8 | Ingbert | PCG-23 | CATT | RP-44 |  |
| 643 | 166 | 3.84 Mcps TDD MBSFN Integrated Mobile Broadcast | 395d? | 2007-06-04 A | 2008-12-05 A | 100% |  | 2007-06-04 | 2008-12-05 | 395d? |  |  | R1 | 3160h | 3160h | MBSFN-DOB | Rel-8 | Patrick |  | Ericsson |  | RP-080218 |
| 644 | 167 | Conformance Test Aspects – 3.84 Mcps TDD MBSFN Integrated Mobile Broadcast | 136d? | 2009-05-30 | 2009-12-04 |  |  | 2009-05-30 | 2009-12-04 | 136d? | 200d | finish no earlier than 2009-12-04 | R5 | 1088h |  | MBSFN_IMB_UEConTest | Rel-8 | Ingbert | PCG-23 | IPwireless | RP-44 |  |
| 645 | 168 | GERAN support for GERAN - 3G Long Term Evolution interworking | 641d? | 2006-09-08 A | 2009-02-20 A | 100% |  | 2006-09-08 | 2009-02-20 | 641d? |  | finish no earlier than 2009-02-20 | GP | 5128h | 5128h | GELTE | Rel-8 | Paolo |  | Nokia, Nokia Siemens Networks |  |  |
| 646 | 169 | U-TDOA Enhancement | 131d? | 2007-05-18 A | 2007-11-16 A | 100% |  | 2007-05-18 | 2007-11-16 | 131d? |  | finish no earlier than 2007-05-18 | GP | 1048h | 1048h | GUTEN | Rel-8 | Paolo |  | TruePosition |  |  |
| 647 | 170 | **GAN Enhancements** | 604.2d? | 2007-05-15 A | 2009-09-04 | 84% | 97.49d? | 2007-05-15 | 2009-09-04 | 604.2d? | 265d |  | GP | 9432h | 7910.15h | GANENH | Rel-8 | Paolo |  | T-Mobile |  |  |
| 648 | 170.1 | Update to GAN specifications | 126d? | 2007-08-31 A | 2008-02-22 A | 100% |  | 2007-08-31 | 2008-02-22 | 126d? |  | finish no earlier than 2008-02-22 | GP | 1008h | 1008h | GANENH-SPEC | Rel-8 | Paolo |  | T-Mobile |  |  |
| 649 | 170.2 | Update TS 51.010 Mobile Station (MS) Conformance Specification for GAN Enhancements | 526d? | 2007-05-15 A | 2009-09-04 | 80% | 105.2d? | 2007-05-15 | 2009-09-04 | 526d? | 265d | finish no earlier than 2009-09-04 | G3new | 4208h | 3366.4h | GANENH-MStest | Rel-8 | Ingbert |  | T-Mobile |  |  |
| 650 | 171 | **AoIP (A-interface over IP)** | 2335d? | 2000-01-03 A | 2008-12-11 A | 100% |  | 2000-01-03 | 2008-12-11 | 2335d? |  |  | GP,S4,C4,C1,C3 | 41412.1h | 41412.1h | AoIP | Rel-8 | Paolo | PCG-21 | China Mobile, Ericsson |  |  |
| 651 | 171.1 | GERAN aspects of AoIP | 2321d? | 2000-01-03 A | 2008-11-21 A | 100% |  | 2000-01-03 | 2008-11-21 | 2321d? |  | finish no earlier than 2008-11-21 | GP | 18560h | 18560h | AoIP | Rel-8 | Paolo | PCG-21 | China Mobile, Ericsson | SP-40 |  |
| 652 | 171.2 | Media Requirements for CS over IP based User Plane | 267d? | 2007-12-05 A | 2008-12-11 A | 100% |  | 2007-12-05 | 2008-12-11 | 267d? |  | finish no earlier than 2008-12-11 | S4 | 1996.09h | 1996.09h | AoIP-CSoIP | Rel-8 | Paolo | PCG-21 | China Mobile, Ericsson | SP-40 |  |
| 653 | 171.3 | Core Network Impacts for A-Interface User Plane over IP | 136d? | 2008-05-30 A | 2008-12-05 A | 100% |  | 2008-05-30 | 2008-12-05 | 136d? |  | start no earlier than 2008-05-30 | C4 | 1088h | 1088h | AoIP-CN | Rel-8 | Kimmo | PCG-21 | Ericsson | CP-40 |  |
| 654 | 171.4 | Core Network Impacts for A-Interface User Plane over IP | 68d? | 2008-05-30 A | 2008-12-05 A | 100% |  | 2008-05-30 | 2008-12-05 | 68d? |  | finish no earlier than 2008-12-05 | C1 | 544h | 544h | AoIP-CN | Rel-8 | Frederic | PCG-21 | Ericsson | CP-40 |  |
| 655 | 171.5 | Core Network Impacts for A-Interface User Plane over IP | 68d? | 2008-05-30 A | 2008-12-05 A | 100% |  | 2008-05-30 | 2008-12-05 | 68d? |  | finish no earlier than 2008-12-05 | C3 | 544h | 544h | AoIP-CN | Rel-8 | Gwiho | PCG-21 | Ericsson | CP-40 |  |
| 656 | 172 | New multicarrier BTS class | 261d? | 2007-08-31 A | 2008-08-29 A | 100% |  | 2007-08-31 | 2008-08-29 | 261d? |  | finish no earlier than 2008-08-29 | G1 | 2088h | 2088h | MCBTS | Rel-8 | Paolo |  | Alcatel-Lucent |  |  |
| 657 | 173 | **Support for Additional Navigation Satellite Systems (ANSS) for LCS** | 150d? | 2008-05-16 A | 2008-12-11 A | 100% |  | 2008-05-16 | 2008-12-11 | 150d? |  |  | S1,G2 | 3384h | 3384h | ANSS | Rel-8 | Paolo |  | Qualcomm |  | RP-080813 |
| 658 | 173.1 | Stage 1 for ANSS for LCS | 1d? | 2008-12-11 A | 2008-12-11 A | 100% |  | 2008-12-11 | 2008-12-11 | 1d? |  | start no earlier than 2008-12-11 | S1 | 8h | 8h | ANSS | Rel-8 | Alain | PCG-22 |  | SP-42 |  |
| 659 | 173.2 | Support for Additional Navigation Satellite Systems (ANSS) for LCS | 136d? | 2008-05-16 A | 2008-11-21 A | 100% |  | 2008-05-16 | 2008-11-21 | 136d? |  | start no earlier than 2008-05-16 | G2 | 1088h | 1088h | ANSS | Rel-8 | Paolo |  | Qualcomm |  |  |
| 660 | 173.3 | Support for Additional Navigation Satellite Systems (ANSS) for LCS | 136d? | 2008-05-30 A | 2008-12-05 A | 100% |  | 2008-05-30 | 2008-12-05 | 136d? |  | finish no earlier than 2008-12-08 | R2 | 1088h | 1088h | RANimp-ANSS | Rel-8 | Joern | PCG-21 | Qualcomm | RP-40 | RP-080813 |

Notes:
- 634: 05/08: Linked to Feature UID_20029 (RANimp)
- 635: RP#43 Completion target 03/09=>09/09 / Text3: 34.108, 34.121-1, 34.121-2, 34.123-1, 34.123-2, 34.123-3 / Text5: leif.mattisson@ericsson.com
- 636: RP#43 Completion target 03/09=>09/09. Linked UID_370036 / Text3: 34.108, 34.123-1, 34.123-2, 34.123-3 / Text5: leif.mattisson@ericsson.com
- 637: RP#44 completed. Linked UID_380075 RANimp-64Qam1.28TDD / Text3: 34.108, 34.122, 34.123-1, 34.123-2, 34.123-3 / Text5: ma.zijiang@zte.com.cn
- 638: RP#44 completion target 09/09=>12/09. Testing for UID_400052 / Text3: 34.108, 34.121-1, 34.121-2, 34.123-1, 34.123-2, 34.123-3 / Text5: Shubhang Vora (svora@qualcomm.com)
- 639: Testing for UID_370037 / Text3: 34.108, 34.121-1, 34.121-2, 34.123-1, 34.123-2, 34.123-3 / Text5: jarkko.hellsten@nokia.com
- 640: Text3: 34.108, 34.121-1, 34.121-2 / Text5: Ashokkumar Narayanaswamy (anarayan@qualcomm.com)
- 641: Linked to UID_380076 Enhanced CELL_FACH state in 1.28 Mcps TDD (RANimp-EnhState1.28TDD) / Text3: 34.108, 34.123-1, 34.123-2, 34.123-3 / Text5: Xiaozhong Chen (chenxiaozhong@datangmobile.cn)
- 642: Linked to Rel-7 UID_340039 Improved L2 support for high data rates (RANimp-L2DataRates) and Rel-8 UID_370036 Improved L2 for uplink (RANimp-UplinkL2dataRates) / Text3: 34.108, 34.123-1, 34.123-2, 34.123-3 / Text5: Xiaozhong Chen (chenxiaozhong@datangmobile.cn)
- 643: RP#42 completed. WID updated RP-070493=>RP-081124 (changed WI title "MBSFN Downlink Optimized Broadcast (DOB) 3.84 Mcps TDD" => "3.84Mcps TDD MBSFN Integrated Mobile Broadcast"). RP#39 SR in RP-080218. / Text3: 25.102, 25.105, 25.123, 25.201, 25.221, 25.222, 25.223, 25.224, 25.304, 25.306, 25.331, 25.346, 25.402, 25.433 / Text5: Lars.Lindbom@ericsson.com
- 644: Text3: 34.108, 34.122, 34.123-1, 34.123-2, 34.123-3 / Text5: Phil Young (pyoung@ipwireless.com)
- 645: GP#41 completed (MS conformance testing open). GP#40 Rel-8 exception to 02/09 / Text3: 24.008, 43.055, 43.129, 43.246, 44.018, 44.060, 45.002, 45.008, 45.010, 48.008, 48.018, 51.010 / Text5: sergio.parolari@nsn.com, vlora.rexhepi@nokia.com
- 646: GP#36 completed U-TDOA (Uplink Time Difference of Arrival) / Text3: 43.059, 45.008, 48.071 / Text5: Terry Brooks (terri.brooks@trueposition.com)
- 647: GP#37 completed. Testing open / Text5: mohammed.versi@t-mobile.com
- 648: GP#37 completed / Text3: 43.318, 44.318 / Text5: mohammed.versi@t-mobile.com
- 649: GP#42 completion 05/09=>09/09 / Text3: 51.010 / Text5: mohammed.versi@t-mobile.com
- 650: GP#40/TSG#42 completed . Triggered by TR 43.903 Study on A-interface over IP (AINTIP) UID_50589. / Text5: wangshuaiyu@chinamobile.com, paul.schliwa-bertling@ericsson.com
- 651: GP#40 completed. GP#39 updated WID GP-080901=>GP-081362. / Text3: 48.001, 48.002, 48.008, 48.020, 49.008, 48.103 / Text5: wangshuaiyu@chinamobile.com, paul.schliwa-bertling@ericsson.com
- 652: SA#42 completed / Text3: 26.102, 26.103, 26.202 / Text5: Karl.Hellwig@Ericsson.com
- 653: CT#42 completed. Updated WID CP-080278=>CP-080722 / Text3: 23.205, 23.153, 23.231, 29.232 / Text5: philip.hodges@ericsson.com
- 654: CT#42 completed. Updated WID CP-080278=>CP-080722 / Text3: 23.009 / Text5: philip.hodges@ericsson.com
- 655: CT#42 completed. Updated WID CP-080278=>CP-080722 / Text3: 29.007 / Text5: philip.hodges@ericsson.com
- 656: GP#39 completed / Text3: 45.005, 45.050, 51.021 / Text5: thomas.bitzer@alcatel-lucent.de
- 657: GP#40 completed. Align with RANimp-ANSS ongoing work item. GP#40 WID updated GP-080776=>GP-081784 (Conformance testing moved to A-GNSS WID) / Text5: Mungal Dhanda
- 658: SA#42 completed by 22.071 CR0077 / Text3: 22.071
- 659: GP#40 completed. Align with RANimp-ANSS ongoing work item. GP#40 WID updated GP-080776=>GP-081784 (Conformance testing moved to A-GNSS WID) / Text3: 43.059, 44.031, 49.031, 44.071, 48.031, 51.010 / Text5: Mungal Dhanda
- 660: SR in RP-080813. RP#42 WI closed at 95%. GERAN leading the work / considers performance requirements for Rel-9 / Text3: 25.305, 25.306, 25.331, 25.413, 25.423, 25.433, 25.453 / Text5: Etienne Chaponniere (echaponn@qualcomm.com)

| ID | WBS | Task | Type | Duration | Start | Finish | Complete | Remaining | Baseline start | Baseline finish | Baseline duration | Total slack | Constraint | Resources | Work | Actual work | Text1 | Text4 | Text6 | Text8 | Text3 | Text2 | Text7 | Text12 |
| --- | --- | --- | --- | --- | --- | --- | --- | --- | --- | --- | --- | --- | --- | --- | --- | --- | --- | --- | --- | --- | --- | --- | --- | --- |
| 661 | 174 | **A-GNSS Performances and Testing Procedures** |  | 342d? | 2008-05-16 A | 2009-09-04 | 37% | 213.94d? | 2008-05-16 | 2009-09-04 | 342d? | 265d |  | GP | 8200h | 3070.5h | AGNSSPTP | Thales | Rel-8 | Paolo |  |  |  |  |
| 662 | 174.1 | A-GNSS Minimum Performances |  | 341d? | 2008-05-16 A | 2009-09-04 | 75% | 85.25d? | 2008-05-16 | 2009-09-04 | 341d? | 265d | finish no earlier than 2009-09-04 | G1 | 2728h | 2046h | AGNSSPTP- Perfreq | Thales | Rel-8 | Paolo | 45.005 |  |  |  |
| 663 | 174.2 | A-GNSS Testing Procedures |  | 342d? | 2008-05-16 | 2009-09-04 |  |  | 2008-05-16 | 2009-09-04 | 342d? | 265d | finish no earlier than 2009-09-04 | G3new | 2736h |  | AGNSSPTP-MStest | Thales | Rel-8 | Ingbert | 51.010-1 |  |  |  |
| 664 | 175 | **Conformance testing for the Latency Reductions feature** |  | 457d? | 2008-02-22 A | 2009-11-20 | 84% | 72.56d? | 2008-02-22 | 2009-11-20 | 457d? | 210d |  | G1, G3new | 9392h | 7899.52h | CTLATRED | Ericsson | Rel-8 | Paolo |  | PCG-21 |  |  |
| 665 | 175.1 | MS conformance testing for the Latency Reductions feature |  | 457d? | 2008-02-22 A | 2009-11-20 | 75% | 114d? | 2008-02-22 | 2009-11-20 | 457d? | 210d | finish no earlier than 2009-11-20 | G3new | 3648h | 2736h | CTLATRED-MStest | Ericsson | Rel-8 | Ingbert | 51.010 | PCG-21 |  |  |
| 666 | 175.2 | BTS conformance testing for the Latency Reductions feature |  | 261d? | 2008-02-22 A | 2009-02-20 A | 100% |  | 2008-02-22 | 2009-02-20 | 261d? |  | finish no earlier than 2009-02-20 | G1 | 2088h | 2088h | CTLATRED-BTStest | Ericsson | Rel-8 | Paolo | 51.021 | PCG-21 |  |  |
| 667 | 176 | MS conformance testing of changes introduced by WI “Support of Packet-switched Handover for GERAN A/Gb mode” |  | 196d? | 2008-02-22 A | 2008-11-21 A | 100% |  | 2008-02-22 | 2008-11-21 | 196d? |  | finish no earlier than 2008-11-21 | G3new | 1568h | 1568h | PSHCT-MStest | Rohde & Schwarz | Rel-8 | Ingbert | 51.010 | PCG-21 |  |  |
| 668 | 177 | MS conformance testing of Support of Conversational Services in A/Gb mode via the PS domain |  | 401d? | 2008-02-25 | 2009-09-04 |  |  | 2008-02-25 | 2009-09-04 | 401d? | 265d | finish no earlier than 2009-09-04 | G3new | 3208h |  | SCSAGBCT-MStest | Nokia | Rel-8 | Ingbert | 51.010 | PCG-21 |  |  |
| 669 | 178 | (Small) Technical Enhancements and Improvements for Rel-8 |  | 509d? | 2007-01-01 A | 2008-12-11 A | 100% |  | 2007-01-01 | 2008-12-11 | 509d? |  | finish no earlier than 2008-12-11 | All | 4072h | 4072h | TEI8 | ALL | Rel-8 |  |  |  |  |  |
| 670 | 179 | Test - (Small) Technical Enhancements and Improvements for Rel-8 |  | 402d? | 2008-05-30 A | 2009-12-11 | 80% | 80.4d? | 2008-05-30 | 2009-12-11 | 402d? | 195d | finish no earlier than 2009-12-11 | R5 | 3216h | 2572.8h | TEI8_Test | ALL | Rel-8 | Ingbert |  | PCG-21 | RP-40 |  |
| 671 | 180 | **Deleted - All-IP Network** |  | 448d? | 2004-06-28 A | 2006-03-15 A | 100% |  | 2004-06-28 | 2006-03-15 | 448d? |  |  | S1 | 7168h | 7168h | AIPN | NTT DoCoMo | Rel-8 | Alain |  |  |  | SP-38 |
| 672 | 180.1 | Deleted - Stage 1 |  | 448d? | 2004-06-28 A | 2006-03-15 A | 100% |  | 2004-06-28 | 2006-03-15 | 448d? |  | finish no earlier than 2006-03-15 | S1 | 3584h | 3584h | AIPN | NTT DoCoMo | Rel-8 | Alain | 22.258 |  |  | SP-38 |
| 673 | 181 | Deleted - was Rel7 - LCS for 3GPP Interworking WLAN | milestone | 0d? | 2007-09-28 A | 2007-09-28 A | 100% |  | 2007-09-28 | 2007-09-28 | 0d? |  | start no earlier than 2007-09-28 | S2 |  |  | LCS4_IWLAN | LG Electronics | Rel-8 | Maurice | 23.234, 23.271, 23.167 |  |  | SP-35 |
| 674 | 182 | Deleted - never approved- FBI Phase 2 | milestone | 0d | 2007-09-28 A | 2007-09-28 A | 100% |  | 2007-09-28 | 2007-09-28 | 0d |  | start no earlier than 2007-09-28 | S2 |  |  | FBI2 | Nokia Siemens Networks | Rel-8 | Maurice |  |  |  | SP-38 |
| 675 | 183 | Deleted -Enhancements to BS30 Bearer service for Videotelephony | milestone | 0d? | 2007-03-15 A | 2007-03-15 A | 100% |  | 2007-03-15 | 2007-03-15 | 0d? |  | finish no earlier than 2007-03-15 | S1 |  |  | BS30 |  | Rel-8 | Alain | 22.002, 22.004, 22.101, 22.105, 24.008 |  |  | SP-38 |
| 676 | 184 | Deleted - IMS Enhancements Rel-8 |  | 75d? | 2007-09-03 A | 2007-12-14 A | 100% |  | 2007-09-03 | 2007-12-14 | 75d? |  |  | S1 | 600h | 600h | IMS8 | Telecom Italia | Rel-8 | Alain |  |  | SP-37 | SP-38 |
| 677 | 185 | Release 8 Feasibility Studies | milestone | 0d? | 2008-03-20 | 2008-03-20 |  |  | 2008-03-20 | 2008-03-20 | 0d? | 647d | finish no earlier than 2008-03-20 | CP,GP,RP,SP |  |  |  |  | Rel-8 |  |  |  |  |  |
| 678 | 186 | Study on Customised Alerting Tone (CAT) Requirements |  | 245d? | 2005-10-07 A | 2006-09-14 A | 100% |  | 2005-10-07 | 2006-09-14 | 245d? |  | start no earlier than 2005-10-07 | S1 | 1960h | 1960h | FS_CAT | China Mobile | Rel-8 | Alain | 22.982 |  |  |  |
| 679 | 187 | Study on Facilitating Machine to Machine Communication in GSM and UMTS (M2M) |  | 350d? | 2005-11-04 A | 2007-03-08 A | 100% |  | 2005-11-04 | 2007-03-08 | 350d? |  | finish no earlier than 2006-06-16 | S1 | 2800h | 2800h | FS_M2M | Siemens | Rel-8 | Alain | 22.868 |  |  |  |
| 680 | 188 | Study on Network Composition |  | 526d? | 2005-12-07 A | 2007-12-12 A | 100% |  | 2005-12-07 | 2007-12-12 | 526d? |  | finish no earlier than 2006-09-27 | S1 | 4208h | 4208h | FS_NetComp | Nokia Siemens Networks | Rel-8 | Alain | 22.980 |  |  |  |
| 681 | 189 | Study on Requirements of IMS Multimedia Conferencing |  | 330d? | 2006-06-08 A | 2007-09-12 A | 100% |  | 2006-06-08 | 2007-09-12 | 330d? |  | finish no earlier than 2007-03-21 | S1 | 2640h | 2640h | FS_IMSconf | China Mobile | Rel-8 | Alain | 22.948 |  |  |  |
| 682 | 190 | Study on support of a Public Warning System |  | 140d? | 2007-09-03 A | 2008-03-14 A | 100% |  | 2007-09-03 | 2008-03-14 | 140d? |  |  | S1 | 1120h | 1120h | FS_PWS | T-Mobile | Rel-8 | Alain | 22.968 |  |  |  |
| 683 | 191 | Study on Paging Permission with Access Control |  | 256d? | 2006-09-28 A | 2007-09-20 A | 100% |  | 2006-09-28 | 2007-09-20 | 256d? |  | finish no earlier than 2007-09-20 | S1 | 2048h | 2048h | FS_PPAC | NTT DoCoMo | Rel-8 | Alain | 22.908 |  |  |  |
| 684 | 192 | Study on Non 3GPP access NSP |  | 392d? | 2006-12-06 A | 2008-06-05 A | 100% |  | 2006-12-06 | 2008-06-05 | 392d? |  | finish no earlier than 2007-11-19 | S1 | 3136h | 3136h | FS_N3GtoNSP | Telefonica O2 | Rel-8 | Alain | 22.912 |  |  |  |
| 685 | 193 | Study on Value Added Services for Short Message Service |  | 263d? | 2006-12-06 A | 2007-12-07 A | 100% |  | 2006-12-06 | 2007-12-07 | 263d? |  | finish no earlier than 2007-12-07 | S1 | 2104h | 2104h | FS_VAS4SMS | China Mobile | Rel-8 | Alain | 22.942 |  |  |  |
| 686 | 194 | Study on Service continuity between mobile and WLAN networks |  | 262d? | 2006-12-06 A | 2007-12-06 A | 100% |  | 2006-12-06 | 2007-12-06 | 262d? |  | finish no earlier than 2008-12-25 | S1 | 2096h | 2096h | FS_SMLSWLAN | BT | Rel-8 | Alain | 22.937 |  |  |  |
| 687 | 195 | Study on Services Alignment and Migration |  | 331d? | 2006-12-06 A | 2008-03-12 A | 100% |  | 2006-12-06 | 2008-03-12 | 331d? |  | finish no earlier than 2007-09-20 | S1 | 2648h | 2648h | FS_ServAl | China Mobile | Rel-8 | Alain | 22.983 |  | SP-37 |  |

Notes:
- 661: GP#42 completion 05/09=>09/09 / Text5: Michel.monnerat@thalesaleniaspace.com
- 662: GP#42 completion 05/09=>09/09 / Text5: Michel.monnerat@thalesaleniaspace.com
- 663: GP#42 stagnates at 0% / Text5: Michel.monnerat@thalesaleniaspace.com
- 664: GP#41 completion 09/09=>11/09 / Text5: mats.y.samuelsson@ericsson.com, hakan.e.grunditz@ericsson.com
- 665: GP#41 completion 09/09=>11/09 / Text5: hakan.e.grunditz@ericsson.com
- 666: GP#41 completed / Text5: mats.y.samuelsson@ericsson.com
- 667: GP#40 completed / Text5: Franz.Segerer@ROHDE-SCHWARZ.COM
- 668: GP#42 stagnates at 0%. Decision to continue/stop at GP#43 09/09 / Text5: arsi.heino@nokia.com
- 671: SA#38 stopped. 25/07/08 Moved UID_31059 Study on All-IP Network (FS_AIPN/was AIPFS ) to Rel-7 out of the stopped Rel-8 Feature UID_31067 Deleted - All-IP Network (AIPN) / Text5: c.masyu@nttdocomo.co.jp
- 672: 22.258 withdrawn, superseded by 22.278 (UID 320022). SA#38 stopped / Text5: c.masyu@nttdocomo.co.jp
- 673: SP-35 stopped / Text5: dhshim@lge.com
- 674: SA#38 stopped
- 675: SA#38 stopped (no support) / Text5: andre.jarvis@three.co.uk
- 676: SA#38 stopped
- 678: Spin-off WID UID_370028 under Feature CAT UID_340029 / Text5: fenglingjuan@chinamobile.com
- 679: SA#35 completed. Spin-off SA3 SID UID_370053. SA#40 Spin-off new Feature UID_400033 (NIMTC) / Text5: Juergen Merkel
- 680: SA#38 completed / Text5: Joerg Swetina (joerg.swetina@nw.neclab.eu)
- 681: SA#37 completed. Spin-off New Feature UID_370026 (VAS4SM) / Text5: zhengjianping@chinamobile.com
- 682: SA#39 completed. Spin-off Rel-9 Feature UID_380057 (PWS) / Text5: mark.younge@t-mobile.com
- 683: SA#37 completed. Spin-off new Feature UID_370084 (PPACR) / Text5: noguchi@nttdocomo.co.jp
- 684: SA#38 completed. Spin-off New Feature UID_380062 (N3GTONSP). SA#40 WID updated SP-060930=>SP-080318. TR re-approved with new # 22.812=>22.912 / Text5: chris.friel@o2.com
- 685: SA#38 completed. Spin-off New Feature UID_370026 (VAS4SM) / Text5: wubin@chinamobile.com
- 686: SA#38 completed / Text5: mike.meyerstein@bt.com
- 687: SA#39 completed. Spin-off Feature UID_330017 (ServAl) / Text5: fenglingjuan@chinamobile.com

| ID | WBS | Task | Duration | Start | Finish | Complete | Remaining | Baseline start | Baseline finish | Baseline duration | Total slack | Constraint | Resources | Work | Actual work | Text1 | Text4 | Text5 | Text6 | Text8 | Text3 | Text2 | Text7 | Text11 | Text9 | Text12 |
| --- | --- | --- | --- | --- | --- | --- | --- | --- | --- | --- | --- | --- | --- | --- | --- | --- | --- | --- | --- | --- | --- | --- | --- | --- | --- | --- |
| 688 | 196 | **Study on 3GPP System Architecture Evolution** | 1115d? | 2004-12-03 A | 2009-03-12 A | 100% |  | 2004-12-03 | 2009-03-12 | 1115d? |  |  | S2,S3 | 23456h | 23456h | FS_SAE | Vodafone | Chris Pudney | Rel-8 | Maurice |  |  |  |  |  |  |
| 689 | 196.1 | Stage 2 Interim conclusion for RAN Work to start | 990d? | 2004-12-03 A | 2008-09-18 A | 100% |  | 2004-12-03 | 2008-09-18 | 990d? |  | finish no earlier than 2005-09-23 | S2 | 7920h | 7920h | FS_SAE | Vodafone | Chris Pudney | Rel-8 | Maurice | 23.882 |  |  |  |  |  |
| 690 | 196.2 | Stage 2 study on 3GPP architectural development | 704d? | 2006-01-09 A | 2008-09-18 A | 100% |  | 2006-01-09 | 2008-09-18 | 704d? |  | finish no earlier than 2007-09-28 | S2 | 5632h | 5632h | FS_SAE | Vodafone | Chris Pudney | Rel-8 | Maurice | 23.882 |  |  |  |  |  |
| 691 | 196.3 | Security study for Inter-access mobility between non-3GPP and 3GPP system | 334d? | 2007-09-03 A | 2009-03-12 A | 100% |  | 2007-09-03 | 2009-03-12 | 334d? |  | finish no earlier than 2009-03-12 | S3 | 2672h | 2672h | FS_SAE | Nokia | dajiang.zhang@nokia.com | Rel-8 | Dionisio | 33.821, 33.822 |  |  |  |  |  |
| 692 | 197 | Study on Stage 2 aspects of IMS Service Brokering | 589d? | 2006-06-19 A | 2008-09-18 A | 100% |  | 2006-06-19 | 2008-09-18 | 589d? |  | finish no earlier than 2008-09-18 | S2 | 4712h | 4712h | FS_ISB_ST2 | Telcordia | raquel@research.telcordia.com | Rel-8 | Maurice | 23.810 |  |  |  |  |  |
| 693 | 198 | Study on IMS utilizing multicast bearer services | 447d? | 2006-03-22 A | 2007-12-06 A | 100% |  | 2006-03-22 | 2007-12-06 | 447d? |  | finish no earlier than 2007-12-03 | S2 | 3576h | 3576h | FS_MLTICAST-IMS | Nokia Siemens Networks |  | Rel-8 | Maurice | 23.847 |  |  |  |  |  |
| 694 | 199 | Study on Mobility between 3GPP-WLAN Interworking and 3GPP Systems | 393d? | 2007-03-20 A | 2008-09-18 A | 100% |  | 2007-03-20 | 2008-09-18 | 393d? |  | finish no earlier than 2008-09-18 | S2 | 3144h | 3144h | FS_SM3GWLAN | Orange |  | Rel-8 | Maurice | 23.827 withdrawn |  |  |  |  |  |
| 695 | 200 | Study on Multimedia Session Continuity | 291d? | 2007-04-26 A | 2008-06-05 A | 100% |  | 2007-04-26 | 2008-06-05 | 291d? |  | finish no earlier than 2008-06-05 | S2 | 2328h | 2328h | FS_MMSC | LG Electronics |  | Rel-8 | Maurice | 23.893 |  |  |  |  |  |
| 696 | 201 | **Study on centralized IMS service control** | 363d? | 2006-10-23 A | 2008-03-12 A | 100% |  | 2006-10-23 | 2008-03-12 | 363d? |  |  | S2,S1 | 7952h | 7952h | FS_ICS | Ericsson | peter.bleckert@ericsson.com | Rel-8 | Alain |  | PCG-21 | SP-38 |  |  |  |
| 697 | 201.1 | Study on centralized IMS services requirements | 268d? | 2007-03-05 A | 2008-03-12 A | 100% |  | 2007-03-05 | 2008-03-12 | 268d? |  | start no earlier than 2007-03-05 | S1 | 2144h | 2144h | FS_ICS-S1 | Ericsson | peter.bleckert@ericsson.com | Rel-8 | Alain | 22.892 |  | SP-37 |  |  |  |
| 698 | 201.2 | Study on centralized IMS services control | 363d? | 2006-10-23 A | 2008-03-12 A | 100% |  | 2006-10-23 | 2008-03-12 | 363d? |  | finish no earlier than 2008-02-21 | S2 | 2904h | 2904h | FS_IMS_CSC | Alcatel-Lucent | Andy Bennett (andybennett@alcatel-lucent.com) | Rel-8 | Maurice | 23.892 |  |  |  |  |  |
| 699 | 202 | Study on Architecture of IMS based Customized Alerting Tone (CAT) | 208d? | 2007-12-04 A | 2008-09-18 A | 100% |  | 2007-12-04 | 2008-09-18 | 208d? |  | finish no earlier than 2008-09-08 | S2 | 1664h | 1664h | FS_CAT-St2 | China Mobile | WANG, Jing (wangjing@chinamobilecom) | Rel-8 | Maurice | 23.872 | PCG-21 | SP-38 |  |  |  |
| 700 | 203 | Study on Home (e)NodeB Security | 321d? | 2007-12-20 A | 2009-03-12 A | 100% |  | 2007-12-20 | 2009-03-12 | 321d? |  | finish no earlier than 2009-03-10 | S3 | 2568h | 2568h | FS_HNB_Sec | Huawei | yangyanmei@huawei.com | Rel-8 | Dionisio | 33.820 | PCG-21 | SP-38 |  |  |  |
| 701 | 204 | Study on Transferring of emergency call data – in-band modem solution | 265d? | 2006-12-07 A | 2007-12-12 A | 100% |  | 2006-12-07 | 2007-12-12 | 265d? |  | finish no earlier than 2008-09-18 | S4 | 2120h | 2120h | eCALLIBMS | Airbiquity | lhong@airbiquity.com | Rel-8 | Paolo | 26.967 |  |  |  |  |  |
| 702 | 205 | Study on Element Operations Systems Function (EOSF) definition | 266d? | 2007-06-07 A | 2008-06-12 A | 100% |  | 2007-06-07 | 2008-06-12 | 266d? |  | finish no earlier than 2008-12-11 | S5 | 2128h | 2128h | OAM7-NIM- EOSF | China Mobile | LI, Jian | Rel-8 | Dionisio | 32.819 |  |  |  |  |  |
| 703 | 206 | Study on SA5 MTOSI XML Harmonization | 351d? | 2006-05-10 A | 2007-09-12 A | 100% |  | 2006-05-10 | 2007-09-12 | 351d? |  | finish no earlier than 2007-12-14 | S5 | 2808h | 2808h | OAM7-NIM-XML | Nortel | jduguay@nortel.com | Rel-8 | Dionisio | 32.818 |  |  |  |  |  |
| 704 | 207 | Study on Common Profile Storage (CPS) Framework of User Data for network services and management | 244d? | 2006-07-03 A | 2007-06-07 A | 100% |  | 2006-07-03 | 2007-06-07 | 244d? |  | finish no earlier than 2007-06-07 | S5 | 1952h | 1952h | OAM7-CPS | T-Mobile | istvan.aba@t-mobile.at | Rel-8 | Dionisio | 32.808 |  |  |  |  |  |
| 705 | 208 | Study on Management for LTE and SAE | 526d? | 2006-12-07 A | 2008-12-11 A | 100% |  | 2006-12-07 | 2008-12-11 | 526d? |  | finish no earlier than 2008-12-11 | S5 | 4208h | 4208h | FS_OAM_LTE_SAE | Ericsson | PETERSEN, Robert | Rel-8 | Dionisio | 32.816 |  |  |  |  |  |
| 706 | 209 | Study on Charging Aspects of 3GPP System Evolution | 179d? | 2007-04-02 A | 2007-12-06 A | 100% |  | 2007-04-02 | 2007-12-06 | 179d? |  | finish no earlier than 2007-12-06 | S5 | 1432h | 1432h | FS_SAEcharg | Nokia Siemens Networks | GÖRMER, Gerald | Rel-8 | Dionisio | 32.820 |  |  |  |  |  |
| 707 | 210 | Study on AS-MRFC media server control protocol | 583d? | 2006-03-22 A | 2008-06-13 A | 100% |  | 2006-03-22 | 2008-06-13 | 583d? |  | finish no earlier than 2008-06-13 | C1 | 4664h | 4664h | MRFC | HP | mark.syrett@hp.com | Rel-8 | Frederic | 24.880 |  |  |  |  |  |
| 708 | 211 | Study on IMS Restoration Procedures | 310d? | 2007-03-26 A | 2008-05-30 A | 100% |  | 2007-03-26 | 2008-05-30 | 310d? |  | finish no earlier than 2008-05-30 | C4 | 2480h | 2480h | FS_IMS_RP | Ericsson | german.blanco@ericsson.com | Rel-8 | Kimmo | 23.820 |  |  |  |  |  |
| 709 | 212 | Study on IMS Application Server Service Data Descriptions for AS interoperability | 261d? | 2007-09-14 A | 2008-09-12 A | 100% |  | 2007-09-14 | 2008-09-12 | 261d? |  | finish no earlier than 2008-09-12 | C4 | 2088h | 2088h | FS_IMS_ASIO | Alcatel-Lucent | Jean-Jacques Trottin | Rel-8 | Kimmo | 29.864 |  |  |  |  |  |
| 710 | 213 | Study on Customized Alerting Tone (CAT) solution for voice and video call in CS domain | 261d? | 2007-09-14 A | 2008-09-12 A | 100% |  | 2007-09-14 | 2008-09-12 | 261d? |  |  | C4 | 626.4h | 626.4h | FS_CAT_VVC_CS | China Mobile | zhanghao@chinamobile.com | Rel-8 | Kimmo | 29.882 |  |  |  |  |  |
| 711 | 214 | Study on InterWorking Function between MAP based and Diameter based interfaces | 266d? | 2007-11-30 A | 2008-12-05 A | 100% |  | 2007-11-30 | 2008-12-05 | 266d? |  | finish no earlier than 2008-12-05 | C4 | 2128h | 2128h | FS_MAP2Diam | Huawei | liming49985@huawei.com | Rel-8 | Kimmo | 29.805 | PCG-21 | CP-38 |  |  |  |
| 712 | 215 | Study on Scope of future HSPA Evolution for 1.28Mcps TDD | 186d? | 2007-09-14 A | 2008-05-30 A | 100% |  | 2007-09-14 | 2008-05-30 | 186d? |  | finish no earlier than 2008-05-30 | R1 | 1488h | 1488h | FS_RAN-LCRTDDHSPAEvo | RITT | Xu Fei | Rel-8 | Patrick | 25.824 |  | RP-37 | RP-080290 |  |  |
| 713 | 216 | Study on Synchronized E-DCH for UTRA FDD | 126d? | 2007-09-14 A | 2008-03-07 A | 100% |  | 2007-09-14 | 2008-03-07 | 126d? |  | finish no earlier than 2008-03-14 | R1 | 1008h | 1008h | FS_RAN-UplinkSync | Nokia Siemens Networks | Karri.Ranta-aho@nsn.com | Rel-8 | Patrick | 25.823 |  | RP-37 | RP-080068 |  |  |
| 714 | 217 | Study on Improved network controlled mobility between LTE and 3GPP2/mobile WiMAX radio technologies | 131d? | 2007-06-04 A | 2007-12-03 A | 100% |  | 2007-06-04 | 2007-12-03 | 131d? |  | finish no earlier than 2007-12-03 | R4 | 1048h | 1048h | FS_RAN-LTEmob | Motorola | hao.bi@Motorola.com | Rel-8 | Stefania | 36.938 |  |  | RP-070827 |  |  |
| 715 | 218 | Study on 3G Home NodeB/eNodeB | 325d? | 2007-03-05 A | 2008-05-30 A | 100% |  | 2007-03-05 | 2008-05-30 | 325d? |  | finish no earlier than 2008-05-30 | R4 | 2600h | 2600h | FS_RAN-HNBeNB | Motorola | howard.thomas@motorola.com | Rel-8 | Stefania | 25.820 |  |  | RP-080289 |  |  |
| 716 | 219 | Study on HS-PDSCH serving cell change enhancements | 60d? | 2007-12-17 A | 2008-03-07 A | 100% |  | 2007-12-17 | 2008-03-07 | 60d? |  | finish no earlier than 2008-06-12 | R4 | 480h | 480h | FS_RAN-HSPDSCH | Qualcomm |  | Rel-8 | Stefania | none | PCG-21 | RP-38 | RP-080070 |  |  |
| 717 | 220 | Study on Dual-Cell HSDPA operation | 261d? | 2007-08-15 A | 2009-03-06 A | 100% |  | 2007-08-15 | 2009-03-06 | 261d? |  | finish no earlier than 2009-03-06 | R1 | 2088h | 2088h | FS_RAN-DCHS | Qualcomm | Josef Blanz | Rel-8 | Patrick | withdrawn 25.825 v100 | PCG-21 | RP-39 | RP-090066 |  |  |
| 718 | 221 | Study on A-interface over IP | 126d? | 2007-08-31 A | 2008-02-22 A | 100% |  | 2007-08-31 | 2008-02-22 | 126d? |  | finish no earlier than 2008-02-22 | GP | 1008h | 1008h | AINTIP | China Mobile, Ericsson | paul.schliwa-bertling@ericsson.com | Rel-8 | Paolo | 43.903 |  |  |  |  |  |
| 719 | 222 | Study on Multi-User Reusing-One-Slot | 472d? | 2007-11-16 A | 2009-09-04 | 98% | 9.42d? | 2007-11-16 | 2009-09-04 | 472d? | 265d | finish no earlier than 2009-09-04 | GP | 3768h | 3692.64h | MUROS | Nokia Siemens Networks | juergen.hofmann@nsn.com | Rel-8 | Paolo | 45.914 |  |  |  |  |  |
| 720 | 223 | Study on Optimized Transmit Pulse Shape for Downlink EGPRS2-B | 472d? | 2007-11-16 A | 2009-09-04 | 95% | 23.55d? | 2007-11-16 | 2009-09-04 | 472d? | 265d | finish no earlier than 2009-09-04 | G1 | 3768h | 3579.6h | WIDER | RIM, Nokia Siemens Networks | jdwyer@RIM.COM and eddie.riddington@nsn.com | Rel-8 | Paolo | 45.913 |  |  |  |  |  |
| 721 | 224 | Deleted - equals 340035 -FS on Service continuity between mobile and WLAN networks | 75d? | 2007-09-03 A | 2007-12-14 A | 100% |  | 2007-09-03 | 2007-12-14 | 75d? |  | finish no earlier than 2007-12-14 | S1 | 600h | 600h | FSSCMobToW | BT | mike.meyerstein@bt.com | Rel-8 | Alain | 22.937 |  | SP-37 |  | PCG-21 | SP-39 |
| 722 | 225 | Deleted - Study on Evaluation of LCS Control Plane Solution for EPS | 100d? | 2008-01-14 A | 2008-05-30 A | 100% |  | 2008-01-14 | 2008-05-30 | 100d? |  | finish no earlier than 2009-03-20 | S2 | 800h | 800h | FS_LCS_EPS | SiRF |  | Rel-8 | Maurice | 23.891 |  | SP-38 |  | PCG-21 | SP-40 |
| 723 | 226 | Release 7 Features | 1d? | 2000-01-03 | 2000-01-03 |  |  | 2000-01-03 | 2000-01-03 | 1d? | 2791d | start no earlier than 2000-01-01 | CP,GP, RP,SP | 8h |  |  |  |  | Rel-7 |  |  |  |  |  |  |  |

Notes:
- 688: SA#43 completed
- 689: SA#41 completed
- 690: SA#41 completed
- 691: SA#43 completed
- 692: SA#41 completed. No spin-off activity proposed. [Note: IMS Service Brokering enhancements UID_31088 moved back from R8 to R7 to give a home to 22228CR0036_(Rel-7)_S1-051232. Hence, Rel-7 ISB has Stage 1 only (and is misaligned with Rel-7 Stages 2/3.]
- 693: SA#38 completed
- 694: 08/08/08 TR 23.827 v 0.4.0 no progress for 1 year. MCC recommended FS be completed and 23.827 brought under CR. SA#41 completed (draft TR 23.827 not SA approved/published; TR content implemented in TSs)
- 695: SA#40 completed
- 696: SA#39 completed
- 697: SA#39 completed
- 698: SA#39 completed
- 699: SA#41 completed as Rel-8
- 700: SA#43 completed as Rel-8
- 701: SA#38 completed. Spin-off WID UID_34042 (eCall_Phase2)
- 702: SA#40 completed. SID updated SP-050608=>SP-070307
- 703: SA#37 completed. SID updated SP-050295=>SP-070305
- 704: SA#36 completed. Spin-off New Feature UID_400034 (UDC)
- 705: SA#42 completed
- 706: SA#38 completed
- 707: CT#40 completed. Spin-off New Feature UID_380035 (MRFC_TS)
- 708: CT#40 completed. Spin-off WID UID_400012 (IMS_RP)
- 709: CT#41 completed. Linked to SA5 Study on Common Profile Storage framework UID_320006. Spin-off WID UID_410003 (IMS_ASIO)
- 710: CT#41 completed. Spin-off WID under Feature CAT UID_340029
- 711: CT#41 Spin-off WID UID_410007 (MAP2Diam). CP#42 completed
- 712: SID in RP-070748. RP#40 completed. SR in RP-080290
- 713: SID in RP-070678. RP#39 completed. SR in RP-080068
- 714: SR in RP-070827. RP#38 completed
- 715: SID in RP-070257. RP#40 completed. SR in RP-080289
- 716: SID in RP-071044. SR in RP-080070. The study produced no TR. RP#39 completed. Spin-off New implementation WID in RP-080227
- 717: RP#43 closed. TR 25.825 v100 withdrawn. Conclusions in RP-090318 RAN1 findings of the UTRA Multi-Carrier Evolution study). RP#42 New WID RP-080490 (RANimp-DCHSDPA) UID_400052 approved
- 718: GP#37 completed. Spin-off implementation Feature AoIP (A-interface over IP) UID_50591
- 719: GP#42 completion 11/08=>02/09=>05/09=>09/09. Spin-off implementation WI UID_420002 VAMOS (Voice services over Adaptive Multi-user channels on One Slot)
- 720: GP#42 completion 11/08=>02/09=>05/09=>09/09. Needs some more work to define possible Rel-9 or Rel-10 implementation work
- 721: SA#39 stopped
- 722: SA#40 spin-off Feature UID_400038 (LCS_CPS_EPS). SA#40 FS stopped

| ID | WBS | Task | Type | Duration | Start | Finish | Complete | Baseline start | Baseline finish | Baseline duration | Constraint | Resources | Work | Actual work | Text1 | Text4 | Text5 | Text6 | Text8 | Text12 | Text11 | Text7 | Text2 |
| --- | --- | --- | --- | --- | --- | --- | --- | --- | --- | --- | --- | --- | --- | --- | --- | --- | --- | --- | --- | --- | --- | --- | --- |
| 724 | 227 | **Identification of Communication Services in IMS** |  | 620d? | 2005-05-02 A | 2007-09-14 A | 100% | 2005-05-02 | 2007-09-14 | 620d? |  | S2,S1,C1,S5 | 13016h | 13016h | ServID | Ericsson | stephen.terrill@ericsson.com | Rel-7 | Maurice |  |  |  |  |
| 725 | 227.1 | TR on ServID |  | 232d? | 2005-05-02 A | 2006-03-21 A | 100% | 2005-05-02 | 2006-03-21 | 232d? | finish no earlier than 2006-03-20 | S2 | 1856h | 1856h | ServID | Ericsson | stephen.terrill@ericsson.com | Rel-7 | Maurice |  |  |  |  |
| 726 | 227.2 | Stage 1,2 of ServID |  | 144d? | 2005-11-11 A | 2006-05-31 A | 100% | 2005-11-11 | 2006-05-31 | 144d? | start no earlier than 2005-11-11 | S1,S2 | 1152h | 1152h | ServID | Ericsson | stephen.terrill@ericsson.com | Rel-7 | Maurice |  |  |  |  |
| 727 | 227.3 | Stage 3 of ServID |  | 250d? | 2006-03-31 A | 2007-03-15 A | 100% | 2006-03-31 | 2007-03-15 | 250d? | finish no earlier than 2007-03-15 | C1 | 2000h | 2000h | ServID | Ericsson | christer.holmberg@ericsson.com | Rel-7 | Frederic |  |  |  |  |
| 728 | 227.4 | Charging of ServID |  | 381d? | 2006-03-31 A | 2007-09-14 A | 100% | 2006-03-31 | 2007-09-14 | 381d? | finish no earlier than 2007-09-14 | S5 | 3048h | 3048h | ServID | Orange | alain.bibas@orange-ft.com | Rel-7 | Dionisio |  |  |  |  |
| 729 | 228 | **Supporting Globally Routable User Agent URIs in IMS** |  | 415d? | 2005-11-14 A | 2007-06-15 A | 100% | 2005-11-14 | 2007-06-15 | 415d? |  | S2,S1,C1 | 7760h | 7760h | GRUU | RIM | Adrian Buckley (abuckley@rim.com) | Rel-7 | Maurice |  |  |  |  |
| 730 | 228.1 | Deleted - TR on GRUU |  | 219d? | 2005-11-14 A | 2006-09-14 A | 100% | 2005-11-14 | 2006-09-14 | 219d? | finish no earlier than 2006-09-14 | S2 | 1752h | 1752h | GRUU | RIM | Adrian Buckley (abuckley@rim.com) | Rel-7 | Maurice | SP-32 |  |  |  |
| 731 | 228.2 | Stage 1,2 of GRUU |  | 65d? | 2006-07-03 A | 2006-09-29 A | 100% | 2006-07-03 | 2006-09-29 | 65d? | start no earlier than 2006-07-03 | S1,S2 | 520h | 520h | GRUU | RIM | Adrian Buckley (abuckley@rim.com) | Rel-7 | Maurice |  |  |  |  |
| 732 | 228.3 | Stage 3 of GRUU |  | 271d? | 2006-06-02 A | 2007-06-15 A | 100% | 2006-06-02 | 2007-06-15 | 271d? | finish no earlier than 2007-06-15 | C1 | 2168h | 2168h | GRUU | CableLabs | Bernie McKibben | Rel-7 | Frederic |  |  |  |  |
| 733 | 229 | **Multimedia Telephony Service for IMS** |  | 357d? | 2006-02-01 A | 2007-06-15 A | 100% | 2006-02-01 | 2007-06-15 | 357d? |  | S1,C1,S4 | 8976h | 8976h | MTSI | Ericsson | peter.bleckert@ericsson.com | Rel-7 | Alain |  |  |  |  |
| 734 | 229.1 | Stage 1 of MTSI |  | 173d? | 2006-02-01 A | 2006-09-29 A | 100% | 2006-02-01 | 2006-09-29 | 173d? | start no earlier than 2006-02-01 | S1 | 1384h | 1384h | MTSI-REQ | Ericsson | peter.bleckert@ericsson.com | Rel-7 | Alain |  |  |  |  |
| 735 | 229.2 | Stage 3 of MTSI |  | 330d? | 2006-03-10 A | 2007-06-14 A | 100% | 2006-03-10 | 2007-06-14 | 330d? | finish no earlier than 2007-06-15 | C1 | 2640h | 2640h | MTSI | Ericsson | christer.holmberg@ericsson.com | Rel-7 | Frederic |  |  |  |  |
| 736 | 229.3 | Media handling and interaction in MTSI |  | 262d? | 2006-03-15 A | 2007-03-15 A | 100% | 2006-03-15 | 2007-03-15 | 262d? | finish no earlier than 2007-03-15 | S4 | 2096h | 2096h | MTSI-MHI | Ericsson | olle.franceschi@ericsson.com | Rel-7 | Paolo |  |  |  |  |
| 737 | 229.4 | Deleted - duplicates UID7039 - IMS Multimedia Telephony Service | milestone | 0d? | 2007-06-15 A | 2007-06-15 A | 100% | 2007-06-15 | 2007-06-15 | 0d? | start no earlier than 2007-06-15 | S1 |  |  | MMTEL | Ericsson | peter.bleckert@ericsson.com | Rel-7 | Alain | SP-32 |  |  |  |
| 738 | 230 | Multimedia Telephony Service for IMS (MTSI) - UE Conformance Testing |  | 387d | 2007-09-19 A | 2009-03-12 A | 100% | 2007-09-19 | 2009-03-12 | 387d | finish no earlier than 2009-03-13 | R5 | 1664h | 1664h | MTSI-UEConfTest | Ericsson, Motorola | Leif.Mattisson@ericsson.com, Jacob.John@motorola.com | Rel-7 | Ingbert |  | RP-090056 |  |  |
| 739 | 231 | TISPAN requirements for Multimedia Telephony with PSTN/ISDN simulation services |  | 58d? | 2007-09-18 A | 2007-12-06 A | 100% | 2007-09-18 | 2007-12-06 | 58d? | start no earlier than 2007-09-18 | S1 | 464h | 464h | TMMTEL7 |  |  | Rel-7 | Alain |  |  | SP-37 |  |
| 740 | 232 | **Maintenance of TISPAN release 1 common IMS** |  | 58d? | 2007-09-18 A | 2007-12-06 A | 100% | 2007-09-18 | 2007-12-06 | 58d? |  | S2 | 1392h | 1392h | MCIMSTR1 | Ericsson | Raymond Forbes | Rel-7 | Maurice |  |  | SP-38 | PCG-21 |
| 741 | 232.1 | SA1 aspects of MCIMSTR1 |  | 58d? | 2007-09-18 A | 2007-12-06 A | 100% | 2007-09-18 | 2007-12-06 | 58d? | finish no earlier than 2007-12-06 | S1 | 464h | 464h | MCIMSTR1-S1 | Telecom Italia | Marco.DeLuca1@telecomitalia.it | Rel-7 | Alain |  |  | SP-38 | PCG-21 |
| 742 | 232.2 | SA2 aspects of MCIMSTR1 |  | 58d? | 2007-09-18 A | 2007-12-06 A | 100% | 2007-09-18 | 2007-12-06 | 58d? | finish no earlier than 2007-12-06 | S2 | 464h | 464h | MCIMSTR1-S2 | Ericsson | Raymond Forbes | Rel-7 | Maurice |  |  | SP-38 | PCG-21 |
| 743 | 233 | **PS domain and IMS impacts for supporting IMS Emergency calls** |  | 1760d? | 2000-09-18 A | 2007-06-15 A | 100% | 2000-09-18 | 2007-06-15 | 1760d? |  | S2,S1 | 44157h | 44157h | EMC1 | Siemens | Rainer Liebhart | Rel-7 | Maurice |  |  |  |  |
| 744 | 10.1.1 | Service Requirements for IP-based emergency calls |  | 985d | 2000-09-18 A | 2004-06-25 A | 100% | 2000-09-18 | 2004-06-25 | 985d | finish no earlier than 2004-06-25 | S1 | 7880h | 7880h | EMC1 | Siemens | Rainer Liebhart | Rel-7 | Alain |  |  |  |  |
| 745 | 233.2 | Study on Stage 2 for IMS-level solution |  | 668d? | 2003-02-26 A | 2005-09-16 A | 100% | 2003-02-26 | 2005-09-16 | 668d? | finish no earlier than 2005-09-16 | S2 | 5344h | 5344h | EMC1 | Siemens | Rainer Liebhart | Rel-7 | Maurice |  |  |  |  |
| 746 | 233.3 | Study on Stage 2 for GPRS-level solution |  | 301d? | 2004-10-14 A | 2005-12-08 A | 100% | 2004-10-14 | 2005-12-08 | 301d? | finish no earlier than 2005-12-08 | S2 | 2408h | 2408h | EMC1 | Siemens | Rainer Liebhart | Rel-7 | Maurice |  |  |  |  |
| 747 | 233.4 | Stage 2 Specification Phase - IMS-level |  | 200d? | 2005-09-05 A | 2006-06-09 A | 100% | 2005-09-05 | 2006-06-09 | 200d? | finish no earlier than 2006-06-09 | S2 | 1600h | 1600h | EMC1 | Siemens | Rainer Liebhart | Rel-7 | Maurice |  |  |  |  |
| 748 | 233.5 | Deleted - Stage 2 Specification Phase - GPRS-level | milestone | 0d? | 2007-03-02 A | 2007-03-02 A | 100% | 2007-03-02 | 2007-03-02 | 0d? | start no earlier than 2007-03-02 | S2 |  |  | EMC1 | Siemens | Rainer Liebhart | Rel-7 | Maurice | SP-32 |  |  |  |

Notes:
- 724: WID approved SA#28. WID updated SA#32
- 725: Text3: 23.816
- 726: Text3: 22.228, 23.228, 23.203
- 727: CT#32 approved WID / Text3: 23.218, 24.229
- 728: Text3: 32.260, 32.298, 32.299
- 729: SA#29 approved WID
- 730: Abandoned
- 731: SA#29 approved WID / Text3: 22.228, 23.228, 23.218, 24.229
- 732: CT#32 approved WID / Text3: 24.229
- 734: Text3: 22.173
- 735: Text3: 24.173
- 736: Text3: 26.114
- 737: Text3: 22.173
- 738: RP#43 completed. Linked UID_7038 (MTSI) / Text3: 34.123-1, 34.123-2, 34.123-3, 34.229-1, 34.229-2
- 739: Text3: 22.273 (EI 181 002 maintenance)
- 740: Text3: http://www.3gpp.org/specs/TISPAN-IMS-ansfer.htm
- 741: Text3: 22.173, 22.273
- 742: Text3: 23.406, 23.417, 23.508,23.509, 23.511
- 744: Text3: 22.976 (DB shows 04/2003 withdrawn Study on PS domain services and capabilities (az: belongs this really here ?!)
- 745: Text3: 23.867
- 746: Text3: 23.867
- 747: Text3: 23.167, 23.228, 23.060, 23.002, 23.271

| ID | WBS | Task | Type | Duration | Start | Finish | Complete | Baseline start | Baseline finish | Baseline duration | Constraint | Resources | Work | Actual work | Text1 | Text4 | Text5 | Text6 | Text8 | Text3 | Text12 | Text10 | Text11 |
| --- | --- | --- | --- | --- | --- | --- | --- | --- | --- | --- | --- | --- | --- | --- | --- | --- | --- | --- | --- | --- | --- | --- | --- |
| 749 | 10.1 | **Emergency Call Enhancements for IP& PS Based Calls – stage 3** |  | 375d | 2006-01-09 A | 2007-06-15 A | 100% | 2006-01-09 | 2007-06-15 | 375d |  | C1 | 12845h | 12845h | EMC1 | Ericsson | alf.heidermark@ericsson.com | Rel-7 | Frederic |  |  |  |  |
| 750 | 10.1.2 | CT1 IMS aspects to support IMS Emergency sessions |  | 350.82d | 2006-01-09 A | 2007-06-15 A | 100% | 2006-01-09 | 2007-06-15 | 350.82d | finish no earlier than 2007-06-15 | C1 | 2806.57h | 2806.57h | EMC1 | Ericsson | alf.heidermark@ericsson.com | Rel-7 | Frederic | 24.229 |  |  |  |
| 751 | 10.1.2 | Deleted - CT3 IMS aspects to support IMS Emergency sessions |  | 95d | 2006-05-08 A | 2006-09-15 A | 100% | 2006-05-08 | 2006-09-15 | 95d | finish no earlier than 2006-09-15 | C3 | 760h | 760h | EMC1 | Ericsson | alf.heidermark@ericsson.com | Rel-7 | Gwiho | 29.163 | CP-33 |  |  |
| 752 | 10.1.5 | Deleted - CT3 PS domain aspects to support IMS Emergency sessions |  | 95d | 2006-05-08 A | 2006-09-15 A | 100% | 2006-05-08 | 2006-09-15 | 95d | start no earlier than 2006-05-08 | C3 | 760h | 760h | EMC1 | Ericsson | alf.heidermark@ericsson.com | Rel-7 | Gwiho | 29.061 | CP-33 |  |  |
| 753 | 10.1.5 | CT1 PS domain aspects to support IMS Emergency sessions |  | 349.9d | 2006-01-09 A | 2007-06-15 A | 100% | 2006-01-09 | 2007-06-15 | 349.9d | finish no earlier than 2007-06-15 | C1 | 2799.2h | 2799.2h | EMC1 | Ericsson | alf.heidermark@ericsson.com | Rel-7 | Frederic | 24.008, 24.234 |  |  |  |
| 754 | 10.1.5 | CT4 PS domain aspects to support IMS Emergency sessions |  | 365d | 2006-01-09 A | 2007-06-01 A | 100% | 2006-01-09 | 2007-06-01 | 365d | finish no earlier than 2007-06-01 | C4 | 2920h | 2920h | EMC1-GPRSc4 | Ericsson | alf.heidermark@ericsson.com | Rel-7 | Kimmo | 29.060 |  |  |  |
| 755 | 234 | IMS Support of Conferencing |  | 355d? | 2005-11-04 A | 2007-03-15 A | 100% | 2005-11-04 | 2007-03-15 | 355d? | finish no earlier than 2007-03-15 | C1 | 2840h | 2840h | IMSconf | Alcatel-Lucent | Keith Drage (drage@alcatel-lucent.com) | Rel-7 | Frederic | 24.147, 24.229 |  |  |  |
| 756 | 235 | Performance Characterization of VoIMS over HSDPA\EUL channels |  | 713d? | 2005-03-15 A | 2007-12-06 A | 100% | 2005-03-15 | 2007-12-06 | 713d? | finish no earlier than 2007-12-06 | S4 | 5704h | 5704h | VoIMS-PCVoIMS | Alcatel-Lucent | mcgowan@alcatel-lucent.com | Rel-7 | Paolo | 26.935 |  |  |  |
| 757 | 236 | **WLAN-UMTS Interworking Phase 2** |  | 371d? | 2004-01-05 A | 2005-06-07 A | 100% | 2004-01-05 | 2005-06-07 | 371d? |  | S1 | 3888h | 3888h | WLAN2 | Telenor | frederic.paint@telenor.com | Rel-7 | Alain | 33.234 (SP-36 SA3 CRs approved) |  |  |  |
| 758 | 236.1 | Stage 1 on Session Continuity |  | 115d? | 2004-01-05 A | 2004-06-11 A | 100% | 2004-01-05 | 2004-06-11 | 115d? | start no earlier than 2004-01-05 | S1 | 920h | 920h | WLAN-SC |  |  | Rel-7 | Alain | 22.234 |  | SP-24 |  |
| 759 | 236.2 | Stage 2 on Session Continuity: covered by SAE | milestone | 0d? | 2005-06-07 A | 2005-06-07 A | 100% | 2005-06-07 | 2005-06-07 | 0d? | finish no earlier than 2005-06-07 | S2 |  |  | WLAN-SC |  |  | Rel-7 | Maurice |  |  |  |  |
| 760 | 237 | **WLAN Interworking – Private Network access from WLAN 3GPP IP Access** |  | 252d? | 2005-10-10 A | 2006-09-26 A | 100% | 2005-10-10 | 2006-09-26 | 252d? |  | S2,C1,C3,C4 | 8936h | 8936h | WLANPNA | NEC | Toshiyuki Tamura (tamurato@aj.jp.nec.com) | Rel-7 | Maurice |  |  |  |  |
| 761 | 237.1 | WLAN-PNA - Stage 2 |  | 185d? | 2005-10-10 A | 2006-06-23 A | 100% | 2005-10-10 | 2006-06-23 | 185d? | start no earlier than 2005-10-10 | S2 | 1480h | 1480h | WLANPNA-st2 | NEC | Toshiyuki Tamura (tamurato@aj.jp.nec.com) | Rel-7 | Maurice | 23.234, 33.234 |  |  |  |
| 762 | 237.2 | **WLAN-PNA - Stage 3** |  | 170d? | 2006-02-01 A | 2006-09-26 A | 100% | 2006-02-01 | 2006-09-26 | 170d? |  | C1,C3,C4 | 5440h | 5440h | WLANPNA-st3 | NEC |  | Rel-7 | Frederic |  |  |  |  |
| 763 | 237.2.1 | CT1 aspets for WLAN-PNA |  | 170d? | 2006-02-01 A | 2006-09-26 A | 100% | 2006-02-01 | 2006-09-26 | 170d? | start no earlier than 2006-02-01 | C1 | 1360h | 1360h | WLANPNA-st3 | NEC |  | Rel-7 | Frederic | 24.234 |  |  |  |
| 764 | 237.2.2 | CT3 aspets for WLAN-PNA |  | 170d? | 2006-02-01 A | 2006-09-26 A | 100% | 2006-02-01 | 2006-09-26 | 170d? | start no earlier than 2006-02-01 | C3 | 1360h | 1360h | WLANPNA-st3 | NEC |  | Rel-7 | Gwiho | 29.161 |  |  |  |
| 765 | 237.2.3 | Deleted - CT4 aspets for WLAN-PNA |  | 170d? | 2006-02-01 A | 2006-09-26 A | 100% | 2006-02-01 | 2006-09-26 | 170d? | start no earlier than 2006-02-01 | C4 | 1360h | 1360h | WLANPNA-st3 | NEC |  | Rel-7 | Kimmo | 29.234 | CP-32 |  |  |
| 766 | 238 | **Enhancements to support QoS provisioning over 3GPP/WLAN Interworking** |  | 520d? | 2005-03-14 A | 2007-03-09 A | 100% | 2005-03-14 | 2007-03-09 | 520d? |  | S2,C4,C1 | 8360h | 8360h | WLANQOS | Samsung |  | Rel-7 | Maurice |  |  |  |  |
| 767 | 238.1 | Deleted - TR on support of QoS on WLAN |  | 232d? | 2005-03-14 A | 2006-01-31 A | 100% | 2005-03-14 | 2006-01-31 | 232d? | start no earlier than 2005-03-14 | S2 | 1856h | 1856h | WLANQOS | Samsung |  | Rel-7 | Maurice | 23.836 | SP-32 |  |  |
| 768 | 238.2 | Stage 2 on support of QoS over 3GPP/WLAN interworking |  | 108d? | 2006-02-01 A | 2006-06-30 A | 100% | 2006-02-01 | 2006-06-30 | 108d? | start no earlier than 2006-02-01 | S2 | 864h | 864h | WLANQOS | Samsung |  | Rel-7 | Maurice | 23.234 |  |  |  |
| 769 | 238.3 | Stage 3 CT4 on support of QoS over 3GPP/WLAN Interworking |  | 121d? | 2006-09-22 A | 2007-03-09 A | 100% | 2006-09-22 | 2007-03-09 | 121d? | finish no earlier than 2007-03-09 | C4 | 968h | 968h | WLANQOS | Huawei | zhang.peng@huawei.com | Rel-7 | Kimmo | 29.234, 23.008 |  |  |  |
| 770 | 238.4 | Stage 3 CT1 on support of QoS over 3GPP/WLAN Interworking |  | 64d? | 2006-09-04 A | 2006-11-30 A | 100% | 2006-09-04 | 2006-11-30 | 64d? | finish no earlier than 2006-11-30 | C1 | 512h | 512h | WLANQOS | Huawei | zhang.peng@huawei.com | Rel-7 | Frederic | 24.234 |  |  |  |
| 771 | 239 | **Location Services enhancements** |  | 906d? | 2004-06-28 A | 2007-12-17 A | 100% | 2004-06-28 | 2007-12-17 | 906d? |  | S1,S2,GP,C4,R2 | 46933.6h | 46933.6h | LCS3 |  |  | Rel-7 | Alain |  |  |  |  |
| 772 | 239.1 | Stage 2 for LCS3 (including IMS emergency location aspects) |  | 446d? | 2004-12-31 A | 2006-09-15 A | 100% | 2004-12-31 | 2006-09-15 | 446d? | finish no earlier than 2006-09-15 | S2 | 3568h | 3568h | LCS3 | SiRF | brodilitz@sirf.com | Rel-7 | Maurice | 23.271 |  |  |  |
| 773 | 239.2 | LCS Enhancements related to Location-Based Services |  | 695d? | 2005-01-03 A | 2007-08-31 A | 100% | 2005-01-03 | 2007-08-31 | 695d? | finish no earlier than 2007-08-31 | GP | 5560h | 5560h | LCS3-LBS | SiRF | kjudge@sirf.com | Rel-7 | Paolo | 43.059, 44.031, 48.008, 49.031 |  |  |  |
| 774 | 239.3 | CT4 aspects for LCS UEPos-LBS |  | 240d? | 2006-01-02 A | 2006-12-01 A | 100% | 2006-01-02 | 2006-12-01 | 240d? | finish no earlier than 2006-12-01 | C4 | 1920h | 1920h | LCS3-UEPos-LBS | SiRF | brodilitz@sirf.com | Rel-7 | Kimmo | 24.030, 24.080, 29.002 |  |  |  |
| 775 | 239.4 | UE positioning - Velocity |  | 394d? | 2005-03-15 A | 2006-09-15 A | 100% | 2005-03-15 | 2006-09-15 | 394d? | finish no earlier than 2006-09-15 | R2 | 3152h | 3152h | LCS3-UEPos-Velocity | SiRF | BRodilitz@SiRF.com | Rel-7 | Joern | 25.305, 25.331, 25.410, 25.413, 25.453 |  |  | RP-060459 |
| 776 | 239.5 | Inclusion of Uplink TDOA UE positioning method in the UTRAN specifications |  | 849d? | 2004-09-15 A | 2007-12-17 A | 100% | 2004-09-15 | 2007-12-17 | 849d? | finish no earlier than 2007-12-17 | R2 | 6792h | 6792h | LCS3-UEPos-UTDOA | TruePosition | Robert Gross | Rel-7 | Joern | 25.305, 25.453 |  |  | RP-070797 |

Notes:
- 751: Cancelled for Rel-7 and there is now corresponding Rel-8 WI
- 752: Cancelled for Rel-7 and there is now corresponding Rel-8 WI
- 755: CT#35 revised WID
- 757: Created at TSG#27 by A. Sultan because of WLAN items belonging to Rel-7. az: This WI is an exception of the WLAN-UMTS Interworking Rel-6 (No new WID)
- 761: Approved at SA#29
- 762: Approved at CT#29
- 763: Approved at CT#29
- 764: Approved at CT#29
- 765: CT4#31; no impacts identified, therefore completed. CP-32 stopped
- 766: Moved from FS section Feb 06. SP-30 updated WID
- 767: SP-32 stopped
- 768: SP-30 updated WID
- 769: CP-32 approved WID
- 770: CP-32 approved WID
- 772: SA#27 approved WID.
- 775: Completed Sept 2006; SR in RP-060459
- 776: Completed Nov 2007; SR in RP-070797

| ID | WBS | Task | Type | Duration | Start | Finish | Complete | Remaining | Baseline start | Baseline finish | Baseline duration | Total slack | Constraint | Resources | Work | Actual work | Text1 | Text4 | Text5 | Text6 | Text8 | Text12 | Text11 | Text2 | Text7 |
| --- | --- | --- | --- | --- | --- | --- | --- | --- | --- | --- | --- | --- | --- | --- | --- | --- | --- | --- | --- | --- | --- | --- | --- | --- | --- |
| 777 | 239.6 | **LCS for 3GPP Interworking WLAN** |  | 700d? | 2004-06-28 A | 2007-03-02 A | 100% |  | 2004-06-28 | 2007-03-02 | 700d? |  |  | S1 | 11901.6h | 11901.6h | LCS3-IWLAN | Telcordia | Mike Loushine | Rel-7 | Alain |  |  |  |  |
| 778 | 239.6.1 | FS on 3GPP system to WLAN Interworking with LCS |  | 512.7d? | 2004-06-28 A | 2006-06-30 A | 100% |  | 2004-06-28 | 2006-06-30 | 512.7d? |  | finish no earlier than 2005-09-29 | S1 | 4101.6h | 4101.6h | LCS3-IWLAN-FSs1 | Telcordia | Mike Loushine, Vijay Varma | Rel-7 | Alain |  |  |  |  |
| 779 | 239.6.2 | Delete - Study of work on an LCS architecture for I-WLAN. |  | 180d? | 2006-06-26 A | 2007-03-02 A | 100% |  | 2006-06-26 | 2007-03-02 | 180d? |  | finish no earlier than 2007-03-02 | S2 | 1440h | 1440h | LCS3-IWLAN-FSs2 | LG Electronics | dhshim@lge.com ; phede@lge.com | Rel-7 | Maurice | SP-35 |  |  |  |
| 780 | 239.6.3 | Stage 2 for LCS architecture for I-WLAN |  | 95d? | 2006-10-23 A | 2007-03-02 A | 100% |  | 2006-10-23 | 2007-03-02 | 95d? |  | finish no earlier than 2007-03-02 | S2 | 760h | 760h | LCS3-IWLAN | LG Electronics | dhshim@lge.com ; phede@lge.com | Rel-7 | Maurice |  |  |  |  |
| 781 | 239.7 | Deleted - UE positioning Rel-7 |  | 849d? | 2004-09-15 A | 2007-12-17 A | 100% |  | 2004-09-15 | 2007-12-17 | 849d? |  |  | RP | 6792h | 6792h | LCS3-UEpos |  |  | Rel-7 |  | RP-38 |  |  |  |
| 782 | 239.8 | Deleted - RAN2 aspects for LBS | milestone | 0d? | 2005-06-15 A | 2005-06-15 A | 100% |  | 2005-06-15 | 2005-06-15 | 0d? |  | start no earlier than 2005-06-15 | R2 |  |  | LCS3-UEPos-LBS | SiRF | BRodilitz@SiRF.com | Rel-7 | Joern | RP-31 |  |  |  |
| 783 | 240 | **MBMS Enhancements** |  | 625d? | 2005-07-11 A | 2007-11-30 A | 100% |  | 2005-07-11 | 2007-11-30 | 625d? |  |  | S1 | 10844.6h | 10844.6h | MBMSE | China Mobile | liuhongyfw@chinamobile.com | Rel-7 | Alain |  |  |  |  |
| 784 | 240.1 | Stage 1 of MBMSE |  | 109d? | 2005-07-11 A | 2005-12-08 A | 100% |  | 2005-07-11 | 2005-12-08 | 109d? |  | finish no earlier than 2005-12-08 | S1,R1,C3 | 872h | 872h | MBMSE | China Mobile | liuhongyfw@chinamobile.com | Rel-7 | Alain |  |  |  |  |
| 785 | 240.2 | MBMS FDD Physical layer Enhancements |  | 117.29d? | 2006-12-15 A | 2007-06-04 A | 100% |  | 2006-12-15 | 2007-06-04 | 117.29d? |  | finish no earlier than 2007-06-04 | R1 | 938.32h | 938.32h | MBMSE-RANPhysFDD | Ericsson | Lars.Lindbom@ericsson.com | Rel-7 | Patrick |  | RP-070290 |  |  |
| 786 | 240.3 | MBMS TDD Physical layer Enhancements |  | 117.29d? | 2006-12-15 A | 2007-06-04 A | 100% |  | 2006-12-15 | 2007-06-04 | 117.29d? |  | finish no earlier than 2007-06-04 | R1 | 938.32h | 938.32h | MBMSE-RANPhysTDD | IPWireless | Nicholas Anderson | Rel-7 | Patrick |  | RP-070291 |  |  |
| 787 | 240.4 | MBMS Low Chip Rate TDD Physical Layer Enhancement |  | 127d? | 2007-03-16 A | 2007-09-10 A | 100% |  | 2007-03-16 | 2007-09-10 | 127d? |  | finish no earlier than 2007-09-10 | R1 | 1016h | 1016h | MBMSE-RANPhysLCRTDD | RITT | Lin Hui | Rel-7 | Patrick |  | RP-070292 |  |  |
| 788 | 240.5 | MBMS Mz interface |  | 260d? | 2006-12-04 A | 2007-11-30 A | 100% |  | 2006-12-04 | 2007-11-30 | 260d? |  | finish no earlier than 2007-05-11 | C3 | 2080h | 2080h | MBMSMz | Huawei | Deng Tingting (ttdeng@huawei.com) | Rel-7 | Gwiho |  |  |  |  |
| 789 | 241 | **MBMS - UE Conformance Testing** |  | 602d? | 2007-06-01 A | 2009-09-18 | 68% | 191.38d? | 2007-06-01 | 2009-09-18 | 602d? | 255d |  | R5 | 12960h | 8837.34h | MBMSE_UEConTest |  |  | Rel-7 | Ingbert |  |  | PCG-21 | SP-40 |
| 790 | 241.1 | Conformance Test Aspects – MBMS TDD Physical layer Enhancements – MBSFN for HCR and VHCR TDD |  | 336d? | 2007-06-01 A | 2008-09-12 A | 100% |  | 2007-06-01 | 2008-09-12 | 336d? |  | start no earlier than 2007-06-01 | R5 | 2688h | 2688h | MBMSE-RANPhysTDD_UEConTest | IPWireless | tspeight@ipwireless.com | Rel-7 | Ingbert |  | RP-080541 |  |  |
| 791 | 241.2 | Conformance Test Aspects – MBMS LCR TDD Physical Layer Enhancement |  | 342d? | 2008-05-30 A | 2009-09-18 | 80% | 68.2d? | 2008-05-30 | 2009-09-18 | 342d? | 255d | finish no earlier than 2009-09-18 | R5 | 2728h | 2182.4h | MBMSE-RANPhysLCRTDD_UEConTest | CATT | chenxiaozhong@datangmobile.cn | Rel-7 | Ingbert |  | RP-090416 | PCG-21 | RP-40 |
| 792 | 241.3 | Conformance Test Aspects – MBSFN for FDD |  | 341d? | 2008-05-30 A | 2009-09-18 | 25% | 255.75d? | 2008-05-30 | 2009-09-18 | 341d? | 255d | finish no earlier than 2009-09-18 | R5 | 2728h | 682h | MBMSE-UEConTest_RANPhysFDD | Huawei | Xiang Li (trica_li@huawei.com) | Rel-7 | Ingbert |  | RP-090413 | PCG-21 | RP-40 |
| 793 | 242 | MBMS User Service Extensions |  | 392d? | 2005-12-07 A | 2007-06-07 A | 100% |  | 2005-12-07 | 2007-06-07 | 392d? |  | finish no earlier than 2007-06-07 | S4 | 3136h | 3136h | MBMSUSE | Ericsson | Thorsten.Lohmar@ericsson.com | Rel-7 | Paolo |  |  |  |  |
| 794 | 243 | **Advanced Global Navigation Satellite System (A-GNSS) concept** |  | 830d? | 2004-06-28 A | 2007-08-31 A | 100% |  | 2004-06-28 | 2007-08-31 | 830d? |  |  | S1,GP,R2 | 9553.6h | 9553.6h | LCS3-AGNSS | Alcatel | Michel.monnerat@thalesaleniaspace.com | Rel-7 | Alain |  |  |  |  |
| 795 | 243.1 | Towards A-GNSS Concept |  | 811.2d? | 2004-06-28 A | 2007-08-31 A | 100% |  | 2004-06-28 | 2007-08-31 | 811.2d? |  | finish no earlier than 2007-08-31 | GP | 6489.6h | 6489.6h | AGNSS-GP | Alcatel | richard.couty@space.alcatel.fr | Rel-7 | Paolo |  |  |  |  |
| 796 | 243.2 | Global Navigation Satellite System (GNSS) in UTRAN |  | 383d? | 2005-12-15 A | 2007-06-04 A | 100% |  | 2005-12-15 | 2007-06-04 | 383d? |  | finish no earlier than 2007-06-04 | R2 | 3064h | 3064h | LCS3-GNSS-UTRAN | France Telecom | alain.abinakhoul@francetelecom.com | Rel-7 | Joern |  | RP-070482 |  |  |
| 797 | 243.3 | Deleted - Towards A-GNSS Concept | milestone | 0d? | 2007-02-16 A | 2007-02-16 A | 100% |  | 2007-02-16 | 2007-02-16 | 0d? |  | start no earlier than 2007-02-16 | S1 |  |  | GNSS | Alcatel | richard.couty@space.alcatel.fr | Rel-7 | Alain | SP-34 |  |  |  |
| 798 | 244 | A-GPS Minimum Performance |  | 351d? | 2006-04-28 A | 2007-08-31 A | 100% |  | 2006-04-28 | 2007-08-31 | 351d? |  | finish no earlier than 2007-08-31 | GP | 2808h | 2808h | GAGR | Spirent | richard.catmur@spirentcom.com | Rel-7 | Paolo |  |  |  |  |
| 799 | 245 | **USSD message delivery and transfer to USIM** |  | 376d? | 2004-03-05 A | 2005-08-12 A | 100% |  | 2004-03-05 | 2005-08-12 | 376d? |  |  | S1,C6 | 2762.4h | 2762.4h | USSD-USIM | Axalto | Christophe Dubois (cdubois@axalto.com) | Rel-7 | Alain |  |  |  |  |
| 800 | 245.1 | Stage 1 |  | 152d? | 2004-03-18 A | 2004-10-15 A | 100% |  | 2004-03-18 | 2004-10-15 | 152d? |  | start no earlier than 2004-03-18 | S1 | 1216h | 1216h | USSD-USIM | Axalto | Christophe Dubois (cdubois@axalto.com) | Rel-7 | Alain |  |  |  |  |
| 801 | 245.2 | Alignment with requirements regarding USSD usage |  | 193.3d? | 2004-03-05 A | 2005-08-12 A | 100% |  | 2004-03-05 | 2005-08-12 | 193.3d? |  | finish no earlier than 2005-08-12 | C6 | 1546.4h | 1546.4h | USSD-USIM | Axalto | Christophe Dubois (cdubois@axalto.com) | Rel-7 | Xavier |  |  |  |  |

Notes:
- 777: Text3: 22.935
- 778: Text3: 22.935
- 779: Updated WID at SA#32 to change "stage 2" to "study" , duplicated UID 320017 deleted. SA#33 TR for Information. exception Granted for Rel-7 until 03/07. Last mention SP-35 Mar 2007 (abandoned ?) / Text3: 23.837
- 780: WID at SA#55 / Text3: 23.234, 23.271, 23.167
- 782: Text3: 25.305, 25.331, 25.410, 25.413, 25.453
- 784: Structure created by MCC to include RAN aspects under SA1 Feature / Text3: 22.146, 22.246, 22.228
- 785: Completed May 2007; SR in RP-070290 / Text3: 25.211, 25.212, 25.213, 25.101, 25.104, 25.331, 25.433, 25.346, 25.306
- 786: Completed May 2007; SR in RP-070291 / Text3: 25.346, 25.221, 25.222, 25.223, 25.224, 25.306, 25.331, 25.402, 25.433, 25.102, 25.105, 25.123
- 787: Completed May 2007; SR in RP-070292 / Text3: 25.346, 25.221, 25.222, 25.223, 25.224, 25.306, 25.331, 25.402, 25.433, 25.102, 25.105, 25.123
- 788: Text3: 29.061
- 789: Linked to Feature UID_31084 (MBMSE). 1 Apr 2009 Flagged as Rel-7 i/o Rel-8 to match the Core specs release
- 790: SR in RP-080541. RP#41 completed / Text3: 34.108, 34.122, 34.123-1/2/3
- 791: 1 Apr 2009 Flagged as Rel-7 i/o Rel-8 to match the Core specs release / Text3: 34.108, 34.123-1
- 792: RP#43 Completion target 03/09=>09/09. 1 Apr 2009 Flagged as Rel-7 i/o Rel-8 to match the Core specs release / Text3: 34.108, 34.109, 34.121-1, 34.121-2, 34.123-1, 34.123-2, 34.123-3
- 793: Text3: 26.346, 26.946
- 795: GP#36 completed
- 796: Completed Sept 2006; SR in RP-070482 / Text3: 25.305, 25.331, 25.306, 25.413, 25.423, 25.433, 25.453, 25.302, 25.215, 25.401, 25.402, 25.450, 25.452
- 798: Text3: 45.005, 51.010
- 800: Text3: 22.090

| ID | WBS | Task | Type | Duration | Start | Finish | Complete | Baseline start | Baseline finish | Baseline duration | Constraint | Resources | Work | Actual work | Text1 | Text4 | Text5 | Text6 | Text8 | Text3 | Text12 |
| --- | --- | --- | --- | --- | --- | --- | --- | --- | --- | --- | --- | --- | --- | --- | --- | --- | --- | --- | --- | --- | --- |
| 802 | 246 | **Combinational Services** |  | 296d? | 2005-01-17 A | 2006-03-06 A | 100% | 2005-01-17 | 2006-03-06 | 296d? |  | S1,S2,C1,S4 | 5176h | 5176h | CSICS | TeliaSonera | Robert.Frank@teliasonera.com | Rel-7 | Alain |  |  |
| 803 | 246.1 | Stage 1 for CSICS |  | 104d? | 2005-01-17 A | 2005-06-09 A | 100% | 2005-01-17 | 2005-06-09 | 104d? | start no earlier than 2005-01-17 | S1 | 832h | 832h | CSICS | TeliaSonera | Robert.Frank@teliasonera.com | Rel-7 | Alain | 22.279 |  |
| 804 | 246.2 | Stage 2 for CSICS |  | 130d? | 2005-01-17 A | 2005-07-15 A | 100% | 2005-01-17 | 2005-07-15 | 130d? | start no earlier than 2005-01-17 | S2 | 1040h | 1040h | CSICS | TeliaSonera | Robert.Frank@teliasonera.com | Rel-7 | Maurice | 23.279 |  |
| 805 | 246.3 | Stage 3 for CSICS CN aspects |  | 221d? | 2005-05-02 A | 2006-03-06 A | 100% | 2005-05-02 | 2006-03-06 | 221d? | finish no earlier than 2006-03-06 | C1 | 1768h | 1768h | CSICS | Vodafone | Peter Dawes | Rel-7 | Frederic | 24.879, 24.279, 24.229, 24.008 |  |
| 806 | 246.4 | Stage 3 for codec aspects |  | 192d? | 2005-03-15 A | 2005-12-07 A | 100% | 2005-03-15 | 2005-12-07 | 192d? | finish no earlier than 2005-12-07 | S4 | 1536h | 1536h | CSICS-Codec | Ericsson | Per.Frojdh@ericsson.com | Rel-7 | Paolo | 26.141, 26.235 |  |
| 807 | 247 | **CAMEL Trunk Triggers** |  | 251d? | 2004-12-17 A | 2005-12-05 A | 100% | 2004-12-17 | 2005-12-05 | 251d? |  | S1,C4 | 6024h | 6024h | TTCAMEL | Nortel | Amar Deol (deola@nortelnetworks.com) | Rel-7 | Alain |  |  |
| 808 | 247.1 | Stage 1 for CAMEL Trunk Triggers |  | 251d? | 2004-12-17 A | 2005-12-05 A | 100% | 2004-12-17 | 2005-12-05 | 251d? |  | S1 | 2008h | 2008h | TTCAMEL | Nortel | Amar Deol (deola@nortelnetworks.com) | Rel-7 | Alain | 22.078 |  |
| 809 | 247.2 | CAMEL Trunk Originated Trigger Detection Points |  | 251d? | 2004-12-17 A | 2005-12-05 A | 100% | 2004-12-17 | 2005-12-05 | 251d? | start no earlier than 2004-12-17 | C4 | 2008h | 2008h | CamelR7 | Nortel | David Hutton (dhutton@nortel.com) | Rel-7 | Kimmo |  |  |
| 810 | 248 | **IMS Service Brokering enhancements** |  | 69d? | 2005-12-07 A | 2006-03-13 A | 100% | 2005-12-07 | 2006-03-13 | 69d? |  | S1 | 1104h | 1104h | ISB | Telcordia | jbakker@telcordia.com | Rel-7 | Alain | 22.228 |  |
| 811 | 248.1 | Stage 1 for ISB |  | 69d? | 2005-12-07 A | 2006-03-13 A | 100% | 2005-12-07 | 2006-03-13 | 69d? | finish no earlier than 2006-03-13 | S1 | 552h | 552h | ISB-s1 | Telcordia | jbakker@telcordia.com | Rel-7 | Alain | 22.228 |  |
| 812 | 249 | **Enhancements of VGCS for public authority officials** |  | 731d? | 2004-08-27 A | 2007-06-15 A | 100% | 2004-08-27 | 2007-06-15 | 731d? |  | S1 | 25920h | 25920h | EVGCS |  |  | Rel-7 | Alain | 43.068, 44.068, 24.008, 29.002 |  |
| 813 | 249.1 | Stage 1 | milestone | 0d? | 2004-08-27 A | 2004-08-27 A | 100% | 2004-08-27 | 2004-08-27 | 0d? | finish no earlier than 2004-08-27 | S1 |  |  | EVGCS | Siemens | Joerg Swetina (joerg.swetina@nw.neclab.eu) | Rel-7 | Alain | 42.068, 43.068 |  |
| 814 | 249.2 | **Architecture and protocol aspects** |  | 731d? | 2004-08-27 A | 2007-06-15 A | 100% | 2004-08-27 | 2007-06-15 | 731d? |  | C1 | 14904h | 14904h | EVGCS | Siemens | robert.zaus@nsn.com | Rel-7 | Frederic | 43.068, 44.068 |  |
| 815 | 249.2.1 | CT1 aspects of EVGCS |  | 731d? | 2004-08-27 A | 2007-06-15 A | 100% | 2004-08-27 | 2007-06-15 | 731d? | finish no earlier than 2006-09-15 | C1 | 5848h | 5848h | EVGCS | Siemens |  | Rel-7 | Frederic | 43.068, 44.068, 24.008 |  |
| 816 | 249.2.2 | CT4 aspects of EVGCS |  | 401d? | 2004-08-27 A | 2006-03-10 A | 100% | 2004-08-27 | 2006-03-10 | 401d? | finish no earlier than 2006-03-10 | C4 | 3208h | 3208h | EVGCS-St23-c4 | Siemens |  | Rel-7 | Kimmo | 29.002 |  |
| 817 | 249.3 | GERAN2 aspects |  | 646d? | 2004-08-27 A | 2007-02-16 A | 100% | 2004-08-27 | 2007-02-16 | 646d? | finish no earlier than 2007-02-16 | G2 | 5168h | 5168h | EVGCS | Siemens | kenneth.isaacs@roke.co.uk | Rel-7 | Gert |  |  |
| 818 | 250 | **Improvements of VGCS for parallel use of services** |  | 523d? | 2005-03-15 A | 2007-03-15 A | 100% | 2005-03-15 | 2007-03-15 | 523d? |  | S1 | 12230.2h | 12230.2h | IVGCS |  |  | Rel-7 | Alain |  |  |
| 819 | 250.1 | Service Requirements for VGCS improvements |  | 62d? | 2005-03-15 A | 2005-06-08 A | 100% | 2005-03-15 | 2005-06-08 | 62d? | finish no earlier than 2005-06-08 | S1 | 496h | 496h | IVGCS | T-Mobile | kurt.bischinger@t-mobile.at | Rel-7 | Alain | 42.068 |  |
| 820 | 250.2 | Stage 2 modifications for VGCS improvements |  | 335d? | 2005-12-01 A | 2007-03-14 A | 100% | 2005-12-01 | 2007-03-14 | 335d? | start no earlier than 2005-12-01 | C1 | 2680h | 2680h | IVGCS | T-Mobile | kurt.bischinger@t-mobile.at | Rel-7 | Frederic | 43.068 |  |
| 821 | 250.3 | **Protocol aspects** |  | 336d? | 2005-12-01 A | 2007-03-15 A | 100% | 2005-12-01 | 2007-03-15 | 336d? |  | C1 | 5376h | 5376h | IVGCS | T-Mobile | Dieter Jacobsohn | Rel-7 | Frederic | 44.068 |  |
| 822 | 250.3.1 | CT1 aspects of IVGCS |  | 336d? | 2005-12-01 A | 2007-03-15 A | 100% | 2005-12-01 | 2007-03-15 | 336d? | finish no earlier than 2007-03-15 | C1 | 2688h | 2688h | IVGCS | T-Mobile |  | Rel-7 | Frederic | 43.068, 44.068 |  |
| 823 | 250.3.2 | Deleted - CT4 aspects of IVGCS | milestone | 0d? | 2007-03-09 A | 2007-03-09 A | 100% | 2007-03-09 | 2007-03-09 | 0d? | finish no earlier than 2007-03-09 | C4 |  |  | IVGCS-St3-c4 | T-mobile |  | Rel-7 | Kimmo | 29.002 | CP-35 |
| 824 | 251 | **OSA Rel-7** |  | 584d? | 2005-03-15 A | 2007-06-08 A | 100% | 2005-03-15 | 2007-06-08 | 584d? |  | S1,C5 | 17920h | 17920h | OSA7 | AePONA | eamonn.murray@aepona.com | Rel-7 | Alain |  |  |
| 825 | 251.1 | Service Requirements for OSA Service Broker |  | 62d? | 2005-03-15 A | 2005-06-08 A | 100% | 2005-03-15 | 2005-06-08 | 62d? | finish no earlier than 2005-06-08 | S1 | 496h | 496h | OSA7-SB | AePONA | eamonn.murray@aepona.com | Rel-7 | Alain | 22.127 |  |
| 826 | 251.2 | Stage 2 OSA API Service Brokering |  | 156d? | 2006-04-28 A | 2006-12-01 A | 100% | 2006-04-28 | 2006-12-01 | 156d? |  | C5 | 1248h | 1248h | OSA7-SB | AePONA | damian.oneill@aepona.com | Rel-7 | Kimmo | 23.198 |  |
| 827 | 251.3 | Stage 3 OSA API Service Brokering |  | 156d? | 2006-04-28 A | 2006-12-01 A | 100% | 2006-04-28 | 2006-12-01 | 156d? | finish no earlier than 2006-12-01 | C5 | 1248h | 1248h | OSA7-SB | AePONA | damian.oneill@aepona.com | Rel-7 | Kimmo | 29.198-16 |  |

Notes:
- 810: No CR submitted in rel-8 (according to CR database).
- 811: No Rel-8 changes
- 819: "completeed" as from Chris S' e-mail
- 820: Updated by CT1 chair
- 821: Previous name (before CT32) was Architecture and protocol aspects
- 822: end date updated by CT1-chairman after CT#33
- 823: CT4#33 stage 2 solution is still open. ...
- 825: az: WID URL corrected

| ID | WBS | Task | Type | Duration | Start | Finish | Complete | Baseline start | Baseline finish | Baseline duration | Constraint | Resources | Work | Actual work | Text1 | Text3 | Text4 | Text5 | Text6 | Text8 | Text12 | Text11 |
| --- | --- | --- | --- | --- | --- | --- | --- | --- | --- | --- | --- | --- | --- | --- | --- | --- | --- | --- | --- | --- | --- | --- |
| 828 | 251.4 | **OSA Stage 2/3 enhancements** |  | 291d? | 2006-04-28 A | 2007-06-08 A | 100% | 2006-04-28 | 2007-06-08 | 291d? |  | C5 | 10256h | 10256h | OSA7 | 29.198/9, 23.198 | AePONA | damian.oneill@aepona.com | Rel-7 | Kimmo |  |  |
| 829 | 251.4.1 | Parlay X Message Broadcast Web Service |  | 156d? | 2006-04-28 A | 2006-12-01 A | 100% | 2006-04-28 | 2006-12-01 | 156d? | finish no earlier than 2006-12-01 | C5 | 1248h | 1248h | OSA7 | 29.199-15, 23.198 | ETRI |  | Rel-7 | Kimmo |  |  |
| 830 | 251.4.2 | Parlay X Geocoding Web Service |  | 156d? | 2006-04-28 A | 2006-12-01 A | 100% | 2006-04-28 | 2006-12-01 | 156d? | finish no earlier than 2006-12-01 | C5 | 1248h | 1248h | OSA7 | 29.199-16, 23.198 | ETRI |  | Rel-7 | Kimmo |  |  |
| 831 | 251.4.3 | Parlay X Application driven QoS Web Service |  | 226d? | 2006-04-28 A | 2007-03-09 A | 100% | 2006-04-28 | 2007-03-09 | 226d? | finish no earlier than 2007-03-09 | C5 | 1808h | 1808h | OSA7 | 29.199-17, 23.198 | BT |  | Rel-7 | Kimmo |  |  |
| 832 | 251.4.4 | Parlay-X Device Capabilities and Configuration |  | 162d? | 2006-10-26 A | 2007-06-08 A | 100% | 2006-10-26 | 2007-06-08 | 162d? | finish no earlier than 2007-06-09 | C5 | 1296h | 1296h | OSA7 | 29.199-18, 23.198 | Telenor |  | Rel-7 | Kimmo |  |  |
| 833 | 251.4.5 | Parlay-X Multimedia Streaming Session Management Web Service |  | 97d? | 2006-10-26 A | 2007-03-09 A | 100% | 2006-10-26 | 2007-03-09 | 97d? | start no earlier than 2006-10-26 | C5 | 776h | 776h | OSA7 | 29.199-19, 23.198 | Telenor |  | Rel-7 | Kimmo |  |  |
| 834 | 251.4.6 | Parlay-X Multimedia Multicast Control Web Service |  | 97d? | 2006-10-26 A | 2007-03-09 A | 100% | 2006-10-26 | 2007-03-09 | 97d? | start no earlier than 2006-10-26 | C5 | 776h | 776h | OSA7 | 29.199-20, 23.198 | ETRI |  | Rel-7 | Kimmo |  |  |
| 835 | 251.4.7 | OSA API Conference Call Control SCF |  | 97d? | 2006-10-26 A | 2007-03-09 A | 100% | 2006-10-26 | 2007-03-09 | 97d? | start no earlier than 2006-10-26 | C5 | 776h | 776h | OSA7 | 29.198-04-5, 23.198 | Ericsson |  | Rel-7 | Kimmo |  |  |
| 836 | 252 | **Selective Disabling of UE Capabilities** |  | 624.36d? | 2005-01-24 A | 2007-06-15 A | 100% | 2005-01-24 | 2007-06-15 | 624.36d? |  | S1,S2,C1 | 12351.7h | 12351.7h | SDoUE |  | Motorola |  | Rel-7 | Alain |  |  |
| 837 | 252.1 | Stage 1 of SDoUE |  | 393.6d? | 2005-01-24 A | 2006-12-08 A | 100% | 2005-01-24 | 2006-12-08 | 393.6d? | finish no earlier than 2006-12-08 | S1 | 3148.8h | 3148.8h | SDoUE-CR | 22.011 | Motorola |  | Rel-7 | Alain |  |  |
| 838 | 252.2 | Deleted - TR on different possible architectures |  | 195d? | 2005-03-21 A | 2005-12-16 A | 100% | 2005-03-21 | 2005-12-16 | 195d? | finish no earlier than 2005-12-16 | S2 | 1560h | 1560h | SDoUE-FS | 23.805 abandonned at SP-30; descendant C1 24.305 | Vodafone | Gavin.Wong@vodafone.com | Rel-7 | Maurice | SP-30 |  |
| 839 | 252.3 | Stage 3 of SDoUE |  | 331d? | 2006-03-10 A | 2007-06-15 A | 100% | 2006-03-10 | 2007-06-15 | 331d? | finish no earlier than 2007-06-15 | C1 | 2648h | 2648h | SDoUE | 24.305 | Ericsson | christian.herrero@ericsson.com | Rel-7 | Frederic |  |  |
| 840 | 253 | **Network selection enhancements (NSP)** |  | 328d? | 2006-03-15 A | 2007-06-15 A | 100% | 2006-03-15 | 2007-06-15 | 328d? |  | S1 | 6320h | 6320h | NSP-CR | 22.101, 22.011, 23.122, 24.008, 25.304, 31.102, 45.008 | O2 | chris.friel@o2.com | Rel-7 | Alain |  |  |
| 841 | 253.1 | Stage 1 of NSP |  | 191d? | 2006-03-15 A | 2006-12-06 A | 100% | 2006-03-15 | 2006-12-06 | 191d? | start no earlier than 2006-03-15 | S1 | 1528h | 1528h | NSP-TS | 22.101, 22.011, 23.122, 24.008, 25.304, 31.102, 45.008 | O2 | chris.friel@o2.com | Rel-7 | Alain |  |  |
| 842 | 253.2 | Procedural aspects of NSP |  | 271d? | 2006-06-02 A | 2007-06-15 A | 100% | 2006-06-02 | 2007-06-15 | 271d? | finish no earlier than 2007-06-15 | C1 | 2168h | 2168h | NSP-CR | 23.122, 24.008, 31.102 | Motorola | Andrew Howell | Rel-7 | Frederic |  |  |
| 843 | 254 | Network Selection enhancements (NSP) - UE Conformance Testing |  | 396d? | 2007-06-01 A | 2008-12-05 A | 100% | 2007-06-01 | 2008-12-05 | 396d? | finish no earlier than 2008-12-05 | R5 | 3168h | 3168h | NSP-CR_UEConTest | 34.108, 34.123-1, 34.123-2, 34.123-3 | Nokia | jarkko.hellsten@nokia.com | Rel-7 | Ingbert |  | RP-080819 |
| 844 | 255 | **Access Class Barring and Overload Protection** |  | 650d? | 2004-03-15 A | 2006-09-08 A | 100% | 2004-03-15 | 2006-09-08 | 650d? |  | S2,C1 | 3568h | 3568h | ACBOP | 23.898 | Vodafone | Chris Pudney | Rel-7 | Maurice |  |  |
| 845 | 255.1 | TR on Stage 2 |  | 274d? | 2004-03-15 A | 2005-03-31 A | 100% | 2004-03-15 | 2005-03-31 | 274d? | finish no earlier than 2005-03-31 | S2 | 2192h | 2192h | ACBOP | 23.898 | NTT DoCoMo | Jean-Jacques Davidian (davidian@docomo.fr) | Rel-7 | Maurice |  |  |
| 846 | 255.2 | Stage 3 CN aspects of ACBOP |  | 172d? | 2005-06-06 A | 2006-01-31 A | 100% | 2005-06-06 | 2006-01-31 | 172d? | start no earlier than 2005-06-06 | C1 | 1376h | 1376h | ACBOP | 24.008 |  |  | Rel-7 | Frederic |  |  |
| 847 | 255.3 | Deleted - Potential impact on Iu interface Overload functionality | milestone | 0d? | 2004-03-15 A | 2004-03-15 A | 100% | 2004-03-15 | 2004-03-15 | 0d? | finish no earlier than 2004-03-15 | RP |  |  | ACBOP | 25.413 |  |  | Rel-7 | Stefania | RP-25 |  |
| 848 | 255.4 | Deleted - Extra ACBOP information in RAN | milestone | 0d? | 2004-03-15 A | 2004-03-15 A | 100% | 2004-03-15 | 2004-03-15 | 0d? | finish no earlier than 2004-03-15 | RP |  |  | ACBOP | 25.331 |  |  | Rel-7 | Stefania | RP-25 |  |
| 849 | 255.5 | Deleted - Extra ACBOP information in GERAN | milestone | 0d? | 2006-09-08 A | 2006-09-08 A | 100% | 2006-09-08 | 2006-09-08 | 0d? | start no earlier than 2006-09-08 | GP |  |  | ACBOP | 44.018 |  |  | Rel-7 | Paolo | RP-33 |  |
| 850 | 256 | **System enhancements for fixed broadband access to IMS** |  | 876d? | 2003-11-05 A | 2007-03-14 A | 100% | 2003-11-05 | 2007-03-14 | 876d? |  | S2,S3,S5,C1,C3,C4 | 36656h | 36656h | FBI |  |  |  | Rel-7 | Maurice |  |  |
| 851 | 256.1 | **TISPAN Rel 1 related aspects** |  | 873d? | 2003-11-05 A | 2007-03-09 A | 100% | 2003-11-05 | 2007-03-09 | 873d? |  | S2 | 31568h | 31568h | FBI-TIS1 |  |  |  | Rel-7 | Maurice |  |  |
| 852 | 256.1.1 | Stage 2 of FBI for TISPAN R1 |  | 365d? | 2004-10-14 A | 2006-03-08 A | 100% | 2004-10-14 | 2006-03-08 | 365d? | start no earlier than 2004-10-14 | S2 | 2920h | 2920h | FBI-TIS1 |  |  |  | Rel-7 | Maurice |  |  |

Notes:
- 828: CT#34: WID updated. Completion 12/06 =>03/07
- 836: Moved from FS section Feb 06
- 837: Moved from FS section Feb 06
- 838: Moved from FS section Feb 06. Abandoned at SP-30
- 843: RP#42 completed. SR in RP-080819. Linked to UID_7041 (NSP-CR).
- 846: NEW - inserted on 2/9/2004

| ID | WBS | Task | Duration | Start | Finish | Complete | Baseline start | Baseline finish | Baseline duration | Constraint | Resources | Work | Actual work | Text1 | Text4 | Text5 | Text6 | Text8 | Text3 | Text12 |
| --- | --- | --- | --- | --- | --- | --- | --- | --- | --- | --- | --- | --- | --- | --- | --- | --- | --- | --- | --- | --- |
| 853 | 256.1.2 | **Protocol impact of FBI for TISPAN R1** | 873d? | 2003-11-05 A | 2007-03-09 A | 100% | 2003-11-05 | 2007-03-09 | 873d? |  | C1 | 20720h | 20720h | FBI-TIS1 | Siemens | peter.leis@nsn.com | Rel-7 | Frederic |  |  |
| 854 | 256.1.2.1 | CT1 aspects of FBI for TISPAN R1 | 802d? | 2003-11-05 A | 2006-11-30 A | 100% | 2003-11-05 | 2006-11-30 | 802d? | finish no earlier than 2006-11-30 | C1 | 6416h | 6416h | FBI-TIS1 | Siemens | peter.leis@nsn.com | Rel-7 | Frederic | 24.819, 24.229 |  |
| 855 | 256.1.2.2 | CT3 aspects of FBI for TISPAN R1 | 808d? | 2003-11-05 A | 2006-12-08 A | 100% | 2003-11-05 | 2006-12-08 | 808d? | finish no earlier than 2006-12-08 | C3 | 6464h | 6464h | FBI-TIS1 | Siemens | peter.leis@nsn.com | Rel-7 | Gwiho | 29.163, 29.209 |  |
| 856 | 256.1.2.3 | CT4 aspects of FBI for TISPAN R1 | 301d? | 2006-01-13 A | 2007-03-09 A | 100% | 2006-01-13 | 2007-03-09 | 301d? | finish no earlier than 2007-03-09 | C4 | 2408h | 2408h | FBI-TIS1-st3-c4 | Siemens | peter.leis@nsn.com | Rel-7 | Kimmo | 29.229 |  |
| 857 | 256.1.3 | Security Enhancements for FBI | 118d? | 2005-06-28 A | 2005-12-08 A | 100% | 2005-06-28 | 2005-12-08 | 118d? | start no earlier than 2005-06-28 | S3 | 944h | 944h | FBI-ISE | Ericsson | Bengt.Sahlin@ericsson.com | Rel-7 | Dionisio | 33.203 |  |
| 858 | 256.2 | **PacketCable Related aspects** | 291d? | 2006-02-01 A | 2007-03-14 A | 100% | 2006-02-01 | 2007-03-14 | 291d? |  | S2,S5,C1 | 5088h | 5088h | FBI-PCBL | CableLabs | Bernie McKibben | Rel-7 | Maurice |  |  |
| 859 | 256.2.1 | Stage 1,2 of FBI for PacketCable | 228d? | 2006-02-01 A | 2006-12-15 A | 100% | 2006-02-01 | 2006-12-15 | 228d? | finish no earlier than 2006-12-15 | S2 | 1824h | 1824h | FBI-PCBL | CableLabs | Bernie McKibben | Rel-7 | Maurice | 22.228, 23.228 |  |
| 860 | 256.2.2 | Protocol impact of FBI for PacketCable | 228d? | 2006-05-01 A | 2007-03-14 A | 100% | 2006-05-01 | 2007-03-14 | 228d? | finish no earlier than 2007-03-15 | C1 | 1824h | 1824h | FBI-PCBL |  |  | Rel-7 | Frederic |  |  |
| 861 | 256.2.3 | SA5 Charging aspects of FBI for PacketCable | 180d? | 2006-03-31 A | 2006-12-07 A | 100% | 2006-03-31 | 2006-12-07 | 180d? | finish no earlier than 2006-12-07 | S5 | 1440h | 1440h | FBI-PCBL-CH | CableLabs | Bernie McKibben | Rel-7 | Dionisio | 32.240, 32.260, 32.298, 32.299 |  |
| 862 | 257 | **Support of SMS over generic 3GPP IP access** | 696d? | 2004-10-14 A | 2007-06-14 A | 100% | 2004-10-14 | 2007-06-14 | 696d? |  | S2,C4,C1 | 12408h | 12408h | SMSIP | Huawei | zhangwenlin@huawei.com | Rel-7 | Maurice |  |  |
| 863 | 257.1 | FS on SMSIP | 173d? | 2004-10-14 A | 2005-06-13 A | 100% | 2004-10-14 | 2005-06-13 | 173d? | start no earlier than 2004-10-14 | S2 | 1384h | 1384h | SMSIP | Huawei | zhangwenlin@huawei.com | Rel-7 | Maurice | 23.804 |  |
| 864 | 257.2 | Stage 2 for SMSIP | 333d? | 2005-06-08 A | 2006-09-15 A | 100% | 2005-06-08 | 2006-09-15 | 333d? | finish no earlier than 2006-09-15 | S2 | 2664h | 2664h | SMSIP | Huawei | zhangwenlin@huawei.com | Rel-7 | Maurice | 23.204 |  |
| 865 | 257.3 | **Stage 3 for SMSIP** | 527d? | 2005-06-08 A | 2007-06-14 A | 100% | 2005-06-08 | 2007-06-14 | 527d? |  | C4,C1 | 8360h | 8360h | SMSIP-St3 | Nokia | jari.jansson@nokia.com | Rel-7 | Kimmo |  |  |
| 866 | 257.3.1 | CT1 aspects for SMSIP | 527d? | 2005-06-08 A | 2007-06-14 A | 100% | 2005-06-08 | 2007-06-14 | 527d? | finish no earlier than 2007-06-15 | C1 | 4216h | 4216h | SMSIP | Nokia | jari.jansson@nokia.com | Rel-7 | Frederic | 23.040, 24.229 |  |
| 867 | 257.3.2 | CT4 aspects for SMSIP | 518d? | 2005-06-08 A | 2007-06-01 A | 100% | 2005-06-08 | 2007-06-01 | 518d? | finish no earlier than 2007-06-01 | C4 | 4144h | 4144h | SMSIP-St3-c4 | Nokia | jari.jansson@nokia.com | Rel-7 | Kimmo | 23.008, 29.002 |  |
| 868 | 258 | **Evolution of Policy Control and Charging** | 817d? | 2004-10-14 A | 2007-11-30 A | 100% | 2004-10-14 | 2007-11-30 | 817d? |  | S2,S5,C3,C1 | 30336h | 30336h | PCC | Nokia | balazs.bertenyi@nsn.com | Rel-7 | Maurice |  |  |
| 869 | 258.1 | Deleted - TR for PCC | 315d? | 2004-10-14 A | 2005-12-29 A | 100% | 2004-10-14 | 2005-12-29 | 315d? | finish no earlier than 2005-12-28 | S2 | 2520h | 2520h | PCC | Nokia | balazs.bertenyi@nsn.com | Rel-7 | Maurice | 23.803 | SP-33 |
| 870 | 258.2 | Stage 2 for PCC | 315d? | 2005-07-04 A | 2006-09-15 A | 100% | 2005-07-04 | 2006-09-15 | 315d? | finish no earlier than 2006-09-15 | S2 | 2520h | 2520h | PCC | Nokia | balazs.bertenyi@nsn.com | Rel-7 | Maurice | 23.203 |  |
| 871 | 258.3 | Evolution of policy control and flow based bearer level charging | 109d? | 2006-08-01 A | 2006-12-29 A | 100% | 2006-08-01 | 2006-12-29 | 109d? | start no earlier than 2006-08-01 | S2 | 872h | 872h | PCC | Nokia | balazs.bertenyi@nsn.com | Rel-7 | Maurice | 23.207, 23.002, 23.228 |  |
| 872 | 258.4 | SA5 Charging aspects of PCC | 316d? | 2006-03-31 A | 2007-06-15 A | 100% | 2006-03-31 | 2007-06-15 | 316d? | finish no earlier than 2007-06-15 | S5 | 2528h | 2528h | PCC-CH | Orange | alain.bibas@orange-ft.com | Rel-7 | Dionisio | 32.250, 32.251, 32.298, 32.299 |  |
| 873 | 258.5 | Gx reference point for Policy and Charging Control | 521d? | 2005-12-02 A | 2007-11-30 A | 100% | 2005-12-02 | 2007-11-30 | 521d? | finish no earlier than 2007-09-14 | C3 | 4168h | 4168h | PCC-Gx | Siemens | Thomas.Belling@nsn.com | Rel-7 | Gwiho | 29.212 (not progressed to Rel-7: 29.210, 29.207, 29.208) |  |
| 874 | 258.6 | **Rx reference point for PCC CT3 aspects** | 521d? | 2005-12-02 A | 2007-11-30 A | 100% | 2005-12-02 | 2007-11-30 | 521d? |  | C3,C1 | 11192h | 11192h | PCC-Rx | Ericsson | j.javier.pastor@ericsson.com | Rel-7 | Gwiho |  |  |
| 875 | 258.6.1 | PCC-Rx CT3 aspects | 521d? | 2005-12-02 A | 2007-11-30 A | 100% | 2005-12-02 | 2007-11-30 | 521d? | finish no earlier than 2007-09-14 | C3 | 4168h | 4168h | PCC-Rx-c3 | Ericsson | j.javier.pastor@ericsson.com | Rel-7 | Gwiho | 29.213, 29.214 (not progressed to Rel-7: 29.209, 29.211) |  |
| 876 | 258.6.2 | PCC-Rx CT1 aspects | 357d? | 2005-12-02 A | 2007-06-15 A | 100% | 2005-12-02 | 2007-06-15 | 357d? | finish no earlier than 2007-06-15 | C1 | 2856h | 2856h | PCC-Rx-Gx-c1 | Ericsson | j.javier.pastor@ericsson.com | Rel-7 | Frederic | 24.229 |  |

Notes:
- 854: end date updated by CT1-chairman after CT#33
- 856: CT4#32: a set of CRs on FBI for cable labs
- 857: Duplicated entry ("ACCSEC2", "Access Security Enhancements", SP-040865) deleted by A.Sultan
- 861: 03/2006 SA#31 WID approved
- 862: SA#33 updated WID (removed MMS)
- 863: SA#33 updated WID
- 864: SA#33 updated WID
- 865: CT#34 updated WID
- 866: CT#34 updated WID
- 867: CT#34 updated WID
- 868: SP-29 approved WID. SP-31 updated WID adding SA5 charging. 23.125 will be discontinued from Rel-7.
- 869: SP-30: S2 has no intention for TR completion
- 870: SP-29 approved WID. SP-31 updated WID. 23.125 will be discontinued from Rel-7.
- 871: SP-29 approved WID. SP-31 updated WID. 23.125 will be discontinued from Rel-7.
- 872: SP-31 updated WID with SA5 charging.
- 874: WID approved at CT#30, Revised at CT#31, Revised at CT#33

| ID | WBS | Task | Type | Duration | Start | Finish | Complete | Baseline start | Baseline finish | Baseline duration | Constraint | Resources | Work | Actual work | Text1 | Text4 | Text5 | Text6 | Text8 | Text3 | Text12 |
| --- | --- | --- | --- | --- | --- | --- | --- | --- | --- | --- | --- | --- | --- | --- | --- | --- | --- | --- | --- | --- | --- |
| 877 | 259 | **Voice call continuity between CS and IMS (incl. I-WLAN)** |  | 641d? | 2004-12-31 A | 2007-06-15 A | 100% | 2004-12-31 | 2007-06-15 | 641d? |  | S2,S1,S5,C1,C4 | 12224h | 12224h | VCC | Alcatel-Lucent | Keith Drage (drage@alcatel-lucent.com) | Rel-7 | Maurice |  |  |
| 878 | 259.1 | TR for VCC |  | 245d? | 2004-12-31 A | 2005-12-08 A | 100% | 2004-12-31 | 2005-12-08 | 245d? | finish no earlier than 2005-12-08 | S2 | 1960h | 1960h | VCC | Alcatel-Lucent | Andy Bennett (andybennett@alcatel-lucent.com) | Rel-7 | Maurice | 23.806 |  |
| 879 | 259.2 | Stage 1 for VCC |  | 140d? | 2005-03-17 A | 2005-09-28 A | 100% | 2005-03-17 | 2005-09-28 | 140d? | finish no earlier than 2005-09-28 | S1 | 1120h | 1120h | VCC | Alcatel-Lucent | Andy Bennett (andybennett@alcatel-lucent.com) | Rel-7 | Alain | 22.101 |  |
| 880 | 259.3 | Stage 2 for VCC |  | 264d? | 2005-09-06 A | 2006-09-08 A | 100% | 2005-09-06 | 2006-09-08 | 264d? | finish no earlier than 2006-09-08 | S2 | 2112h | 2112h | VCC | Alcatel-Lucent | Andy Bennett (andybennett@alcatel-lucent.com) | Rel-7 | Maurice | 23.206 |  |
| 881 | 259.4 | SA5 Charging aspects of VCC |  | 325d? | 2006-03-17 A | 2007-06-14 A | 100% | 2006-03-17 | 2007-06-14 | 325d? | finish no earlier than 2007-06-14 | S5 | 2600h | 2600h | VCC-CH | Orange | alain.bibas@orange-ft.com | Rel-7 | Dionisio | 32.250, 32.260 |  |
| 882 | 259.5 | **Stage 3 for VCC** |  | 358d? | 2006-02-01 A | 2007-06-15 A | 100% | 2006-02-01 | 2007-06-15 | 358d? |  | C1,C4 | 4432h | 4432h | VCC | Alcatel-Lucent | Keith Drage (drage@alcatel-lucent.com) | Rel-7 | Frederic |  |  |
| 883 | 259.5.1 | CT1 aspects of VCC |  | 358d? | 2006-02-01 A | 2007-06-15 A | 100% | 2006-02-01 | 2007-06-15 | 358d? | finish no earlier than 2007-06-15 | C1 | 2864h | 2864h | VCC | Alcatel-Lucent | Keith Drage (drage@alcatel-lucent.com) | Rel-7 | Frederic | 24.206, 24.216 |  |
| 884 | 259.5.2 | CT4 aspects of VCC |  | 196d? | 2006-06-09 A | 2007-03-09 A | 100% | 2006-06-09 | 2007-03-09 | 196d? | start no earlier than 2006-06-09 | C4 | 1568h | 1568h | VCC-St3-c4 | Alcatel-Lucent | Keith Drage (drage@alcatel-lucent.com) | Rel-7 | Kimmo | 23.003 |  |
| 885 | 259.5.3 | Deleted - CT3 aspects of VCC | milestone | 0d? | 2006-11-02 A | 2006-11-02 A | 100% | 2006-11-02 | 2006-11-02 | 0d? | finish no earlier than 2006-11-02 | C3 |  |  | VCC | Alcatel-Lucent | Keith Drage (drage@alcatel-lucent.com) | Rel-7 | Gwiho | 29.163 | CP-33 |
| 886 | 260 | **One Tunnel solution for Optimisation of Packet Data Traffic** |  | 418d? | 2006-03-27 A | 2007-10-31 A | 100% | 2006-03-27 | 2007-10-31 | 418d? |  | S2 | 7048h | 7048h | OPTUNEL | Nokia | antti.j.pasanen@nokia.com | Rel-7 | Maurice |  |  |
| 887 | 260.1 | Deleted - Study on Stage 2 for One Tunnel solution |  | 125d? | 2006-03-27 A | 2006-09-15 A | 100% | 2006-03-27 | 2006-09-15 | 125d? | finish no earlier than 2005-09-12 | S2 | 1000h | 1000h | OPTUNEL-Study | Nokia | antti.j.pasanen@nokia.com | Rel-7 | Maurice | 23.809 | SP-34 |
| 888 | 260.2 | One Tunnel Deployment Guideline |  | 268d? | 2006-10-23 A | 2007-10-31 A | 100% | 2006-10-23 | 2007-10-31 | 268d? | finish no earlier than 2007-10-31 | S2 | 2144h | 2144h | OPTUNEL-Guide | Huawei | lan.liu@huawei.com | Rel-7 | Maurice | 23.919 |  |
| 889 | 260.3 | Stage 2 specification for One Tunnel solution |  | 70d? | 2006-09-11 A | 2006-12-15 A | 100% | 2006-09-11 | 2006-12-15 | 70d? | finish no earlier than 2006-12-15 | S2 | 560h | 560h | OPTUNEL-Stage2 | Nokia | antti.j.pasanen@nokia.com | Rel-7 | Maurice | 23.060 |  |
| 890 | 261 | **CSI Terminating Session handling** |  | 267d? | 2006-06-08 A | 2007-06-15 A | 100% | 2006-06-08 | 2007-06-15 | 267d? |  | S2,C1 | 4728h | 4728h | CSItermS | Samsung | Osok Song | Rel-7 | Maurice |  |  |
| 891 | 261.1 | Stage 2 of CStermS |  | 192d? | 2006-06-08 A | 2007-03-02 A | 100% | 2006-06-08 | 2007-03-02 | 192d? | start no earlier than 2006-06-08 | S2 | 1536h | 1536h | CSItermS | Samsung | Osok Song | Rel-7 | Maurice | 23.279 |  |
| 892 | 261.2 | Stage 3 of CStermS |  | 132d? | 2006-12-14 A | 2007-06-15 A | 100% | 2006-12-14 | 2007-06-15 | 132d? | finish no earlier than 2007-06-15 | C1 | 1056h | 1056h | CSItermS | Samsung | chenho.chin@samsung.com | Rel-7 | Frederic | 24.229, 24.279 |  |
| 893 | 261.3 | Deleted - duplicated with UID 340015 -Stage 3 CSI Terminating Session handling | milestone | 0d? | 2007-03-09 A | 2007-03-09 A | 100% | 2007-03-09 | 2007-03-09 | 0d? | start no earlier than 2007-03-09 | C1 |  |  | CSItermS | Samsung | chenho.chin@samsung.com | Rel-7 | Frederic | 24.229, 24.179, 24.279 | CP-34 |
| 894 | 262 | Liberty Alliance and 3GPP Security Interworking |  | 451d? | 2005-03-10 A | 2006-11-30 A | 100% | 2005-03-10 | 2006-11-30 | 451d? | finish no earlier than 2006-11-30 | S3 | 3608h | 3608h | LibSec | Nokia | Silke.Holtmanns@NOKIA.COM | Rel-7 | Dionisio | 33.980 |  |
| 895 | 263 | Trust Requirements for Open Platforms in 3GPP |  | 499d? | 2005-01-03 A | 2006-11-30 A | 100% | 2005-01-03 | 2006-11-30 | 499d? | finish no earlier than 2006-11-30 | S3 | 3992h | 3992h | TrustOP | Nokia | Silke.Holtmanns@NOKIA.COM | Rel-7 | Dionisio | 33.905 |  |
| 896 | 264 | Development of UEA2 and UIA2 |  | 268d? | 2004-12-01 A | 2005-12-09 A | 100% | 2004-12-01 | 2005-12-09 | 268d? | finish no earlier than 2005-12-09 | S3 | 2144h | 2144h | AlgUEA2 | TeliaSonera | per.christoffersson@teliasonera.com | Rel-7 | Dionisio | 35.919, 35.215, 35.216, 35.217, 35.218 |  |
| 897 | 265 | Lawful Interception in the 3GPP Rel-7 architecture |  | 118d? | 2005-06-28 A | 2005-12-08 A | 100% | 2005-06-28 | 2005-12-08 | 118d? | start no earlier than 2005-06-28 | S3 | 944h | 944h | LI-7A | BMWI | berthold.wilhelm@regtp.de | Rel-7 | Dionisio | 33.106, 33.107, 33.108 |  |
| 898 | 266 | Key establishment between a UICC and a terminal |  | 201.45d? | 2005-12-07 A | 2006-09-28 A | 100% | 2005-12-07 | 2006-09-28 | 201.45d? | finish no earlier than 2006-09-28 | S3 | 1611.6h | 1611.6h | KeyEstUTerm | Gemalto | mireille.pauliac@gemplus.com | Rel-7 | Dionisio | 33.110 |  |
| 899 | 267 | NDS Authentication Framework Extension for Transport Layer Security |  | 50d? | 2006-09-28 A | 2006-12-06 A | 100% | 2006-09-28 | 2006-12-06 | 50d? | finish no earlier than 2006-09-28 | S3 | 400h | 400h | NDSAFTLS | Nokia | tiina.s.koskinen@nokia.com | Rel-7 | Dionisio | 33.310 |  |
| 900 | 268 | **Security enhancements** |  | 319d? | 2005-09-12 A | 2006-11-30 A | 100% | 2005-09-12 | 2006-11-30 | 319d? |  | S3,C1,C4 | 4856h | 4856h | SEC7 |  |  | Rel-7 | Dionisio |  |  |
| 901 | 268.1 | HTTPS connection between a UICC and a NAF |  | 1d? | 2005-09-12 A | 2005-09-12 A | 100% | 2005-09-12 | 2005-09-12 | 1d? | start no earlier than 2005-09-12 | S3,C1 | 8h | 8h | SEC7-HSUN | Gemalto | JSeif@axalto.com, mireille.pauliac@gemplus.com | Rel-7 | Dionisio | 33.918, 33.222, 24.109 |  |
| 902 | 268.2 | 2G GBA: 2G SIM usage in 3GPP GAA framework |  | 61d? | 2005-09-12 A | 2005-12-05 A | 100% | 2005-09-12 | 2005-12-05 | 61d? | finish no earlier than 2005-12-05 | S3 | 488h | 488h | SEC7-2GGBA | Nokia | Silke.Holtmanns@nokia.com | Rel-7 | Dionisio | 33.920, 33.220 |  |
| 903 | 268.3 | Generic Authentication Architecture usage extensions and optimisations |  | 319d? | 2005-09-12 A | 2006-11-30 A | 100% | 2005-09-12 | 2006-11-30 | 319d? | finish no earlier than 2006-11-30 | S3 | 2552h | 2552h | SEC7-GAA2 | Nokia | Silke.Holtmanns@nokia.com | Rel-7 | Dionisio | 33.220, 29.109, 24.109, (33.223 goes to R8) |  |

Notes:
- 877: WID approved SA#27; updated SA#28; updated SA#32
- 881: 03/2006 SA#31 WID approved
- 887: S2#52 CREATED. TR for Info SP-33. SP-34: S2 Report intention to discontinue TR
- 888: S2#55 CREATED: SP-34 Approved and exception request granted until 03/07
- 889: S2#52 CREATED
- 890: Triggered by the abandoned Study UID_32117
- 892: CP-34 approved WID. CP-35 updated WID
- 893: CP-34 approved WID
- 894: WID approved SA#27.
- 895: WID approved SA#26.
- 896: WID approved SA#26, Dependant on Funding Availability.
- 899: TLS profile is moved to Rel-8
- 903: 33.223 goes to R8

| ID | WBS | Task | Duration | Start | Finish | Complete | Baseline start | Baseline finish | Baseline duration | Total slack | Constraint | Resources | Work | Actual work | Text1 | Text4 | Text5 | Text6 | Text8 | Text3 | Text12 | Text2 | Text7 |
| --- | --- | --- | --- | --- | --- | --- | --- | --- | --- | --- | --- | --- | --- | --- | --- | --- | --- | --- | --- | --- | --- | --- | --- |
| 904 | 268.4 | **SS7 TCAP security Gateway** | 241d? | 2005-09-12 A | 2006-08-14 A | 100% | 2005-09-12 | 2006-08-14 | 241d? |  |  | S3,C4 | 1808h | 1808h | SEC7-NDS-TCAPsec | Siemens | marc.blommaert.ext@nsn.com | Rel-7 | Dionisio |  |  |  |  |
| 905 | 268.4.1 | SA3 aspects of SEC7-NDS-TCAPsec | 130d? | 2005-09-12 A | 2006-03-10 A | 100% | 2005-09-12 | 2006-03-10 | 130d? |  | finish no earlier than 2006-03-10 | S3 | 1040h | 1040h | SEC7-NDS-TCAPsec-SA3 | Siemens | marc.blommaert.ext@nsn.com | Rel-7 | Dionisio | 33.204 |  |  |  |
| 906 | 268.4.2 | TCAPsec Gateway | 96d? | 2006-04-03 A | 2006-08-14 A | 100% | 2006-04-03 | 2006-08-14 | 96d? |  | start no earlier than 2006-04-01 | C4 | 768h | 768h | SEC7-TCAP | Siemens | Ulrich.wiehe@gksag.de | Rel-7 | Kimmo | 29.204, 29.002 |  |  |  |
| 907 | 269 | IMS Stage 3 IETF Protocol alignment | 589d? | 2004-12-10 A | 2007-03-14 A | 100% | 2004-12-10 | 2007-03-14 | 589d? |  | finish no earlier than 2007-03-15 | C1 | 4712h | 4712h | IMSProtoc |  |  | Rel-7 | Frederic | 24.930 |  |  |  |
| 908 | 270 | **Interoperability between VGCS/VBS and A/Gb flexibility** | 253d? | 2006-03-22 A | 2007-03-09 A | 100% | 2006-03-22 | 2007-03-09 | 253d? |  |  | C1,C4 | 3296h | 3296h | VGCSFlex | Siemens | robert.zaus@nsn.com | Rel-7 | Frederic |  |  |  |  |
| 909 | 270.1 | CT1 aspects of VGCSFlex | 159d? | 2006-03-22 A | 2006-10-30 A | 100% | 2006-03-22 | 2006-10-30 | 159d? |  | finish no earlier than 2006-10-30 | C1 | 1272h | 1272h | VGCSFlex | Siemens | robert.zaus@nsn.com | Rel-7 | Frederic | 43.068, 43.069 |  |  |  |
| 910 | 270.2 | CT4 aspects of VGCSFlex | 253d? | 2006-03-22 A | 2007-03-09 A | 100% | 2006-03-22 | 2007-03-09 | 253d? |  | finish no earlier than 2007-03-09 | C4 | 2024h | 2024h | VGCSFlex-c4 | Siemens | robert.zaus@nsn.com | Rel-7 | Kimmo | 29.002 |  |  |  |
| 911 | 271 | DIAMETER on the GGSN Gi interface | 586d? | 2004-09-10 A | 2006-12-08 A | 100% | 2004-09-10 | 2006-12-08 | 586d? |  | finish no earlier than 2006-12-08 | C3 | 4688h | 4688h | DIAMGi | Vodafone | Nico.Gabriele@vodafone.com | Rel-7 | Gwiho | 29.061 |  |  |  |
| 912 | 272 | DIAMETER on the PDG Wi interface | 586d? | 2004-09-10 A | 2006-12-08 A | 100% | 2004-09-10 | 2006-12-08 | 586d? |  | finish no earlier than 2006-12-08 | C3 | 4688h | 4688h | DIAMWi | Vodafone | Nico.Gabriele@vodafone.com | Rel-7 | Gwiho | 29.161 |  |  |  |
| 913 | 273 | Interworking between the 3GPP CS domain with BICC or ISUP as signalling protocol and external SIP-I networks | 478d? | 2006-09-22 A | 2008-07-22 A | 100% | 2006-09-22 | 2008-07-22 | 478d? |  | finish no earlier than 2007-09-14 | C3 | 3824h | 3824h | ExtSIPI | Siemens | Thomas.Belling@nsn.com | Rel-7 | Gwiho | 29.164 |  |  |  |
| 914 | 274 | PDU multiplexing at Nb Interface with IP transport | 427d? | 2006-12-04 A | 2008-07-22 A | 100% | 2006-12-04 | 2008-07-22 | 427d? |  | start no earlier than 2006-12-04 | C3 | 3416h | 3416h | NbIPMux | Alcatel-Lucent | Jean.Rzeznik@alcatel-lucent.fr | Rel-7 | Gwiho | 29.414 |  |  |  |
| 915 | 275 | **Mp (MRFC - MRFP) interface** | 345d? | 2006-02-13 A | 2007-06-08 A | 100% | 2006-02-13 | 2007-06-08 | 345d? |  |  | C4,C1 | 4384h | 4384h | Mp | Ericsson | philip.hodges@ericsson.com | Rel-7 | Kimmo |  |  |  |  |
| 916 | 275.1 | CT1 aspects of Mp | 1d | 2006-02-13 A | 2006-02-13 A | 100% | 2006-02-13 | 2006-02-13 | 1d |  | finish no earlier than 2006-02-13 | C1 | 8h | 8h | Mp | Ericsson | philip.hodges@ericsson.com | Rel-7 | Frederic | 24.229 |  |  |  |
| 917 | 275.2 | Deleted - CT3 aspects of Mp | 1d | 2006-09-22 A | 2006-09-22 A | 100% | 2006-09-22 | 2006-09-22 | 1d |  | start no earlier than 2006-09-22 | C3 | 8h | 8h | Mp | Ericsson | philip.hodges@ericsson.com | Rel-7 | Gwiho | 29.162 | CP-33 |  |  |
| 918 | 275.3 | Procedures description | 201d? | 2006-06-02 A | 2007-03-09 A | 100% | 2006-06-02 | 2007-03-09 | 201d? |  | finish no earlier than 2007-03-09 | C4 | 1608h | 1608h | Mp-PROCc4 | Huawei | Chencheng@huawei.com | Rel-7 | Kimmo | 23.333 |  |  |  |
| 919 | 275.4 | Stage 3 | 345d | 2006-02-13 A | 2007-06-08 A | 100% | 2006-02-13 | 2007-06-08 | 345d |  | finish no earlier than 2007-06-08 | C4 | 2760h | 2760h | Mp-St3c4 | Ericsson | philip.hodges@ericsson.com | Rel-7 | Kimmo | 29.333 |  |  |  |
| 920 | 276 | Routeing of MT-SMs via the HPLMN | 71d? | 2006-12-01 A | 2007-03-09 A | 100% | 2006-12-01 | 2007-03-09 | 71d? |  | finish no earlier than 2007-03-09 | C4,C1 | 568h | 568h | SMSviaH | Vodafone | Nick.Russell@vodafone.com | Rel-7 | Kimmo | 23.040, 29.002 |  |  |  |
| 921 | 277 | Mobile Termination whilst the MS is moving to another MSC | 60d? | 2007-03-09 A | 2007-05-31 A | 100% | 2007-03-09 | 2007-05-31 | 60d? |  | start no earlier than 2007-03-09 | C4 | 480h | 480h | MTmovMS | Alcatel-Lucent | bruno.landais@alcatel-lucent.fr | Rel-7 | Kimmo | 23.008, 23.012, 23.018, 23.078, 23.079, 29.002 |  |  |  |
| 922 | 278 | ISIM API for Java Card | 620d? | 2005-03-14 A | 2007-07-27 A | 100% | 2005-03-14 | 2007-07-27 | 620d? |  | finish no earlier than 2007-07-27 | C6 | 4960h | 4960h | APIJAVA | Sun | Sebastian Hans | Rel-7 | Xavier | 31.103, 102 241 |  |  |  |
| 923 | 279 | Rel-7 (U)SIM API Testing | 206d? | 2009-05-30 | 2010-03-12 |  | 2009-05-30 | 2010-03-12 | 206d? | 130d | finish no earlier than 2010-03-12 | C6 | 1648h |  | USIM_API_test | Sagem Orga | gerrit.hartbrod@sagem-orga.com | Rel-7 | Xavier | 31.213 |  | PCG-23 | CP-44 |
| 924 | 280 | High speed interface between the UICC and the ME | 311d? | 2006-09-22 A | 2007-11-30 A | 100% | 2006-09-22 | 2007-11-30 | 311d? |  | finish no earlier than 2007-11-30 | C6 | 2488h | 2488h | HSI | Gemalto | jacques.seif@GEMALTO.COM | Rel-7 | Xavier | 31.101 |  |  |  |
| 925 | 281 | Video Codec Performance Requirements | 634d? | 2005-01-03 A | 2007-06-07 A | 100% | 2005-01-03 | 2007-06-07 | 634d? |  | finish no earlier than 2007-06-07 | S4 | 5072h | 5072h | VICPer | Siemens | juergen.pandel@siemens.com | Rel-7 | Paolo | 26.234, 26.235, 26.346, 26.140, 26.902 |  |  |  |
| 926 | 282 | Dynamic and Interactive Multimedia Scenes | 583d? | 2005-03-15 A | 2007-06-07 A | 100% | 2005-03-15 | 2007-06-07 | 583d? |  | finish no earlier than 2007-06-07 | S4 | 4664h | 4664h | DIMS | Streamezzo | gaelle.martin-cocher@streamezzo.com | Rel-7 | Paolo | 26.140, 26.142, 26.234, 26.244, 23.346 |  |  |  |
| 927 | 283 | 3G-324M Video Telephony Call Setup Times Improvements | 341d? | 2005-06-08 A | 2006-09-27 A | 100% | 2005-06-08 | 2006-09-27 | 341d? |  | finish no earlier than 2006-09-27 | S4 | 2728h | 2728h | VTCSTI | Vodafone | edward.hall@vodafone.co.uk | Rel-7 | Paolo | 26.911 |  |  |  |

Notes:
- 907: TR 24.930: Signalling flows for the session setup in the IM CN subsystem based on Session Initiation Protocol (SIP)
- 914: 08/03/2007 08:00
- 917: CT#34: CT3 not involved in Mp interface definition
- 920: WID approved in CT#34
- 923: Update of Rel-6 (U)SIM API for Java Card Testing UID_43007 under Rel-6 UICC/USIM enhancements and interworking UID_1800
- 924: Following ETSI publication of TS 102 600, expected to be completed at CT6#45

| ID | WBS | Task | Type | Duration | Start | Finish | Complete | Baseline start | Baseline finish | Baseline duration | Constraint | Resources | Work | Actual work | Text1 | Text4 | Text5 | Text6 | Text8 | Text12 |
| --- | --- | --- | --- | --- | --- | --- | --- | --- | --- | --- | --- | --- | --- | --- | --- | --- | --- | --- | --- | --- |
| 928 | 284 | **Optimizations for Multimedia Telephony over IMS** |  | 0d? | 2005-09-28 A | 2005-09-28 A | 100% | 2005-09-28 | 2005-09-28 | 0d? |  | S4 |  |  | OMTIMS | Ericsson | olle.franceschi@ericsson.com | Rel-7 | Paolo |  |
| 929 | 284.1 | Deleted - Characterisation of Adaptive Jitter Management Performance for VoIP Services | milestone | 0d? | 2005-09-28 A | 2005-09-28 A | 100% | 2005-09-28 | 2005-09-28 | 0d? | start no earlier than 2007-03-15 | S4 |  |  | OMTIMS-CAJMP | Lucent | dhuo@lucent.com | Rel-7 | Paolo | SP-35 |
| 930 | 285 | End-to-End Multimedia Services Performance Metrics |  | 382d? | 2005-09-28 A | 2007-03-15 A | 100% | 2005-09-28 | 2007-03-15 | 382d? | finish no earlier than 2007-03-15 | S4 | 3056h | 3056h | E2EMSPM | China Mobile | zhangyanyf@chinamobile.com | Rel-7 | Paolo |  |
| 931 | 286 | Packet Switched Streaming Enhancements |  | 261d? | 2006-06-08 A | 2007-06-07 A | 100% | 2006-06-08 | 2007-06-07 | 261d? | finish no earlier than 2007-06-07 | S4 | 2088h | 2088h | PSSe | Ericsson | olle.franceschi@ericsson.com | Rel-7 | Paolo |  |
| 932 | 287 | **OAM&P** |  | 472.86d? | 2005-09-02 A | 2007-06-26 A | 100% | 2005-09-02 | 2007-06-26 | 472.86d? |  | S5 | 82725.8h | 82725.8h | OAM7 | Huawei | Christian.Toche@huawei.com | Rel-7 | Dionisio |  |
| 933 | 287.1 | **Network Infrastructure Management** |  | 465d? | 2005-09-02 A | 2007-06-14 A | 100% | 2005-09-02 | 2007-06-14 | 465d? |  | S5 | 41800h | 41800h | OAM7-NIM |  |  | Rel-7 | Dionisio |  |
| 934 | 287.1.1 | Enhance NRM to accommodate NGN (IMS as basis of the Next Generation Network) |  | 465d? | 2005-09-02 A | 2007-06-14 A | 100% | 2005-09-02 | 2007-06-14 | 465d? | finish no earlier than 2007-06-14 | S5 | 3720h | 3720h | OAM7-NIM | Motorola |  | Rel-7 | Dionisio |  |
| 935 | 287.1.2 | Co-operative Element Management interface (CO-OP) (Study + Implementation) |  | 400d? | 2005-09-02 A | 2007-03-15 A | 100% | 2005-09-02 | 2007-03-15 | 400d? | finish no earlier than 2007-03-15 | S5 | 3200h | 3200h | OAM7-NIM | Motorola |  | Rel-7 | Dionisio |  |
| 936 | 287.1.3 | Network Management (NM) Itf-N performance criteria |  | 465d? | 2005-09-02 A | 2007-06-14 A | 100% | 2005-09-02 | 2007-06-14 | 465d? | finish no earlier than 2007-06-14 | S5 | 3720h | 3720h | OAM7-NIM | China Mobile |  | Rel-7 | Dionisio |  |
| 937 | 287.1.4 | Delta synchronization between IRP Manager and IRP Agent (Study + Implementation) |  | 465d? | 2005-09-02 A | 2007-06-14 A | 100% | 2005-09-02 | 2007-06-14 | 465d? | finish no earlier than 2007-06-14 | S5 | 3720h | 3720h | OAM7-NIM | Siemens |  | Rel-7 | Dionisio |  |
| 938 | 287.1.5 | Subscription Management (SuM) IRP Solution Sets |  | 330d? | 2005-09-02 A | 2006-12-07 A | 100% | 2005-09-02 | 2006-12-07 | 330d? | finish no earlier than 2006-12-07 | S5 | 2640h | 2640h | OAM7-NIM | Ericsson |  | Rel-7 | Dionisio |  |
| 939 | 287.1.6 | Integration Reference Point (IRP) Security Management |  | 400d? | 2005-09-02 A | 2007-03-15 A | 100% | 2005-09-02 | 2007-03-15 | 400d? | finish no earlier than 2007-03-15 | S5 | 3200h | 3200h | OAM7-NIM | Huawei | Christian.Toche@huawei.com | Rel-7 | Dionisio |  |
| 940 | 287.1.7 | Partial suspension of Itf-N during maintenance/testing (Study + Implementation) |  | 465d? | 2005-09-02 A | 2007-06-14 A | 100% | 2005-09-02 | 2007-06-14 | 465d? | finish no earlier than 2007-06-14 | S5 | 3720h | 3720h | OAM7-NIM | Siemens |  | Rel-7 | Dionisio |  |
| 941 | 287.1.8 | Deleted - Management of Legacy Equipment |  | 336d? | 2005-09-02 A | 2006-12-15 A | 100% | 2005-09-02 | 2006-12-15 | 336d? | finish no earlier than 2006-12-15 | S5 | 2688h | 2688h | OAM7-NIM | Siemens |  | Rel-7 | Dionisio | SP-35 |
| 942 | 287.1.9 | Deleted - Rules for Vendor Specific Extensions |  | 400d? | 2005-09-02 A | 2007-03-15 A | 100% | 2005-09-02 | 2007-03-15 | 400d? | finish no earlier than 2007-03-15 | S5 | 3200h | 3200h | OAM7-NIM | Siemens |  | Rel-7 | Dionisio | SP-35 |
| 943 | 287.1.10 | Backward and Forward Compatibility of IRP systems |  | 465d? | 2005-09-02 A | 2007-06-14 A | 100% | 2005-09-02 | 2007-06-14 | 465d? | finish no earlier than 2007-06-14 | S5 | 3720h | 3720h | OAM7-NIM | Ericsson |  | Rel-7 | Dionisio |  |
| 944 | 287.1.11 | Repeater Network Resource Model (NRM) definition |  | 214d? | 2006-02-13 A | 2006-12-07 A | 100% | 2006-02-13 | 2006-12-07 | 214d? | finish no earlier than 2006-12-07 | S5 | 1712h | 1712h | OAM7-NIM | China Mobile |  | Rel-7 | Dionisio |  |
| 945 | 287.1.12 | UTRAN radio channel power monitoring |  | 284d? | 2006-02-13 A | 2007-03-15 A | 100% | 2006-02-13 | 2007-03-15 | 284d? | finish no earlier than 2007-03-15 | S5 | 2272h | 2272h | OAM7-NIM | China Mobile |  | Rel-7 | Dionisio |  |
| 946 | 287.1.13 | Notification XML Schema |  | 71d? | 2006-12-07 A | 2007-03-15 A | 100% | 2006-12-07 | 2007-03-15 | 71d? | finish no earlier than 2007-03-15 | S5 | 568h | 568h | OAM7-NIM | Huawei | Christian.Toche@huawei.com | Rel-7 | Dionisio |  |
| 947 | 287.2 | **Performance Management** |  | 465d? | 2005-09-02 A | 2007-06-14 A | 100% | 2005-09-02 | 2007-06-14 | 465d? |  | S5 | 22992h | 22992h | OAM7-PM |  |  | Rel-7 | Dionisio |  |
| 948 | 287.2.1 | Performance measurements definition for CN CS |  | 400d? | 2005-09-02 A | 2007-03-15 A | 100% | 2005-09-02 | 2007-03-15 | 400d? | finish no earlier than 2007-03-15 | S5 | 3200h | 3200h | OAM7-PM | China Mobile |  | Rel-7 | Dionisio |  |
| 949 | 287.2.2 | Enhancement UTRAN performance measurements definition |  | 465d? | 2005-09-02 A | 2007-06-14 A | 100% | 2005-09-02 | 2007-06-14 | 465d? | finish no earlier than 2007-06-14 | S5 | 3720h | 3720h | OAM7-PM | China Mobile |  | Rel-7 | Dionisio |  |
| 950 | 287.2.3 | Add TDD specific counters in Performance measurement |  | 330d? | 2005-09-02 A | 2006-12-07 A | 100% | 2005-09-02 | 2006-12-07 | 330d? | finish no earlier than 2006-12-15 | S5 | 2640h | 2640h | OAM7-PM | CATT |  | Rel-7 | Dionisio |  |
| 951 | 287.2.4 | ATM bearer network Performance measurements |  | 400d? | 2005-09-02 A | 2007-03-15 A | 100% | 2005-09-02 | 2007-03-15 | 400d? | finish no earlier than 2007-03-15 | S5 | 3200h | 3200h | OAM7-PM | ZTE |  | Rel-7 | Dionisio |  |
| 952 | 287.2.5 | Performance measurements definition for IMS |  | 465d? | 2005-09-02 A | 2007-06-14 A | 100% | 2005-09-02 | 2007-06-14 | 465d? | finish no earlier than 2007-06-14 | S5 | 3720h | 3720h | OAM7-PM | China Mobile |  | Rel-7 | Dionisio |  |
| 953 | 287.2.6 | HSDPA performance measurements |  | 349d? | 2006-02-13 A | 2007-06-14 A | 100% | 2006-02-13 | 2007-06-14 | 349d? | finish no earlier than 2007-06-14 | S5 | 2792h | 2792h | OAM7-PM | China Mobile |  | Rel-7 | Dionisio |  |

Notes:
- 928: Text3: 26.235, 26.236
- 929: SP-35 stopped
- 930: Text3: 26.944
- 931: Text3: 26.234, 26.244
- 934: Text3: 32.731/2/3/5, 32.631/2/3/5
- 935: Text3: 32.806, 32.814, 32.101
- 936: Text3: 32.811
- 937: Text3: 32.391/2/3/5
- 938: Text3: 32.307/317/607/667/665, 32.101, 32.175
- 939: Text3: 32.372/3/5, 32.111,32.30x,32.32x,32.33x,32.34x,32.35x,32.36x,32.41x,32.60x,32.61x,32.66x
- 940: Text3: 32.381/2/3/5
- 941: Request to TSG#35 to STOP the WI / Text3: new 32.xxx
- 942: Request to TSG#35 to STOP the WI / Text3: 32.62n; For n = 1 to 5
- 943: Submit exception Sheet for TSG#35 Approval / Text3: 32.154
- 944: Text3: 32.721/2/3/5
- 945: Text3: 32.405, 32.64n; For n = 1 to 5
- 946: 12/2006 SA#34 WID approved / Text3: New 32.325/345/365/415, CR to 32.335/615/665
- 948: Text3: 32.407, 32.408
- 949: Submit exception Sheet for TSG#35 Approval / Text3: 32.405
- 950: Text3: 32.405
- 951: Text3: No impact on 32.404, 32.405, 32.406, 32.407
- 952: Submit exception Sheet for TSG#35 Approval / Text3: 32.404,32.409,32.437, 32.632/3/4/5
- 953: Submit exception Sheet for TSG#35 Approval / Text3: 32.405

| ID | WBS | Task | Type | Duration | Start | Finish | Complete | Baseline start | Baseline finish | Baseline duration | Constraint | Resources | Work | Actual work | Text1 | Text4 | Text6 | Text8 | Text12 | Text5 | Text11 | Text9 |
| --- | --- | --- | --- | --- | --- | --- | --- | --- | --- | --- | --- | --- | --- | --- | --- | --- | --- | --- | --- | --- | --- | --- |
| 954 | 44.5 | **Trace Management** |  | 472.86d? | 2005-09-02 A | 2007-06-26 A | 100% | 2005-09-02 | 2007-06-26 | 472.86d? |  | S5 | 14150.9h | 14150.9h | OAM7-Trace | Vodafone | Rel-7 | Dionisio |  |  |  |  |
| 955 | 287.3.1 | End-to-end Service Level tracing for IMS |  | 350d? | 2005-11-11 A | 2007-03-15 A | 100% | 2005-11-11 | 2007-03-15 | 350d? | finish no earlier than 2007-03-15 | S5 | 2800h | 2800h | OAM7-Trace | Vodafone | Rel-7 | Dionisio | SP-31 |  |  |  |
| 956 | 287.3.2 | Trace record content for UTRAN TDD |  | 330d? | 2005-09-02 A | 2006-12-07 A | 100% | 2005-09-02 | 2006-12-07 | 330d? | finish no earlier than 2006-12-07 | S5 | 2640h | 2640h | OAM7-Trace | Nokia | Rel-7 | Dionisio |  |  |  |  |
| 957 | 287.3.3 | IRP for Subscriber and Equipment Trace Management |  | 465d? | 2005-09-02 A | 2007-06-14 A | 100% | 2005-09-02 | 2007-06-14 | 465d? | finish no earlier than 2007-06-14 | S5 | 3720h | 3720h | OAM7-Trace | Nokia | Rel-7 | Dionisio |  |  |  |  |
| 958 | 287.3.4 | Deleted - SIP enhancements for trace | milestone | 0d? | 2007-06-15 A | 2007-06-26 A | 100% | 2007-06-15 | 2007-06-26 | 0d? | start no earlier than 2007-06-15 | C1 |  |  | OAM7-Trace |  | Rel-7 | Frederic | CP-32 |  |  |  |
| 959 | 287.3.5 | Deleted - duplicated with UID 35063 - IRP for Subscriber and Equipment Trace Management |  | 336d? | 2005-09-02 A | 2006-12-15 A | 100% | 2005-09-02 | 2006-12-15 | 336d? | finish no earlier than 2006-12-15 | S5 | 2688h | 2688h | OAM7-Trace | Nokia | Rel-7 | Dionisio | SP-33 |  |  |  |
| 960 | 288 | **Charging Management small Enhancements Rel-7** |  | 279d? | 2006-05-22 A | 2007-06-14 A | 100% | 2006-05-22 | 2007-06-14 | 279d? |  | S5 | 5952h | 5952h | CH7 | Orange | Rel-7 | Dionisio |  | alain.bibas@orange-ft.com |  |  |
| 961 | 288.1 | Alternate Charged Party (ACP) for IMS |  | 279d? | 2006-05-22 A | 2007-06-14 A | 100% | 2006-05-22 | 2007-06-14 | 279d? | finish no earlier than 2007-06-14 | S5 | 2232h | 2232h | CH7-IMS-ACP | Lucent | Rel-7 | Dionisio |  | njmazzarella@alcatel-lucent.com |  |  |
| 962 | 288.2 | Align 3GPP Charging with OMA PoC Enabler Release 2.0 |  | 186d? | 2006-09-28 A | 2007-06-14 A | 100% | 2006-09-28 | 2007-06-14 | 186d? | finish no earlier than 2007-06-14 | S5 | 1488h | 1488h | CH7-PoC | Siemens | Rel-7 | Dionisio |  | Gerald GÖRMER |  |  |
| 963 | 8.5 | **Multiple Input Multiple Output antennas (MIMO)** |  | 1177d? | 2003-03-14 A | 2007-09-17 A | 100% | 2003-03-14 | 2007-09-17 | 1177d? |  | R1 | 40272h | 40272h | MIMO | Alcatel-Lucent | Rel-7 | Patrick |  | hchuang@Alcatel-Lucent.com | RP-070037, RP-070531 |  |
| 964 | 289.1 | MIMO - Physical layer |  | 915d? | 2003-09-12 A | 2007-03-15 A | 100% | 2003-09-12 | 2007-03-15 | 915d? | finish no earlier than 2007-03-15 | R1 | 7320h | 7320h | MIMO-Phys | Alcatel-Lucent | Rel-7 | Patrick |  | hchuang@Alcatel-Lucent.com | RP-070037 |  |
| 965 | 289.2 | MIMO - Layer 2,3 aspects |  | 915d? | 2003-09-12 A | 2007-03-15 A | 100% | 2003-09-12 | 2007-03-15 | 915d? | finish no earlier than 2007-03-15 | R2 | 7320h | 7320h | MIMO-L23 | Alcatel-Lucent | Rel-7 | Joern |  | hchuang@Alcatel-Lucent.com | RP-070037 |  |
| 966 | 289.3 | MIMO - Iub/Iur Protocol Aspects |  | 1045d? | 2003-03-14 A | 2007-03-15 A | 100% | 2003-03-14 | 2007-03-15 | 1045d? | finish no earlier than 2007-03-15 | R3 | 8360h | 8360h | MIMO-IurIub | Alcatel-Lucent | Rel-7 | Juha |  | hchuang@Alcatel-Lucent.com | RP-070037 |  |
| 967 | 289.4 | MIMO - RF Radio Transmission/Reception, System Performance Requirements and Conformance Testing |  | 982d? | 2003-12-12 A | 2007-09-17 A | 100% | 2003-12-12 | 2007-09-17 | 982d? | finish no earlier than 2007-09-17 | R4 | 7856h | 7856h | MIMO-RF | Alcatel-Lucent | Rel-7 | Stefania |  | ngm@Alcatel-Lucent.com | RP-070531 |  |
| 968 | 290 | **Rel-7 Improvements of the Radio Interface** |  | 709d? | 2004-09-15 A | 2007-06-04 A | 100% | 2004-09-15 | 2007-06-04 | 709d? |  | RP | 29696h | 29696h | RInImp |  | Rel-7 | Stefania |  |  |  |  |
| 969 | 290.1 | Extended UMTS 1.7/2.1 GHz |  | 198d? | 2006-03-15 A | 2006-12-15 A | 100% | 2006-03-15 | 2006-12-15 | 198d? | finish no earlier than 2006-12-15 | R4 | 1584h | 1584h | RInImp-UMTS1721Ext | Ericsson | Rel-7 | Stefania |  | Johan Sköld (johan.skold@ericsson.com) | RP-060681 |  |
| 970 | 290.2 | UMTS 2.6 GHz 7.68 Mcps TDD |  | 67d? | 2006-06-15 A | 2006-09-15 A | 100% | 2006-06-15 | 2006-09-15 | 67d? | finish no earlier than 2006-09-15 | R4 | 536h | 536h | RInImp-UMTS26VHCRTDD | IPWireless | Rel-7 | Stefania |  | Shin Horng Wong (shwong@ipwireless.com) | RP-060451 |  |
| 971 | 290.3 | UMTS 2.6 GHz |  | 195d? | 2004-09-15 A | 2005-06-14 A | 100% | 2004-09-15 | 2005-06-14 | 195d? | finish no earlier than 2005-06-14 | R4 | 1560h | 1560h | RInImp-UMTS2600 | Nokia | Rel-7 | Stefania |  | jussi.numminen@nokia.com | RP-050184 |  |
| 972 | 290.4 | UMTS 2.6 GHz TDD |  | 261d? | 2004-12-15 A | 2005-12-14 A | 100% | 2004-12-15 | 2005-12-14 | 261d? | finish no earlier than 2005-12-15 | R4 | 2088h | 2088h | RInImp-UMTS2600TDD | IPWireless | Rel-7 | Stefania |  | Shin Horng Wong (shwong@ipwireless.com) | RP-050661 |  |
| 973 | 290.5 | UMTS 900 MHz |  | 261d? | 2004-12-15 A | 2005-12-14 A | 100% | 2004-12-15 | 2005-12-14 | 261d? | finish no earlier than 2005-12-15 | R4 | 2088h | 2088h | RInImp-UMTS900 | Nortel | Rel-7 | Stefania |  | Yannick Li (yli@nortelnetworks.com) | RP-050662 |  |
| 974 | 290.6 | UMTS 1700 MHz |  | 197d? | 2005-03-15 A | 2005-12-14 A | 100% | 2005-03-15 | 2005-12-14 | 197d? | finish no earlier than 2005-12-15 | R4 | 1576h | 1576h | RInImp-UMTS1700 | NTT DoCoMo | Rel-7 | Stefania |  | Takehiro Nakamura (nakamurata@nttdocomo.co.jp) | RP-050824 |  |
| 975 | 290.7 | UE Antenna Performance Evaluation Method and Requirements |  | 644d? | 2004-12-15 A | 2007-06-04 A | 100% | 2004-12-15 | 2007-06-04 | 644d? | finish no earlier than 2007-06-04 | R4 | 5152h | 5152h | RInImp-UEAnt | TeliaSonera | Rel-7 | Stefania |  | Christian.Bergljung@TeliaSonera.com | RP-070281 |  |
| 976 | 290.8 | Improved Performance Requirements for HSDPA UE based on Rx Diversity (type 1) & LMMSE equalizer (type 2) | milestone | 0d? | 2005-03-15 A | 2005-03-15 A | 100% | 2005-03-15 | 2005-03-15 | 0d? | finish no earlier than 2005-03-15 | R4 |  |  | RInImp-HSPerf-Type3 | Cingular | Rel-7 | Stefania |  | Marc Grant | RP-060015 |  |
| 977 | 290.9 | **Additional minimum UE performance requirement for non-HSDPA channels based on type 1 enhanced receiver (Rx Diversity)** |  | 327d? | 2005-09-15 A | 2006-12-15 A | 100% | 2005-09-15 | 2006-12-15 | 327d? |  | R4 | 7344h | 7344h | RInImp-RxDiv | Qualcomm | Rel-7 | Stefania |  | Serge Willenegger (sergew@qualcomm.com) |  |  |
| 978 | 290.9.1 | Additional minimum UE performance requirement for DL physical channels in support of DCH/HS-DSCH operation based on type 1 enhanced receiver (RX-Diversity) |  | 195d? | 2005-09-15 A | 2006-06-14 A | 100% | 2005-09-15 | 2006-06-14 | 195d? | finish no earlier than 2006-06-15 | R4 | 1560h | 1560h | RInImp-RxDiv-DCH | Cingular | Rel-7 | Stefania |  | Marc Grant | RP-060235 |  |
| 979 | 290.9.2 | Additional minimum UE performance requirement for downlink physical channels in support of MTCH and MCCH operation based on type 1 enhanced receiver (Rx-Diversity) |  | 198d? | 2006-03-15 A | 2006-12-15 A | 100% | 2006-03-15 | 2006-12-15 | 198d? | finish no earlier than 2006-12-15 | R4 | 1584h | 1584h | RInImp-RxDiv-MBMS | Qualcomm | Rel-7 | Stefania |  | Serge Willenegger (sergew@qualcomm.com) | RP-060678 |  |
| 980 | 290.9.3 | Additional minimum UE performance requirement for downlink physical channels in support of E-DCH operation based on type 1 enhanced receiver (Rx-Diversity) |  | 198d? | 2006-03-15 A | 2006-12-15 A | 100% | 2006-03-15 | 2006-12-15 | 198d? | finish no earlier than 2006-12-15 | R4 | 1584h | 1584h | RInImp-RxDiv-EDCH | Qualcomm | Rel-7 | Stefania |  | Serge Willenegger (sergew@qualcomm.com) | RP-060679 |  |
| 981 | 290.10 | Deleted Improved support of gaming over HSDPA/EDCH |  | 262d? | 2005-12-15 A | 2006-12-15 A | 100% | 2005-12-15 | 2006-12-15 | 262d? | finish no earlier than 2006-12-15 | R2 | 2096h | 2096h | RInImp-Gaming | Cingular | Rel-7 | Joern | RP-34 | Don Zelmer (dz1069@att.com) | RP-060680 |  |
| 982 | 290.11 | Deleted (not approved at PCG) - UMTS 2.6 GHz FDD DL External | milestone | 0d? | 2005-09-15 A | 2005-09-15 A | 100% | 2005-09-15 | 2005-09-15 | 0d? | finish no earlier than 2005-09-15 | R4 |  |  | RInImp-UMTS2600Ext | T-mobile | Rel-7 | Stefania | RP-31 | han.van.bussel@t-mobile.de |  | PCG-16 |

Notes:
- 955: 07/2005: OMA (Stage 1), Stage 2/3 SA5, CT1/3/4 / Text3: CR 32.101, 32.421/2/3.
- 956: Text3: CR 32.421/2/3.
- 957: Submit exception Sheet for TSG#35 Approval / Text3: 32.441/2/3/5, CRs 32.632/3/5
- 958: combined with UID 11067
- 959: Text3: 32.421,32.422,32.423. 3 new 32.4x1,2,3
- 961: Text3: 32.240, 32.260, 32.298, 32.299
- 962: 09/2006 SA#33 WID approved / Text3: 32.240, 32.272, 32.299, 32.298
- 963: Completed Sep 2007; SR in RP-070037and RP-070531 / Text3: 25.876, 25.996
- 964: Completed Sep 2007; SR in RP-070037 / Text3: 25.211, 25.212, 25.213, 25.214, 25.215, 25.221
- 965: Completed Sep 2007; SR in RP-070037 / Text3: 25.876
- 966: Completed Sep 2007; SR in RP-070037
- 967: Completed Sep 2007; SR in RP-070531
- 968: Generic feature
- 969: Completed Dec 2006; SR in RP-060681 / Text3: 25.806, 25.101, 25.104, 25.133, 24.141, 25.331, 25.306, 25.307, 25.423, 25.461, 25.463, 34.121
- 970: Completed Sep 2006; SR in RP-060451 / Text3: 25.102, 25.105, 25.123, 25.113, 25.142, 34.124
- 971: Completed Jun 2005, SR in RP-050184 / Text3: 25.101, 25.104, 25.133, 25.141, 25.331, 25.942, 25.306, 25.307, 34.121
- 972: Completed Dec 2005, SR in RP-050661 / Text3: 25.102, 25.105, 25.113, 25.123, 25.142, 25.331, 25.942, 25.306, 25.307, 34.122, 34.124
- 973: Completed Dec 2005, SR in RP-050662 / Text3: 25.101, 25.104, 25.113, 25.133, 25.141, 25.331, 25.942, 25.306, 25.307, 34.121
- 974: Completed Dec 2005; SR in RP-050824 / Text3: 25.101, 25.104, 25.113, 25.133, 25.141, 25.306, 25.307, 25.331, 34.121
- 975: RP#36 (May 2007) completed. SR in RP-070281 / Text3: 25.101, 25.963
- 976: Completed Mar 2006, SR in RP-060015 / Text3: 25.101
- 977: Text3: 25.101
- 978: Completed Jun 2006, SR in RP-060235 / Text3: 25.101
- 979: Completed Dec 2006, SR in RP-060678 / Text3: 25.101
- 980: Completed Dec 2006, SR in RP-060679 / Text3: 25.101
- 981: RP#34 (Dec 2006) stopped. SR in RP-060680
- 982: This item was conditionnaly approved pending decision of PCG 16 who decided not to approve it / Text3: 25.101, 25.104, 25.133, 25.141, 25.331, 25.942, 25.306, 25.307, 34.121

| ID | WBS | Task | Duration | Start | Finish | Complete | Remaining | Baseline start | Baseline finish | Baseline duration | Total slack | Constraint | Deadline | Resources | Work | Actual work | Text1 | Text6 | Text8 | Text4 | Text5 | Text10 | Text11 |
| --- | --- | --- | --- | --- | --- | --- | --- | --- | --- | --- | --- | --- | --- | --- | --- | --- | --- | --- | --- | --- | --- | --- | --- |
| 983 | 291 | **Rel-7 Improvements of the Radio Interface - UE Conformance Testing** | 741d? | 2005-11-11 A | 2008-09-12 A | 100% |  | 2005-11-11 | 2008-09-12 | 741d? |  |  |  | R5 | 17568h | 17568h | RInImp-UEConTest | Rel-7 | Ingbert |  |  |  |  |
| 984 | 16.5.1 | UE conformance testing for UMTS 2600 MHz | 146d | 2005-11-11 A | 2006-06-02 A | 100% |  | 2005-11-11 | 2006-06-02 | 146d |  | finish no earlier than 2006-06-02 | 2006-06-02 | R5 | 1168h | 1168h | RInImp-UMTS2600_Test | Rel-7 | Ingbert | Nokia | Aleksi.Heino@nokia.com | Fri 7/11/05 |  |
| 985 | 16.5.1 | UE Conformance Test for UMTS 900 MHz (band VIII) | 146d | 2005-11-11 A | 2006-06-02 A | 100% |  | 2005-11-11 | 2006-06-02 | 146d |  | finish no earlier than 2006-06-02 | 2006-06-02 | R5 | 1168h | 1168h | RInImp-UMTS900_Test | Rel-7 | Ingbert | Qualcomm | hanye@qualcomm.com | Fri 11/03/05 |  |
| 986 | 291.3 | Conformance Test Aspects – Improved Performance of HSDPA Receiver type 3 | 191d? | 2006-03-10 A | 2006-12-01 A | 100% |  | 2006-03-10 | 2006-12-01 | 191d? |  | finish no earlier than 2006-12-01 |  | R5 | 1528h | 1528h | RInImp-HSPerf-Type3_Test | Rel-7 | Ingbert | Motorola | carolyn.taylor@motorola.com |  |  |
| 987 | 291.4 | UE antenna Over The Air (OTA) conformance testing | 518d? | 2006-09-20 A | 2008-09-12 A | 100% |  | 2006-09-20 | 2008-09-12 | 518d? |  | finish no earlier than 2008-09-12 |  | R5 | 4144h | 4144h | RInImp-UEAnt_Test | Rel-7 | Ingbert | Nokia | Aleksi.Heino@nokia.com |  | RP-080535 |
| 988 | 291.5 | UE conformance testing for FDD Inter-Band Operation | 131d? | 2006-06-02 A | 2006-12-01 A | 100% |  | 2006-06-02 | 2006-12-01 | 131d? |  | finish no earlier than 2006-12-01 |  | R5 | 1048h | 1048h | RInImp-InterBand_Test | Rel-7 | Ingbert | NEC, Motorola | Jacob.John@motorola.com |  |  |
| 989 | 291.6 | Conformance Test Aspects – Extended UMTS 1.7/2.1 GHz | 131d? | 2006-12-01 A | 2007-06-01 A | 100% |  | 2006-12-01 | 2007-06-01 | 131d? |  | finish no earlier than 2007-06-01 |  | R5 | 1048h | 1048h | RInImp-UEConTest_UMTS1721Ext | Rel-7 | Ingbert | Motorola | carolyn.taylor@motorola.com |  |  |
| 990 | 291.7 | Conformance Test Aspects – Minimum UE performance requirement for downlink physical channels in support of E-DCH operation based on type 1 enhanced receiver (Rx-Diversity) | 136d? | 2007-06-01 A | 2007-12-07 A | 100% |  | 2007-06-01 | 2007-12-07 | 136d? |  | finish no earlier than 2007-12-07 |  | R5 | 1088h | 1088h | RInImp-UEConTest_RxDivEDCH | Rel-7 | Ingbert | Motorola | carolyn.taylor@motorola.com |  |  |
| 991 | 291.8 | Conformance Test Aspects – Minimum UE performance requirement for downlink physical channels in support of MTCGH and MCCH operation based on type 1 enhanced receiver (Rx-Diversity) | 201d? | 2007-06-01 A | 2008-03-07 A | 100% |  | 2007-06-01 | 2008-03-07 | 201d? |  | finish no earlier than 2008-03-07 |  | R5 | 1608h | 1608h | RInImp-UEConTest_RxDivMBMS | Rel-7 | Ingbert | Ericsson | leif.mattisson@ericsson.com |  | RP-080056 |
| 992 | 292 | **Rel-7 RAN improvements** | 653d? | 2004-12-15 A | 2007-06-15 A | 100% |  | 2004-12-15 | 2007-06-15 | 653d? |  |  |  | RP | 29920h | 29920h | RANimp | Rel-7 | Stefania |  |  |  |  |
| 993 | 292.1 | Optimisation of channelisation code utilisation for 1.28 Mcps TDD | 523d? | 2004-12-15 A | 2006-12-15 A | 100% |  | 2004-12-15 | 2006-12-15 | 523d? |  | finish no earlier than 2006-12-15 |  | R1 | 4184h | 4184h | RANimp-RABSE-CodOptLCRTDD | Rel-7 | Patrick | UTStarcom | Ka Leong Lo (kaleong.lo@UTSTAR.COM) |  | RP-060682 |
| 994 | 292.2 | Delay optimisation for procedures applicable to CS and PS Connections | 394d? | 2005-03-15 A | 2006-09-15 A | 100% |  | 2005-03-15 | 2006-09-15 | 394d? |  | finish no earlier than 2006-09-15 |  | R2 | 3152h | 3152h | RANimp-DelayOpt | Rel-7 | Joern | Nokia | juho.pirskanen@nokia.com |  | RP-060453 |
| 995 | 292.3 | Improved support of IMS Realtime Services using HSDPA/HSUPA | 197d? | 2005-03-15 A | 2005-12-14 A | 100% |  | 2005-03-15 | 2005-12-14 | 197d? |  | start no earlier than 2005-03-15 |  | R2 | 1576h | 1576h | RANimp-IMSRealTime | Rel-7 | Joern | Cingular | Don Zelmer (dz1069@att.com) |  | RP-050667 |
| 996 | 292.4 | UE Performance Requirements for MBMS (TDD) | 328d? | 2005-03-15 A | 2006-06-15 A | 100% |  | 2005-03-15 | 2006-06-15 | 328d? |  | finish no earlier than 2006-06-15 |  | R4 | 2624h | 2624h | MBMS-RAN-RF-TDD | Rel-7 | Stefania | IPwireless | shwong@ipwireless.com |  | RP-060477 |
| 997 | 292.5 | Continuous connectivity for packet data users | 524d? | 2005-03-14 A | 2007-03-15 A | 100% |  | 2005-03-14 | 2007-03-15 | 524d? |  | finish no earlier than 2007-03-15 |  | R1 | 4192h | 4192h | RANimp-CPC | Rel-7 | Patrick | Siemens | Joern.Krause@siemens.com |  | RP-070033 |
| 998 | 292.6 | Extended WCDMA Cell Range | 198d? | 2006-03-15 A | 2006-12-15 A | 100% |  | 2006-03-15 | 2006-12-15 | 198d? |  | finish no earlier than 2006-12-15 |  | R3 | 1584h | 1584h | RANimp-ExtCell | Rel-7 | Juha | Ericsson | Muhammad Kazmi |  | RP-060685 |
| 999 | 292.7 | 7.68 Mcps TDD Enhanced Uplink | 198d? | 2006-03-15 A | 2006-12-15 A | 100% |  | 2006-03-15 | 2006-12-15 | 198d? |  | finish no earlier than 2006-12-15 |  | R1 | 1584h | 1584h | RANimp-VHCRTDD-EDCH | Rel-7 | Patrick | IPwireless | nanderson@ipwireless.com |  | RP-060684 |
| 1000 | 292.8 | Enhanced CELL_FACH State in FDD | 181d? | 2006-09-25 A | 2007-06-04 A | 100% |  | 2006-09-25 | 2007-06-04 | 181d? |  | finish no earlier than 2007-06-04 |  | R2 | 1448h | 1448h | RANimp-EnhState | Rel-7 | Joern | Nokia | juho.pirskanen@nokia.com |  | RP-070286 |
| 1001 | 292.9 | 64QAM for HSDPA (FDD) | 110d? | 2006-12-15 A | 2007-06-04 A | 100% |  | 2006-12-15 | 2007-06-04 | 110d? |  | finish no earlier than 2007-06-04 |  | R1 | 880h | 880h | RANimp-64QamDownlink | Rel-7 | Patrick | Ericsson | Johan.Bergman@ericsson.com |  | RP-070287 |
| 1002 | 292.10 | Improved L2 support for high data rates | 122d? | 2006-12-15 A | 2007-06-04 A | 100% |  | 2006-12-15 | 2007-06-04 | 122d? |  | finish no earlier than 2007-06-04 |  | R2 | 976h | 976h | RANimp-L2DataRates | Rel-7 | Joern | Ericsson | Janne.Peisa@ericsson.com |  | RP-070289 |
| 1003 | 292.11 | Introduction of 16QAM in HSUPA (FDD) | 110d? | 2006-12-15 A | 2007-06-04 A | 100% |  | 2006-12-15 | 2007-06-04 | 110d? |  | finish no earlier than 2007-06-04 |  | R1 | 880h | 880h | RANimp-16QamUplink | Rel-7 | Patrick | Nokia | Karri.Ranta-aho@nsn.com |  | RP-070288 |
| 1004 | 292.12 | **Interface to control Tower Mounted Amplifiers (TMAs)** | 101d? | 2007-01-26 A | 2007-06-15 A | 100% |  | 2007-01-26 | 2007-06-15 | 101d? |  |  |  | R3 | 1616h | 1616h | RANImp-TMA | Rel-7 | Juha | Vodafone | alexej.kulakov@vodafone.com |  | RP-070140 |
| 1005 | 292.12.1 | OAM aspects to Interface to control TMAs | 101d? | 2007-01-26 A | 2007-06-15 A | 100% |  | 2007-01-26 | 2007-06-15 | 101d? |  | finish no earlier than 2007-06-15 |  | S5 | 808h | 808h | RANImp-TMA-OAM | Rel-7 | Dionisio | Vodafone | Adrian.Neal@vodafone.com |  |  |
| 1006 | 293 | **Rel-7 RAN improvements - UE Conformance Testing** | 779d? | 2006-09-20 A | 2009-09-11 | 96% | 32.02d? | 2006-09-20 | 2009-09-11 | 779d? | 260d |  |  | R5 | 25384h | 21396.8h | RANimp-UEConTest | Rel-7 | Ingbert |  |  |  |  |
| 1007 | 293.1 | Conformance Test Aspects - 3.84 Mcps and 7.68 Mcps TDD Enhanced Uplink | 518d? | 2006-09-20 A | 2008-09-12 A | 100% |  | 2006-09-20 | 2008-09-12 | 518d? |  | finish no earlier than 2008-09-12 |  | R5 | 4144h | 4144h | RANimp-UEConTest_EDCHTDH | Rel-7 | Ingbert | IPWireless | tspeight@ipwireless.com |  | RP-080536 |
| 1008 | 293.2 | Conformance Test Aspects – 64QAM for HSDPA (FDD) | 257d? | 2007-03-09 A | 2008-03-03 A | 100% |  | 2007-03-09 | 2008-03-03 | 257d? |  | finish no earlier than 2008-03-03 |  | R5 | 2056h | 2056h | RANimp-UEConTest_64QamDownlink | Rel-7 | Ingbert | Ericsson | leif.mattisson@ericsson.com |  | RP-080059 |
| 1009 | 293.3 | Conformance Test Aspects – 16QAM for HSUPA (FDD) | 321d? | 2007-03-09 A | 2008-05-30 A | 100% |  | 2007-03-09 | 2008-05-30 | 321d? |  | finish no earlier than 2008-05-30 |  | R5 | 2568h | 2568h | RANimp-UEConTest_16QamUplink | Rel-7 | Ingbert | Motorola | carolyn.taylor@motorola.com |  | RP-080281 |
| 1010 | 293.4 | Conformance Test Aspects – Improved L2 support for high data rates | 321d? | 2007-03-09 A | 2008-05-30 A | 100% |  | 2007-03-09 | 2008-05-30 | 321d? |  | finish no earlier than 2008-05-30 |  | R5 | 2568h | 2568h | RANimp-UEConTest_L2DataRates | Rel-7 | Ingbert | Ericsson | leif.mattisson@ericsson.com |  | RP-080256 |
| 1011 | 293.5 | Conformance Test Aspects – Continuous connectivity for packet data users | 321d? | 2007-03-09 A | 2008-05-30 A | 100% |  | 2007-03-09 | 2008-05-30 | 321d? |  | finish no earlier than 2008-05-30 |  | R5 | 2568h | 2568h | RANimp-UEConTest_CPC | Rel-7 | Ingbert | Nokia | jarkko.hellsten@nokia.com |  | RP-080282 |
| 1012 | 293.6 | Conformance Test Aspects – Enhanced CELL_FACH state in FDD | 656d? | 2007-03-09 A | 2009-09-11 | 85% | 98.4d? | 2007-03-09 | 2009-09-11 | 656d? | 260d | finish no earlier than 2009-09-11 |  | R5 | 5248h | 4460.8h | RANimp–UEConTest_EnhancedCellFACHState | Rel-7 | Ingbert | Nokia | jarkko.hellsten@nokia.com |  | RP-090411 |

Notes:
- 983: 05/08: Linked to Feature UID_20028 (RInImp)
- 984: Text3: 34.108, 34.121
- 985: Text3: 34.108, 34.121
- 986: Text3: 34.121, 34.108
- 987: SR in RP-080535. RP#41 completed (GERAN aspects might need to be included later) / Text3: 34.114
- 988: Text3: 34.108, 34.123-1, 34.123-2, 34.123-3
- 989: Text3: 34.108, 34.121-1, 34.121-2
- 991: SR in RP-080056
- 992: Generic feature
- 993: Completed Dec 2006; SR in RP-060682
- 994: Completed Sep 2006; SR in RP-060453 / Text3: 25.815, 25.321, 25.322, 25.331
- 995: Closed Dec 2005; SR in RP-050667
- 996: Completed Sep 2006; SR in RP-060477 / Text3: 25.102, 25.123
- 997: Completed at Mar 2007; SR in RP-070033 / Text3: 25.903, 25.201, 25.211, 25.212, 25.214, 25.308, 25.321, 25.331, 25.423, 25.433, 25.101, 25.133
- 998: Completed Dec 2006; SR in RP-060685 / Text3: 25.133, 25.423, 25.425, 25.433, 25.435, 25.453, 25.331
- 999: Completed Dec 2006; SR in RP-060684 / Text3: 25.201, 25.202, 25.221, 25.222, 25.223, 25.224, 25.225, 25.331, 23.321, 25.306, 25.302, 25.401, 25.420, 25.423, 25.427, 25.433, 25.102, 25.105, 25.142
- 1000: Completed May 2007; SR in RP-070286 / Text3: 25.308, 25.304, 25.306, 25.321, 25.331, 25.433, 25.435, 25.423, 25.425,
- 1001: Completed May 2007; SR in RP-070287 / Text3: 25.308, 25.211, 25.212, 25.213, 25.306, 25.331, 25.433, 25.435, 25.423, 25.425, 25.101, 25.104, 25.141
- 1002: Completed May 2007; SR in RP-070289 / Text3: 25.301, 25.308,25.306, 25.321, 25.322, 25.331, 25.433, 25.435, 25.423, 25.425, 25.999
- 1003: Completed May 2007; SR in RP-070288 / Text3: 25.319, 25.101, 25.104, 25.133, 25.141, 25.211, 25.212, 25.213, 25.214, 25.306, 25.321, 25.331, 25.423, 25.433
- 1004: Completed Mar 2007; SR in RP-070140
- 1005: SA#36 Jun 2007 completed / Text3: 32.642/3/5 – Align with RAN 25.466
- 1006: 05/08: Linked to Feature UID_20029 (RANimp)
- 1007: SR in RP-080536. RP#41 completed / Text3: 34.108, 34.122, 34.123-1, 34.123-2, 34.123-3
- 1008: SR in RP-080059. RP#39 completed. / Text3: 34.108, 34.121-1, 34.121-2, 34.123-1, 34.123-2, 34.123-3
- 1009: SR in RP-080281. RP#40 completed / Text3: 34.108, 34.121-1, 34.121-2, 34.123-1, 34.123-2, 34.123-3
- 1010: SR in RP-080256. RP#40 completed / Text3: 34.108, 34.123-1, 34.123-2, 34.123-3
- 1011: SR in RP-080282. RP#40 completed / Text3: 34.108, 34.121-1, 34.121-2, 34.123-1, 34.123-2, 34.123-3
- 1012: RP#44 Completion target 03/09=>05/09=>09/09 / Text3: 34.108, 34.123-1, 34.123-2, 34.123-3

| ID | WBS | Task | Type | Duration | Start | Finish | Complete | Baseline start | Baseline finish | Baseline duration | Constraint | Resources | Work | Actual work | Text1 | Text4 | Text5 | Text6 | Text8 | Text11 | Text12 |
| --- | --- | --- | --- | --- | --- | --- | --- | --- | --- | --- | --- | --- | --- | --- | --- | --- | --- | --- | --- | --- | --- |
| 1013 | 294 | **7.68 Mcps TDD option** |  | 457d? | 2004-09-15 A | 2006-06-15 A | 100% | 2004-09-15 | 2006-06-15 | 457d? |  | RP | 19824h | 19824h | VHCRTDD | IPwireless | Martin Beale (mbeale@ipwireless.com) | Rel-7 | Stefania | RP-060684 |  |
| 1014 | 294.1 | VHCRTDD: Stage 2 |  | 391d? | 2004-09-15 A | 2006-03-15 A | 100% | 2004-09-15 | 2006-03-15 | 391d? | finish no earlier than 2006-03-15 | R1 | 3128h | 3128h | VHCRTDD-Stage2 | IPwireless | Martin Beale (mbeale@ipwireless.com) | Rel-7 | Patrick |  |  |
| 1015 | 294.2 | VHCRTDD: Physical Layer |  | 391d? | 2004-09-15 A | 2006-03-15 A | 100% | 2004-09-15 | 2006-03-15 | 391d? | finish no earlier than 2006-03-15 | R1 | 3128h | 3128h | VHCRTDD-Phys | IPwireless | Martin Beale (mbeale@ipwireless.com) | Rel-7 | Patrick |  |  |
| 1016 | 294.3 | VHCRTDD: Layer 2 and layer 3 protocol aspects |  | 391d? | 2004-09-15 A | 2006-03-15 A | 100% | 2004-09-15 | 2006-03-15 | 391d? | finish no earlier than 2006-03-15 | R2 | 3128h | 3128h | VHCRTDD-L23 | IPwireless | drichards@ipwireless.com | Rel-7 | Joern |  |  |
| 1017 | 294.4 | VHCRTDD: UTRAN Iub/Iur Protocol Aspects |  | 391d? | 2004-09-15 A | 2006-03-15 A | 100% | 2004-09-15 | 2006-03-15 | 391d? | finish no earlier than 2006-03-15 | R3 | 3128h | 3128h | VHCRTDD-IurIub | IPwireless | Peter Legg (plegg@ipwireless.com) | Rel-7 | Juha |  |  |
| 1018 | 294.5 | VHCRTDD: RF Radio Transmission/ Reception, System Performance Requirements and Conformance Testing |  | 457d? | 2004-09-15 A | 2006-06-15 A | 100% | 2004-09-15 | 2006-06-15 | 457d? | finish no earlier than 2006-06-15 | R4 | 3656h | 3656h | VHCRTDD-RF | IPwireless | Shin Horng Wong (shwong@ipwireless.com) | Rel-7 | Stefania |  |  |
| 1019 | 295 | **3.84 Mcps TDD Enhanced Uplink** |  | 394d? | 2005-03-15 A | 2006-09-15 A | 100% | 2005-03-15 | 2006-09-15 | 394d? |  | RP | 18384h | 18384h | EDCHTDD | IPwireless | nanderson@ipwireless.com | Rel-7 | Stefania | RP-060684 |  |
| 1020 | 295.1 | EDCHTDD: Stage 2 |  | 328d? | 2005-03-15 A | 2006-06-15 A | 100% | 2005-03-15 | 2006-06-15 | 328d? | finish no earlier than 2006-06-15 | R2 | 2624h | 2624h | EDCHTDD-Stage2 | IPwireless | nanderson@ipwireless.com | Rel-7 | Joern |  |  |
| 1021 | 295.2 | EDCHTDD: Physical Layer |  | 394d? | 2005-03-15 A | 2006-09-15 A | 100% | 2005-03-15 | 2006-09-15 | 394d? | finish no earlier than 2006-09-15 | R1 | 3152h | 3152h | EDCHTDD-Phys | IPwireless | nanderson@ipwireless.com | Rel-7 | Patrick |  |  |
| 1022 | 295.3 | EDCHTDD: Layer 2 and 3 Protocol Aspects |  | 394d? | 2005-03-15 A | 2006-09-15 A | 100% | 2005-03-15 | 2006-09-15 | 394d? | finish no earlier than 2006-09-15 | R2 | 3152h | 3152h | EDCHTDD-L23 | IPwireless | drichards@ipwireless.com | Rel-7 | Joern |  |  |
| 1023 | 295.4 | EDCHTDD: UTRAN Iub/Iur Protocol Aspects |  | 394d? | 2005-03-15 A | 2006-09-15 A | 100% | 2005-03-15 | 2006-09-15 | 394d? | finish no earlier than 2006-09-15 | R3 | 3152h | 3152h | EDCHTDD-IurIub | Interdigital | jim.miller@interdigital.com | Rel-7 | Juha |  |  |
| 1024 | 295.5 | EDCHTDD: RF Radio Transmission/ Reception, System Performance Requirements and Conformance Testing |  | 394d? | 2005-03-15 A | 2006-09-15 A | 100% | 2005-03-15 | 2006-09-15 | 394d? | finish no earlier than 2006-09-15 | R4 | 3152h | 3152h | EDCHTDD-RF | IPwireless | Shin Horng Wong (shwong@ipwireless.com) | Rel-7 | Stefania |  |  |
| 1025 | 296 | **1.28 Mcps TDD Enhanced Uplink** |  | 328d? | 2006-03-15 A | 2007-06-15 A | 100% | 2006-03-15 | 2007-06-15 | 328d? |  | RP | 11536h | 11536h | LCRTDD-EDCH | CATT | Haijing Hu | Rel-7 | Stefania | RP-070296 |  |
| 1026 | 296.1 | 1.28 Mcps TDD Enhanced Uplink: Physical Layer |  | 262d? | 2006-03-15 A | 2007-03-15 A | 100% | 2006-03-15 | 2007-03-15 | 262d? | finish no earlier than 2007-03-15 | R1 | 2096h | 2096h | LCRTDD-EDCH-Phys | CATT | Ke Wang | Rel-7 | Patrick |  |  |
| 1027 | 296.2 | 1.28 Mcps TDD Enhanced Uplink: Layer 2 and 3 Protocol Aspects |  | 262d? | 2006-03-15 A | 2007-03-15 A | 100% | 2006-03-15 | 2007-03-15 | 262d? | finish no earlier than 2007-03-15 | R2 | 2096h | 2096h | LCRTDD-EDCH-L23 | CATT | Haiyang Quan | Rel-7 | Joern |  |  |
| 1028 | 296.3 | 1.28 Mcps TDD Enhanced Uplink: UTRAN Iub/Iur Protocol Aspects |  | 262d? | 2006-03-15 A | 2007-03-15 A | 100% | 2006-03-15 | 2007-03-15 | 262d? | finish no earlier than 2007-03-15 | R3 | 2096h | 2096h | LCRTDD-EDCH-IubIur | CATT | Yincheng Zhang | Rel-7 | Juha |  |  |
| 1029 | 296.4 | 1.28 Mcps TDD Enhanced Uplink: RF Radio Transmission/ Reception, System Performance Requirements and Conformance Testing |  | 328d? | 2006-03-15 A | 2007-06-15 A | 100% | 2006-03-15 | 2007-06-15 | 328d? | finish no earlier than 2007-06-15 | R4 | 2624h | 2624h | LCRTDD-EDCH-RF | CATT | Yuexia Song | Rel-7 | Stefania |  |  |
| 1030 | 297 | 1.28 Mcps TDD Enhanced Uplink - UE Conformance Testing |  | 257d? | 2007-09-20 A | 2008-09-12 A | 100% | 2007-09-20 | 2008-09-12 | 257d? | finish no earlier than 2008-09-11 | R5 | 624h | 624h | LCRTDD-EDCH-UEConTest | CATT | chenxiaozhong@datangmobile.cn | Rel-7 | Ingbert | RP-080539 |  |
| 1031 | 298 | MS Antenna Performance Evaluation Method and Requirements |  | 731d? | 2005-01-28 A | 2007-11-16 A | 100% | 2005-01-28 | 2007-11-16 | 731d? | finish no earlier than 2007-11-16 | GP | 5848h | 5848h | APEMR | TeliaSonera | Ulf.Tegth@teliasonera.com | Rel-7 | Paolo |  |  |
| 1032 | 299 | **Lower 700 MHz Inclusion in the GERAN Specifications** |  | 390d? | 2005-01-03 A | 2006-06-30 A | 100% | 2005-01-03 | 2006-06-30 | 390d? |  | GP | 7632h | 7632h | GSM710 | UTC | dcotton@mtview.union-tel.com | Rel-7 | Paolo |  |  |
| 1033 | 299.1 | Inclusion of the 698 – 746 MHz band into GERAN core specifications |  | 129d? | 2005-01-03 A | 2005-06-30 A | 100% | 2005-01-03 | 2005-06-30 | 129d? | finish no earlier than 2005-06-30 | G1 | 1032h | 1032h | GSM710-core |  |  | Rel-7 | Paolo |  |  |
| 1034 | 299.2 | G1 aspects of GSM710 |  | 217.5d? | 2005-08-31 A | 2006-06-30 A | 100% | 2005-08-31 | 2006-06-30 | 217.5d? | finish no earlier than 2006-06-30 | G1 | 1740h | 1740h | GSM-710-test |  |  | Rel-7 | Paolo |  |  |
| 1035 | 299.3 | G3 aspects of GSM710 |  | 217.5d? | 2005-08-31 A | 2006-06-30 A | 100% | 2005-08-31 | 2006-06-30 | 217.5d? | finish no earlier than 2006-06-30 | G3new | 1740h | 1740h | GSM-710-test |  |  | Rel-7 | Ingbert |  |  |
| 1036 | 300 | **Support of Conversational Services in A/Gb mode via the PS domain** |  | 626d? | 2005-04-08 A | 2007-08-31 A | 100% | 2005-04-08 | 2007-08-31 | 626d? |  | GP | 15442.8h | 15442.8h | SCSAGB | Ericsson | gunnar.hedby@ericsson.com | Rel-7 | Paolo |  |  |
| 1037 | 300.1 | Minimise the transfer delay between the SGSN and the MS |  | 604.95d? | 2005-04-08 A | 2007-08-31 A | 100% | 2005-04-08 | 2007-08-31 | 604.95d? | finish no earlier than 2007-08-31 | GP | 4839.6h | 4839.6h | SCSAGB-MTD | Ericsson | gunnar.hedby@ericsson.com | Rel-7 | Paolo |  |  |
| 1038 | 300.2 | Definition of radio resource management functionality |  | 626d? | 2005-04-08 A | 2007-08-31 A | 100% | 2005-04-08 | 2007-08-31 | 626d? | finish no earlier than 2007-08-31 | G1 | 5008h | 5008h | SCSAGB-RRM | Ericsson | gunnar.hedby@ericsson.com | Rel-7 | Paolo |  |  |
| 1039 | 300.3 | Support of Conversational Services in A/Gb mode via the PS domain – RLC Non-Persistent mode |  | 101d? | 2006-06-30 A | 2006-11-17 A | 100% | 2006-06-30 | 2006-11-17 | 101d? | finish no earlier than 2006-11-17 | G2 | 808h | 808h | SCSAGB-RLCNP | Ericsson | gunnar.hedby@ericsson.com | Rel-7 | Gert |  |  |
| 1040 | 300.4 | Deleted- Radio Channel Support | milestone | 0d? | 2006-07-17 A | 2006-07-17 A | 100% | 2006-07-17 | 2006-07-17 | 0d? | start no earlier than 2006-07-17 | G2 |  |  | SCSAGB-RCHS | Ericsson | gunnar.hedby@ericsson.com | Rel-7 | Gert |  | SP-32 |
| 1041 | 300.5 | Deleted- Modifications to FLO | milestone | 0d? | 2006-07-17 A | 2006-07-17 A | 100% | 2006-07-17 | 2006-07-17 | 0d? | start no earlier than 2006-07-17 | G2 |  |  | SCSAGB-FLO | Ericsson | gunnar.hedby@ericsson.com | Rel-7 | Gert |  | SP-32 |

Notes:
- 1013: Completed Dec 2006, SR in RP-060684
- 1014: Feature completed and closed at RP#33 with the presentation of the test WI / Text3: 25.202
- 1015: Feature completed and closed at RP#33 with the presentation of the test WI / Text3: 25.221, 25.222, 25.223, 25.224,25.225
- 1016: Feature completed and closed at RP#33 with the presentation of the test WI / Text3: 25.301, 25.302, 25.305, 25.306, 25.321, 25.331
- 1017: Feature completed and closed at RP#33 with the presentation of the test WI / Text3: 25.401, 25.420, 25.423, 25.425, 25.427, 25.430, 25.433, 25.435
- 1018: Feature completed and closed at RP#33 with the presentation of the test WI / Text3: 25.102, 25.105, 25.123, 25.133, 25.142
- 1019: Completed Dec 2006, SR in RP-060684
- 1021: Text3: 25.201, 25.221,25.222, 25.223, 25.224, 25.225
- 1022: Text3: 25.301, 25.302, 25.306, 25.321, 25.331
- 1023: Text3: 25.401, 25.420, 25.423, 25.427, 25.430, 25.433, 25.435
- 1024: Text3: 25.102, 25.105, 25.123, 25.142
- 1025: Completed May 2007; SR in RP-070038 and RP-070296
- 1026: Text3: 25.201, 25.221, 25.222, 25.223, 25.224, 25.225
- 1027: Text3: 25.301, 25.302, 25.306, 25.321, 25.331
- 1028: Text3: 25.401, 25.420, 25.423, 25.425, 25.427, 25.430, 25.433, 25.435
- 1029: Text3: 25.102, 25.105, 25.123, 25.142
- 1030: UID_350046->350146. 05/08: Linked to Feature UID_20055 (LCRTDD-EDCH). SR in RP-080539. RP#41 completed / Text3: 34.108, 34.122, 34.123-1/2/3
- 1031: GP#36 completed for R7 / Text3: 25.914, 25.144, 45.005
- 1032: Text3: 24.008, 43.022, 44.018, 44.118, 45, 001, 45.005, 51.010, 51.021
- 1033: Completed / Text3: 24.008, 43.022, 44.018, 44.118, 45, 001, 45.005,
- 1034: Text3: 51.021
- 1035: Text3: 51.010
- 1036: Originally started Nov. 2003 as GP-030443
- 1039: Text3: 43.955, 43.064, 44.060, 45.001, 45.002, 45.003, 45.005, 45.010, 51.010, 51.021

| ID | WBS | Task | Duration | Start | Finish | Complete | Remaining | Baseline start | Baseline finish | Baseline duration | Total slack | Constraint | Resources | Work | Actual work | Text1 | Text4 | Text5 | Text6 | Text8 | Text12 |
| --- | --- | --- | --- | --- | --- | --- | --- | --- | --- | --- | --- | --- | --- | --- | --- | --- | --- | --- | --- | --- | --- |
| 1042 | 301 | **Addition of new frequency band to GSM (T-GSM810)** | 626d? | 2005-04-08 A | 2007-08-31 A | 100% |  | 2005-04-08 | 2007-08-31 | 626d? |  |  | GP | 12112h | 12112h | TGSM810 | Huawei | chende@huawei.com | Rel-7 | Paolo |  |
| 1043 | 301.1 | Changes to core specification | 106d? | 2005-04-08 A | 2005-09-02 A | 100% |  | 2005-04-08 | 2005-09-02 | 106d? |  | finish no earlier than 2005-09-02 | GP | 848h | 848h | TGSM810-Core | Huawei | chende@huawei.com | Rel-7 | Paolo |  |
| 1044 | 301.2 | Changes to MS testing specification | 626d? | 2005-04-08 A | 2007-08-31 A | 100% |  | 2005-04-08 | 2007-08-31 | 626d? |  | finish no earlier than 2007-08-31 | G3new | 5008h | 5008h | TGSM810-MStest | Huawei | chende@huawei.com | Rel-7 | Ingbert |  |
| 1045 | 301.3 | Changes to BTS testing specification | 156d? | 2005-04-08 A | 2005-11-11 A | 100% |  | 2005-04-08 | 2005-11-11 | 156d? |  | finish no earlier than 2005-11-11 | G1 | 1248h | 1248h | TGSM810-BTStest | Huawei | chende@huawei.com | Rel-7 | Paolo |  |
| 1046 | 302 | **Handover of dedicated and shared resources while in dual transfer mode** | 421d? | 2005-04-08 A | 2006-11-17 A | 100% |  | 2005-04-08 | 2006-11-17 | 421d? |  |  | GP | 12672h | 12672h | HODSRDTM | Nokia | rami.vaittinen@nokia.com | Rel-7 | Paolo |  |
| 1047 | 302.1 | Handover of dedicated and shared resources while in dual transfer mode | 321d? | 2005-04-08 A | 2006-06-30 A | 100% |  | 2005-04-08 | 2006-06-30 | 321d? |  | finish no earlier than 2006-06-30 | G2 | 2568h | 2568h | HODSRDTM-G2 | Nokia | rami.vaittinen@nokia.com | Rel-7 | Gert |  |
| 1048 | 302.2 | Deleted - MS Conformance Testing | 421d? | 2005-04-08 A | 2006-11-17 A | 100% |  | 2005-04-08 | 2006-11-17 | 421d? |  | finish no earlier than 2006-11-17 | G3new | 3368h | 3368h | HODSRDTM-Mstest | Nokia | rami.vaittinen@nokia.com | Rel-7 | Ingbert | GP-32 |
| 1049 | 302.3 | Deleted - BTS conformance testing | 421d? | 2005-04-08 A | 2006-11-17 A | 100% |  | 2005-04-08 | 2006-11-17 | 421d? |  | finish no earlier than 2006-11-17 | G1 | 3368h | 3368h | HODSRDTM-BTStest | Nokia | rami.vaittinen@nokia.com | Rel-7 | Paolo | GP-32 |
| 1050 | 303 | **Mobile Station Receive Diversity (DARP Phase II)** | 526d? | 2005-11-11 A | 2007-11-16 A | 100% |  | 2005-11-11 | 2007-11-16 | 526d? |  |  | GP | 16360h | 16360h | MSRD2 | Nokia | kent.pedersen@nokia.com | Rel-7 | Paolo |  |
| 1051 | 303.1 | Performance Requirements for Mobile Station Receive Diversity, DARP Phase II | 331d? | 2005-11-11 A | 2007-02-16 A | 100% |  | 2005-11-11 | 2007-02-16 | 331d? |  | finish no earlier than 2007-02-16 | GP | 2648h | 2648h | MSRD2-PerfReq | Nokia | kent.pedersen@nokia.com | Rel-7 | Paolo |  |
| 1052 | 303.2 | Capability signalling of Mobile Station Receive Diversity, DARP Phase II | 331d? | 2005-11-11 A | 2007-02-16 A | 100% |  | 2005-11-11 | 2007-02-16 | 331d? |  | finish no earlier than 2007-02-16 | GP | 2648h | 2648h | MSRD2-CapSig | Nokia | kent.pedersen@nokia.com | Rel-7 | Paolo |  |
| 1053 | 303.3 | Test Scenarios for Mobile Station Receive Diversity, DARP Phase II | 331d? | 2005-11-11 A | 2007-02-16 A | 100% |  | 2005-11-11 | 2007-02-16 | 331d? |  | finish no earlier than 2007-02-16 | GP | 2648h | 2648h | MSRD2-TestSc | Nokia | kent.pedersen@nokia.com | Rel-7 | Paolo |  |
| 1054 | 303.4 | MS conformance test of DARP Phase II (MSRD) | 526d? | 2005-11-11 A | 2007-11-16 A | 100% |  | 2005-11-11 | 2007-11-16 | 526d? |  | finish no earlier than 2007-11-16 | GP | 4208h | 4208h | MSRD2-Msconf | Nokia | kent.pedersen@nokia.com | Rel-7 | Ingbert |  |
| 1055 | 304 | **Downlink Dual Carrier** | 421d? | 2006-01-20 A | 2007-08-31 A | 100% |  | 2006-01-20 | 2007-08-31 | 421d? |  |  | GP | 7664h | 7664h | GDCDL | Nokia Siemens Networks | leonardo.provvedi@roke.co.uk | Rel-7 | Paolo |  |
| 1056 | 304.1 | Downlink Dual Carrier Stage 2 | 116d? | 2006-01-20 A | 2006-06-30 A | 100% |  | 2006-01-20 | 2006-06-30 | 116d? |  | finish no earlier than 2006-06-30 | G1 | 928h | 928h | GDCDL-Stage2 | Nokia Siemens Networks | leonardo.provvedi@roke.co.uk | Rel-7 | Paolo |  |
| 1057 | 304.2 | Downlink Dual Carrier Stage 3 | 421d? | 2006-01-20 A | 2007-08-31 A | 100% |  | 2006-01-20 | 2007-08-31 | 421d? |  | finish no earlier than 2007-08-31 | G1 | 3368h | 3368h | GDCDL-Stage2 | Nokia Siemens Networks | leonardo.provvedi@roke.co.uk | Rel-7 | Paolo |  |
| 1058 | 305 | **Downlink Dual Carrier – MS Conformance Test** | 1067d? | 2006-01-20 A | 2010-02-19 | 50% | 533.5d? | 2006-01-20 | 2010-02-19 | 1067d? | 145d |  | G3new | 13062.6h | 6531.3h | GDCDL-Stage3 | Nokia Siemens Networks | leonardo.provvedi@roke.co.uk | Rel-7 | Ingbert |  |
| 1059 | 305.1 | Downlink Dual Carrier – MS Conformance Test | 565.83d? | 2006-01-20 A | 2010-02-19 | 50% | 282.91d? | 2006-01-20 | 2010-02-19 | 565.83d? | 145d | finish no earlier than 2010-02-19 | G3new | 4526.6h | 2263.3h | GDCDL-Stage3 | Nokia Siemens Networks | leonardo.provvedi@roke.co.uk | Rel-7 | Ingbert |  |
| 1060 | 306 | Support of SIGTRAN in GERAN | 116d? | 2006-01-20 A | 2006-06-30 A | 100% |  | 2006-01-20 | 2006-06-30 | 116d? |  | finish no earlier than 2006-06-30 | G3new | 928h | 928h | GDCDL-MStest | Ericsson | peter.ostrup@ericsson.com | Rel-7 | Ingbert |  |
| 1061 | 307 | **Latency Reductions** | 306d? | 2006-06-30 A | 2007-08-31 A | 100% |  | 2006-06-30 | 2007-08-31 | 306d? |  |  | GP | 7344h | 7344h | LATRED | Ericsson | Hakan.Persson@Ericsson.com | Rel-7 | Paolo |  |
| 1062 | 307.1 | Improved Ack/Nack reporting | 306d? | 2006-06-30 A | 2007-08-31 A | 100% |  | 2006-06-30 | 2007-08-31 | 306d? |  | finish no earlier than 2007-08-31 | G2 | 2448h | 2448h | LATRED-ACKNAR | Ericsson | Hakan.Persson@Ericsson.com | Rel-7 | Gert |  |
| 1063 | 307.2 | Reduced TTI | 306d? | 2006-06-30 A | 2007-08-31 A | 100% |  | 2006-06-30 | 2007-08-31 | 306d? |  | finish no earlier than 2007-08-31 | G2 | 2448h | 2448h | LATRED-REDTTI | Ericsson | Hakan.Persson@Ericsson.com | Rel-7 | Gert |  |
| 1064 | 308 | PS Handover between GERAN/UTRAN mode and GAN Mode | 166d? | 2006-06-30 A | 2007-02-16 A | 100% |  | 2006-06-30 | 2007-02-16 | 166d? |  | finish no earlier than 2007-02-16 | G2 | 1328h | 1328h | GUGAN | Ericsson | John.Diachina@Ericsson.com | Rel-7 | Gert |  |
| 1065 | 309 | **Higher Uplink performance for GERAN Evolution** | 516d? | 2006-09-08 A | 2008-08-29 A | 100% |  | 2006-09-08 | 2008-08-29 | 516d? |  |  | GP | 15440h | 15440h | HUGE | Nokia Siemens Networks, Ericsson | eddie.riddington@nokia.com, stefan.g.eriksson@ericsson.com | Rel-7 | Paolo |  |
| 1066 | 309.1 | Stage 2 of HUGE | 261d? | 2006-09-08 A | 2007-09-07 A | 100% |  | 2006-09-08 | 2007-09-07 | 261d? |  | finish no earlier than 2007-09-07 | G1 | 2088h | 2088h | HUGE-Stage2 | Nokia Siemens Networks, Ericsson | eddie.riddington@nokia.com, stefan.g.eriksson@ericsson.com | Rel-7 | Paolo |  |
| 1067 | 309.2 | Layer 1 Support of HUGE | 381d? | 2006-09-08 A | 2008-02-22 A | 100% |  | 2006-09-08 | 2008-02-22 | 381d? |  | finish no earlier than 2008-02-22 | G1 | 3048h | 3048h | HUGE-Layer1 | Nokia Siemens Networks, Ericsson | eddie.riddington@nokia.com, stefan.g.eriksson@ericsson.com | Rel-7 | Paolo |  |
| 1068 | 309.3 | Layer 2/3 Support of HUGE | 256d? | 2006-09-08 A | 2007-08-31 A | 100% |  | 2006-09-08 | 2007-08-31 | 256d? |  | finish no earlier than 2007-08-31 | G2 | 2048h | 2048h | HUGE-Layer23 | Nokia Siemens Networks, Ericsson | eddie.riddington@nokia.com, stefan.g.eriksson@ericsson.com | Rel-7 | Gert |  |
| 1069 | 309.4 | Performance requirements | 516d? | 2006-09-08 A | 2008-08-29 A | 100% |  | 2006-09-08 | 2008-08-29 | 516d? |  | finish no earlier than 2008-08-29 | G1 | 4128h | 4128h | HUGE-Perfreq | Nokia Siemens Networks, Ericsson | eddie.riddington@nokia.com, stefan.g.eriksson@ericsson.com | Rel-7 | Paolo |  |

Notes:
- 1042: Text3: 45.005, 45.050, 24.008, 45.008, 45.001, 43.022, 43.030, 44.018, 44.060, 51.010-1, 51.021
- 1043: Text3: 45.005, 45.050, 24.008, 45.008, 45.001, 43.022, 43.030, 44.018, 44.060
- 1044: Text3: 51010-1
- 1045: Text3: 51021
- 1046: GP#30 completed. Started at GP#24
- 1047: GP#30 completed / Text3: 43.055, 44.018, 44.060
- 1048: Stopped, no work done. 12/2008 Marked as stopped ("deleted") / Text3: 51-010
- 1049: Stopped, no work done. 12/2008 Marked as stopped ("deleted") / Text3: 51.026
- 1050: GP#36 completed / Text3: 24.008, 45.005, 51.010
- 1051: GP#33 completed / Text3: 45.005
- 1052: GP#33 completed / Text3: 24.008
- 1053: GP#33 completed / Text3: 45.005
- 1054: GP#36 completed / Text3: 51.010
- 1055: GP#35 completed
- 1056: GP#30 completed / Text3: 43.055, 43.064
- 1057: GP#35 completed / Text3: 24.008, 44.018, 44.060, 45.001, 45.002, 45.005, 45.008
- 1058: Text3: 51.010
- 1059: GP#41 completion 09/09=>02/10. GP#40 completion 11/08=>09/09 / Text3: 51.010
- 1060: GP#30 completed / Text3: 48.001, 48.006, 43.059, 49.031
- 1061: GP#35 completed / Text3: 45.001, 45.002, 45.003, 45.005, 45.010, 43.055, 43.064, 44.060, 51.010-1, 51.021
- 1062: GP#35 completed / Text3: 45.001, 45.002, 45.003, 45.005, 45.010, 43.055, 43.064, 44.060, 51.010-1, 51.021
- 1063: GP#35 completed / Text3: 45.001, 45.002, 45.003, 45.005, 45.010, 43.055, 43.064, 44.060, 51.010-1, 51.021
- 1064: GP#33 completed / Text3: 43.318, 44.318, 43.129, 25.306, 24.008, 44.060, 25.331, 51.010
- 1065: GP#39 completed. SA#42 split core from testing specification work.
- 1066: GP#35 completed / Text3: 43.055, 43.064
- 1067: GP#37 completed / Text3: 45.001, 45.002, 45.003, 45.004, 45.008
- 1068: GP#35 completed / Text3: 24.008, 44.018, 44.060
- 1069: GP#39 completed / Text3: 45.005

| ID | WBS | Task | Type | Duration | Start | Finish | Complete | Remaining | Baseline start | Baseline finish | Baseline duration | Total slack | Constraint | Resources | Work | Actual work | Text1 | Text4 | Text5 | Text6 | Text8 | Text12 |
| --- | --- | --- | --- | --- | --- | --- | --- | --- | --- | --- | --- | --- | --- | --- | --- | --- | --- | --- | --- | --- | --- | --- |
| 1070 | 310 | **HUGE Conformance Testing** |  | 902d? | 2006-09-08 A | 2010-02-19 | 47% | 479.67d? | 2006-09-08 | 2010-02-19 | 902d? | 145d |  | G1,G3new | 20672h | 6656.4h | HUGE | Nokia Siemens Networks, Ericsson | eddie.riddington@nokia.com, stefan.g.eriksson@ericsson.com | Rel-7 | Paolo |  |
| 1071 | 310.1 | MS Conformance Test |  | 901d? | 2006-09-08 A | 2010-02-19 | 5% | 855.95d? | 2006-09-08 | 2010-02-19 | 901d? | 145d | finish no earlier than 2010-02-19 | G3new | 7208h | 360.4h | HUGE-Mstest | Nokia Siemens Networks, Ericsson | eddie.riddington@nokia.com, stefan.g.eriksson@ericsson.com | Rel-7 | Ingbert |  |
| 1072 | 310.2 | BTS Conformance Test |  | 782d? | 2006-09-08 A | 2009-09-04 | 95% | 39.05d? | 2006-09-08 | 2009-09-04 | 782d? | 265d | finish no earlier than 2009-09-04 | G1 | 6248h | 5935.6h | HUGE-BTStest | Nokia Siemens Networks, Ericsson | eddie.riddington@nokia.com, stefan.g.eriksson@ericsson.com | Rel-7 | Paolo |  |
| 1073 | 311 | **REduced symbol Duration, Higher Order modulation and Turbo coding (RED HOT) for downlink** |  | 391d? | 2006-11-17 A | 2008-05-16 A | 100% |  | 2006-11-17 | 2008-05-16 | 391d? |  |  | GP | 7904h | 7904h | REDHOT | Ericsson, Nokia Siemens Networks, Marvell | stefan.g.eriksson@ericsson.com | Rel-7 | Paolo |  |
| 1074 | 311.1 | Stage 2 for REDHOT |  | 206d? | 2006-11-17 A | 2007-08-31 A | 100% |  | 2006-11-17 | 2007-08-31 | 206d? |  | finish no earlier than 2007-08-31 | G1 | 1648h | 1648h | REDHOT-Stage2 | Ericsson, Nokia Siemens Networks, Marvell | stefan.g.eriksson@ericsson.com | Rel-7 | Paolo |  |
| 1075 | 311.2 | Stage 3 for REDHOT |  | 391d? | 2006-11-17 A | 2008-05-16 A | 100% |  | 2006-11-17 | 2008-05-16 | 391d? |  | finish no earlier than 2008-05-16 | G1 | 3128h | 3128h | REDHOT-Stage3 | Ericsson, Nokia Siemens Networks, Marvell | stefan.g.eriksson@ericsson.com | Rel-7 | Paolo |  |
| 1076 | 312 | **REDHOT Conformance Testing** |  | 852d? | 2006-11-17 A | 2010-02-19 | 46% | 458.59d? | 2006-11-17 | 2010-02-19 | 852d? | 145d |  | G1,G3new | 18832h | 5888.8h | REDHOT | Ericsson, Nokia Siemens Networks, Marvell | stefan.g.eriksson@ericsson.com | Rel-7 | Paolo |  |
| 1077 | 312.1 | MS Conformance Tests |  | 851d? | 2006-11-17 A | 2010-02-19 | 5% | 808.45d? | 2006-11-17 | 2010-02-19 | 851d? | 145d | finish no earlier than 2010-02-19 | G3new | 6808h | 340.4h | REDHOT-Mstest | Ericsson | stefan.g.eriksson@ericsson.com | Rel-7 | Ingbert |  |
| 1078 | 312.2 | BTS Conformance Tests |  | 651d? | 2006-11-17 A | 2009-05-15 A | 100% |  | 2006-11-17 | 2009-05-15 | 651d? |  | finish no earlier than 2009-05-15 | G1 | 5208h | 5208h | REDHOT-BTStest | Ericsson, Nokia Siemens Networks, Marvell | stefan.g.eriksson@ericsson.com | Rel-7 | Paolo |  |
| 1079 | 313 | (Small) Technical Enhancements and Improvements for Rel-7 | milestone | 0d? | 2007-03-26 A | 2007-03-26 A | 100% |  | 2007-03-26 | 2007-03-26 | 0d? |  | start no earlier than 2007-03-26 | All |  |  | TEI7 |  |  | Rel-7 |  |  |
| 1080 | 314 | **Deleted - PS domain and IMS support for IMS Emergency sessions** |  | 63.69d? | 2006-06-23 A | 2006-09-21 A | 100% |  | 2006-06-23 | 2006-09-21 | 63.69d? |  |  | S2 |  |  | IMS-EMER | Nokia | curt.c.wong@nokia.com | Rel-7 | Maurice | SP-30 |
| 1081 | 314.1 | Deleted - IMS aspects to support IMS Emergency sessions | milestone | 0d? | 2006-06-23 A | 2006-09-21 A | 100% |  | 2006-06-23 | 2006-09-21 | 0d? |  | start no earlier than 2006-06-23 | S2 |  |  | IMS-EMER | Nokia | curt.c.wong@nokia.com | Rel-7 | Maurice | SP-30 |
| 1082 | 314.2 | Deleted - PS domain aspects to support IMS Emergency sessions | milestone | 0d? | 2006-06-23 A | 2006-09-21 A | 100% |  | 2006-06-23 | 2006-09-21 | 0d? |  | start no earlier than 2006-06-23 | S2 |  |  | IMS-EMER | Nokia | curt.c.wong@nokia.com | Rel-7 | Maurice | SP-30 |
| 1083 | 315 | Deleted - Covered by SI - Personal Network (PN) and Personal Area Network (PAN) | milestone | 0d? | 2005-12-08 A | 2005-12-20 A | 100% |  | 2005-12-08 | 2005-12-20 | 0d? |  | start no earlier than 2005-12-08 | S1 |  |  | PNPAN | Vodafone | armin.toepfer@vodafone.com | Rel-7 | Alain | SP-30 |
| 1084 | 316 | Deleted - Covered by SI - Multimedia Telephony Capabilities for IMS | milestone | 0d? | 2005-12-08 A | 2005-12-20 A | 100% |  | 2005-12-08 | 2005-12-20 | 0d? |  | start no earlier than 2005-12-08 | S1 |  |  | MITE | Ericsson | peter.bleckert@ericsson.com | Rel-7 | Alain | SP-30 |
| 1085 | 317 | Deleted - Covered by SI - Transferring of emergency Call data | milestone | 0d? | 2005-12-08 A | 2005-12-08 A | 100% |  | 2005-12-08 | 2005-12-08 | 0d? |  | start no earlier than 2005-12-08 | S1 |  |  | eCALL | Motorola | steven.vardy@motorola.com | Rel-7 | Alain | SP-30 |
| 1086 | 318 | Deleted - Covered by SI - MBMS Enhancements | milestone | 0d? | 2005-12-08 A | 2005-12-08 A | 100% |  | 2005-12-08 | 2005-12-08 | 0d? |  | start no earlier than 2005-12-08 | S1 |  |  | MBMSE | China Mobile | liuhongyfw@chinamobile.com | Rel-7 | Alain | SP-30 |
| 1087 | 319 | **Deleted - VoIMS bearer related enhancements** |  | 0d? | 2006-07-21 A | 2006-07-21 A | 100% |  | 2006-07-21 | 2006-07-21 | 0d? |  |  | S2 |  |  | VoIMS |  |  | Rel-7 | Maurice | SP-32 |
| 1088 | 319.1 | Deleted - FS on enhancement of radio performance for VoIMS | milestone | 0d? | 2006-07-21 A | 2006-07-21 A | 100% |  | 2006-07-21 | 2006-07-21 | 0d? |  | start no earlier than 2006-07-21 | S2 |  |  | VoIMS | Nortel | Laurence Lautier (lautierl@nortel.com) | Rel-7 | Maurice | SP-32 |
| 1089 | 320 | Release 7 Feasibility Studies |  | 1d? | 2000-01-03 | 2000-01-03 |  |  | 2000-01-03 | 2000-01-03 | 1d? | 2791d |  | CP,GP, RP,SP | 8h |  |  |  |  | Rel-7 |  |  |
| 1090 | 321 | **Study on Multimedia Telephony Capabilities for IMS** |  | 276d? | 2005-07-11 A | 2006-07-31 A | 100% |  | 2005-07-11 | 2006-07-31 | 276d? |  |  | S1 | 4353.6h | 4353.6h | MITE | Ericsson | peter.bleckert@ericsson.com | Rel-7 | Alain |  |
| 1091 | 321.1 | Deleted covered by UID_31082 - Study of (MITe) - IMS Multimedia Telephony Communication Enabler and supplementary services |  | 276d? | 2005-07-11 A | 2006-07-31 A | 100% |  | 2005-07-11 | 2006-07-31 | 276d? |  | start no earlier than 2005-07-11 | S1 | 2208h | 2208h | MITE | Ericsson | peter.bleckert@ericsson.com | Rel-7 | Alain | SP-28 |
| 1092 | 322 | Study on Behaviour of Multi system UEs |  | 384d? | 2004-06-28 A | 2005-12-15 A | 100% |  | 2004-06-28 | 2005-12-15 | 384d? |  | start no earlier than 2004-06-28 | S1 | 3072h | 3072h | BMSU | Qualcomm | dwilliams@qualcomm.com | Rel-7 | Alain |  |
| 1093 | 323 | Study on Combining CS calls and IMS sessions |  | 189d? | 2004-06-28 A | 2005-03-17 A | 100% |  | 2004-06-28 | 2005-03-17 | 189d? |  | start no earlier than 2004-06-28 | S1 | 1512h | 1512h | IRTSD-CS_IMS |  | Robert Frank | Rel-7 | Alain |  |
| 1094 | 324 | Study on All-IP Network |  | 188d? | 2004-06-28 A | 2005-03-16 A | 100% |  | 2004-06-28 | 2005-03-16 | 188d? |  | start no earlier than 2004-06-28 | S1 | 1504h | 1504h | FS_AIPN | NTT DoCoMo | c.masyu@nttdocomo.co.jp | Rel-7 | Alain |  |
| 1095 | 325 | Study on Videotelephony teleservice |  | 231d? | 2005-03-01 A | 2006-01-17 A | 100% |  | 2005-03-01 | 2006-01-17 | 231d? |  |  | S1 | 1848h | 1848h | VidTel | T-Mobile | kurt.bischinger@t-mobile.at | Rel-7 | Alain |  |
| 1096 | 326 | Study on Network Selection Principles |  | 193d? | 2005-03-15 A | 2005-12-08 A | 100% |  | 2005-03-15 | 2005-12-08 | 193d? |  |  | S1 | 1544h | 1544h | NetSel | O2 | chris.friel@o2.com | Rel-7 | Alain |  |
| 1097 | 327 | Study on Multimedia Priority Service |  | 851d? | 2003-03-28 A | 2006-06-30 A | 100% |  | 2003-03-28 | 2006-06-30 | 851d? |  | finish no earlier than 2005-12-16 | S1 | 6808h | 6808h | PRIOR-MM | Telcordia | jgarraha@telcordia.com | Rel-7 | Alain |  |
| 1098 | 328 | Study on Transferring of emergency Call data |  | 190d? | 2005-07-11 A | 2006-03-31 A | 100% |  | 2005-07-11 | 2006-03-31 | 190d? |  | finish no earlier than 2005-12-08 | S1 | 1520h | 1520h | eCALL | Motorola | steven.vardy@motorola.com | Rel-7 | Alain |  |
| 1099 | 329 | Study on Enhancement of E2E QoS |  | 281.4d? | 2004-06-28 A | 2005-09-15 A | 100% |  | 2004-06-28 | 2005-09-15 | 281.4d? |  | finish no earlier than 2005-12-01 | S2 | 2251.2h | 2251.2h | QoS7 | Huawei | Robert Jaksa | Rel-7 | Maurice |  |
| 1100 | 330 | Study on Bandwidth Saving at Nb Interface with IP transport |  | 261d? | 2006-03-10 A | 2007-03-09 A | 100% |  | 2006-03-10 | 2007-03-09 | 261d? |  | finish no earlier than 2007-03-09 | C3 | 2088h | 2088h | BSNbIP | Siemens | Thomas.Belling@nsn.com | Rel-7 | Gwiho |  |
| 1101 | 331 | Study on Routeing of MT-SMs via the HPLMN |  | 301d? | 2005-10-07 A | 2006-12-01 A | 100% |  | 2005-10-07 | 2006-12-01 | 301d? |  | finish no earlier than 2006-12-01 | C4 | 2408h | 2408h | SMS7 | Vodafone | Nick.Russell@vodafone.com | Rel-7 | Kimmo |  |
| 1102 | 332 | Study on the TCAPsec Gateway concept |  | 96d? | 2005-10-28 A | 2006-03-10 A | 100% |  | 2005-10-28 | 2006-03-10 | 96d? |  | finish no earlier than 2006-03-10 | C4 | 768h | 768h | SEC7-TCAP | Siemens | Ulrich.wiehe@gksag.de | Rel-7 | Kimmo |  |
| 1103 | 333 | Study on using M2PA in 3GPP network |  | 318d? | 2006-03-22 A | 2007-06-08 A | 100% |  | 2006-03-22 | 2007-06-08 | 318d? |  | finish no earlier than 2007-06-08 | C4 | 2544h | 2544h | FS-M2PA | China Mobile | zhaoyuyi@chinamobile.com | Rel-7 | Kimmo |  |

Notes:
- 1070: GP#40 Target completion 05/08=>11/08=>02/09. SA#42 split core from testing specification work.
- 1071: GP#40 target 02/09=>02/10. GP#40 target 05/08=>02/09 / Text3: 51.010
- 1072: GP#42 completion=>05/09=>09/09. GP#41 completion 05/08=>11/08=>02/09=>05/09 / Text3: 51.021
- 1073: GP#38 completed. SA#42 split core from testing specification work.
- 1074: GP#35 completed / Text3: 43.055, 43.064
- 1075: GP#38 completed / Text3: 24.008, 44.018, 44.060, 45.001, 45.002, 45.003, 45.004, 45.005, 45.008
- 1076: GP#40 completion target 05/08=>11/08=>02/09. SA#42 split core from testing specification work.
- 1077: GP#41 completion 02/09=>02/10. GP#40 completion 08/08=>02/09 / Text3: 51.010
- 1078: GP#42 completed / Text3: 51.021
- 1079: Text3: CP-070260
- 1080: Approved at SA#29 / Text3: 23.867, 23.abc, 23.060, 23.002, 23.271
- 1081: Approved at SA#29 / Text3: 23.867, 23.abc, 23.060, 23.002, 23.271
- 1082: Approved at SA#29 / Text3: 23.867, 23.abc, 23.060, 23.002, 23.271
- 1087: Created by MCC to group all VoIMS related items, after consultation of chairs
- 1088: WID approved SA#28: SA2#52: CLOSED - To be removed from the work plan / Text3: 23.807
- 1090: Spin-off Feature UID_7038 (MTSI) / Text3: 22.973
- 1091: Duplicate entry with 31082 / Text3: 22.973
- 1092: Text3: 22.936
- 1093: Text3: 22.979
- 1094: 25/07/08 Moved as FS to Rel-7 out of the stopped Rel-8 Feature UID_31067 Deleted - All-IP Network (AIPN) / Text3: 22.978
- 1095: Text3: 22.903
- 1096: Spin-off Feature Network selection enhancements (NSP-CR) UID_7041 / Text3: 22.811
- 1097: Spin-off Feature PRIOR UID_340044 / Text3: 22.953
- 1098: Text3: 22.967
- 1099: Text3: 23.802
- 1100: Moved to FS at CT32 (in line with slides) / Text3: 29.814
- 1101: Previously known as "Study of a SMS Centre for MT SMS" / Text3: 23.840
- 1102: TR 29.800 content moved to TS 29.204 under implementation WI UID_310005 TCAPsec Gateway / Text3: 29.800
- 1103: Text3: 29.801

| ID | WBS | Task | Type | Duration | Start | Finish | Complete | Baseline start | Baseline finish | Baseline duration | Total slack | Constraint | Resources | Work | Actual work | Text1 | Text3 | Text4 | Text5 | Text6 | Text8 | Text11 | Text12 |
| --- | --- | --- | --- | --- | --- | --- | --- | --- | --- | --- | --- | --- | --- | --- | --- | --- | --- | --- | --- | --- | --- | --- | --- |
| 1104 | 334 | **Study on Support of (G)MSC-S - (G)MSC-S Nc Interface based on the SIP-I protocol** |  | 350d? | 2006-05-15 A | 2007-09-14 A | 100% | 2006-05-15 | 2007-09-14 | 350d? |  |  | C4 | 7800h | 7800h | NcSIP | 29.802 | Vodafone | david.hutton@vodafone.com | Rel-7 | Kimmo |  |  |
| 1105 | 334.1 | CT4 aspects of NcSIP |  | 275d? | 2006-05-15 A | 2007-06-01 A | 100% | 2006-05-15 | 2007-06-01 | 275d? |  | finish no earlier than 2007-06-01 | C4 | 2200h | 2200h | NcSIP | 29.802 | Vodafone | david.hutton@vodafone.com | Rel-7 | Kimmo |  |  |
| 1106 | 334.2 | CT3 aspects of NcSIP |  | 350d? | 2006-05-15 A | 2007-09-14 A | 100% | 2006-05-15 | 2007-09-14 | 350d? |  | finish no earlier than 2007-09-14 | C3 | 2800h | 2800h | NcSIP | 29.802 | Ericsson | ragnar.huslende@ericsson.com | Rel-7 | Gwiho |  |  |
| 1107 | 335 | Study on SOAP/HTTP IRP Solution Sets |  | 330d? | 2005-09-02 A | 2006-12-07 A | 100% | 2005-09-02 | 2006-12-07 | 330d? |  | finish no earlier than 2006-12-07 | S5 | 2640h | 2640h | OAM7-NIM-XML | 32.809 | Nortel |  | Rel-7 | Dionisio |  |  |
| 1108 | 336 | Study on Itf-N Implementation Conformance Statement (ICS) template |  | 400d? | 2005-09-02 A | 2007-03-15 A | 100% | 2005-09-02 | 2007-03-15 | 400d? |  | finish no earlier than 2007-03-15 | S5 | 3200h | 3200h | OAM7-NIM-ICS | 32.812 | China Mobile |  | Rel-7 | Dionisio |  |  |
| 1109 | 337 | Study on IRP Information Model |  | 400d? | 2005-09-02 A | 2007-03-15 A | 100% | 2005-09-02 | 2007-03-15 | 400d? |  | finish no earlier than 2007-03-15 | S5 | 3200h | 3200h | OAM7-NIM-IM | 32.810 | Motorola |  | Rel-7 | Dionisio |  |  |
| 1110 | 338 | Study on Evolved UTRA and UTRAN |  | 458d? | 2004-12-15 A | 2006-09-15 A | 100% | 2004-12-15 | 2006-09-15 | 458d? |  | finish no earlier than 2006-09-15 | RP | 3664h | 3664h | RANFS-Evo | 25.912 | NTT DoCoMo | nakamurata@NTTDOCOMO.CO.JP | Rel-7 | Stefania | RP-060472 |  |
| 1111 | 339 | Study on Performance Evaluation of the UE behaviour in high speed trains with speeds up to 350 kmph |  | 328d? | 2005-03-15 A | 2006-06-15 A | 100% | 2005-03-15 | 2006-06-15 | 328d? |  | finish no earlier than 2006-06-15 | R4 | 2624h | 2624h | RANFS-HSTrains | none | Vodafone | Mike.vogel@vodafone.com,tim.frost@vodafone.com | Rel-7 | Stefania | RP-060412 |  |
| 1112 | 340 | Study on UTRA Tower Mounted Amplifier (FDD) |  | 195d? | 2005-06-15 A | 2006-03-14 A | 100% | 2005-06-15 | 2006-03-14 | 195d? |  | finish no earlier than 2006-03-15 | R4 | 1560h | 1560h | RANFS-TMA | 25.818 | Ericsson | Klas.Sjerling@ericsson.com | Rel-7 | Stefania | RP-060035 |  |
| 1113 | 341 | Study on Continuous connectivity for packet data users |  | 132d? | 2005-03-15 A | 2005-09-14 A | 100% | 2005-03-15 | 2005-09-14 | 132d? |  | finish no earlier than 2005-09-15 | R1 | 1056h | 1056h | RANFS-cont-packet | none | Siemens | joerg.gustrau@siemens.com | Rel-7 | Patrick | RP-050427 |  |
| 1114 | 342 | Study on Improvement of the Multimedia Broadcast Multicast Service (MBMS) in UTRAN |  | 262d? | 2005-12-15 A | 2006-12-15 A | 100% | 2005-12-15 | 2006-12-15 | 262d? |  | finish no earlier than 2006-12-15 | R2 | 2096h | 2096h | RANFS-MBMSImp | 25.905 | LG Electronics | leego@lge.com | Rel-7 | Joern | RP-060692 |  |
| 1115 | 343 | Study on Performance Improvements in Small Cells using HSDPA/EDCH |  | 131d? | 2005-12-15 A | 2006-06-15 A | 100% | 2005-12-15 | 2006-06-15 | 131d? |  | finish no earlier than 2006-06-15 | R4 | 1048h | 1048h | SMALLCELLS | none | Cingular | Marc Grant | Rel-7 | Stefania | RP-060263 |  |
| 1116 | 344 | Study on Further Improved Performance Requirements for UMTS/HSDPA UE (FDD) |  | 383d? | 2005-12-15 A | 2007-06-04 A | 100% | 2005-12-15 | 2007-06-04 | 383d? |  | finish no earlier than 2007-06-04 | R4 | 3064h | 3064h | RANFS-IC | 25.963 | Cingular | Marc Grant | Rel-7 | Stefania | RP-070499 |  |
| 1117 | 345 | Study on Scope of future FDD HSPA Evolution |  | 394d? | 2006-03-15 A | 2007-09-17 A | 100% | 2006-03-15 | 2007-09-17 | 394d? |  | finish no earlier than 2007-09-17 | RP | 3152h | 3152h | RANFS-HSPAEvo | 25.999 | Cingular | Don Zelmer (dz1069@att.com) | Rel-7 | Stefania | RP-070533 |  |
| 1118 | 346 | Study on Dynamically reconfiguring a FDD UE receiver to reduce power consumption when desired Quality of Service is met | milestone | 0d? | 2007-06-22 A | 2007-06-22 A | 100% | 2007-06-22 | 2007-06-22 | 0d? |  |  | R4 |  |  | FSUEPow | 25.906 | Nokia | Chris.callender@nokia.com, tiina.s.koskinen@nokia.com | Rel-7 | Stefania | RP-070534 |  |
| 1119 | 347 | Study on Future GERAN Evolution |  | 486d? | 2005-04-08 A | 2007-02-16 A | 100% | 2005-04-08 | 2007-02-16 | 486d? |  | finish no earlier than 2007-02-16 | GP | 3888h | 3888h | FGE | 45.912 | Nokia | eddie.riddington@nokia.com | Rel-7 | Paolo |  |  |
| 1120 | 348 | Study on GAN Enhancements | milestone | 0d? | 2007-08-31 A | 2007-08-31 A | 100% | 2007-08-31 | 2007-08-31 | 0d? |  | start no earlier than 2007-08-31 | GP |  |  | EGAN | 43.902 | T-Mobile | janne.linkola@t-mobile.com | Rel-7 | Paolo |  |  |
| 1121 | 349 | Deleted - covered by UID33027 - IMS security extensions | milestone | 0d? | 2005-12-08 A | 2005-12-08 A | 100% | 2005-12-08 | 2005-12-08 | 0d? |  | start no earlier than 2005-12-08 | S3 |  |  | IMS-SE |  | Ericsson | Bengt.Sahlin@ericsson.com | Rel-7 | Dionisio |  | SP-30 |
| 1122 | 350 | Deleted - covered by 32108 - Study of work on an LCS architecture for I-WLAN | milestone | 0d? | 2006-12-08 A | 2006-12-08 A | 100% | 2006-12-08 | 2006-12-08 | 0d? |  | start no earlier than 2006-12-08 | S2 |  |  | IMS-SE |  | LG Electronics | Donghee Shim dhshim@lge.com ; phede@lge.com | Rel-7 | Maurice |  | SP-33 |
| 1123 | 351 | **Deleted: Study on applicability of GALILEO for LCS** |  | 0d? | 2005-06-30 A | 2005-06-30 A | 100% | 2005-06-30 | 2005-06-30 | 0d? |  |  | S2 |  |  | Galileo |  |  |  | Rel-7 | Maurice |  | SP-25 |
| 1124 | 351.1 | Deleted - TR on Stage 2 | milestone | 0d? | 2005-06-30 A | 2005-06-30 A | 100% | 2005-06-30 | 2005-06-30 | 0d? |  | finish no earlier than 2005-06-30 | S2 |  |  | Galileo |  |  |  | Rel-7 | Maurice |  | SP-25 |
| 1125 | 351.2 | Deleted - GERAN review of the TR | milestone | 0d? | 2005-06-30 A | 2005-06-30 A | 100% | 2005-06-30 | 2005-06-30 | 0d? |  | start no earlier than 2005-06-30 | GP |  |  | Galileo |  |  |  | Rel-7 | Paolo |  | SP-26 |
| 1126 | 16.7 | **Deleted - IMS Local services** |  | 0d? | 2006-01-06 A | 2006-01-06 A | 100% | 2006-01-06 | 2006-01-06 | 0d? |  |  | S2 |  |  | IMSLocal | 23.228 |  |  | Rel-7 | Maurice |  | SP-28 |
| 1127 | 16.7.1 | Deleted - Stage 2 | milestone | 0d | 2006-01-06 A | 2006-01-06 A | 100% | 2006-01-06 | 2006-01-06 | 0d |  | start no earlier than 2006-01-06 | S2 |  |  | IMSLocal |  |  |  | Rel-7 | Maurice |  | SP-26 |
| 1128 | 352.2 | Deleted - Stage 3 for IMS Local services | milestone | 0d? | 2006-01-06 A | 2006-01-06 A | 100% | 2006-01-06 | 2006-01-06 | 0d? |  | finish no earlier than 2006-01-06 | C1 |  |  | IMSLocal |  | Lucent | Keith Drage (drage@alcatel-lucent.com) | Rel-7 | Frederic |  | SP-25 |
| 1129 | 353 | Deleted - IMS Phase 3 | milestone | 0d? | 2006-01-06 A | 2006-01-06 A | 100% | 2006-01-06 | 2006-01-06 | 0d? |  | start no earlier than 2006-01-06 | S2 |  |  |  |  |  |  | Rel-7 | Maurice |  | SP-25 |
| 1130 | 354 | Deleted - Improvements of Radio Interface | milestone | 0d? | 2004-09-15 A | 2004-09-15 A | 100% | 2004-09-15 | 2004-09-15 | 0d? |  | start no earlier than 2004-09-15 | RP |  |  | RInImp |  |  |  | Rel-7 | Stefania |  | SP-24 |
| 1131 | 355 | Deleted: Generic User Profile Phase 2 | milestone | 0d | 2005-08-08 A | 2006-06-30 A | 100% | 2005-08-08 | 2006-06-30 | 0d |  |  | C4 |  |  |  |  |  |  | Rel-7 | Kimmo |  | SP-27 |
| 1132 | 30.4 | Deleted - Stage 3 - Common objects | milestone | 0d | 2005-08-08 A | 2006-06-30 A | 100% | 2005-08-08 | 2006-06-30 | 0d |  | finish no earlier than 2006-06-30 | C4 |  |  |  | 24.241 |  |  | Rel-7 | Kimmo |  | SP-27 |
| 1133 | 357 | Delete was duplicated- Study of Customised Alerting Tone (CAT) Requirements | milestone | 0d? | 2006-06-30 A | 2006-06-30 A | 100% | 2006-06-30 | 2006-06-30 | 0d? |  | start no earlier than 2006-06-30 | S1 |  |  | CAT |  |  |  | Rel-7 | Alain |  | SP-31 |
| 1134 | 358 | Deleted - FS of enhanced support of Video Telephony | milestone | 0d? | 2006-06-30 A | 2006-06-30 A | 100% | 2006-06-30 | 2006-06-30 | 0d? |  | start no earlier than 2006-06-30 | GP |  |  | VIDGER |  | Ericsson | stefan.g.eriksson@ericsson.com | Rel-7 | Paolo |  | SP-32 |
| 1135 | 359 | Deleted (moved to Rel8) - Study on Transferring of emergency call data – in-band modem solution | milestone | 0d? | 2007-06-22 A | 2007-06-22 A | 100% | 2007-06-22 | 2007-06-22 | 0d? |  | start no earlier than 2007-06-22 | S4 |  |  | eCALLIBMS | 26.967 | Airbiquity | lhong@airbiquity.com | Rel-7 | Paolo |  | SP-38 |
| 1136 | 360 | Deleted - covered by UID 20053 - Study on Interference Cancellation for UTRA FDD UE |  | 1d? | 2007-03-28 A | 2007-03-28 A | 100% | 2007-03-28 | 2007-03-28 | 1d? |  | start no earlier than 2007-03-28 | R4 | 8h | 8h | RANFS-InterfCanc |  |  |  | Rel-7 | Stefania |  | SP-38 |
| 1137 | 361 | Deleted - Study of Personal Network and Personal Area Network | milestone | 0d? | 2006-10-20 A | 2006-10-20 A | 100% | 2006-10-20 | 2006-10-20 | 0d? |  | finish no earlier than 2006-10-20 | S1 |  |  | PNPAN |  |  |  | Rel-7 | Alain |  | SP-31 |
| 1138 | 362 | Deleted - Study on IMS with real time services deployment |  | 316d? | 2004-06-28 A | 2005-09-12 A | 100% | 2004-06-28 | 2005-09-12 | 316d? |  |  | S1 | 2528h | 2528h | IRTSD |  |  |  | Rel-7 | Alain |  | SP-30 |
| 1139 | 363 | Deleted - Study on Stage 2 (IMS services using CS bearers) |  | 316d? | 2004-06-28 A | 2005-09-12 A | 100% | 2004-06-28 | 2005-09-12 | 316d? |  | finish no earlier than 2005-09-12 | S2 | 2528h | 2528h | IRTSD-IMSCS | 23.899 | Nortel | Mark Watson | Rel-7 | Maurice |  | SP-30 |
| 1140 | 364 | Deleted - Study on IMS enhancements and optimisations for real time communication. |  | 430d? | 2005-10-10 A | 2007-06-01 A | 100% | 2005-10-10 | 2007-06-01 | 430d? |  | finish no earlier than 2007-06-01 | S2 | 3440h | 3440h | IMS-RT | 23.818 | Ericsson | stephen.terrill@ericsson.com | Rel-7 | Maurice |  | SP-35 |
| 1141 | 365 | Deleted - Study on Terminating Session handling |  | 255d? | 2006-01-09 A | 2006-12-29 A | 100% | 2006-01-09 | 2006-12-29 | 255d? |  | finish no earlier than 2006-12-29 | S2 | 2040h | 2040h | CSIterm | 23.819 | Samsung |  | Rel-7 | Maurice |  | SP-32 |
| 1142 | 366 | Deleted - Study on IRP usage scenarios |  | 330d? | 2005-09-02 A | 2006-12-07 A | 100% | 2005-09-02 | 2006-12-07 | 330d? |  | finish no earlier than 2006-12-07 | S5 | 2640h | 2640h | OAM-Study | 32.8xy | Lucent |  | Rel-7 | Dionisio |  | SP-32 |
| 1143 | 367 | Release 6 Features |  | 1d? | 2000-01-03 | 2000-01-03 |  | 2000-01-03 | 2000-01-03 | 1d? | 2791d |  | CP,GP, RP,SP,TP | 8h |  |  |  |  |  | Rel-6 |  |  |  |

Notes:
- 1107: SA#34 completed
- 1108: SA#35 completed
- 1109: SA#35 completed
- 1110: RP#33 (Sep 2006) completed. SR in RP-060472
- 1111: RP#32 (Jun 2006) completed. SR in RP-060412
- 1112: RP#31 (Mar 2006) completed. SR in RP-060035
- 1113: RP#29 (Sep 2006) completed. SR in RP-050427
- 1114: RP#34 (Dec 2006) completed. SR in RP-060692
- 1115: RP#32 (Jun 2006) closed (no progress). SR in RP-060263
- 1116: RP#36 (May 2007) completed. SR in RP-070499
- 1117: RP#37 (Sep 2007) completed. SR in RP-070533
- 1118: RP#37 (Sep 2007) completed. SR in RP-070534
- 1119: GP#33 completed
- 1120: GP#35 completed
- 1122: S2#52: Entry created
- 1127: DAB - Not yet required in SA2 as it exists in previous releases
- 1130: Stage 2 description of Interim conclusion
- 1131: Created at TSG#27 by A. Sultan because of the move to Rel-7 of "Common Objects".
- 1132: No progress in CN4#26. This have to be moved to Rel-7. It was deleted from WID
- 1133: Awaiting MCC SA3 input
- 1134: FS CLOSED at G#28 (no input)
- 1135: SP-38 stopped
- 1136: Deleted. Same as FS on Further Improved Performance Requirements for UMTS/HSDPA UE (FDD)
- 1137: Moved from FS section Feb 06
- 1139: SP-30: S2 has no intention for TR completion
- 1140: abandoned at 65%
- 1141: SA#32 Jun 2006 Study abandoned => spin-off Implementation work UID_320029

| ID | WBS | Task | Duration | Start | Finish | Complete | Baseline start | Baseline finish | Baseline duration | Constraint | Resources | Work | Actual work | Text1 | Text6 | Text8 | Text4 | Text5 | Text3 | Text10 | Text12 |
| --- | --- | --- | --- | --- | --- | --- | --- | --- | --- | --- | --- | --- | --- | --- | --- | --- | --- | --- | --- | --- | --- |
| 1144 | 8 | **Rel-6 Improvements of Radio Interface** | 1393d? | 2000-08-14 A | 2005-12-14 A | 100% | 2000-08-14 | 2005-12-14 | 1393d? |  | RP | 38664h | 38664h | RInImp | Rel-6 | Stefania |  |  |  |  |  |
| 1145 | 368.1 | Improved support of IMS Realtime Services using HSDPA/EDCH | 197d? | 2005-03-15 A | 2005-12-14 A | 100% | 2005-03-15 | 2005-12-14 | 197d? | finish no earlier than 2005-12-14 | R2 | 1576h | 1576h | RInImp-IMSRealTime | Rel-6 | Joern | Cingular | Don Zelmer (dz1069@att.com) |  |  |  |
| 1146 | 368.2 | Improving Receiver Performance Requirements for the FDD UE | 401d | 2002-03-08 A | 2003-09-19 A | 100% | 2002-03-08 | 2003-09-19 | 401d | start no earlier than 2002-03-08 | R4 | 3208h | 3208h | RInImp-UERecPerf | Rel-6 | Stefania | Intel | shimon.moshavi@INTEL.COM | 25.101 |  |  |
| 1147 | 8.2 | **Base station classification** | 603d | 2000-08-14 A | 2002-12-04 A | 100% | 2000-08-14 | 2002-12-04 | 603d |  | R4 | 9648h | 9648h | RInImp-BSClass | Rel-6 | Stefania |  |  |  |  |  |
| 1148 | 8.2.1 | FDD Base station classification | 603d | 2000-08-14 A | 2002-12-04 A | 100% | 2000-08-14 | 2002-12-04 | 603d | finish no earlier than 2002-12-04 | R4 | 4824h | 4824h | RInImp-BSClass-FDD | Rel-6 | Stefania | Nokia | antti.toskala@nokia.com | 25.104, 25.141 |  |  |
| 1149 | 368.4 | UMTS-850 | 266d | 2002-12-06 A | 2003-12-12 A | 100% | 2002-12-06 | 2003-12-12 | 266d | finish no earlier than 2003-12-15 | R4 | 2128h | 2128h | RInImp-UMTS850 | Rel-6 | Stefania | Cingular | Don Zelmer (dz1069@att.com) | 25.101, 25.104, 25.133, 25.141, 25.307, 25.331, 25.942 |  |  |
| 1150 | 368.5 | DS-CDMA introduction in the 800 MHz band | 196d | 2003-03-14 A | 2003-12-12 A | 100% | 2003-03-14 | 2003-12-12 | 196d | finish no earlier than 2003-12-15 | R4 | 1568h | 1568h | RInImp-UMTS800 | Rel-6 | Stefania | NTT DoCoMo | Takehiro Nakamura (nakamurata@nttdocomo.co.jp) | 25.101, 25.104, 25.133, 25.141, 25.307, 25.331 |  |  |
| 1151 | 368.6 | UMTS 1.7/2.1 GHz | 261d | 2003-03-14 A | 2004-03-12 A | 100% | 2003-03-14 | 2004-03-12 | 261d | finish no earlier than 2004-03-15 | R4 | 2088h | 2088h | RInImp-UMTS1721 | Rel-6 | Stefania | Nokia | jussi.numminen@NOKIA.COM | 25.101, 25.104, 25.133, 25.141, 25.307, 25.331 |  |  |
| 1152 | 368.7 | **Improved Receiver Performance Requirements for HSDPA** | 392d? | 2003-12-15 A | 2005-06-14 A | 100% | 2003-12-15 | 2005-06-14 | 392d? |  | R4 | 7304h | 7304h | RInImp-HSPerf | Rel-6 | Stefania | Nokia | jussi.numminen@NOKIA.COM |  |  |  |
| 1153 | 368.7.1 | Improved Minimum Performance Requirements for HSDPA UE categories 7 and 8 | 195d? | 2004-09-15 A | 2005-06-14 A | 100% | 2004-09-15 | 2005-06-14 | 195d? | finish no earlier than 2005-06-14 | R4 | 1560h | 1560h | RInImp-HSPerf-10code | Rel-6 | Stefania | Nokia | jussi.numminen@nokia.com | 25.101 |  |  |
| 1154 | 368.7.2 | Performance Requirements of Receive Diversity for HSDPA | 326d | 2003-12-15 A | 2005-03-14 A | 100% | 2003-12-15 | 2005-03-14 | 326d | finish no earlier than 2005-03-14 | R4 | 2608h | 2608h | RInImp-HSPerf-RxDiv | Rel-6 | Stefania | NTT DoCoMo | Takehiro Nakamura (nakamurata@nttdocomo.co.jp) | 25.101 |  |  |
| 1155 | 369 | **Rel-6 RAN Feasibility Studies** | 1196d? | 2000-08-14 A | 2005-03-14 A | 100% | 2000-08-14 | 2005-03-14 | 1196d? |  | RP | 43048h | 43048h |  | Rel-6 | Stefania |  |  |  |  |  |
| 1156 | 369.1 | FS of the improved access to UE measurement data for CRNC to support TDD RRM | 270d? | 2002-12-06 A | 2003-12-18 A | 100% | 2002-12-06 | 2003-12-18 | 270d? | finish no earlier than 2003-09-19 | R3 | 2160h | 2160h | RANimp-RRMopt-FSUEMsD | Rel-6 | Juha | Interdigital | jim.miller@interdigital.com |  | SP-24 |  |
| 1157 | 369.2 | FS on Radio link performance enhancements | 1067d | 2000-08-14 A | 2004-09-14 A | 100% | 2000-08-14 | 2004-09-14 | 1067d | finish no earlier than 2004-09-14 | R1 | 8536h | 8536h | RInImp-Rlperf | Rel-6 | Patrick | Nokia | antti.toskala@nokia.com | 25.899 |  |  |
| 1158 | 369.3 | FS on Improvement of inter-frequency and inter-system measurements for 1.28 Mcps TDD | 461d | 2001-12-14 A | 2003-09-19 A | 100% | 2001-12-14 | 2003-09-19 | 461d | start no earlier than 2001-12-14 | R1 | 3688h | 3688h | RInImp-IfIsMLCR | Rel-6 | Patrick | Samsung | Li Xiao Qiang (xqli@samsung.co.kr) | 25.888 |  |  |
| 1159 | 369.4 | FS for the analysis of OFDM for UTRAN enhancement | 526d | 2002-06-10 A | 2004-06-14 A | 100% | 2002-06-10 | 2004-06-14 | 526d | start no earlier than 2002-06-10 | R1 | 4208h | 4208h | RInImp-FSOFDM | Rel-6 | Patrick | Nortel | Sarah Boumendil | 25.892 |  |  |
| 1160 | 369.5 | FS on Uplink Enhancements for Dedicated Transport Channels | 396d | 2002-09-06 A | 2004-03-12 A | 100% | 2002-09-06 | 2004-03-12 | 396d | finish no earlier than 2004-03-12 | R1 | 3168h | 3168h | RInImp-FSUpDTrCh | Rel-6 | Patrick | Nokia | Karri.Ranta-aho@nsn.com | 25.896 |  |  |
| 1161 | 369.6 | FS on Analysis on Higher Chip Rates for UTRA TDD evolutions | 528d | 2002-09-06 A | 2004-09-14 A | 100% | 2002-09-06 | 2004-09-14 | 528d | finish no earlier than 2004-09-14 | R1 | 4224h | 4224h | RInImp-FSVHCRTDD | Rel-6 | Patrick | IPWireless | mbeale@ipwireless.com | 25.895 |  |  |
| 1162 | 369.7 | FS on Low Output Powers for general purpose FDD BSs | 128d | 2003-06-13 A | 2004-03-12 A | 100% | 2003-06-13 | 2004-03-12 | 128d | finish no earlier than 2004-03-12 | R3 | 1024h | 1024h | RInImp-FSLoPw | Rel-6 | Juha | Telefonica | Ana Burgos (burgos_a@tsm.es) | 25.807 |  |  |
| 1163 | 369.8 | FS on Uplink enhancements for UTRA TDD | 462d | 2003-06-06 A | 2005-03-14 A | 100% | 2003-06-06 | 2005-03-14 | 462d | finish no earlier than 2005-03-14 | R1 | 3696h | 3696h | RInImp-FSUpEnhTDD | Rel-6 | Patrick | Interdigital | Marian.Rudolf@InterDigital.com | 25.804 |  |  |
| 1164 | 8.8 | FS on UE antenna efficiency test methods performance requirements (2) | 131d | 2002-03-08 A | 2002-09-06 A | 100% | 2002-03-08 | 2002-09-06 | 131d | finish no earlier than 2002-09-06 | R4 | 1048h | 1048h | RInImp-UEAnTM2 | Rel-6 | Stefania | Allgon | Alf Ahlström |  |  |  |
| 1165 | 9.4 | Deleted - FS on the evolution of the UTRAN architecture | 592d | 2002-09-09 A | 2004-12-14 A | 100% | 2002-09-09 | 2004-12-14 | 592d | finish no earlier than 2004-12-15 | R3 | 4736h | 4736h | RANimp-FSEvo | Rel-6 | Juha | Nokia | woonhee.hwang@nsn.com, Antti.Toskala@nokia.com |  |  | RP-26 |
| 1166 | 370 | **FDD Enhanced Uplink** | 393d | 2004-03-15 A | 2005-09-14 A | 100% | 2004-03-15 | 2005-09-14 | 393d |  | RP | 14128h | 14128h | EDCH | Rel-6 | Stefania | Ericsson | Joakim Bergström |  |  |  |
| 1167 | 370.1 | FDD Enhanced Uplink - Stage 2 | 197d | 2004-03-15 A | 2004-12-14 A | 100% | 2004-03-15 | 2004-12-14 | 197d | finish no earlier than 2004-12-14 | R2 | 1576h | 1576h | EDCH-Stage2 | Rel-6 | Joern |  |  | 25.309 |  |  |
| 1168 | 370.2 | FDD Enhanced Uplink - Physical Layer | 261d | 2004-03-15 A | 2005-03-14 A | 100% | 2004-03-15 | 2005-03-14 | 261d | finish no earlier than 2005-03-14 | R1 | 2088h | 2088h | EDCH-Phys | Rel-6 | Patrick | Nokia | Karri.Ranta-aho@nsn.com | 25.211, 25.212, 25.213, 25.214, 25.215 |  |  |
| 1169 | 370.3 | FDD Enhanced Uplink - Layer 2 and 3 Protocol Aspects | 261d | 2004-03-15 A | 2005-03-14 A | 100% | 2004-03-15 | 2005-03-14 | 261d | finish no earlier than 2005-03-14 | R2 | 2088h | 2088h | EDCH-L23 | Rel-6 | Joern | Ericsson | Joakim Bergström | 25.301, 25.302, 25.306, 25.321, 25.331 |  |  |
| 1170 | 370.4 | FDD Enhanced Uplink - UTRAN Iub/Iur Protocol Aspects | 261d | 2004-03-15 A | 2005-03-14 A | 100% | 2004-03-15 | 2005-03-14 | 261d | finish no earlier than 2005-03-14 | R3 | 2088h | 2088h | EDCH-IurIub | Rel-6 | Juha | Nortel | Saso Stojanovski | 25.401, 25.420, 25.423, 25.430, 25.433 |  |  |
| 1171 | 370.5 | FDD Enhanced Uplink - RF Radio Transmission/ Reception, System Performance Requirements and Conformance Testing | 393d | 2004-03-15 A | 2005-09-14 A | 100% | 2004-03-15 | 2005-09-14 | 393d | finish no earlier than 2005-09-15 | R4 | 3144h | 3144h | EDCH-RF | Rel-6 | Stefania | Ericsson | thomas.unshelm@ERICSSON.COM | 25.101, 25.104, 25.133, 25.141 |  |  |

Notes:
- 1144: This is a generic feature without particular end date
- 1153: Approved at RP#25 as RP-040375
- 1157: Study finished at RP#25
- 1161: Study finished at RP#25
- 1164: The RInImp-UEAnTM FS was re-opened at TSG RP#15 upon request from WG4
- 1165: Study Closed, work will continue within the FS on evolved UTRA and UTRAN

| ID | WBS | Task | Type | Duration | Start | Finish | Complete | Baseline start | Baseline finish | Baseline duration | Constraint | Resources | Work | Actual work | Text1 | Text6 | Text8 | Text3 | Text4 | Text5 | Text12 | Text10 |
| --- | --- | --- | --- | --- | --- | --- | --- | --- | --- | --- | --- | --- | --- | --- | --- | --- | --- | --- | --- | --- | --- | --- |
| 1172 | 371 | **Rel-6 RAN improvements** |  | 656d? | 2002-09-09 A | 2005-03-14 A | 100% | 2002-09-09 | 2005-03-14 | 656d? |  | RP | 28312h | 28312h | RANimp | Rel-6 | Stefania |  |  |  |  |  |
| 1173 | 9.2 | **RAB support enhancement** |  | 522d? | 2003-03-14 A | 2005-03-14 A | 100% | 2003-03-14 | 2005-03-14 | 522d? |  | R2 | 9360h | 9360h | RANimp-RABSE | Rel-6 | Joern | 25.862 | Nokia | Jussi Kähtävä (juha.mikola@nokia.com) |  |  |
| 1174 | 371.1.1 | Optimisation of downlink channelisation code utilisation |  | 262d | 2004-03-12 A | 2005-03-14 A | 100% | 2004-03-12 | 2005-03-14 | 262d | finish no earlier than 2005-03-14 | R1 | 2096h | 2096h | RANimp-RABSE-CodeOptFDD | Rel-6 | Patrick |  | Nortel | Sarah Boumendil |  |  |
| 1175 | 371.1.2 | Optimisation of channelisation code utilisation for 3.84 Mcps TDD |  | 261d | 2004-03-15 A | 2005-03-14 A | 100% | 2004-03-15 | 2005-03-14 | 261d | finish no earlier than 2005-03-15 | R1 | 2088h | 2088h | RANimp-RABSE-CodOptTDD | Rel-6 | Patrick |  | IPWireless | Nicholas Anderson |  |  |
| 1176 | 371.1.3 | HS-DPCCH ACK/NACK Enhancement |  | 65d? | 2004-09-15 A | 2004-12-14 A | 100% | 2004-09-15 | 2004-12-14 | 65d? | finish no earlier than 2004-12-15 | R1 | 520h | 520h | RANimp-RABSE-ACKNACK | Rel-6 | Patrick | 25.212, 25.214, 24.331, 25.433 | Nokia | Jussi Kähtävä (juha.mikola@nokia.com) |  |  |
| 1177 | 371.1.4 | Deleted - Iu enhancements for IMS support in RAN |  | 320d? | 2003-03-14 A | 2004-06-03 A | 100% | 2003-03-14 | 2004-06-03 | 320d? | start no earlier than 2003-03-14 | R3 | 2560h | 2560h | RANimp-RABSE-IuEnhIMS | Rel-6 | Juha |  | Nortel | Philippe.Godin@nortelnetworks.com | RP-24 |  |
| 1178 | 371.1.5 | Deleted - Improvement of RRM across RNS and RNS/BSS | milestone | 0d? | 2003-12-05 A | 2003-12-05 A | 100% | 2003-12-05 | 2003-12-05 | 0d? | finish no earlier than 2003-12-05 | R3 |  |  | RANimp-RRM1 | Rel-6 | Juha |  | Nokia | antti.toskala@nokia.com | RP-23 |  |
| 1179 | 9.1 | Beamforming Enhancements |  | 66d | 2003-09-19 A | 2003-12-19 A | 100% | 2003-09-19 | 2003-12-19 | 66d | finish no earlier than 2004-03-12 | R1 | 528h | 528h | RANimp-BFE | Rel-6 | Patrick | 24.215, 25.423, 25.425, 25.433, 25.435 | Nokia | Jussi Kähtävä (juha.mikola@nokia.com) |  |  |
| 1180 | 371.3 | **Rel6 RRM optimization for Iur and Iub** |  | 126d | 2003-09-19 A | 2004-03-12 A | 100% | 2003-09-19 | 2004-03-12 | 126d |  | R3 | 2016h | 2016h | RANimp-RRMopt | Rel-6 | Juha |  | Ericsson | Gert-Jan.van.Lieshout@eln.ericsson.se |  |  |
| 1181 | 371.3.1 | Improved access to UE measurement data for CRNC to support TDD RRM |  | 126d | 2003-09-19 A | 2004-03-12 A | 100% | 2003-09-19 | 2004-03-12 | 126d | finish no earlier than 2004-03-15 | R3 | 1008h | 1008h | RANimp-RRMopt-UEMsD | Rel-6 | Juha | 25.423 | Interdigital | jim.miller@interdigital.com | RP-22 |  |
| 1182 | 371.4 | **Remote Control of Electrical Tilting Antennas** |  | 395d? | 2003-03-14 A | 2004-09-16 A | 100% | 2003-03-14 | 2004-09-16 | 395d? |  | R3 | 7464h | 7464h | RANimp-TiltAnt | Rel-6 | Juha |  | Vodafone | Andreas.Hauser@vodafone.com |  |  |
| 1183 | 371.4.1 | Tilting Antenna - RAN aspects |  | 393d? | 2003-03-14 A | 2004-09-14 A | 100% | 2003-03-14 | 2004-09-14 | 393d? | finish no earlier than 2004-09-14 | R3 | 3144h | 3144h | RANimp-TiltAnt | Rel-6 | Juha | 25.460, 25.461, 25.462, 25.463 | Vodafone | Andreas.Hauser@vodafone.com |  |  |
| 1184 | 371.4.2 | OAM&P impacts |  | 145d | 2004-02-27 A | 2004-09-16 A | 100% | 2004-02-27 | 2004-09-16 | 145d | finish no earlier than 2004-09-16 | S5 | 1160h | 1160h | RANimp-TiltAnt-OAM | Rel-6 | Dionisio | 32.804, 32.64x | Vodafone | Adrian.Neal@vodafone.com |  | SP-24 |
| 1185 | 371.5 | Network Assisted Cell Change (NACC) from UTRAN to GERAN - network-side aspects |  | 462d? | 2002-09-09 A | 2004-06-15 A | 100% | 2002-09-09 | 2004-06-15 | 462d? | finish no earlier than 2004-06-15 | R3 | 3696h | 3696h | RANimp-NACC | Rel-6 | Juha |  | Vodafone | Brendan.McWilliams@gb.vodafone.co.uk |  |  |
| 1186 | 12 | **Location Services enhancements 2** |  | 1024d? | 2001-01-15 A | 2004-12-16 A | 100% | 2001-01-15 | 2004-12-16 | 1024d? |  | S2,S5,N4,RP | 78152h | 78152h | LCS2 | Rel-6 | Maurice | 23.271 |  |  |  |  |
| 1187 | 12.1 | **Improvement on Le interface** |  | 653d? | 2002-06-17 A | 2004-12-15 A | 100% | 2002-06-17 | 2004-12-15 | 653d? |  | S2 | 9872h | 9872h |  | Rel-6 | Maurice |  |  |  |  |  |
| 1188 | 372.1.1 | Stage 2 |  | 331d? | 2002-06-17 A | 2003-09-22 A | 100% | 2002-06-17 | 2003-09-22 | 331d? | start no earlier than 2002-06-17 | S2 | 2648h | 2648h |  | Rel-6 | Maurice |  |  |  |  |  |
| 1189 | 372.1.2 | Stage 3 - impacts MLP (Mobile Location Protocol) |  | 250d? | 2004-01-01 A | 2004-12-15 A | 100% | 2004-01-01 | 2004-12-15 | 250d? | finish no earlier than 2004-12-15 | OMA | 2000h | 2000h |  | Rel-6 |  |  |  | OMA-LIAISON@mail.openmobilealliance.org |  |  |
| 1190 | 12.2 | **Enhanced support for anonymity and user privacy** |  | 638d? | 2002-07-08 A | 2004-12-15 A | 100% | 2002-07-08 | 2004-12-15 | 638d? |  | S2 | 9144h | 9144h |  | Rel-6 | Maurice |  |  |  |  |  |
| 1191 | 372.2.1 | Stage 2 |  | 255d? | 2002-07-08 A | 2003-06-27 A | 100% | 2002-07-08 | 2003-06-27 | 255d? | finish no earlier than 2003-06-27 | S2 | 2040h | 2040h |  | Rel-6 | Maurice |  |  |  |  |  |
| 1192 | 372.2.2 | Stage 3 - impacts MLP and RLP |  | 250d? | 2004-01-01 A | 2004-12-15 A | 100% | 2004-01-01 | 2004-12-15 | 250d? | finish no earlier than 2004-12-15 | OMA | 2000h | 2000h |  | Rel-6 |  |  |  | OMA-LIAISON@mail.openmobilealliance.org |  |  |
| 1193 | 12.3 | **Enhanced inter-GMLC interface** |  | 648d? | 2002-06-24 A | 2004-12-15 A | 100% | 2002-06-24 | 2004-12-15 | 648d? |  | S2 | 9704h | 9704h |  | Rel-6 | Maurice |  |  |  |  |  |
| 1194 | 372.3.1 | Stage 2 |  | 315d? | 2002-06-24 A | 2003-09-05 A | 100% | 2002-06-24 | 2003-09-05 | 315d? | finish no earlier than 2003-09-05 | S2 | 2520h | 2520h |  | Rel-6 | Maurice |  |  |  |  |  |
| 1195 | 372.3.2 | Stage 3 - definition of RLP and PCP |  | 250d? | 2004-01-01 A | 2004-12-15 A | 100% | 2004-01-01 | 2004-12-15 | 250d? | finish no earlier than 2004-12-15 | OMA | 2000h | 2000h |  | Rel-6 |  |  |  | OMA-LIAISON@mail.openmobilealliance.org |  |  |

Notes:
- 1172: Generic feature
- 1173: building block without particular end date
- 1175: WIDS modified in RP#26, RP-040551
- 1176: Approved at RP#25 as RP-040390
- 1177: Closed RP#24 due to the lack of progress
- 1178: abandoned RP-23
- 1183: Finished at RP#25
- 1184: SA#25 09/2004 completed
- 1189: Updated according to SP-040232
- 1192: Updated according to SP-040232
- 1195: Updated according to SP-040232

| ID | WBS | Task | Type | Duration | Start | Finish | Complete | Baseline start | Baseline finish | Baseline duration | Constraint | Resources | Work | Actual work | Text6 | Text8 | Text5 | Text1 | Text4 | Text12 |
| --- | --- | --- | --- | --- | --- | --- | --- | --- | --- | --- | --- | --- | --- | --- | --- | --- | --- | --- | --- | --- |
| 1196 | 12.4 | **Location Services support for IMS public identities** |  | 473d? | 2003-02-24 A | 2004-12-15 A | 100% | 2003-02-24 | 2004-12-15 | 473d? |  | S2 | 7704h | 7704h | Rel-6 | Maurice |  |  |  |  |
| 1197 | 372.4.1 | Stage 2 |  | 240d? | 2003-02-24 A | 2004-01-23 A | 100% | 2003-02-24 | 2004-01-23 | 240d? | finish no earlier than 2004-01-23 | S2 | 1920h | 1920h | Rel-6 | Maurice |  |  |  |  |
| 1198 | 372.4.2 | Stage 3 - impacts MLP, RLP and PCP |  | 250d? | 2004-01-01 A | 2004-12-15 A | 100% | 2004-01-01 | 2004-12-15 | 250d? | finish no earlier than 2004-12-15 | OMA | 2000h | 2000h | Rel-6 |  | OMA-LIAISON@mail.openmobilealliance.org |  |  |  |
| 1199 | 12.5 | **New area event for location service triggering reports** |  | 663d? | 2002-06-03 A | 2004-12-15 A | 100% | 2002-06-03 | 2004-12-15 | 663d? |  | S2 | 11416h | 11416h | Rel-6 | Maurice |  |  |  |  |
| 1200 | 372.5.1 | Stage 2 |  | 280d? | 2002-06-03 A | 2003-06-27 A | 100% | 2002-06-03 | 2003-06-27 | 280d? | finish no earlier than 2003-06-27 | S2 | 2240h | 2240h | Rel-6 | Maurice |  |  |  |  |
| 1201 | 372.5.2 | Stage 3 for UE-CN signalling |  | 234d? | 2003-10-09 A | 2004-08-31 A | 100% | 2003-10-09 | 2004-08-31 | 234d? | start no earlier than 2003-10-09 | N4 | 1872h | 1872h | Rel-6 | Kimmo |  |  |  |  |
| 1202 | 372.5.3 | Stage 3 - impacts MLP, RLP and PCP |  | 250d? | 2004-01-01 A | 2004-12-15 A | 100% | 2004-01-01 | 2004-12-15 | 250d? | finish no earlier than 2004-12-15 | OMA | 2000h | 2000h | Rel-6 |  | OMA-LIAISON@mail.openmobilealliance.org |  |  |  |
| 1203 | 12.7 | **UE positioning** |  | 957d? | 2001-01-15 A | 2004-09-14 A | 100% | 2001-01-15 | 2004-09-14 | 957d? |  | RP | 18480h | 18480h | Rel-6 | Stefania |  | LCS2-UEpos |  |  |
| 1204 | 12.8 | Open SMLC-SRNC Interface within the UTRAN to support UTRAN Rel4 positioning methods |  | 700d? | 2001-01-15 A | 2003-09-19 A | 100% | 2001-01-15 | 2003-09-19 | 700d? | finish no earlier than 2003-09-19 | R2 | 5600h | 5600h | Rel-6 | Joern | Meik.Kottkamp@siemens.com | LCS-Rel4Pos | Siemens |  |
| 1205 | 372.6.2 | A-GPS minimum performance specification |  | 333d? | 2003-06-06 A | 2004-09-14 A | 100% | 2003-06-06 | 2004-09-14 | 333d? | finish no earlier than 2004-09-14 | R4 | 2664h | 2664h | Rel-6 | Stefania | donglin.shen@attws.com | LCS-UEPos-AGPSPerf | AT&T Wireless |  |
| 1206 | 12.7.2 | FS on Enhancements to OTDOA Positioning using advanced blanking methods |  | 320d | 2002-07-01 A | 2003-09-19 A | 100% | 2002-07-01 | 2003-09-19 | 320d | finish no earlier than 2003-09-19 | R2 | 2560h | 2560h | Rel-6 | Joern | david.bartlett@cursor-system.com | LCS2-UEpos-FSBlank | Cambridge Positioning Systems |  |
| 1207 | 372.6.4 | Deleted - UE positioning enhancements - other methods | milestone | 0d? | 2003-09-26 A | 2003-09-26 A | 100% | 2003-09-26 | 2003-09-26 | 0d? | finish no earlier than 2003-09-26 | R2 |  |  | Rel-6 | Joern | Meik.Kottkamp@siemens.com | LCS2-UEpos-enh | Siemens | RP-24 |
| 1208 | 372.7 | LCS charging |  | 455d? | 2003-03-21 A | 2004-12-16 A | 100% | 2003-03-21 | 2004-12-16 | 455d? | start no earlier than 2003-03-21 | S5 | 3640h | 3640h | Rel-6 | Dionisio | alain.bibas@orange-ft.com | LCS2-CH | France Telecom |  |
| 1209 | 14 | **Rel-6 Security enhancements** |  | 1018d? | 2001-01-03 A | 2004-11-26 A | 100% | 2001-01-03 | 2004-11-26 | 1018d? |  | S3 | 28824h | 28824h | Rel-6 | Dionisio | Peter.Howard@vodafone.com | SEC1 | Vodafone |  |
| 1210 | 14.1 | **Enhanced HE control of security (including positive authentication reporting)** |  | 712d | 2001-01-03 A | 2003-09-25 A | 100% | 2001-01-03 | 2003-09-25 | 712d |  | S3 | 14064h | 14064h | Rel-6 | Dionisio | Peter.Howard@vodafone.com |  | Vodafone |  |
| 1211 | 14.1.1 | Deleted - Stage 2 |  | 378d | 2001-01-03 A | 2002-06-14 A | 100% | 2001-01-03 | 2002-06-14 | 378d | finish no earlier than 2002-06-14 | S3 | 3024h | 3024h | Rel-6 | Dionisio |  |  |  | SP-16 |
| 1212 | 14.1.3 | **Network domain security** |  | 334d | 2002-06-17 A | 2003-09-25 A | 100% | 2002-06-17 | 2003-09-25 | 334d |  | S3 | 5344h | 5344h | Rel-6 | Dionisio | Geir-myrdahl.koien@telenor.com | SEC1-NDS | Telenor |  |
| 1213 | 14.1.3.1 | IP network layer security (NDS/IP) |  | 334d | 2002-06-17 A | 2003-09-25 A | 100% | 2002-06-17 | 2003-09-25 | 334d | finish no earlier than 2003-09-25 | S3 | 2672h | 2672h | Rel-6 | Dionisio |  | SEC1-NDS-IP |  |  |
| 1214 | 373.2 | Network Domain Security; Authentication Framework (NDS/AF) |  | 521d? | 2002-02-15 A | 2004-02-13 A | 100% | 2002-02-15 | 2004-02-13 | 521d? | finish no earlier than 2004-02-13 | S3 | 4168h | 4168h | Rel-6 | Dionisio | tommi.viitanen@nokia.com | SEC1-NDS-AF | Nokia |  |
| 1215 | 373.3 | Key Management of group keys for Voice Group Call Services |  | 306d | 2003-09-26 A | 2004-11-26 A | 100% | 2003-09-26 | 2004-11-26 | 306d | finish no earlier than 2004-11-26 | S3 | 2448h | 2448h | Rel-6 | Dionisio | benno.tietz@vodafone.com | SECGKYV | Vodafone |  |
| 1216 | 16 | **IMS Phase 2** |  | 1395d? | 2000-08-28 A | 2005-12-30 A | 100% | 2000-08-28 | 2005-12-30 | 1395d? |  | S1,S2,S3,S5,NP | 130248h | 130248h | Rel-6 | Alain |  | IMS2 |  |  |
| 1217 | 374.1 | Enhancements to the Cx and Sh interfaces |  | 323d? | 2003-06-06 A | 2004-08-31 A | 100% | 2003-06-06 | 2004-08-31 | 323d? | finish no earlier than 2004-08-31 | N4 | 2584h | 2584h | Rel-6 | Kimmo |  | IMS2-CCR |  |  |
| 1218 | 16.12 | **IMS Group Management** |  | 715d? | 2002-03-14 A | 2004-12-08 A | 100% | 2002-03-14 | 2004-12-08 | 715d? |  | S1 | 12680h | 12680h | Rel-6 | Alain | juha.kalliokulju@nokia.com | IMSGM | Nokia |  |
| 1219 | 16.12.1 | Stage 1 - TS on IMS group management |  | 193d | 2002-03-14 A | 2002-12-09 A | 100% | 2002-03-14 | 2002-12-09 | 193d | finish no earlier than 2002-12-09 | S1 | 1544h | 1544h | Rel-6 | Alain | juha.kalliokulju@nokia.com |  | Nokia |  |
| 1220 | 374.2.2 | Stage 2 |  | 158d? | 2003-05-26 A | 2003-12-31 A | 100% | 2003-05-26 | 2003-12-31 | 158d? | finish no earlier than 2003-12-31 | S2 | 1264h | 1264h | Rel-6 | Maurice |  |  |  |  |
| 1221 | 374.2.3 | Stage 3 for IMS Group management (e.g. chat) |  | 519d? | 2002-12-13 A | 2004-12-08 A | 100% | 2002-12-13 | 2004-12-08 | 519d? | finish no earlier than 2004-12-08 | N1 | 4152h | 4152h | Rel-6 | Frederic | Keith Drage (drage@alcatel-lucent.com) |  | Lucent |  |

Notes:
- 1198: Updated according to SP-040232
- 1201: 31/10/2003 work has started. Current stage 3 fullfills the requirements of stage 2. ......
- 1202: Updated according to SP-040232
- 1204: Text3: 25.305, 25.401, 25.450, 25.452, 25.453
- 1205: Finished at RP#25 / Text3: 25.171
- 1207: building block without particular end date
- 1208: SA#26 12/2004 completed / Text3: 32.271
- 1209: Added BB UE authentication and rapporteur added.
- 1210: Added by SP-000575 without any dates. 18/10/00: Change of WI title, added hyperlink rapporteur new end date 03/01. New end date and correct Release to be decided S3#18
- 1211: New end date and correct Release to be decided S3#18. Marked as stopped 12/2008
- 1212: WID approved for Rel-6 at SA#17. Completed 2004-12
- 1213: Should be complete after SA3#27. Completed 2004-12 / Text3: 33.210
- 1214: WID approved SA#19. Work started after FS approved SA#18
- 1215: Approved TSG#21. Completed 2004-12 / Text3: 42.068, 43.068, 44.068, 42.069, 43.069, 44.069, 31.102, 24.008, 48.008, 42.009, 43.020
- 1216: Not yet available: verbally approved at SA15, actual WID to be provided at SA16 by Lucent / Text3: 23.228
- 1217: Shared public user identities need to be solved. If email approval CR is accepted. Work 100% done....
- 1221: Depends on CN decision on CPCP in Rel-6. Complete, if unresolved IETF dependencies are dropped (-> LS to CN plenary)

| ID | WBS | Task | Type | Duration | Start | Finish | Complete | Baseline start | Baseline finish | Baseline duration | Constraint | Resources | Work | Actual work | Text6 | Text8 | Text4 | Text5 | Text1 | Text3 | Text12 |
| --- | --- | --- | --- | --- | --- | --- | --- | --- | --- | --- | --- | --- | --- | --- | --- | --- | --- | --- | --- | --- | --- |
| 1222 | 374.3 | **IMS Conferencing** |  | 548d? | 2002-11-04 A | 2004-12-08 A | 100% | 2002-11-04 | 2004-12-08 | 548d? |  | N1 | 10960h | 10960h | Rel-6 | Frederic |  |  |  |  |  |
| 1223 | 374.3.1 | Stage 2 |  | 303d? | 2002-11-04 A | 2003-12-31 A | 100% | 2002-11-04 | 2003-12-31 | 303d? | finish no earlier than 2003-12-31 | S2 | 2424h | 2424h | Rel-6 | Maurice |  |  |  |  |  |
| 1224 | 374.3.2 | Stage 3 |  | 519d? | 2002-12-13 A | 2004-12-08 A | 100% | 2002-12-13 | 2004-12-08 | 519d? | finish no earlier than 2004-12-08 | N1 | 4152h | 4152h | Rel-6 | Frederic | Lucent | Keith Drage (drage@alcatel-lucent.com) |  |  |  |
| 1225 | 16.11 | **IMS Messaging** |  | 992d? | 2002-03-14 A | 2005-12-30 A | 100% | 2002-03-14 | 2005-12-30 | 992d? |  | S1 | 23912h | 23912h | Rel-6 | Alain | Nokia | juha.kalliokulju@nokia.com | IMSM |  |  |
| 1226 | 16.11.1 | TR on support of messaging in the IMS |  | 193d | 2002-03-14 A | 2002-12-09 A | 100% | 2002-03-14 | 2002-12-09 | 193d | finish no earlier than 2002-12-09 | S1 | 1544h | 1544h | Rel-6 | Alain | Nokia | juha.kalliokulju@nokia.com | IMSM-TR |  |  |
| 1227 | 374.4.2 | Stage 1 22.340 |  | 23d? | 2002-11-11 A | 2002-12-11 A | 100% | 2002-11-11 | 2002-12-11 | 23d? | finish no earlier than 2002-12-11 | S1 | 184h | 184h | Rel-6 | Alain | Nokia | juha.kalliokulju@nokia.com | IMSM-TS | 22.340 |  |
| 1228 | 374.4.3 | CRs to 22.140 & 22.228 |  | 263d? | 2002-03-14 A | 2003-03-17 A | 100% | 2002-03-14 | 2003-03-17 | 263d? | finish no earlier than 2003-03-17 | S1 | 2104h | 2104h | Rel-6 | Alain | Nokia | juha.kalliokulju@nokia.com | IMSM-CR | 22.140,22.228 |  |
| 1229 | 16.11.3 | Stage 2 |  | 477d | 2002-11-04 A | 2004-08-31 A | 100% | 2002-11-04 | 2004-08-31 | 477d | finish no earlier than 2004-08-31 | S2 | 3816h | 3816h | Rel-6 | Maurice |  |  |  |  |  |
| 1230 | 374.4.5 | Stage 3 for IMS Messaging |  | 519d? | 2002-12-13 A | 2004-12-08 A | 100% | 2002-12-13 | 2004-12-08 | 519d? | finish no earlier than 2004-12-08 | N1 | 4152h | 4152h | Rel-6 | Frederic | Lucent | Keith Drage (drage@alcatel-lucent.com) |  |  |  |
| 1231 | 374.4.6 | SIP/SIMPLE Instant messaging |  | 522d? | 2004-01-01 A | 2005-12-30 A | 100% | 2004-01-01 | 2005-12-30 | 522d? | finish no earlier than 2005-06-30 | OMA | 4176h | 4176h | Rel-6 |  |  | OMA-LIAISON@mail.openmobilealliance.org |  |  |  |
| 1232 | 374.5 | **Additional SIP Capabilities support not covered by Rel-5** |  | 680d? | 2002-11-11 A | 2005-06-17 A | 100% | 2002-11-11 | 2005-06-17 | 680d? |  | N1 | 13392h | 13392h | Rel-6 | Frederic |  |  |  |  |  |
| 1233 | 374.5.1 | Stage 2 for add SIP cap (e.g. forking) |  | 335d? | 2002-11-11 A | 2004-02-20 A | 100% | 2002-11-11 | 2004-02-20 | 335d? | finish no earlier than 2004-02-20 | S2 | 2680h | 2680h | Rel-6 | Maurice |  |  |  |  |  |
| 1234 | 374.5.2 | Stage 3 for Additional SIP Capabilities |  | 454d? | 2002-12-13 A | 2004-09-08 A | 100% | 2002-12-13 | 2004-09-08 | 454d? | finish no earlier than 2004-09-08 | N1 | 3632h | 3632h | Rel-6 | Frederic | Lucent | Keith Drage (drage@alcatel-lucent.com) |  |  |  |
| 1235 | 374.5.3 | Procedured associated with IMS-ALG |  | 205d? | 2004-09-06 A | 2005-06-17 A | 100% | 2004-09-06 | 2005-06-17 | 205d? | start no earlier than 2004-09-06 | N1 | 1640h | 1640h | Rel-6 | Frederic |  |  |  |  |  |
| 1236 | 374.6 | Review additional SIP Capabilities against IMS |  | 454d? | 2002-12-13 A | 2004-09-08 A | 100% | 2002-12-13 | 2004-09-08 | 454d? | finish no earlier than 2004-09-08 | N1 | 3632h | 3632h | Rel-6 | Frederic | Lucent | Keith Drage (drage@alcatel-lucent.com) |  |  |  |
| 1237 | 16.5 | **Interworking between IMS and IP networks** |  | 1118d? | 2000-08-28 A | 2004-12-08 A | 100% | 2000-08-28 | 2004-12-08 | 1118d? |  | N3 | 31712h | 31712h | Rel-6 | Gwiho | BT | nigel.holland@bt.com | IMS-CCR-IWIP | 23.821, 29.061, 29.162 |  |
| 1238 | 16.5.1 | Interworking for 3GPP_SIP and IETF_SIP |  | 730d | 2000-08-28 A | 2003-06-13 A | 100% | 2000-08-28 | 2003-06-13 | 730d | finish no earlier than 2003-06-13 | N3 | 5840h | 5840h | Rel-6 | Gwiho | Siemens | Thomas.Belling@nsn.com |  | New 29.962 |  |
| 1239 | 16.5.2 | Interworking for IPv6 to IPv4 |  | 1118d | 2000-08-28 A | 2004-12-08 A | 100% | 2000-08-28 | 2004-12-08 | 1118d | finish no earlier than 2004-12-08 | N3 | 8944h | 8944h | Rel-6 | Gwiho |  |  |  | 29.163 |  |
| 1240 | 374.7.3 | Interworking for IPv6 to IPv4 (SIP / SDP aspects) |  | 87d? | 2004-05-11 A | 2004-09-08 A | 100% | 2004-05-11 | 2004-09-08 | 87d? | finish no earlier than 2004-09-08 | N1 | 696h | 696h | Rel-6 | Frederic |  |  |  |  |  |
| 1241 | 16.8.1 | stage 3 of interworking with non-IMS IP networks |  | 911d | 2001-03-14 A | 2004-09-08 A | 100% | 2001-03-14 | 2004-09-08 | 911d | finish no earlier than 2004-09-08 | N1 | 7288h | 7288h | Rel-6 | Frederic |  |  |  |  |  |
| 1242 | 16.6.1 | Interworking between IMS and CS networks |  | 929d? | 2000-08-28 A | 2004-03-18 A | 100% | 2000-08-28 | 2004-03-18 | 929d? | finish no earlier than 2004-03-18 | N3 | 7432h | 7432h | Rel-6 | Gwiho | Vodafone | Brendan.McWilliams@gb.vodafone.co.uk | IMS-CCR-IWCS | 29.163, 29.061, 24.228, and new CN4 specification |  |
| 1243 | 16.10 | Mn interface (IM-MGW to MGCF) enhancements (CN4 Part) |  | 418d | 2001-08-07 A | 2004-09-01 A | 100% | 2001-08-07 | 2004-09-01 | 418d | finish no earlier than 2004-09-01 | N4 | 3344h | 3344h | Rel-6 | Kimmo |  |  | IMS-CCR-Mn |  |  |
| 1244 | 374.10 | Study of subscriber and operators relationship in IMS and related ISIM requirements for Rel 6” |  | 20d? | 2002-11-15 A | 2002-12-12 A | 100% | 2002-11-15 | 2002-12-12 | 20d? | finish no earlier than 2002-12-12 | S1 | 160h | 160h | Rel-6 | Alain | Nokia | juha.kalliokulju@nokia.com |  |  |  |
| 1245 | 374.11 | Lawful Interception in the 3GPP Rel-6 architecture |  | 269d? | 2002-12-09 A | 2003-12-18 A | 100% | 2002-12-09 | 2003-12-18 | 269d? | finish no earlier than 2003-12-18 | S3 | 2152h | 2152h | Rel-6 | Dionisio | Reg TP | berthold.wilhelm@regtp.de | SEC1-LI | 33.106, 33.107, 33.108 |  |
| 1246 | 374.12 | IMS Subscription and access scenarios |  | 130d? | 2002-12-16 A | 2003-06-13 A | 100% | 2002-12-16 | 2003-06-13 | 130d? | start no earlier than 2002-12-16 | S1 | 1040h | 1040h | Rel-6 | Alain |  |  |  | 22.800 |  |
| 1247 | 374.13 | IMS charging |  | 455d? | 2003-03-21 A | 2004-12-16 A | 100% | 2003-03-21 | 2004-12-16 | 455d? | finish no earlier than 2004-12-16 | S5 | 3640h | 3640h | Rel-6 | Dionisio |  |  | IMS2-CH | 32.260 |  |
| 1248 | 374.14 | IMS Management objects |  | 306d? | 2004-09-03 A | 2005-11-04 A | 100% | 2004-09-03 | 2005-11-04 | 306d? | finish no earlier than 2005-03-04 | N1 | 2448h | 2448h | Rel-6 | Frederic |  |  |  | 24.167 |  |
| 1249 | 374.15 | Deleted - Stage 2 of IMS Phase 2 | milestone | 0d? | 2003-09-19 A | 2003-09-19 A | 100% | 2003-09-19 | 2003-09-19 | 0d? | finish no earlier than 2003-09-19 | S2 |  |  | Rel-6 | Maurice |  |  |  |  | SP-21 |

Notes:
- 1224: Depends on CN decision on IETF dependencies in Rel-6. Higher figure if CPCP is dropped (-> LS to CN plenary)
- 1231: Updated according to SP-040232
- 1237: [DAB 14.02.02] - end date pushed back to March 2003
- 1238: [DAB - 20.08.03] - CN Part of TR Complete @ CN#20
- 1242: [DAB - 25.05.04] - CN3 consider this work to be complete
- 1243: TISPAN issue is open
- 1247: SA#26 12/2004 completed

| ID | WBS | Task | Type | Duration | Start | Finish | Complete | Baseline start | Baseline finish | Baseline duration | Constraint | Resources | Work | Actual work | Text1 | Text3 | Text4 | Text5 | Text6 | Text8 | Text10 | Text12 |
| --- | --- | --- | --- | --- | --- | --- | --- | --- | --- | --- | --- | --- | --- | --- | --- | --- | --- | --- | --- | --- | --- | --- |
| 1250 | 375 | **3GPP Enablers for services like Push to Talk over Cellular (PoC)** |  | 459d? | 2003-09-08 A | 2005-06-09 A | 100% | 2003-09-08 | 2005-06-09 | 459d? |  | S2,S4,S5 | 10696h | 10696h | PoC | 23.979 | Ericsson | Shabnam Sultana | Rel-6 | Maurice |  |  |
| 1251 | 375.1 | Feasibility Study |  | 322d? | 2003-09-08 A | 2004-11-30 A | 100% | 2003-09-08 | 2004-11-30 | 322d? | finish no earlier than 2004-11-30 | S2 | 2576h | 2576h | PoC | 23.979 | Ericsson | Shabnam Sultana | Rel-6 | Maurice | SP-24 |  |
| 1252 | 375.2 | Dependencies on OMA PoC |  | 303d? | 2004-01-01 A | 2005-02-28 A | 100% | 2004-01-01 | 2005-02-28 | 303d? | finish no earlier than 2004-12-30 | OMA | 2424h | 2424h | PoC |  |  | OMA-LIAISON@mail.openmobilealliance.org | Rel-6 |  | SP-24 |  |
| 1253 | 375.3 | Selection of one or more PoC codec(s) for PoC |  | 69d? | 2004-09-13 A | 2004-12-16 A | 100% | 2004-09-13 | 2004-12-16 | 69d? | start no earlier than 2004-09-13 | S4 | 552h | 552h | PoC | 26.235, 26.236 |  |  | Rel-6 | Paolo | SP-25 |  |
| 1254 | 375.4 | PoC charging |  | 184d? | 2004-09-27 A | 2005-06-09 A | 100% | 2004-09-27 | 2005-06-09 | 184d? | finish no earlier than 2005-06-09 | S5 | 1472h | 1472h | PoC-CH | 32.272 |  |  | Rel-6 | Dionisio |  |  |
| 1255 | 376 | Interworking aspects and migration scenarios for IPv4 based IMS Implementations (Study) |  | 210d? | 2003-09-08 A | 2004-06-25 A | 100% | 2003-09-08 | 2004-06-25 | 210d? | finish no earlier than 2004-06-25 | S2 | 1680h | 1680h | IPv4IMS | 23.881 | Siemens | Alexander Milinski | Rel-6 | Maurice |  |  |
| 1256 | 16.3 | **Interoperability and Commonality between IMS using different "IP-connectivity Networks"** |  | 325d? | 2002-09-16 A | 2003-12-12 A | 100% | 2002-09-16 | 2003-12-12 | 325d? |  | S2 | 9176h | 9176h | IMSCOOP | 23.864 |  |  | Rel-6 | Maurice |  |  |
| 1257 | 16.3.1 | Stage 2 for Interoperability |  | 272d | 2002-09-16 A | 2003-09-30 A | 100% | 2002-09-16 | 2003-09-30 | 272d | finish no earlier than 2003-09-30 | S2 | 2176h | 2176h |  | 23.864 | Nokia | balazs.bertenyi@nsn.com | Rel-6 | Maurice |  |  |
| 1258 | 377.2 | Stage 2 for commonality |  | 265d? | 2002-09-16 A | 2003-09-19 A | 100% | 2002-09-16 | 2003-09-19 | 265d? | start no earlier than 2002-09-16 | S2 | 2120h | 2120h |  | 23.864 | Nokia | balazs.bertenyi@nsn.com | Rel-6 | Maurice |  |  |
| 1259 | 16.3.2 | Stage 3 |  | 305d | 2002-10-14 A | 2003-12-12 A | 100% | 2002-10-14 | 2003-12-12 | 305d | finish no earlier than 2003-12-12 | N1 | 2440h | 2440h |  |  | Lucent | Keith Drage (drage@alcatel-lucent.com) | Rel-6 | Frederic |  |  |
| 1260 | 17 | **Support of Push Services** |  | 823d | 2001-01-03 A | 2004-02-27 A | 100% | 2001-01-03 | 2004-02-27 | 823d |  | S1 | 11390.6h | 11390.6h | PUSH | 23.976 | NTT Comware | Yoshinori Kitada | Rel-6 | Alain |  |  |
| 1261 | 17.1 | Stage 1 |  | 378d | 2001-01-03 A | 2002-06-14 A | 100% | 2001-01-03 | 2002-06-14 | 378d | finish no earlier than 2002-06-14 | S1 | 3024h | 3024h |  |  |  |  | Rel-6 | Alain |  |  |
| 1262 | 17.3 | TR 23.976 on Push Architecture |  | 340d | 2002-11-11 A | 2004-02-27 A | 100% | 2002-11-11 | 2004-02-27 | 340d | finish no earlier than 2004-02-27 | S2 | 2720h | 2720h |  | 23.976 | RIM | Nick Alfano | Rel-6 | Maurice |  |  |
| 1263 | 18 | **Multimedia Messaging (MMS) enhancements** |  | 865d? | 2002-08-15 A | 2005-12-07 A | 100% | 2002-08-15 | 2005-12-07 | 865d? |  | T2,S1,S4,S5 | 31936h | 31936h | MMS6 |  | Siemens | Josef.Laumen@SAL.SIEMENS.DE | Rel-6 | Kimmo |  |  |
| 1264 | 18.1 | **Definition of service requirements** |  | 286d? | 2002-11-15 A | 2003-12-19 A | 100% | 2002-11-15 | 2003-12-19 | 286d? |  | S1 | 4576h | 4576h | MMS6-SR | 22.140 |  |  | Rel-6 | Alain |  |  |
| 1265 | 379.1.1 | Definition of service requirements charging |  | 286d? | 2002-11-15 A | 2003-12-19 A | 100% | 2002-11-15 | 2003-12-19 | 286d? | finish no earlier than 2003-12-20 | S1 | 2288h | 2288h |  | 22.140 | Siemens | Josef.Laumen@SAL.SIEMENS.DE | Rel-6 | Alain |  |  |
| 1266 | 18.2 | Technical realization |  | 591d | 2002-09-06 A | 2004-12-10 A | 100% | 2002-09-06 | 2004-12-10 | 591d | finish no earlier than 2004-12-10 | T2 | 4728h | 4728h |  | 23.140 | Siemens | Josef.Laumen@SAL.SIEMENS.DE | Rel-6 | Kimmo |  |  |
| 1267 | 18.3 | OMA dependencies |  | 446d | 2003-08-15 A | 2005-04-29 A | 100% | 2003-08-15 | 2005-04-29 | 446d | finish no earlier than 2004-12-10 | OMA | 3568h | 3568h |  | OMA specs |  |  | Rel-6 | Kimmo |  |  |
| 1268 | 18.4 | MMS formats and codecs |  | 865d | 2002-08-15 A | 2005-12-07 A | 100% | 2002-08-15 | 2005-12-07 | 865d | finish no earlier than 2005-12-07 | S4 | 6920h | 6920h | MMS6-Codec | 26.140, 26.936 | Nokia | roberto.castagno@nokia.com | Rel-6 | Paolo |  |  |
| 1269 | 379.5 | Handling of private addressing schemes in MMS |  | 263d | 2003-12-10 A | 2004-12-10 A | 100% | 2003-12-10 | 2004-12-10 | 263d | finish no earlier than 2004-12-10 | T2 | 2104h | 2104h |  | 23.140 | T-Mobile | Steffen.Habermann@T-MOBILE.DE | Rel-6 | Kimmo |  |  |
| 1270 | 379.6 | MMS charging |  | 390d? | 2003-03-21 A | 2004-09-16 A | 100% | 2003-03-21 | 2004-09-16 | 390d? | start no earlier than 2003-03-21 | S5 | 3120h | 3120h | MMS6-CH | 32.270 |  |  | Rel-6 | Dionisio |  |  |
| 1271 | 379.7 | Deleted - FS Multiple MMS Relay/Server Architecture | milestone | 0d | 2004-12-10 A | 2004-12-10 A | 100% | 2004-12-10 | 2004-12-10 | 0d | finish no earlier than 2004-12-10 | T2 |  |  |  | probably Annex to 23.140 | Telefónica Móviles | Juan Gorospe (gorospe_j@tsm.es) | Rel-6 | Kimmo |  | TP-26 |
| 1272 | 19 | **Rel-6 MExE enhancements** |  | 326d | 2002-03-08 A | 2003-06-06 A | 100% | 2002-03-08 | 2003-06-06 | 326d |  | T2 | 7328h | 7328h | MEXE6 |  |  |  | Rel-6 | Kimmo |  |  |
| 1273 | 19.1 | MExE Rel-6 Improvements and Investigations |  | 264d | 2002-03-08 A | 2003-03-12 A | 100% | 2002-03-08 | 2003-03-12 | 264d | finish no earlier than 2003-03-12 | T2 | 2112h | 2112h | MEXE6-ENHANC | 22.057, 23.057 | TTPCom | Lars Brenk ( (lsb_ttpcom@HOTMAIL.COM) | Rel-6 |  |  |  |
| 1274 | 19.2 | MExE Run-Time Independent Framework Feasibility Study |  | 326d | 2002-03-08 A | 2003-06-06 A | 100% | 2002-03-08 | 2003-06-06 | 326d | finish no earlier than 2003-06-06 | T2 | 2608h | 2608h | MEXE6-RTIF | 22.857 | Intel | Aaron.Cohen@intel.com | Rel-6 |  |  |  |
| 1275 | 21 | Subscription Management |  | 650d | 2002-09-20 A | 2005-03-17 A | 100% | 2002-09-20 | 2005-03-17 | 650d | finish no earlier than 2005-03-17 | S5 | 5200h | 5200h | SuM | 32.140/1, 32.171/2/5, 32.803 | T-Mobile | istvan.aba@t-mobile.at | Rel-6 | Dionisio |  |  |

Notes:
- 1252: Updated according to SP-040232
- 1253: Completed
- 1254: SA#28 06/2005 completed
- 1257: No contributions assumed that no more will be done in 3GPP hence work may need to be done in 3GPP2
- 1260: AS: Changed from FS to actual support of Push
- 1270: SA#25 09/2004 completed
- 1271: originally it was intended to create a FS TR but most likely the work will become an Annex of 23.140
- 1275: SA#27 03/2005 completed

| ID | WBS | Task | Duration | Start | Finish | Complete | Baseline start | Baseline finish | Baseline duration | Constraint | Resources | Work | Actual work | Text1 | Text4 | Text5 | Text6 | Text8 | Text3 |
| --- | --- | --- | --- | --- | --- | --- | --- | --- | --- | --- | --- | --- | --- | --- | --- | --- | --- | --- | --- |
| 1276 | 22 | **Presence Capability** | 1233d? | 2001-03-19 A | 2005-12-07 A | 100% | 2001-03-19 | 2005-12-07 | 1233d? |  | S1 | 37112h | 37112h | PRESNC | Motorola | Mark Cataldo | Rel-6 | Alain |  |
| 1277 | 22.1 | Stage 1 | 610d | 2001-03-19 A | 2003-07-18 A | 100% | 2001-03-19 | 2003-07-18 | 610d | finish no earlier than 2003-07-18 | S1 | 4880h | 4880h |  |  |  | Rel-6 | Alain | 22.141 |
| 1278 | 22.2 | Stage 2 | 268d | 2001-09-12 A | 2002-09-20 A | 100% | 2001-09-12 | 2002-09-20 | 268d | finish no earlier than 2002-09-20 | S2 | 2144h | 2144h |  | Nokia | balazs.bertenyi@nsn.com | Rel-6 | Maurice |  |
| 1279 | 22.3 | Stage 3 | 703d | 2002-04-01 A | 2004-12-08 A | 100% | 2002-04-01 | 2004-12-08 | 703d | finish no earlier than 2004-12-08 | N1 | 5624h | 5624h |  | Lucent | Keith Drage (drage@alcatel-lucent.com) | Rel-6 | Frederic |  |
| 1280 | 382.4 | Stage 3 (CN3 Part Pk interface) | 770d? | 2002-04-01 A | 2005-03-11 A | 100% | 2002-04-01 | 2005-03-11 | 770d? | finish no earlier than 2005-03-11 | N3 | 6160h | 6160h |  |  |  | Rel-6 | Gwiho |  |
| 1281 | 382.5 | Media Codecs and Formats for IMS Messaging and Presence | 650d? | 2003-06-12 A | 2005-12-07 A | 100% | 2003-06-12 | 2005-12-07 | 650d? | finish no earlier than 2005-12-07 | S4 | 5200h | 5200h | PRESNC-COFIMP | Nokia | harri.honko@nokia.com | Rel-6 | Paolo | 26.141, 26.936 |
| 1282 | 22.4 | Security issues | 79d | 2002-08-26 A | 2002-12-12 A | 100% | 2002-08-26 | 2002-12-12 | 79d | finish no earlier than 2002-12-12 | S3 | 632h | 632h |  |  |  | Rel-6 | Dionisio |  |
| 1283 | 382.7 | SIMPLE Presence | 326d? | 2004-01-01 A | 2005-03-31 A | 100% | 2004-01-01 | 2005-03-31 | 326d? | finish no earlier than 2004-12-30 | OMA | 2608h | 2608h |  |  | OMA-LIAISON@mail.openmobilealliance.org | Rel-6 |  |  |
| 1284 | 25 | **Enhanced A/Gb feasibility study** | 51d? | 2002-08-30 A | 2002-11-08 A | 100% | 2002-08-30 | 2002-11-08 | 51d? |  | GP | 3264h | 3264h | AGbEnFS | Vodafone | jose-luis.carrizo@vodafone.co.uk | Rel-6 | Paolo |  |
| 1285 | 25.1 | **Feasibility study on A/Gb enhancements** | 51d? | 2002-08-30 A | 2002-11-08 A | 100% | 2002-08-30 | 2002-11-08 | 51d? |  | G2 | 2856h | 2856h | AGbEnFS-FS |  |  | Rel-6 | Gert |  |
| 1286 | 25.1.1 | Requirements for the support of conversational services | 51d | 2002-08-30 A | 2002-11-08 A | 100% | 2002-08-30 | 2002-11-08 | 51d | finish no earlier than 2002-11-08 | GP | 408h | 408h |  |  |  | Rel-6 | Paolo |  |
| 1287 | 383.1.2 | Identification of the different building blocks for the provision of conversational services on the existing A/Gb protocol stack | 51d? | 2002-08-30 A | 2002-11-08 A | 100% | 2002-08-30 | 2002-11-08 | 51d? | finish no earlier than 2002-11-08 | GP | 408h | 408h |  |  |  | Rel-6 | Paolo |  |
| 1288 | 383.1.3 | Outline of impact and feasibility of these building blocks and their different solutions | 51d? | 2002-08-30 A | 2002-11-08 A | 100% | 2002-08-30 | 2002-11-08 | 51d? | finish no earlier than 2002-11-08 | GP | 408h | 408h |  |  |  | Rel-6 | Paolo |  |
| 1289 | 25.1.4 | Impact on 3GPP architecture and requirement to co-ordinatge with other TSGs (CN, SA) | 51d | 2002-08-30 A | 2002-11-08 A | 100% | 2002-08-30 | 2002-11-08 | 51d | finish no earlier than 2002-11-08 | GP | 408h | 408h |  |  |  | Rel-6 | Paolo |  |
| 1290 | 25.1.5 | Standardisation effort | 51d | 2002-08-30 A | 2002-11-08 A | 100% | 2002-08-30 | 2002-11-08 | 51d | finish no earlier than 2002-11-08 | GP | 408h | 408h |  |  |  | Rel-6 | Paolo |  |
| 1291 | 25.1.6 | Dependency to other features | 51d | 2002-08-30 A | 2002-11-08 A | 100% | 2002-08-30 | 2002-11-08 | 51d | finish no earlier than 2002-11-08 | GP | 408h | 408h |  |  |  | Rel-6 | Paolo |  |
| 1292 | 26 | **Flexible Layer One for GERAN** | 1171d | 2000-01-03 A | 2004-06-25 A | 100% | 2000-01-03 | 2004-06-25 | 1171d |  | GP | 71551h | 71551h | FLOGER | Nokia | benoist.sebire@nokia.com | Rel-6 | Paolo |  |
| 1293 | 26.1 | **Realisation of a Flexible Layer One** | 1126d | 2000-01-03 A | 2004-04-23 A | 100% | 2000-01-03 | 2004-04-23 | 1126d |  | GP | 42816h | 42816h | FLOGER-Real | Nokia | benoist.sebire@nokia.com | Rel-6 | Paolo |  |
| 1294 | 26.1.1 | Technical Report | 471d | 2002-04-19 A | 2004-02-06 A | 100% | 2002-04-19 | 2004-02-06 | 471d | finish no earlier than 2004-02-06 | GP | 3768h | 3768h |  |  |  | Rel-6 | Paolo |  |
| 1295 | 26.1.2 | Architecture in 45.001 and 43.051 | 526d | 2002-04-19 A | 2004-04-23 A | 100% | 2002-04-19 | 2004-04-23 | 526d | finish no earlier than 2004-04-23 | G1 | 4208h | 4208h |  |  |  | Rel-6 |  |  |
| 1296 | 26.1.3 | Multiplexing in 45.002 | 526d | 2002-04-19 A | 2004-04-23 A | 100% | 2002-04-19 | 2004-04-23 | 526d | finish no earlier than 2004-04-23 | G1 | 4208h | 4208h |  |  |  | Rel-6 |  |  |
| 1297 | 26.1.4 | Channel Coding in 45.003 | 526d | 2002-04-19 A | 2004-04-23 A | 100% | 2002-04-19 | 2004-04-23 | 526d | finish no earlier than 2004-04-23 | G1 | 4208h | 4208h |  |  |  | Rel-6 |  |  |
| 1298 | 26.1.5 | Performance Requirements in 45.005 | 1126d | 2000-01-03 A | 2004-04-23 A | 100% | 2000-01-03 | 2004-04-23 | 1126d | finish no earlier than 2004-04-23 | G1 | 9000h | 9000h |  |  |  | Rel-6 |  |  |
| 1299 | 26.1.6 | Radio subsystem link control in 45.008 | 526d | 2002-04-19 A | 2004-04-23 A | 100% | 2002-04-19 | 2004-04-23 | 526d | finish no earlier than 2004-04-23 | G1 | 4208h | 4208h |  |  |  | Rel-6 |  |  |
| 1300 | 26.1.7 | Requirements in 44.004 | 526d | 2002-04-19 A | 2004-04-23 A | 100% | 2002-04-19 | 2004-04-23 | 526d | finish no earlier than 2004-04-23 | G2 | 4208h | 4208h |  |  |  | Rel-6 | Gert |  |

Notes:
- 1276: A Sultan merged "Presence Service Enhancements" (UID31028, PRES1) to this feature as no answer was provided on why Presence and Presence Encmts had same target completion date
- 1279: Dependency to 2 IETF drafts, no known work at the moment
- 1280: No Contributions so far - only requires a little work
- 1282: LSs handled in SA3. WID approved SA#17 Contribution at S3#25 & following e-mail discussion. Marked as closed 12/2008 (was marked 90% complete)
- 1283: Updated according to SP-040232
- 1284: Closed
- 1292: Nokia, Ericsson, Siemens, Telia

| ID | WBS | Task | Type | Duration | Start | Finish | Complete | Baseline start | Baseline finish | Baseline duration | Constraint | Resources | Work | Actual work | Text1 | Text4 | Text5 | Text6 | Text8 | Text12 | Text3 |
| --- | --- | --- | --- | --- | --- | --- | --- | --- | --- | --- | --- | --- | --- | --- | --- | --- | --- | --- | --- | --- | --- |
| 1301 | 26.2 | **Signalling and protocol support for a Flexible Layer One** |  | 571d | 2002-04-19 A | 2004-06-25 A | 100% | 2002-04-19 | 2004-06-25 | 571d |  | G2 | 13704h | 13704h | FLOGER-SigPro | Nokia | benoist.sebire@nokia.com | Rel-6 | Gert |  |  |
| 1302 | 26.2.1 | Modifications to RLC/MAC in 44.060 and 44.160 |  | 571d | 2002-04-19 A | 2004-06-25 A | 100% | 2002-04-19 | 2004-06-25 | 571d | finish no earlier than 2004-06-25 | G2 | 4568h | 4568h |  |  |  | Rel-6 | Gert |  |  |
| 1303 | 26.2.2 | Modifications to RRC in 44.118 and 44.018 |  | 571d | 2002-04-19 A | 2004-06-25 A | 100% | 2002-04-19 | 2004-06-25 | 571d | finish no earlier than 2004-06-25 | G2 | 4568h | 4568h |  |  |  | Rel-6 | Gert |  |  |
| 1304 | 26.3 | **Security for a Flexible Layer One** |  | 356d | 2002-04-19 A | 2003-08-29 A | 100% | 2002-04-19 | 2003-08-29 | 356d |  | S3, G2 | 5663.03h | 5663.03h | FLOGER-SecFLO | Nokia | benoist.sebire@nokia.com | Rel-6 | Dionisio |  |  |
| 1305 | 26.3.1 | Ciphering in 44.160,44.118, 44.060 and 44.018 |  | 356d | 2002-04-19 A | 2003-08-29 A | 100% | 2002-04-19 | 2003-08-29 | 356d | finish no earlier than 2003-08-29 | S3, G2 | 2848h | 2848h |  |  |  | Rel-6 | Dionisio |  |  |
| 1306 | 26.4 | **Deleted at TSG#27 - GERAN MS Conformance test for the Flexible Layer One - DELETE** |  | 0d | 2004-02-06 A | 2004-02-06 A | 100% | 2004-02-06 | 2004-02-06 | 0d |  | G4,G5 |  |  | FLOGER-Msconf | Nokia | benoist.sebire@nokia.com | Rel-6 | Paolo | GP-22 |  |
| 1307 | 26.4.1 | Deleted at TSG #27 - MS Test in 51.010 | milestone | 0d | 2004-02-06 A | 2004-02-06 A | 100% | 2004-02-06 | 2004-02-06 | 0d | finish no earlier than 2004-02-06 | G4,G5 |  |  |  |  |  | Rel-6 | Paolo | GP-22 |  |
| 1308 | 26.5 | **Deleted at TSG#27 - GERAN BTS Conformance test for the Flexible Layer One - DELETE** |  | 0d | 2004-02-06 A | 2004-02-06 A | 100% | 2004-02-06 | 2004-02-06 | 0d |  | G3new |  |  | FLOGER-BTSconf | Nokia | benoist.sebire@nokia.com | Rel-6 | Ingbert | GP-22 |  |
| 1309 | 26.5.1 | Deleted at TGS #27 - BTS Test in 51.021 - DELETE | milestone | 0d | 2004-02-06 A | 2004-02-06 A | 100% | 2004-02-06 | 2004-02-06 | 0d | finish no earlier than 2004-02-06 | G3new |  |  |  |  |  | Rel-6 | Ingbert | GP-22 |  |
| 1310 | 27 | Uplink TDOA feasibility study |  | 151d | 2001-11-30 A | 2002-06-28 A | 100% | 2001-11-30 | 2002-06-28 | 151d | finish no earlier than 2002-06-28 | GP | 1208h | 1208h | TDOAF | TruePosition | Bob Gross (rlgross@trueposition.com) | Rel-6 | Paolo |  | 45.811 |
| 1311 | 28 | **Multimedia Broadcast and Multicast Service** |  | 1781d? | 2001-05-11 A | 2008-03-07 A | 100% | 2001-05-11 | 2008-03-07 | 1781d? |  | S1,S2,S4,S5,RP,GP | 144311h | 144311h | MBMS |  |  | Rel-6 | Alain |  |  |
| 1312 | 28.1 | Stage 1 |  | 232d | 2001-05-11 A | 2002-04-01 A | 100% | 2001-05-11 | 2002-04-01 | 232d | finish no earlier than 2002-04-01 | S1 | 1856h | 1856h | MBMS |  |  | Rel-6 | Alain |  | 22.146, 22.101 |
| 1313 | 28.2 | **Stage 2** |  | 648d | 2001-09-24 A | 2004-03-17 A | 100% | 2001-09-24 | 2004-03-17 | 648d |  | S2 | 10408h | 10408h | MBMS |  |  | Rel-6 | Maurice |  |  |
| 1314 | 28.2.1 | TR on Architectural Study |  | 240d | 2001-09-24 A | 2002-08-23 A | 100% | 2001-09-24 | 2002-08-23 | 240d | finish no earlier than 2002-08-23 | S2 | 1920h | 1920h | MBMS |  |  | Rel-6 | Maurice |  | 23.846 |
| 1315 | 28.2.2 | Stage 2 Specification Work |  | 413d | 2002-08-19 A | 2004-03-17 A | 100% | 2002-08-19 | 2004-03-17 | 413d | finish no earlier than 2004-03-17 | S2 | 3304h | 3304h | MBMS |  |  | Rel-6 | Maurice |  | 23.246 |
| 1316 | 28.3 | **Introduction of MBMS in RAN** |  | 967d? | 2002-01-01 A | 2005-09-14 A | 100% | 2002-01-01 | 2005-09-14 | 967d? |  | R2 | 15992h | 15992h | MBMS-RAN | Nokia | juho.pirskanen@nokia.com | Rel-6 | Joern |  | 25.346, 25.304, 25.321, 25.322, 25.323, 25.331 |
| 1317 | 386.3.1 | Introduction of MBMS in RAN (physical & upper layers, access network interfaces) |  | 771d? | 2002-01-01 A | 2004-12-14 A | 100% | 2002-01-01 | 2004-12-14 | 771d? | finish no earlier than 2004-12-14 | R2 | 6168h | 6168h | MBMS-RAN | Nokia | juho.pirskanen@nokia.com | Rel-6 | Joern |  | 25.346, 25.304, 25.321, 25.322, 25.323 |
| 1318 | 386.3.2 | UE Performance Requirements for MBMS |  | 261d? | 2004-09-15 A | 2005-09-14 A | 100% | 2004-09-15 | 2005-09-14 | 261d? | finish no earlier than 2005-09-15 | R4 | 2088h | 2088h | MBMS-RAN-RF | Ericsson | Torgny.Palenius@ericsson.com | Rel-6 | Stefania |  | 25.101, 25.133 |
| 1319 | 28.4 | Support of the MBMS in CN protocols |  | 647d | 2002-06-18 A | 2004-12-08 A | 100% | 2002-06-18 | 2004-12-08 | 647d | finish no earlier than 2004-12-08 | N1 | 5176h | 5176h | MBMS |  |  | Rel-6 | Frederic |  |  |
| 1320 | 386.5 | Gmb interface for MBMS (CN3 part) |  | 334d | 2003-08-29 A | 2004-12-08 A | 100% | 2003-08-29 | 2004-12-08 | 334d | finish no earlier than 2004-12-08 | N3 | 2672h | 2672h | MBMS |  |  | Rel-6 | Gwiho |  | 29.061 |
| 1321 | 28.5 | Security Aspects of MBMS |  | 710d | 2002-07-01 A | 2005-03-18 A | 100% | 2002-07-01 | 2005-03-18 | 710d | finish no earlier than 2005-03-18 | S3 | 5680h | 5680h | MBMS |  | adrian.escott@three.co.uk | Rel-6 | Dionisio |  |  |
| 1322 | 28.6 | **Support of MBMS in GERAN** |  | 892d? | 2001-08-30 A | 2005-01-28 A | 100% | 2001-08-30 | 2005-01-28 | 892d? |  | GP | 71040h | 71040h | MBMS-GERAN |  |  | Rel-6 | Paolo |  |  |
| 1323 | 28.6.1 | Impact on the logical and physical channels |  | 631d | 2002-08-30 A | 2005-01-28 A | 100% | 2002-08-30 | 2005-01-28 | 631d | finish no earlier than 2005-01-28 | GP | 5048h | 5048h | MBMS-GERAN |  |  | Rel-6 | Paolo |  |  |
| 1324 | 28.6.4 | Re-synchronisation at cell change |  | 631d | 2002-08-30 A | 2005-01-28 A | 100% | 2002-08-30 | 2005-01-28 | 631d | finish no earlier than 2005-01-28 | G2 | 5048h | 5048h | MBMS-GERAN |  |  | Rel-6 | Gert |  |  |
| 1325 | 386.7.3 | Simultaneous support of MBMS services |  | 631d? | 2002-08-30 A | 2005-01-28 A | 100% | 2002-08-30 | 2005-01-28 | 631d? | finish no earlier than 2005-01-28 | GP | 5048h | 5048h | MBMS-GERAN |  |  | Rel-6 | Paolo |  |  |
| 1326 | 386.7.4 | Simultaneous support of MBMS and non-MBMS services |  | 892d? | 2001-08-30 A | 2005-01-28 A | 100% | 2001-08-30 | 2005-01-28 | 892d? | finish no earlier than 2005-01-28 | GP | 7136h | 7136h | MBMS-GERAN |  |  | Rel-6 | Paolo |  |  |
| 1327 | 386.7.5 | Resynchronisation at cell change |  | 892d? | 2001-08-30 A | 2005-01-28 A | 100% | 2001-08-30 | 2005-01-28 | 892d? | finish no earlier than 2005-01-28 | GP | 7136h | 7136h | MBMS-GERAN |  |  | Rel-6 | Paolo |  |  |
| 1328 | 28.6.5 | Decision making process between point-to-point or pont-to-multipoint configurations |  | 631d | 2002-08-30 A | 2005-01-28 A | 100% | 2002-08-30 | 2005-01-28 | 631d | finish no earlier than 2005-01-28 | GP | 5048h | 5048h | MBMS-GERAN |  |  | Rel-6 | Paolo |  |  |
| 1329 | 28.6.6 | MBMS channel allocations procedures to multiple MSs |  | 631d | 2002-08-30 A | 2005-01-28 A | 100% | 2002-08-30 | 2005-01-28 | 631d | finish no earlier than 2005-01-28 | GP | 5048h | 5048h | MBMS-GERAN |  |  | Rel-6 | Paolo |  |  |
| 1330 | 28.6.7 | Changes to the Gb interface |  | 631d | 2002-08-30 A | 2005-01-28 A | 100% | 2002-08-30 | 2005-01-28 | 631d | finish no earlier than 2005-01-28 | GP | 5048h | 5048h | MBMS-GERAN |  |  | Rel-6 | Paolo |  |  |
| 1331 | 28.6.8 | GERAN specific changes to the Iu-ps interface |  | 631d | 2002-08-30 A | 2005-01-28 A | 100% | 2002-08-30 | 2005-01-28 | 631d | finish no earlier than 2005-01-28 | GP | 5048h | 5048h | MBMS-GERAN |  |  | Rel-6 | Paolo |  |  |
| 1332 | 28.6.9 | Interaction between MBMS and Iu-flex |  | 631d | 2002-08-30 A | 2005-01-28 A | 100% | 2002-08-30 | 2005-01-28 | 631d | finish no earlier than 2005-01-28 | GP | 5048h | 5048h | MBMS-GERAN |  |  | Rel-6 | Paolo |  |  |
| 1333 | 28.6.10 | Security aspects |  | 631d | 2002-08-30 A | 2005-01-28 A | 100% | 2002-08-30 | 2005-01-28 | 631d | finish no earlier than 2005-01-28 | GP | 5048h | 5048h | MBMS-GERAN |  |  | Rel-6 | Paolo |  |  |
| 1334 | 386.7.12 | MS conformance tests- G3 |  | 786d? | 2002-01-25 A | 2005-01-28 A | 100% | 2002-01-25 | 2005-01-28 | 786d? | finish no earlier than 2005-01-28 | G3new | 6288h | 6288h | MBMS-GERAN |  |  | Rel-6 | Ingbert |  |  |
| 1335 | 386.7.13 | Deleted - MS conformance tests - G5 | milestone | 0d? | 2003-06-27 A | 2003-06-27 A | 100% | 2003-06-27 | 2003-06-27 | 0d? | start no earlier than 2003-06-27 | G5 |  |  | MBMS-GERAN |  |  | Rel-6 | Paolo | GP-19 |  |

Notes:
- 1306: DELETE
- 1307: DELETE
- 1308: DELETE
- 1309: DELETE
- 1311: Title renamed at SA#13
- 1312: This may or may not be a separate stage 1. In the meantime, CRs are proposed for 22.101
- 1317: Was "Introduction of MBMS in RAN" before RP#25. Created w/o WIDS after RAN approved the WT for RF aspects.Take WIDS from the parent BB
- 1318: Approved at RP#25 as RP-040370
- 1321: WID approved SA#17. 2004-12: Expected completion March 2005
- 1322: Completed
- 1334: Under evaluation

| ID | WBS | Task | Type | Duration | Start | Finish | Complete | Baseline start | Baseline finish | Baseline duration | Constraint | Deadline | Resources | Work | Actual work | Text1 | Text6 | Text8 | Text4 | Text5 | Text10 | Text12 |
| --- | --- | --- | --- | --- | --- | --- | --- | --- | --- | --- | --- | --- | --- | --- | --- | --- | --- | --- | --- | --- | --- | --- |
| 1336 | 28.1 | **MBMS User Services** |  | 743d? | 2003-05-13 A | 2006-03-16 A | 100% | 2003-05-13 | 2006-03-16 | 743d? |  |  | S1 | 13576h | 13576h | MBMS | Rel-6 | Alain |  |  |  |  |
| 1337 | 28.1 | MBMS User Services Stage 1 |  | 233d | 2003-05-13 A | 2004-04-01 A | 100% | 2003-05-13 | 2004-04-01 | 233d | start no earlier than 2003-05-13 |  | S1 | 1864h | 1864h | MBMS | Rel-6 | Alain |  |  |  |  |
| 1338 | 386.8.2 | Definition of MBMS user services, media codecs, formats and transport/application protocols using MBMS |  | 721d? | 2003-06-12 A | 2006-03-16 A | 100% | 2003-06-12 | 2006-03-16 | 721d? | finish no earlier than 2006-03-16 |  | S4 | 5768h | 5768h | MBMS-TSMBMS | Rel-6 | Paolo | Nokia | igor.curcio@nokia.com |  |  |
| 1339 | 386.9 | MBMS charging |  | 108d? | 2005-01-11 A | 2005-06-09 A | 100% | 2005-01-11 | 2005-06-09 | 108d? | start no earlier than 2005-01-11 |  | S5 | 864h | 864h | MBMS-CH | Rel-6 | Dionisio |  |  |  |  |
| 1340 | 386.10 | **MBMS UE Conformance Testing** |  | 521d? | 2006-03-10 A | 2008-03-07 A | 100% | 2006-03-10 | 2008-03-07 | 521d? |  |  | R5 | 17047.2h | 17047.2h | MBMS-UEConTest | Rel-6 | Ingbert |  |  |  |  |
| 1341 | 16.5.1 | RF/RRM Conformance Test Aspects – MBMS (FDD) |  | 461d | 2006-06-02 A | 2008-03-07 A | 100% | 2006-06-02 | 2008-03-07 | 461d | finish no earlier than 2008-03-07 | 2006-06-02 | R5 | 3688h | 3688h | MBMS-RAN-RF_Test | Rel-6 | Ingbert | Ericsson | leif.mattisson@ericsson.com | Fri 11/03/05 |  |
| 1342 | 386.10.2 | Conformance Test Aspects - MBMS for 3.84 Mcps and 7.68 Mcps TDD |  | 318d? | 2006-09-20 A | 2007-12-07 A | 100% | 2006-09-20 | 2007-12-07 | 318d? | finish no earlier than 2007-12-07 |  | R5 | 2544h | 2544h | MBMS-UEConTest_TDH | Rel-6 | Ingbert | IPWireless | Timothy Speight (tspeight@ipwireless.com) |  |  |
| 1343 | 386.10.3 | Signalling Conformance Test Aspects – MBMS for LCR TDD |  | 318d? | 2006-09-20 A | 2007-12-07 A | 100% | 2006-09-20 | 2007-12-07 | 318d? | finish no earlier than 2007-12-07 |  | R5 | 2544h | 2544h | MBMS-UEConTest_SIGTDL | Rel-6 | Ingbert | DATANG | zhaojian@datangmobile.cn |  |  |
| 1344 | 386.10.4 | Conformance Test Aspects – MBMS |  | 396d? | 2006-03-10 A | 2007-09-14 A | 100% | 2006-03-10 | 2007-09-14 | 396d? | finish no earlier than 2007-09-14 |  | R5 | 3168h | 3168h | MBMS_Test | Rel-6 | Ingbert | Qualcomm | Shubhang Vora (svora@qualcomm.com) |  |  |
| 1345 | 16.5.1 | Conformance Test Aspects - 1.28Mcps TDD MBMS RF/RRM |  | 136d | 2007-06-01 A | 2007-12-07 A | 100% | 2007-06-01 | 2007-12-07 | 136d | finish no earlier than 2007-12-07 | 2006-06-02 | R5 | 1088h | 1088h | MBMS-UEConTest_RFTDL | Rel-6 | Ingbert | Datang Mobile | chenxiaozhong@datangmobile.cn | Fri 11/03/05 |  |
| 1346 | 29 | **Speech Recognition and Speech Enabled Services** |  | 1105d? | 2001-10-08 A | 2005-12-30 A | 100% | 2001-10-08 | 2005-12-30 | 1105d? |  |  | S1 | 20176h | 20176h | SRSES | Rel-6 | Alain |  |  |  |  |
| 1347 | 29.1 | Speech Enabled Services Based on Distributed Speech Recognition (DSR) |  | 115d | 2001-10-08 A | 2002-03-15 A | 100% | 2001-10-08 | 2002-03-15 | 115d | finish no earlier than 2002-03-15 |  | S1 | 920h | 920h | DSR | Rel-6 | Alain | Qualcomm | Dwilliams@qualcomm.com |  |  |
| 1348 | 29.2 | TR on Architectural impacts |  | 212d | 2003-05-12 A | 2004-03-02 A | 100% | 2003-05-12 | 2004-03-02 | 212d | finish no earlier than 2004-03-02 |  | S2 | 1696h | 1696h |  | Rel-6 |  |  |  |  |  |
| 1349 | 387.3 | Codec Work to Support Speech Recognition Framework for Automated Voice Services |  | 568d? | 2002-10-15 A | 2004-12-16 A | 100% | 2002-10-15 | 2004-12-16 | 568d? | finish no earlier than 2004-12-16 |  | S4 | 4544h | 4544h | SRSES-Codec | Rel-6 | Paolo | Motorola | David Pearce (bdp003@motorola.com) |  |  |
| 1350 | 387.4 | Multimodal support |  | 522d? | 2004-01-01 A | 2005-12-30 A | 100% | 2004-01-01 | 2005-12-30 | 522d? | finish no earlier than 2005-06-30 |  | OMA | 4176h | 4176h |  | Rel-6 |  |  | OMA-LIAISON@mail.openmobilealliance.org | SP-24 |  |
| 1351 | 387.5 | Deleted - SES codec negotiation at SDP | milestone | 0d? | 2003-06-04 A | 2003-06-04 A | 100% | 2003-06-04 | 2003-06-04 | 0d? | start no earlier than 2003-06-04 |  | N1 |  |  |  | Rel-6 | Frederic |  |  |  | NP-23 |
| 1352 | 30 | **Generic User Profile Rel-6** |  | 889d | 2001-10-08 A | 2005-03-03 A | 100% | 2001-10-08 | 2005-03-03 | 889d |  |  | S1 | 24295.8h | 24295.8h | GUP | Rel-6 | Alain |  |  |  |  |
| 1353 | 30.1 | Stage 1 - Requirements |  | 430d | 2001-10-08 A | 2003-05-30 A | 100% | 2001-10-08 | 2003-05-30 | 430d | finish no earlier than 2002-12-09 |  | S1 | 3440h | 3440h |  | Rel-6 | Alain | T-Mobile | kurt.bischinger@t-mobile.at |  |  |
| 1354 | 30.3 | Stage 2 - Architecture |  | 355d | 2002-01-28 A | 2003-06-06 A | 100% | 2002-01-28 | 2003-06-06 | 355d | finish no earlier than 2003-06-06 |  | S2 | 2840h | 2840h |  | Rel-6 | Maurice | Nokia | harri.o.koskinen@nokia.com |  |  |
| 1355 | 30.2 | Stage 2 - Data Description Method |  | 586d | 2002-12-05 A | 2005-03-03 A | 100% | 2002-12-05 | 2005-03-03 | 586d | finish no earlier than 2005-03-03 |  | N4 | 4688h | 4688h |  | Rel-6 | Kimmo | T-Mobile | kurt.bischinger@t-mobile.at |  |  |
| 1356 | 30.5 | Stage 3 - Network |  | 468.98d | 2003-05-19 A | 2005-03-03 A | 100% | 2003-05-19 | 2005-03-03 | 468.98d | finish no earlier than 2005-03-03 |  | N4 | 3751.83h | 3751.83h |  | Rel-6 | Kimmo |  |  |  |  |
| 1357 | 30.6 | Security Aspects |  | 308d | 2002-07-16 A | 2003-09-18 A | 100% | 2002-07-16 | 2003-09-18 | 308d | finish no earlier than 2003-09-18 |  | S3 | 2464h | 2464h |  | Rel-6 | Dionisio | Lucent | Owen, Bradley (bvowen@lucent.com) |  |  |
| 1358 | 31 | **Digital Rights Management** |  | 690d? | 2001-10-08 A | 2004-05-28 A | 100% | 2001-10-08 | 2004-05-28 | 690d? |  |  | S1 | 10152h | 10152h | DRM | Rel-6 | Alain |  |  |  |  |
| 1359 | 31.1 | Requirements |  | 179d | 2001-10-08 A | 2002-06-13 A | 100% | 2001-10-08 | 2002-06-13 | 179d | finish no earlier than 2002-06-13 |  | S1 | 1432h | 1432h |  | Rel-6 | Alain | Openwave | nicholas.wood@openwave.com |  |  |
| 1360 | 389.2 | Stage 2 |  | 107d? | 2004-01-01 A | 2004-05-28 A | 100% | 2004-01-01 | 2004-05-28 | 107d? | finish no earlier than 2004-05-28 |  | OMA | 856h | 856h |  | Rel-6 |  |  | OMA-LIAISON@mail.openmobilealliance.org | SP-24 |  |
| 1361 | 389.3 | Stage 3 |  | 107d? | 2004-01-01 A | 2004-05-28 A | 100% | 2004-01-01 | 2004-05-28 | 107d? | finish no earlier than 2004-05-28 |  | OMA | 856h | 856h |  | Rel-6 |  |  | OMA-LIAISON@mail.openmobilealliance.org | SP-24 |  |
| 1362 | 31.3 | Security |  | 186d | 2002-06-17 A | 2003-03-03 A | 100% | 2002-06-17 | 2003-03-03 | 186d | finish no earlier than 2003-03-03 |  | OMA | 1488h | 1488h |  | Rel-6 |  |  |  |  |  |
| 1363 | 389.5 | Deleted - Monitoring of Stages 2 and 3 progress (actual work to be done by OMA) | milestone | 0d? | 2003-03-21 A | 2003-03-21 A | 100% | 2003-03-21 | 2003-03-21 | 0d? | start no earlier than 2002-08-19 |  | S1 |  |  |  | Rel-6 | Alain |  |  |  | SP-19 |

Notes:
- 1336: Text3: 22.246
- 1337: Text3: 22.246
- 1338: TR26.946 tbc by March 06 / Text3: 26.346, 26.936, 26.946
- 1339: SA#28 06/2005 completed / Text3: 32.273
- 1340: BB place holder for a number of RAN5 Tasks. Moved in from the Stoyan/Testing WP / Text3: 34.108, 34.109, 34.121-1, 34.121-2, 34.122, 34.123-1, 34.123-2, 34.123-3
- 1341: TS 34.109 is under RAN2; RAN5 need to identify possible new requirements on UE test loop functionality to enable testing / Text3: 34.108, 34.109, 34.121-1, 34.121-2
- 1342: Text3: 34.108, 34.122, 34.123-1, 34.123-2, 34.123-3
- 1343: Text3: 34.108, 34.123-1, 34.123-2, 34.123-3
- 1344: Text3: 34.108, 34.123-1, 34.123-2, 34.123-3
- 1345: Text3: 34.108, 34.109, 34.122
- 1347: Text3: 22.941, 23.207, 22.243
- 1348: Text3: 23.877
- 1349: Completed / Text3: 26.235, 26.236, 26.243, 26.177, 26.943
- 1351: Abandoned NP-23
- 1353: Text3: 22.240, 22.228
- 1354: Text3: 23.240
- 1355: TR approved in CN#26 / Text3: 23.241
- 1356: 17 May no activity in CN4............ / Text3: 29.240
- 1357: WID approved SA#17. SA WG3 progress slow, depends on progress in other groups. / Text3: 33.102, 33.203, 33.210
- 1358: Foreseen start and completion dates introduced by MCC (no indication at all on the WID)
- 1362: SA3 acknowledge role in WI at SA3#20. Active contribution S3#24, S3#25. S3 WID approved SA#17
- 1363: Replaced by UID 60005 and 60006

| ID | WBS | Task | Duration | Start | Finish | Complete | Baseline start | Baseline finish | Baseline duration | Constraint | Resources | Work | Actual work | Text1 | Text4 | Text5 | Text6 | Text8 | Text3 | Text10 |
| --- | --- | --- | --- | --- | --- | --- | --- | --- | --- | --- | --- | --- | --- | --- | --- | --- | --- | --- | --- | --- |
| 1364 | 32 | **WLAN-UMTS Interworking Rel-6** | 1495d? | 2000-01-03 A | 2005-09-22 A | 100% | 2000-01-03 | 2005-09-22 | 1495d? |  | S1 | 48472h | 48472h | WLAN | Telenor | frederic.paint@telenor.com | Rel-6 | Alain |  |  |
| 1365 | 32.1 | Technical Report | 901d? | 2000-01-03 A | 2003-06-13 A | 100% | 2000-01-03 | 2003-06-13 | 901d? | finish no earlier than 2003-06-13 | S1 | 7200h | 7200h | WLAN-TR | Telenor | frederic.paint@telenor.com | Rel-6 | Alain | 22.934, 22.101, 22.105 |  |
| 1366 | 390.2 | **Stage 1** | 375d? | 2003-01-06 A | 2004-06-11 A | 100% | 2003-01-06 | 2004-06-11 | 375d? |  | S1 | 3920h | 3920h | WLAN-TS | Telenor | frederic.paint@telenor.com | Rel-6 | Alain | 22.234 | SP-24 |
| 1367 | 390.2.1 | Global stage 1 | 375d? | 2003-01-06 A | 2004-06-11 A | 100% | 2003-01-06 | 2004-06-11 | 375d? | finish no earlier than 2004-06-11 | S1 | 3000h | 3000h | WLAN-TS | Telenor | frederic.paint@telenor.com | Rel-6 | Alain | 22.234 | SP-24 |
| 1368 | 32.2 | Architecture Definition for scenarii 2 and 3 | 571d | 2002-03-25 A | 2004-05-31 A | 100% | 2002-03-25 | 2004-05-31 | 571d | finish no earlier than 2004-05-31 | S2 | 4568h | 4568h |  |  |  | Rel-6 | Maurice | 23.234 |  |
| 1369 | 32.3 | Security | 125d | 2002-09-30 A | 2003-03-21 A | 100% | 2002-09-30 | 2003-03-21 | 125d | finish no earlier than 2003-03-21 | S3 | 1000h | 1000h |  | Ericsson | luis.lopez-soria@ece.ericsson.se | Rel-6 | Dionisio | 21.133, 33.106, 33.107, 33.108, 33.200, 33.203, 33.210 |  |
| 1370 | 390.5 | Stage 3 - CN4 aspects | 334d? | 2003-05-23 A | 2004-09-01 A | 100% | 2003-05-23 | 2004-09-01 | 334d? | finish no earlier than 2004-09-01 | N4 | 2672h | 2672h | WLAN-IW | Nokia | raquel.rodriguez@nokia.com | Rel-6 | Kimmo | 29.234, 29.061 |  |
| 1371 | 390.6 | Stage 3 - CN3 aspects (Wi Interface for Scenario 3) | 355d? | 2003-05-23 A | 2004-09-30 A | 100% | 2003-05-23 | 2004-09-30 | 355d? | start no earlier than 2003-05-23 | N3 | 2840h | 2840h | WLAN |  |  | Rel-6 | Gwiho | 29.161 | SP-24 |
| 1372 | 390.7 | Stage 3 for scenario 2 | 339d? | 2003-05-23 A | 2004-09-08 A | 100% | 2003-05-23 | 2004-09-08 | 339d? | finish no earlier than 2004-09-08 | N1 | 2712h | 2712h |  |  |  | Rel-6 | Frederic |  |  |
| 1373 | 390.8 | Stage 3 for scenario 3 | 404d? | 2003-05-23 A | 2004-12-08 A | 100% | 2003-05-23 | 2004-12-08 | 404d? | finish no earlier than 2004-12-08 | N1 | 3232h | 3232h |  |  |  | Rel-6 | Frederic |  | SP-24 |
| 1374 | 390.9 | WLAN charging | 655d? | 2003-03-21 A | 2005-09-22 A | 100% | 2003-03-21 | 2005-09-22 | 655d? | finish no earlier than 2005-09-22 | S5 | 5240h | 5240h | WLAN-CH | Nokia | Benni ALEXANDER | Rel-6 | Dionisio | 32.252 |  |
| 1375 | 390.10 | USIM enhancements for WLAN Interworking | 391d? | 2003-09-05 A | 2005-03-04 A | 100% | 2003-09-05 | 2005-03-04 | 391d? | finish no earlier than 2005-03-04 | T3 | 3128h | 3128h |  | Axalto | Jabellan@axalto.com | Rel-6 |  |  |  |
| 1376 | 33 | **Priority Service** | 347d? | 2002-05-30 A | 2003-09-26 A | 100% | 2002-05-30 | 2003-09-26 | 347d? |  | S1 | 6464h | 6464h | NTShar |  |  | Rel-6 | Alain |  |  |
| 1377 | 33.1 | Feasibility Study | 1d | 2002-06-14 A | 2002-06-14 A | 100% | 2002-06-14 | 2002-06-14 | 1d | finish no earlier than 2002-06-14 | S1 | 8h | 8h | PRIOR-FS | Telcordia | Biplab K. Pramanik (bpramani@telcordia.com) | Rel-6 | Alain | 22.950 |  |
| 1378 | 33.2 | Stage 1 - Requirements | 340d | 2002-05-30 A | 2003-09-17 A | 100% | 2002-05-30 | 2003-09-17 | 340d | finish no earlier than 2003-09-17 | S1 | 2720h | 2720h | PRIOR-SR | Telcordia | James J. Garrahan (bpramani@telcordia.com) | Rel-6 | Alain |  |  |
| 1379 | 391.3 | Priority service implementation guide | 131d? | 2003-03-28 A | 2003-09-26 A | 100% | 2003-03-28 | 2003-09-26 | 131d? | finish no earlier than 2003-09-26 | S1 | 1048h | 1048h |  | Telcordia | Biplab K. Pramanik (bpramani@telcordia.com) | Rel-6 | Alain | 22.952 |  |
| 1380 | 34 | **Network Sharing** | 498d? | 2003-01-20 A | 2004-12-15 A | 100% | 2003-01-20 | 2004-12-15 | 498d? |  | S1 | 16608h | 16608h | NTShar |  |  | Rel-6 | Alain |  |  |
| 1381 | 34.1 | Technical Report | 240d? | 2003-01-20 A | 2003-12-19 A | 100% | 2003-01-20 | 2003-12-19 | 240d? |  | S1 | 1920h | 1920h | NTShar-TR |  |  | Rel-6 | Alain | 22.951 |  |
| 1382 | 392.2 | Stage 1 - CRs to implement Network Sharing | 240d? | 2003-01-20 A | 2003-12-19 A | 100% | 2003-01-20 | 2003-12-19 | 240d? | finish no earlier than 2003-12-19 | S1 | 1920h | 1920h | NTShar-CR |  |  | Rel-6 | Alain | 22.011, 22.101, 22.115, 22.129 |  |
| 1383 | 392.3 | Stage 2 | 372d? | 2003-02-27 A | 2004-07-30 A | 100% | 2003-02-27 | 2004-07-30 | 372d? | finish no earlier than 2004-07-30 | S2 | 2976h | 2976h |  |  |  | Rel-6 | Maurice | 23.251 |  |
| 1384 | 392.4 | Network sharing - stage 3 | 404d? | 2003-05-23 A | 2004-12-08 A | 100% | 2003-05-23 | 2004-12-08 | 404d? | finish no earlier than 2004-12-08 | N1 | 3232h | 3232h |  |  |  | Rel-6 | Frederic |  |  |
| 1385 | 392.5 | Enhancement of the support of network sharing in the UTRAN | 324d | 2003-09-19 A | 2004-12-15 A | 100% | 2003-09-19 | 2004-12-15 | 324d | finish no earlier than 2004-12-15 | R2 | 2592h | 2592h | NTShar-UTRANEnh | TeliaSonera | Anders.Dahlen@TeliaSonera.com | Rel-6 | Joern | 25.401, 25.413, 25.331, 25.304 |  |
| 1386 | 35 | **QoS Improvements** | 628d? | 2002-07-15 A | 2004-12-08 A | 100% | 2002-07-15 | 2004-12-08 | 628d? |  | S2 | 13128h | 13128h | QoS1 | Nokia |  | Rel-6 | Maurice |  |  |
| 1387 | 35.1 | FS on Dynamic Policy control enhancements for end-to-end QoS | 465d | 2002-07-15 A | 2004-04-23 A | 100% | 2002-07-15 | 2004-04-23 | 465d | finish no earlier than 2004-04-23 | S2 | 3720h | 3720h | QoS1 | Nortel | Claire Mousset | Rel-6 | Maurice | 23.917 |  |
| 1388 | 393.2 | Definition of the Gq interface | 214d? | 2003-07-01 A | 2004-04-23 A | 100% | 2003-07-01 | 2004-04-23 | 214d? | finish no earlier than 2004-04-23 | S2 | 1712h | 1712h |  |  | Janne Rinne | Rel-6 |  | 23.221 |  |
| 1389 | 393.3 | Gq interface specification for Dynamic Policy control enhancements – Stage 3 | 334d | 2003-08-29 A | 2004-12-08 A | 100% | 2003-08-29 | 2004-12-08 | 334d | finish no earlier than 2004-12-08 | N3 | 2672h | 2672h |  | Nokia | Anna.Sillanpaai@nokia.com | Rel-6 | Gwiho | 24,228, 29.207, 29.208 |  |

Notes:
- 1369: Active contribution S3#24, S3#25. WID approved SA#17
- 1370: WID approved at CN#19...............
- 1374: SA#28: delayed 09/2005. WT also under SA5 BB 35017 Charging Management for Bearer level
- 1389: [DAB - 25.05.04] - Delayed to Sept - possibly Dec 2004

| ID | WBS | Task | Type | Duration | Start | Finish | Complete | Baseline start | Baseline finish | Baseline duration | Constraint | Resources | Work | Actual work | Text1 | Text4 | Text5 | Text6 | Text8 | Text10 | Text12 |
| --- | --- | --- | --- | --- | --- | --- | --- | --- | --- | --- | --- | --- | --- | --- | --- | --- | --- | --- | --- | --- | --- |
| 1390 | 36 | **Subscriber certificates** |  | 728d? | 2002-02-25 A | 2004-12-08 A | 100% | 2002-02-25 | 2004-12-08 | 728d? |  | S3 | 12888h | 12888h | SEC1-SC | Nokia | valtteri.niemi@nokia.com | Rel-6 | Maurice |  |  |
| 1391 | 36.1 | Stage 1 |  | 144d | 2002-02-25 A | 2002-09-12 A | 100% | 2002-02-25 | 2002-09-12 | 144d | finish no earlier than 2002-09-12 | S3 | 1152h | 1152h |  |  |  | Rel-6 | Dionisio |  |  |
| 1392 | 36.2 | Architecture review |  | 24d | 2002-10-14 A | 2002-11-14 A | 100% | 2002-10-14 | 2002-11-14 | 24d | finish no earlier than 2002-11-14 | S2 | 192h | 192h |  |  |  | Rel-6 | Maurice |  |  |
| 1393 | 394.3 | Stage 3 |  | 313d? | 2003-09-19 A | 2004-11-30 A | 100% | 2003-09-19 | 2004-11-30 | 313d? | finish no earlier than 2004-11-30 | N4 | 2504h | 2504h | SEC1-SC | Nokia | Lauri Laitinen | Rel-6 | Kimmo |  |  |
| 1394 | 394.4 | Stage 3 Ua & Ub interfaces |  | 288d? | 2003-11-03 A | 2004-12-08 A | 100% | 2003-11-03 | 2004-12-08 | 288d? | finish no earlier than 2004-12-08 | N1 | 2304h | 2304h |  |  |  | Rel-6 | Frederic |  |  |
| 1395 | 394.5 | OMA dependencies on Subscriber certificates |  | 114d? | 2004-01-01 A | 2004-06-08 A | 100% | 2004-01-01 | 2004-06-08 | 114d? | finish no earlier than 2004-06-08 | OMA | 912h | 912h |  |  | OMA-LIAISON@mail.openmobilealliance.org | Rel-6 |  | SP-24 |  |
| 1396 | 395 | **Rel-6 OSA enhancements** |  | 616d? | 2002-10-31 A | 2005-03-10 A | 100% | 2002-10-31 | 2005-03-10 | 616d? |  | N5 | 22576h | 22576h | OSA3 | Alcatel | Chelo.Abarca@alcatel.fr | Rel-6 | Kimmo |  |  |
| 1397 | 395.1 | Scope of the Open Service Access Release 6 |  | 66d? | 2003-03-28 A | 2003-06-27 A | 100% | 2003-03-28 | 2003-06-27 | 66d? | finish no earlier than 2003-06-27 | S1 | 528h | 528h |  |  |  | Rel-6 | Alain |  |  |
| 1398 | 395.2 | OSA Stage 2 |  | 150d? | 2004-08-13 A | 2005-03-10 A | 100% | 2004-08-13 | 2005-03-10 | 150d? | finish no earlier than 2005-03-10 | N5 | 1200h | 1200h |  |  |  | Rel-6 | Kimmo |  |  |
| 1399 | 395.3 | Multi Media Messaging function |  | 487d? | 2002-10-31 A | 2004-09-10 A | 100% | 2002-10-31 | 2004-09-10 | 487d? | finish no earlier than 2004-09-10 | N5 | 3896h | 3896h |  |  |  | Rel-6 | Kimmo |  |  |
| 1400 | 395.4 | Policy management extensions |  | 292d? | 2002-10-31 A | 2003-12-12 A | 100% | 2002-10-31 | 2003-12-12 | 292d? | finish no earlier than 2003-12-12 | N5 | 2336h | 2336h |  |  |  | Rel-6 | Kimmo |  |  |
| 1401 | 395.5 | TS on Presence and Availability Management (from the PRESNC WI) |  | 367d? | 2002-10-31 A | 2004-03-26 A | 100% | 2002-10-31 | 2004-03-26 | 367d? | finish no earlier than 2004-03-26 | N5 | 2936h | 2936h |  |  |  | Rel-6 | Kimmo |  |  |
| 1402 | 395.6 | OSA interfaces at different levels of abstractions (Parlay X, Web services) |  | 305d? | 2003-07-14 A | 2004-09-10 A | 100% | 2003-07-14 | 2004-09-10 | 305d? | finish no earlier than 2004-09-10 | N5 | 2440h | 2440h |  |  |  | Rel-6 | Kimmo |  |  |
| 1403 | 395.7 | Introduction of migration support mechanism |  | 290d? | 2002-10-31 A | 2003-12-10 A | 100% | 2002-10-31 | 2003-12-10 | 290d? | finish no earlier than 2003-12-12 | N5 | 2320h | 2320h |  |  |  | Rel-6 | Kimmo |  |  |
| 1404 | 395.8 | Framework Function for Federation |  | 225d? | 2003-02-03 A | 2003-12-12 A | 100% | 2003-02-03 | 2003-12-12 | 225d? | finish no earlier than 2003-12-12 | N5 | 1800h | 1800h |  |  |  | Rel-6 | Kimmo |  |  |
| 1405 | 395.9 | OMA potential overlaps with 3GPP OSA Stage 3 (Web services) |  | 196d? | 2003-12-18 A | 2004-09-16 A | 100% | 2003-12-18 | 2004-09-16 | 196d? | start no earlier than 2003-12-18 | OMA | 1568h | 1568h |  |  |  | Rel-6 |  | SP-24 |  |
| 1406 | 395.10 | Deleted - TR on Presence and Availability Management (from the PRESNC WI) | milestone | 0d? | 2004-09-17 A | 2004-09-17 A | 100% | 2004-09-17 | 2004-09-17 | 0d? | start no earlier than 2004-09-17 | N5 |  |  |  |  |  | Rel-6 | Kimmo |  | NP-24 |
| 1407 | 39 | **Addition of frequency bands to GSM (TAPS)** |  | 676d | 2002-06-28 A | 2005-01-28 A | 100% | 2002-06-28 | 2005-01-28 | 676d |  | GP | 16640h | 16640h | TAPS | Nokia | Torben Themsen | Rel-6 | Paolo |  |  |
| 1408 | 39.1 | **Addition of frequency bands to GSM – Changes to core specs** |  | 26d | 2002-11-15 A | 2002-12-20 A | 100% | 2002-11-15 | 2002-12-20 | 26d |  | G1 | 416h | 416h | TAPS-Specs | Nokia | Torben Themsen | Rel-6 |  |  |  |
| 1409 | 39.1.1 | Changes to core specs |  | 26d | 2002-11-15 A | 2002-12-20 A | 100% | 2002-11-15 | 2002-12-20 | 26d | finish no earlier than 2002-12-20 | G1 | 208h | 208h |  |  |  | Rel-6 |  |  |  |
| 1410 | 39.2 | **Deleted at TSG #27 - Addition of frequency bands to GSM – Changes for conformance tests** |  | 676d | 2002-06-28 A | 2005-01-28 A | 100% | 2002-06-28 | 2005-01-28 | 676d |  | G4 | 10816h | 10816h | TAPS-Conf | Nokia | Torben Themsen | Rel-6 | Paolo |  | GP-23 |
| 1411 | 39.2.1 | Deleted at TSG #27 - 51.010-1 Add testing |  | 676d | 2002-06-28 A | 2005-01-28 A | 100% | 2002-06-28 | 2005-01-28 | 676d | finish no earlier than 2005-01-28 | G4 | 5408h | 5408h |  |  |  | Rel-6 | Paolo |  | GP-23 |
| 1412 | 40 | **Seamless support of streaming services in A/Gb mode** |  | 1426d? | 2000-01-03 A | 2005-06-17 A | 100% | 2000-01-03 | 2005-06-17 | 1426d? |  | GP | 53096h | 53096h | SSStrea | Vodafone | José Luis Carrizo Martínez | Rel-6 | Paolo |  |  |
| 1413 | 40.1 | **Identification of requirements for streaming** |  | 46d? | 2003-06-27 A | 2003-08-29 A | 100% | 2003-06-27 | 2003-08-29 | 46d? |  | G1 | 736h | 736h |  |  |  | Rel-6 |  |  |  |
| 1414 | 397.1.1 | Requirements |  | 46d? | 2003-06-27 A | 2003-08-29 A | 100% | 2003-06-27 | 2003-08-29 | 46d? | finish no earlier than 2003-08-29 | G1 | 368h | 368h |  |  |  | Rel-6 |  |  |  |

Notes:
- 1390: Approved at SA#14. This may require BBs from CN1, CN4, SA5 and T3 / Text3: 33.102
- 1391: Contribution received S3#24, S3#25
- 1393: Finished in CN4#26
- 1395: Updated according to SP-040420
- 1396: CN#25: Updated WID NP-040351 replaces NP-040144. / Text3: 22.127, 23.198, 29.198, 29.199, 29.998
- 1398: Inherited by CN5 from SA2 at TSG#25 Sep 2004. SA2's 23.127 (OSA/VHE Stage 2) replaced from Rel-6 onwards by a new CN5 TS 23.198 (Stage 2 OSA-only). / Text3: 23.198 OSA Stage 2-ONLY replaces 23.127 (OSA/VHE) from Rel-6 onwards
- 1399: Text3: 29.198-15
- 1400: Text3: 29.198, 29.998
- 1401: N5#26: Split WI into TS & TR. / Text3: 29.198-14
- 1402: Text3: 29.199
- 1403: Text3: 29.198, 29.998
- 1404: Text3: 29.198, 29.998
- 1405: TSG#25 Approved CN5 29.199 Parlay X Web services. Ongoing 3GPP/OMA co-ordination to avoid OMA producing conflicting/OVERLAPING specs (NP-040283/SP-040493).
- 1406: N5#26:TR Completion 09/04; consistent with CN1 delayed Rel-6 completion.
- 1408: Ready
- 1410: DELETE
- 1411: DELETE
- 1413: Started

| ID | WBS | Task | Duration | Start | Finish | Complete | Baseline start | Baseline finish | Baseline duration | Constraint | Resources | Work | Actual work | Text6 | Text8 | Text3 | Text4 | Text5 | Text1 |
| --- | --- | --- | --- | --- | --- | --- | --- | --- | --- | --- | --- | --- | --- | --- | --- | --- | --- | --- | --- |
| 1415 | 40.2 | **Performance study of cell change mechanisms** | 956d? | 2000-01-03 A | 2003-08-29 A | 100% | 2000-01-03 | 2003-08-29 | 956d? |  | G1 | 30568h | 30568h | Rel-6 |  |  |  |  |  |
| 1416 | 397.2.1 | Performance of NACC | 956d? | 2000-01-03 A | 2003-08-29 A | 100% | 2000-01-03 | 2003-08-29 | 956d? | finish no earlier than 2003-08-29 | G1 | 7640h | 7640h | Rel-6 |  |  |  |  |  |
| 1417 | 397.2.2 | Performance of cell change in DTM for the PS domain | 956d? | 2000-01-03 A | 2003-08-29 A | 100% | 2000-01-03 | 2003-08-29 | 956d? | finish no earlier than 2003-08-29 | G1 | 7640h | 7640h | Rel-6 |  |  |  |  |  |
| 1418 | 397.2.3 | Handover | 956d? | 2000-01-03 A | 2003-08-29 A | 100% | 2000-01-03 | 2003-08-29 | 956d? | finish no earlier than 2003-08-29 | G1 | 7640h | 7640h | Rel-6 |  |  |  |  |  |
| 1419 | 40.3 | **Reduction of service interruption times and packet loss during mobility procedures** | 516d? | 2003-06-27 A | 2005-06-17 A | 100% | 2003-06-27 | 2005-06-17 | 516d? |  | G2 | 10800h | 10800h | Rel-6 | Gert |  |  |  |  |
| 1420 | 397.3.1 | Optimisations of existing mechanisms/procedures | 106d? | 2003-06-27 A | 2003-11-21 A | 100% | 2003-06-27 | 2003-11-21 | 106d? | finish no earlier than 2003-11-21 | G2 | 848h | 848h | Rel-6 | Gert |  |  |  |  |
| 1421 | 397.3.2 | Inter-system NACC | 106d? | 2003-06-27 A | 2003-11-21 A | 100% | 2003-06-27 | 2003-11-21 | 106d? | finish no earlier than 2003-11-21 | G2 | 848h | 848h | Rel-6 | Gert |  |  |  |  |
| 1422 | 397.3.3 | PS Handover (within GERAN and between GERAN and UTRAN) | 516d? | 2003-06-27 A | 2005-06-17 A | 100% | 2003-06-27 | 2005-06-17 | 516d? | finish no earlier than 2003-11-21 | G2 | 4128h | 4128h | Rel-6 | Gert |  |  |  |  |
| 1423 | 397.3.4 | Dependency to other features | 106d? | 2003-06-27 A | 2003-11-21 A | 100% | 2003-06-27 | 2003-11-21 | 106d? | finish no earlier than 2003-11-21 | G2 | 848h | 848h | Rel-6 | Gert |  |  |  |  |
| 1424 | 40.5 | **MS conformance testing** | 31d? | 2003-12-19 A | 2004-01-30 A | 100% | 2003-12-19 | 2004-01-30 | 31d? |  | G3new | 248h | 248h | Rel-6 | Ingbert |  |  |  |  |
| 1425 | 397.4.1 | MS conformance tests | 31d? | 2003-12-19 A | 2004-01-30 A | 100% | 2003-12-19 | 2004-01-30 | 31d? | finish no earlier than 2004-01-30 | G4,G5 | 248h | 248h | Rel-6 | Paolo |  |  |  |  |
| 1426 | 397.5 | GERAN A/Gb mode security enhancements | 612d? | 2002-09-26 A | 2005-01-28 A | 100% | 2002-09-26 | 2005-01-28 | 612d? | finish no earlier than 2005-01-28 | S3 | 4896h | 4896h | Rel-6 | Dionisio | 33.102 | Vodafone | peter.howard@vodafone.com |  |
| 1427 | 41 | Performance characterisation of default codecs for PS conversational multimedia application | 455d | 2002-09-13 A | 2004-06-10 A | 100% | 2002-09-13 | 2004-06-10 | 455d | finish no earlier than 2004-06-10 | S4 | 3640h | 3640h | Rel-6 | Paolo | 26.935 | Nokia | pasi.s.ojala@nokia.com | CODCAR |
| 1428 | 43 | Study on Privacy Capability | 83d | 2003-11-10 A | 2004-03-03 A | 100% | 2003-11-10 | 2004-03-03 | 83d | start no earlier than 2003-11-10 | S1 | 664h | 664h | Rel-6 | Alain | 21.949 | Lucent | Liz Daniel | PrivCap |
| 1429 | 44 | **OAM&P Rel-6** | 652d? | 2002-09-12 A | 2005-03-11 A | 100% | 2002-09-12 | 2005-03-11 | 652d? |  | S5 | 30819.5h | 30819.5h | Rel-6 | Dionisio | 32-series | Motorola |  | OAM |
| 1430 | 44.1 | Principles, high level Requirements and Architecture | 526d | 2002-09-12 A | 2004-09-16 A | 100% | 2002-09-12 | 2004-09-16 | 526d | finish no earlier than 2004-09-16 | S5 | 4208h | 4208h | Rel-6 | Dionisio | 32.101, 32.102 | Motorola |  | OAM-AR |
| 1431 | 44.2 | Performance Management | 591d | 2002-09-12 A | 2004-12-16 A | 100% | 2002-09-12 | 2004-12-16 | 591d | finish no earlier than 2004-12-16 | S5 | 4728h | 4728h | Rel-6 | Dionisio | 32.401/3, 52.402, 32.411/2/3, 32.432/5/6 | Nortel |  | OAM-PM |
| 1432 | 44.4 | Network Infrastructure Management | 591d | 2002-09-12 A | 2004-12-16 A | 100% | 2002-09-12 | 2004-12-16 | 591d | finish no earlier than 2004-12-16 | S5 | 4728h | 4728h | Rel-6 | Dionisio | 32.15x, 32.3/6/7xy | Ericsson | thomas.tovinger@ericsson.com | OAM-NIM |
| 1433 | 44.5 | **Trace Management Rel-6** | 646d? | 2002-09-20 A | 2005-03-11 A | 100% | 2002-09-20 | 2005-03-11 | 646d? |  | S5 | 12061.9h | 12061.9h | Rel-6 | Dionisio | 32.42x, 52.008 | Nokia | kari.t.ronka@nokia.com | OAM-Trace |
| 1434 | 400.4.1 | Subscriber and UE trace management | 585d | 2002-09-20 A | 2004-12-16 A | 100% | 2002-09-20 | 2004-12-16 | 585d | finish no earlier than 2004-12-16 | S5 | 4680h | 4680h | Rel-6 | Dionisio | 32.421/2/3, 52.008 | Nokia | kari.t.ronka@nokia.com | OAM-Trace |
| 1435 | 400.4.2 | Subscriber and equipment trace in UTRAN | 268d? | 2003-06-06 A | 2004-06-15 A | 100% | 2003-06-06 | 2004-06-15 | 268d? | finish no earlier than 2004-06-15 | R3 | 2144h | 2144h | Rel-6 | Juha | 25.413, 25.420, 25.423 | Nortel | Yann Sehedi (sehedic@nortelnetworks.com) | OAM-Trace-RAN |
| 1436 | 400.4.3 | Trace Management, Stage3 | 193.74d? | 2004-06-09 A | 2005-03-11 A | 100% | 2004-06-09 | 2005-03-11 | 193.74d? | finish no earlier than 2005-03-11 | N4 | 1549.92h | 1549.92h | Rel-6 | Kimmo | 23.205, 29.232, 29.060, 29.002, 29.228 | Nokia | seppo.kauntola@nokia.com | OAM-Trace |
| 1437 | 401 | **Charging Management** | 666d? | 2002-11-21 A | 2005-06-09 A | 100% | 2002-11-21 | 2005-06-09 | 666d? |  | S5 | 55320h | 55320h | Rel-6 | Dionisio | 32.2xy | T-Mobile | karl-heinz.nenner@t-mobile.de | CH |
| 1438 | 401.1 | Charging architecture and principles | 390d? | 2003-03-21 A | 2004-09-16 A | 100% | 2003-03-21 | 2004-09-16 | 390d? | start no earlier than 2003-03-21 | S5 | 3120h | 3120h | Rel-6 | Dionisio | 32.240 |  |  | CH |
| 1439 | 401.2 | Charging Data Record (CDR) file format and transfer | 260d? | 2003-03-21 A | 2004-03-18 A | 100% | 2003-03-21 | 2004-03-18 | 260d? | start no earlier than 2003-03-21 | S5 | 2080h | 2080h | Rel-6 | Dionisio | 32.297 |  |  | CH |
| 1440 | 401.3 | CDR parameter description | 580d? | 2003-03-21 A | 2005-06-09 A | 100% | 2003-03-21 | 2005-06-09 | 580d? | finish no earlier than 2005-06-09 | S5 | 4640h | 4640h | Rel-6 | Dionisio | 32.298 |  |  | CH |
| 1441 | 401.4 | Diameter charging applications | 390d? | 2003-03-21 A | 2004-09-16 A | 100% | 2003-03-21 | 2004-09-16 | 390d? | start no earlier than 2003-03-21 | S5 | 3120h | 3120h | Rel-6 | Dionisio | 32.299 |  |  | CH |
| 1442 | 401.5 | Online Charging System (OCS) architecture study | 130d? | 2003-03-21 A | 2003-09-18 A | 100% | 2003-03-21 | 2003-09-18 | 130d? | start no earlier than 2003-03-21 | S5 | 1040h | 1040h | Rel-6 | Dionisio | 32.815 |  |  | CH |
| 1443 | 401.6 | OCS: Applications and interfaces | 455d? | 2003-03-21 A | 2004-12-16 A | 100% | 2003-03-21 | 2004-12-16 | 455d? | start no earlier than 2003-03-21 | S5 | 3640h | 3640h | Rel-6 | Dionisio | 32.296 |  |  | CH |

Notes:
- 1415: Started
- 1419: Completed at GERP#17
- 1424: Closed, no work needed
- 1425: Closed, no work needed
- 1426: Possible changes to 33.102 or new specification needed.
- 1429: SA#26: Updated WID SP-040766 was SP-020445. Completion delayed 12/04->03/05 due to OAM-Trace in CN1/4.
- 1430: SA#25 09/2004 completed
- 1431: SA#26 12/2004 completed
- 1432: SA#26 12/2004 completed
- 1433: SA#26 12/2004 SA5 completed 12/04. Signalling Based Trace Activation for IMS (SIP) moved to Rel-7. Reason: CN1 cannot complete 24.229 trace without IETF dependency => estimate 05/2005.
- 1434: SA#26 12/2004 completed
- 1437: SA#28 Target 09/2005 for WLAN Charging 32.252
- 1438: SA#25 09/2004 completed
- 1439: SA#23 03/2004 completed
- 1440: SA#28 06/2005 completed
- 1441: SA#25 09/2004 completed
- 1442: SA#21 09/2003 completed
- 1443: SA#26 12/2004 completed

| ID | WBS | Task | Duration | Start | Finish | Complete | Baseline start | Baseline finish | Baseline duration | Constraint | Resources | Work | Actual work | Text1 | Text4 | Text5 | Text6 | Text8 | Text10 | Text12 |
| --- | --- | --- | --- | --- | --- | --- | --- | --- | --- | --- | --- | --- | --- | --- | --- | --- | --- | --- | --- | --- |
| 1444 | 401.7 | **Charging Management for Bearer level** | 390d? | 2003-03-21 A | 2004-09-16 A | 100% | 2003-03-21 | 2004-09-16 | 390d? |  | S5 | 11440h | 11440h | CH-BC | Nokia | Benni ALEXANDER | Rel-6 | Dionisio |  |  |
| 1445 | 401.7.1 | CS domain charging | 260d? | 2003-03-21 A | 2004-03-18 A | 100% | 2003-03-21 | 2004-03-18 | 260d? | start no earlier than 2003-03-21 | S5 | 2080h | 2080h | CH |  |  | Rel-6 | Dionisio |  |  |
| 1446 | 401.7.2 | PS domain charging | 390d? | 2003-03-21 A | 2004-09-16 A | 100% | 2003-03-21 | 2004-09-16 | 390d? | start no earlier than 2003-03-21 | S5 | 3120h | 3120h | CH |  |  | Rel-6 | Dionisio |  |  |
| 1447 | 401.7.3 | CDR transfer | 390d? | 2003-03-21 A | 2004-09-16 A | 100% | 2003-03-21 | 2004-09-16 | 390d? | start no earlier than 2003-03-21 | S5 | 3120h | 3120h | CH |  |  | Rel-6 | Dionisio |  |  |
| 1448 | 401.8 | Charging Management for the IMS | 455d? | 2003-03-21 A | 2004-12-16 A | 100% | 2003-03-21 | 2004-12-16 | 455d? | finish no earlier than 2004-12-16 | S5 | 3640h | 3640h | IMS2-CH | Ericsson | Patrik TEPPO | Rel-6 | Dionisio |  |  |
| 1449 | 401.9 | Charging Management for the Service domain | 580d? | 2003-03-21 A | 2005-06-09 A | 100% | 2003-03-21 | 2005-06-09 | 580d? | finish no earlier than 2005-06-09 | S5 | 4640h | 4640h | CH | Siemens | Gerald GÖRMER | Rel-6 | Dionisio |  |  |
| 1450 | 401.10 | **Overall architectural aspects of IP flow based bearer level charging** | 602d? | 2002-11-21 A | 2005-03-11 A | 100% | 2002-11-21 | 2005-03-11 | 602d? |  | S2 | 12632h | 12632h | CH-FBC |  |  | Rel-6 | Maurice |  |  |
| 1451 | 401.10.1 | Overall definition of FBC architecture | 334d? | 2002-11-21 A | 2004-03-02 A | 100% | 2002-11-21 | 2004-03-02 | 334d? | start no earlier than 2002-11-21 | S2 | 2672h | 2672h |  |  |  | Rel-6 | Maurice | SP-24 |  |
| 1452 | 401.10.2 | Study on providing policy control with FBC | 130d? | 2004-02-02 A | 2004-07-30 A | 100% | 2004-02-02 | 2004-07-30 | 130d? | start no earlier than 2004-02-01 | S2 | 1040h | 1040h |  |  |  | Rel-6 | Maurice | SP-24 |  |
| 1453 | 401.10.3 | Gx interface for flow based charging | 223d? | 2004-02-02 A | 2004-12-08 A | 100% | 2004-02-02 | 2004-12-08 | 223d? | start no earlier than 2004-02-01 | N3 | 1784h | 1784h | CH-FBC | Nokia | juha.a.rasanen@nokia.com | Rel-6 | Gwiho | SP-25 |  |
| 1454 | 401.10.4 | Rx interface for flow based charging | 290d? | 2004-02-02 A | 2005-03-11 A | 100% | 2004-02-02 | 2005-03-11 | 290d? | finish no earlier than 2005-03-11 | N3 | 2320h | 2320h | CH-FBC | Nortel | Javier Gonzalez Gallego | Rel-6 | Gwiho | SP-25 |  |
| 1455 | 13 | **Rel-6 UICC/USIM enhancements and interworking** | 1164d? | 2000-09-25 A | 2005-03-10 A | 100% | 2000-09-25 | 2005-03-10 | 1164d? |  | T3 | 43088h | 43088h | USAT1 |  |  | Rel-6 | Xavier |  |  |
| 1456 | 13.1 | **UICC API** | 777d | 2002-03-20 A | 2005-03-10 A | 100% | 2002-03-20 | 2005-03-10 | 777d |  | T3 | 15024h | 15024h | USAT1-API |  |  | Rel-6 | Xavier |  |  |
| 1457 | 13.1.1 | Java API Test specification | 59d | 2002-03-20 A | 2002-06-10 A | 100% | 2002-03-20 | 2002-06-10 | 59d | finish no earlier than 2002-09-20 | T3 | 472h | 472h |  | Microelectrónica Española | Mario Pérez | Rel-6 |  |  |  |
| 1458 | 402.1.2 | 2G/3G Java Card™ API based applet interworking | 255d | 2003-03-17 A | 2004-03-05 A | 100% | 2003-03-17 | 2004-03-05 | 255d | finish no earlier than 2004-02-19 | T3 | 2040h | 2040h | USAT1-API | Oberthur Card Systems | Stéphane Andrau | Rel-6 |  |  |  |
| 1459 | 402.1.3 | (U)SIM API for Java Card Testing | 519d | 2003-03-17 A | 2005-03-10 A | 100% | 2003-03-17 | 2005-03-10 | 519d | finish no earlier than 2005-03-10 | T3 | 4152h | 4152h |  | Axalto | Christophe Begassat (cbegassat@axalto.com) | Rel-6 | Xavier |  |  |
| 1460 | 13.1.2 | Deleted - Java API Test specification (TS 43.019 Rel-5) | 268d | 2002-05-30 A | 2003-06-09 A | 100% | 2002-05-30 | 2003-06-09 | 268d | finish no earlier than 2003-09-17 | T3 | 2144h | 2144h |  | Microelectrónica Española | Mario Pérez | Rel-6 |  |  | TP-20 |
| 1461 | 402.2 | **Rel-6 USIM toolkit enhancements** | 1160d? | 2000-09-25 A | 2005-03-04 A | 100% | 2000-09-25 | 2005-03-04 | 1160d? |  | T3 | 21848h | 21848h |  |  |  | Rel-6 | Xavier |  |  |
| 1462 | 402.2.1 | **C SIM API** | 525d | 2000-09-25 A | 2002-09-27 A | 100% | 2000-09-25 | 2002-09-27 | 525d |  | T3 | 9960h | 9960h | USAT1-API-MULTOS |  |  | Rel-6 |  |  |  |
| 1463 | 402.2.1.1 | Specification | 525d | 2000-09-25 A | 2002-09-27 A | 100% | 2000-09-25 | 2002-09-27 | 525d | finish no earlier than 2002-09-27 | T3 | 4200h | 4200h |  | Aspects Software | Neil Livingston | Rel-6 |  |  |  |
| 1464 | 402.2.1.2 | Test specification | 195d | 2001-01-01 A | 2001-09-28 A | 100% | 2001-01-01 | 2001-09-28 | 195d | finish no earlier than 2001-09-28 | T3 | 1560h | 1560h |  | Aspects Software | Neil Livingston | Rel-6 |  |  |  |
| 1465 | 402.2.2 | USIM application toolkit Conformance Test Specification for Mobile Equipments | 326d? | 2003-12-05 A | 2005-03-04 A | 100% | 2003-12-05 | 2005-03-04 | 326d? | start no earlier than 2003-12-05 | T3 | 2608h | 2608h |  | Gemplus | Eric.laffont@gemplus.com | Rel-6 |  |  |  |
| 1466 | 403 | **Packet Switched Streaming Services Rel-6** | 798d? | 2002-11-18 A | 2005-12-07 A | 100% | 2002-11-18 | 2005-12-07 | 798d? |  | S4 | 11579.4h | 11579.4h | PSSrel6 | Ericsson | olle.franceschi@ericsson.com | Rel-6 | Paolo |  |  |
| 1467 | 403.1 | Stage 1 | 86d? | 2002-11-18 A | 2003-03-17 A | 100% | 2002-11-18 | 2003-03-17 | 86d? | finish no earlier than 2003-03-17 | S1 | 688h | 688h |  |  |  | Rel-6 | Alain |  |  |
| 1468 | 403.2 | Stage 3 | 779d? | 2002-12-13 A | 2005-12-07 A | 100% | 2002-12-13 | 2005-12-07 | 779d? | finish no earlier than 2005-12-07 | S4 | 6232h | 6232h | PSSrel6-Stage3 | Ericsson | olle.franceschi@ericsson.com | Rel-6 | Paolo |  |  |
| 1469 | 404 | AMR-WB extension for high audio quality | 779d | 2002-12-13 A | 2005-12-07 A | 100% | 2002-12-13 | 2005-12-07 | 779d | finish no earlier than 2005-12-07 | S4 | 6232h | 6232h | AMRWB+ | Nokia | janne.m.vainio@nokia.com | Rel-6 | Paolo |  |  |
| 1470 | 405 | Codec Enhancements for Packet Switched Conversational Multimedia Applications | 198d? | 2004-03-16 A | 2004-12-16 A | 100% | 2004-03-16 | 2004-12-16 | 198d? | finish no earlier than 2004-12-16 | S4 | 1584h | 1584h | CEPSCM | Nokia | miska.hannuksela@nokia.com | Rel-6 | Paolo |  |  |
| 1471 | 406 | 3G-324M Improvements | 198d? | 2004-03-16 A | 2004-12-16 A | 100% | 2004-03-16 | 2004-12-16 | 198d? | finish no earlier than 2004-12-16 | S4 | 1584h | 1584h | 3G-324MI | Ericsson | bo.burman@ericsson.com | Rel-6 | Paolo |  |  |
| 1472 | 407 | Single Antenna Receiver Interference Cancellation (SAIC) | 420.92d? | 2002-11-15 A | 2004-06-25 A | 100% | 2002-11-15 | 2004-06-25 | 420.92d? | finish no earlier than 2004-08-27 | GP,G1 | 3367.36h | 3367.36h | SAIC | Cingular | Marc Grant | Rel-6 | Paolo |  |  |

Notes:
- 1444: SA#28 Target 09/2005 for WLAN Charging 32.252
- 1445: SA#23 03/2004 completed / Text3: 32.250
- 1446: SA#25 09/2004 completed / Text3: 32.251
- 1447: SA#25 09/2004 completed / Text3: 32.295
- 1448: SA#26 12/2004 completed / Text3: 32.260
- 1449: SA#26: Updated WID SP-040778 was SP-030050. Target completion 06/2005. Consisting of MMS-CH, LCS-CH, WLAN-CH, POC-CH, MBMS-CH / Text3: 32.252, 32.270/1/2
- 1450: Text3: 23.125
- 1453: Text3: 29.210
- 1454: Text3: 29.209
- 1456: 8/3/2001: test spec is based on R99 core spec, so deleted from Workplan
- 1459: Text3: 31.213
- 1460: MOVED to Rel-5 WP
- 1465: Text3: 31.124
- 1467: 2nd resp SA4 / Text3: 22.233
- 1468: TR tbc by Sept. 05 / Text3: 26.233, 26.234, 26.244, 26.245, 26.246, 26.401, 26.402, 26.403, 26.404, 26.405, 26.406, 26.410, 26.411, 26.412, 26.273, 26.290, 26.304, 26.412, 26.274, 26.936
- 1469: TR tbc by Sept. 05 / Text3: 26.290, 26.304, 26.273, 26.274, 26.412, 26.936
- 1470: Completed / Text3: 26.235, 26.236
- 1471: Completed / Text3: 26.111, 26.911

| ID | WBS | Task | Type | Duration | Start | Finish | Complete | Baseline start | Baseline finish | Baseline duration | Constraint | Resources | Work | Actual work | Text1 | Text4 | Text5 | Text6 | Text8 | Text3 | Text12 |
| --- | --- | --- | --- | --- | --- | --- | --- | --- | --- | --- | --- | --- | --- | --- | --- | --- | --- | --- | --- | --- | --- |
| 1473 | 408 | **Enhancement of dialled service for CAMEL** |  | 199d | 2003-03-28 A | 2003-12-31 A | 100% | 2003-03-28 | 2003-12-31 | 199d |  | S1 | 3184h | 3184h | EDCAMEL | Samsung | Craig Bishop | Rel-6 | Alain |  |  |
| 1474 | 408.1 | Stages 2 and 3 |  | 199d | 2003-03-28 A | 2003-12-31 A | 100% | 2003-03-28 | 2003-12-31 | 199d | finish no earlier than 2003-09-19 | N4 | 1592h | 1592h |  |  |  | Rel-6 | Kimmo |  |  |
| 1475 | 409 | Bandwidth and resource savings in CS networks |  | 273d? | 2003-06-01 A | 2004-06-16 A | 100% | 2003-06-01 | 2004-06-16 | 273d? | finish no earlier than 2004-06-16 | S2 | 2184h | 2184h | BARS |  |  | Rel-6 | Maurice | 23.977 |  |
| 1476 | 410 | FS on (U)SIM Security Reuse by Peripheral Devices on Local Interfaces |  | 127d? | 2003-07-03 A | 2003-12-26 A | 100% | 2003-07-03 | 2003-12-26 | 127d? | finish no earlier than 2003-12-26 | S3 | 1016h | 1016h |  | Toshiba | Raziq Yaqub (ryaqub@tari.toshiba.com) | Rel-6 | Dionisio |  |  |
| 1477 | 411 | **Multiple TBF in A/Gb mode** |  | 736d? | 2002-04-05 A | 2005-01-28 A | 100% | 2002-04-05 | 2005-01-28 | 736d? |  | GP,G2 | 17600h | 17600h | MULTBF | Ericsson | gunnar.mildh@era.ericsson.se | Rel-6 | Paolo |  |  |
| 1478 | 411.1 | **Multiple TBF in A/Gb mode** |  | 366d? | 2002-04-05 A | 2003-08-29 A | 100% | 2002-04-05 | 2003-08-29 | 366d? |  | GP,G2 | 11712h | 11712h | MULTBF-Agbmode | Ericsson | gunnar.mildh@era.ericsson.se | Rel-6 | Paolo |  |  |
| 1479 | 411.1.1 | Multiple TBF Concept paper |  | 366d? | 2002-04-05 A | 2003-08-29 A | 100% | 2002-04-05 | 2003-08-29 | 366d? | finish no earlier than 2003-08-29 | GP,G2 | 2928h | 2928h |  |  |  | Rel-6 | Paolo |  |  |
| 1480 | 411.1.2 | Multiple TBF Stage 2 (43.064) CRs |  | 366d? | 2002-04-05 A | 2003-08-29 A | 100% | 2002-04-05 | 2003-08-29 | 366d? | finish no earlier than 2003-08-29 | GP,G2 | 2928h | 2928h |  |  |  | Rel-6 | Paolo |  |  |
| 1481 | 411.1.3 | Multiple TBF Stage 3 (44.060) CRs |  | 366d? | 2002-04-05 A | 2003-08-29 A | 100% | 2002-04-05 | 2003-08-29 | 366d? | finish no earlier than 2003-08-29 | GP,G2 | 2928h | 2928h |  |  |  | Rel-6 | Paolo |  |  |
| 1482 | 411.2 | Deleted at TGS # 27 - Multiple TBF in A/Gb mode – MS testing | milestone | 0d? | 2005-01-28 A | 2005-01-28 A | 100% | 2005-01-28 | 2005-01-28 | 0d? | start no earlier than 2005-01-28 | G3new |  |  | MULTBF-Testing | Ericsson | gunnar.mildh@era.ericsson.se | Rel-6 | Paolo |  | GP-23 |
| 1483 | 412 | **Alignment between the test-regimes for GERAN capable MS** |  | 526d? | 2003-08-29 A | 2005-09-02 A | 100% | 2003-08-29 | 2005-09-02 | 526d? |  | G3new | 4208h | 4208h | ALTERE | Ericsson | Toubassi | Rel-6 | Ingbert |  |  |
| 1484 | 412.1 | Determine the controversial test cases in the different test regimes and align them with 3GPP GERAN test specifications. Such test cases to be added to TS 51.010. |  | 526d? | 2003-08-29 A | 2005-09-02 A | 100% | 2003-08-29 | 2005-09-02 | 526d? | finish no earlier than 2005-09-02 | G3new | 4208h | 4208h | ALTERE-TC |  |  | Rel-6 | Ingbert |  |  |
| 1485 | 413 | Addition of U-TDOA in the CS domain |  | 111d? | 2003-11-21 A | 2004-04-23 A | 100% | 2003-11-21 | 2004-04-23 | 111d? | finish no earlier than 2004-04-23 | GP | 888h | 888h | UTDOACS | TruePosition | Bob Gross, Rhys Robinson (rlgross@trueposition.com) | Rel-6 | Paolo |  |  |
| 1486 | 414 | Addition of U-TDOA in the PS domain |  | 361d? | 2003-06-27 A | 2004-11-12 A | 100% | 2003-06-27 | 2004-11-12 | 361d? | finish no earlier than 2004-11-12 | GP | 2888h | 2888h | UTDOAPS | TruePosition | Bob Gross, Rhys Robinson (rlgross@trueposition.com) | Rel-6 | Paolo |  |  |
| 1487 | 415 | **Downlink Advanced Receiver Performance** |  | 466d? | 2003-11-21 A | 2005-09-02 A | 100% | 2003-11-21 | 2005-09-02 | 466d? |  | GP | 19160h | 19160h | DARP | Nokia | tommy.bysted@nokia.com | Rel-6 | Paolo |  |  |
| 1488 | 415.1 | DARP test scenarios |  | 201d? | 2003-11-21 A | 2004-08-27 A | 100% | 2003-11-21 | 2004-08-27 | 201d? | finish no earlier than 2004-08-27 | GP | 1608h | 1608h | DARP-TS | Nokia | tommy.bysted@nokia.com | Rel-6 | Paolo |  |  |
| 1489 | 415.2 | **DARP for GMSK modulated voice services** |  | 201d? | 2004-02-06 A | 2004-11-12 A | 100% | 2004-02-06 | 2004-11-12 | 201d? |  | GP | 4824h | 4824h | DARP-GMSK | Nokia | tommy.bysted@nokia.com | Rel-6 | Paolo |  |  |
| 1490 | 415.2.1 | Performance requirements in 45.005 |  | 201d? | 2004-02-06 A | 2004-11-12 A | 100% | 2004-02-06 | 2004-11-12 | 201d? | finish no earlier than 2004-11-12 | GP | 1608h | 1608h | DARP-GMSK-Perf |  |  | Rel-6 | Paolo |  |  |
| 1491 | 415.2.2 | Radio subsystem link control in 45.008 |  | 201d? | 2004-02-06 A | 2004-11-12 A | 100% | 2004-02-06 | 2004-11-12 | 201d? | finish no earlier than 2004-11-12 | GP | 1608h | 1608h | DARP-GMSK-LC |  |  | Rel-6 | Paolo |  |  |
| 1492 | 415.3 | **DARP for GPRS and EGPRS MCS1-MCS4** |  | 201d? | 2004-02-06 A | 2004-11-12 A | 100% | 2004-02-06 | 2004-11-12 | 201d? |  | GP | 4824h | 4824h | DARP-GPRSE | Nokia | tommy.bysted@nokia.com | Rel-6 | Paolo |  |  |
| 1493 | 415.3.1 | Performance requirements in 45.005 |  | 201d? | 2004-02-06 A | 2004-11-12 A | 100% | 2004-02-06 | 2004-11-12 | 201d? | finish no earlier than 2004-11-12 | GP | 1608h | 1608h | DARP-GPRSE-Perf |  |  | Rel-6 | Paolo |  |  |
| 1494 | 415.3.2 | Radio subsystem link control in 45.008 |  | 201d? | 2004-02-06 A | 2004-11-12 A | 100% | 2004-02-06 | 2004-11-12 | 201d? | finish no earlier than 2004-11-12 | GP | 1608h | 1608h | DARP-GPRSE-LC |  |  | Rel-6 | Paolo |  |  |
| 1495 | 415.4 | DARP Capability signalling |  | 256d? | 2003-11-21 A | 2004-11-12 A | 100% | 2003-11-21 | 2004-11-12 | 256d? | finish no earlier than 2004-11-12 | GP | 2048h | 2048h | DARP-CAPSIG | Nokia | tommy.bysted@nokia.com | Rel-6 | Paolo |  |  |
| 1496 | 415.5 | GERAN MS Conformance test for DARP |  | 266d? | 2004-08-27 A | 2005-09-02 A | 100% | 2004-08-27 | 2005-09-02 | 266d? | finish no earlier than 2005-06-24 | G3new | 2128h | 2128h | ARP-ConfTest | Nokia | tommy.bysted@nokia.com | Rel-6 | Ingbert |  |  |

Notes:
- 1476: Approved TSG#20
- 1482: DELETE
- 1484: Completed
- 1485: Completed, except for potential LMU performance specs
- 1496: Started

| ID | WBS | Task | Type | Duration | Start | Finish | Complete | Baseline start | Baseline finish | Baseline duration | Constraint | Resources | Work | Actual work | Text1 | Text4 | Text5 | Text6 | Text8 | Text12 | Text3 | Text10 |
| --- | --- | --- | --- | --- | --- | --- | --- | --- | --- | --- | --- | --- | --- | --- | --- | --- | --- | --- | --- | --- | --- | --- |
| 1497 | 416 | **Reduction of PS service interruption in Dual Transfer Mode** |  | 416d? | 2003-11-21 A | 2005-06-24 A | 100% | 2003-11-21 | 2005-06-24 | 416d? |  | G2 | 8360h | 8360h | PSintDTM | Siemens | toby.proctor@roke.co.uk | Rel-6 | Gert |  |  |  |
| 1498 | 416.1 | Use case and requirement definition |  | 111d? | 2003-11-21 A | 2004-04-23 A | 100% | 2003-11-21 | 2004-04-23 | 111d? | finish no earlier than 2004-04-23 | G2 | 888h | 888h | PSintDTM-Req | Siemens | toby.proctor@roke.co.uk | Rel-6 | Gert |  |  |  |
| 1499 | 416.2 | Performance Study of Current Procedures |  | 111d? | 2003-11-21 A | 2004-04-23 A | 100% | 2003-11-21 | 2004-04-23 | 111d? | start no earlier than 2003-11-21 | G2 | 888h | 888h | PSintDTM-Perf | Siemens | toby.proctor@roke.co.uk | Rel-6 | Gert |  |  |  |
| 1500 | 416.3 | Reduction of service interruption times and packet loss during Dual Transfer Mode and mobility procedures |  | 146d? | 2004-04-23 A | 2004-11-12 A | 100% | 2004-04-23 | 2004-11-12 | 146d? | finish no earlier than 2004-11-12 | G2 | 1168h | 1168h | PSintDTM-Reduct | Siemens | toby.proctor@roke.co.uk | Rel-6 | Gert |  |  |  |
| 1501 | 416.4 | Deleted - MS Conformance testing |  | 261d? | 2004-06-25 A | 2005-06-24 A | 100% | 2004-06-25 | 2005-06-24 | 261d? | finish no earlier than 2005-06-24 | G3new | 2088h | 2088h | PSintDTM-ConfMS |  |  | Rel-6 | Ingbert | GP-25 |  |  |
| 1502 | 416.5 | Deleted - BTS Conformance testing | milestone | 0d? | 2005-06-24 A | 2005-06-24 A | 100% | 2005-06-24 | 2005-06-24 | 0d? | finish no earlier than 2005-06-24 | G3new |  |  | PSintDTM-ConfBTS |  |  | Rel-6 | Ingbert | GP-25 |  |  |
| 1503 | 417 | CAMEL prepay interworking with SCUDIF |  | 206d | 2003-12-08 A | 2004-10-05 A | 100% | 2003-12-08 | 2004-10-05 | 206d |  | N4 | 1648h | 1648h | SCCAMEL |  |  | Rel-6 | Kimmo |  |  |  |
| 1504 | 418 | **Circuit Switched Video and Voice Service Improvements** |  | 430d? | 2004-01-12 A | 2005-09-02 A | 100% | 2004-01-12 | 2005-09-02 | 430d? |  | S1 | 6536h | 6536h | CS_VSS | Vodafone | John Watson | Rel-6 | Alain |  | 23.801 |  |
| 1505 | 418.1 | Stage 1 - Requirements |  | 199d | 2004-01-12 A | 2004-10-14 A | 100% | 2004-01-12 | 2004-10-14 | 199d | finish no earlier than 2004-10-14 | S1 | 1592h | 1592h | CS_VSS | Vodafone | John Watson | Rel-6 | Alain |  |  |  |
| 1506 | 418.2 | Stage 2 Study on architecture alternatives |  | 155d? | 2004-01-12 A | 2004-08-13 A | 100% | 2004-01-12 | 2004-08-13 | 155d? | finish no earlier than 2004-08-13 | S2 | 1240h | 1240h | CS_VSS |  |  | Rel-6 | Maurice |  |  | SP-24 |
| 1507 | 418.3 | Stage 2 description on Redial |  | 164d? | 2004-05-03 A | 2004-12-16 A | 100% | 2004-05-03 | 2004-12-16 | 164d? | finish no earlier than 2004-12-16 | S2 | 1312h | 1312h | CS_VSS |  |  | Rel-6 | Maurice |  | 23.903 | SP-24 |
| 1508 | 418.4 | Switching between voice and video call - Redial solution |  | 120d? | 2005-01-03 A | 2005-06-17 A | 100% | 2005-01-03 | 2005-06-17 | 120d? | start no earlier than 2005-01-03 | C1 | 960h | 960h | CS_VSS |  |  | Rel-6 | Frederic |  |  |  |
| 1509 | 418.5 | Deleted - GERAN2 Part | milestone | 0d | 2005-09-02 A | 2005-09-02 A | 100% | 2005-09-02 | 2005-09-02 | 0d | start no earlier than 2005-09-02 | G2 |  |  | CS_VSS |  |  | Rel-6 | Gert | GP-26 |  |  |
| 1510 | 418.6 | Deleted - CN3 Part | milestone | 0d? | 2004-10-14 A | 2004-10-14 A | 100% | 2004-10-14 | 2004-10-14 | 0d? | start no earlier than 2004-10-14 | N3 |  |  | CS_VSS |  |  | Rel-6 | Gwiho | TP-26 |  |  |
| 1511 | 419 | Network Domain Security; MAP application layer security (NDS/MAPsec) |  | 127d? | 2004-07-06 A | 2004-12-29 A | 100% | 2004-07-06 | 2004-12-29 | 127d? | finish no earlier than 2003-12-26 | S3 | 1016h | 1016h | MAPSEC | Vodafone | Peter.Howard@vodafone.com | Rel-6 | Dionisio |  |  |  |
| 1512 | 420 | FS on Security for early IMS |  | 127d? | 2004-10-01 A | 2005-03-28 A | 100% | 2004-10-01 | 2005-03-28 | 127d? | finish no earlier than 2003-12-26 | S3 | 1016h | 1016h | SEC-IMS | Vodafone | Peter.Howard@vodafone.com | Rel-6 | Dionisio |  |  |  |
| 1513 | 421 | Reorganisation of CS Data Specifications |  | 14d? | 2004-11-19 A | 2004-12-08 A | 100% | 2004-11-19 | 2004-12-08 | 14d? | finish no earlier than 2004-12-24 | N3 | 112h | 112h | CS Data | Siemens | Thomas.Belling@nsn.com | Rel-6 | Gwiho |  |  |  |
| 1514 | 422 | **Generic Access to A/Gb Interface (GAAI)** |  | 411d? | 2004-06-25 A | 2006-01-20 A | 100% | 2004-06-25 | 2006-01-20 | 411d? |  | GP | 9160h | 9160h | GAAI | Motorola |  | Rel-6 | Paolo |  |  |  |
| 1515 | 422.1 | FS on GAAI |  | 46d? | 2004-06-25 A | 2004-08-27 A | 100% | 2004-06-25 | 2004-08-27 | 46d? | finish no earlier than 2004-08-27 | GP | 368h | 368h | GAAG | Motorola |  | Rel-6 | Paolo |  | 43.901 |  |
| 1516 | 422.2 | GAAI – Stage 2 |  | 161d? | 2004-08-27 A | 2005-04-08 A | 100% | 2004-08-27 | 2005-04-08 | 161d? | finish no earlier than 2005-04-08 | GP | 1288h | 1288h | GAAI-Stage2 | Ericsson | jari.vikberg@ericsson.com | Rel-6 | Paolo |  | 43.318 |  |
| 1517 | 422.3 | GAAI – Stage 3 |  | 161d? | 2004-08-27 A | 2005-04-08 A | 100% | 2004-08-27 | 2005-04-08 | 161d? | finish no earlier than 2005-04-08 | GP | 1288h | 1288h | GAAI-Stage3 |  |  | Rel-6 | Paolo |  | 44.318 |  |
| 1518 | 422.4 | MS Conformance Test for GAAI |  | 366d? | 2004-08-27 A | 2006-01-20 A | 100% | 2004-08-27 | 2006-01-20 | 366d? | finish no earlier than 2006-01-20 | GP | 2928h | 2928h | GAAI-CT |  |  | Rel-6 | Ingbert |  |  |  |
| 1519 | 423 | **Support of PS Handover for GERAN A/Gb mode** |  | 473d? | 2003-11-03 A | 2005-08-24 A | 100% | 2003-11-03 | 2005-08-24 | 473d? |  | GP,G2 | 11352h | 11352h | SPSHAGB | Ericsson | gunnar.hedby@ericsson.com | Rel-6 | Paolo |  |  |  |
| 1520 | 423.1 | Stage 2 |  | 473d? | 2003-11-03 A | 2005-08-24 A | 100% | 2003-11-03 | 2005-08-24 | 473d? | finish no earlier than 2005-09-02 | GP,G2 | 3784h | 3784h | SPSHAGB-Stage2 | Ericsson | gunnar.hedby@ericsson.com | Rel-6 | Paolo |  | 43.129 |  |
| 1521 | 423.2 | PS handover |  | 473d? | 2003-11-03 A | 2005-08-24 A | 100% | 2003-11-03 | 2005-08-24 | 473d? | finish no earlier than 2005-09-02 | GP,G2 | 3784h | 3784h | SPSHAGB-PSHO | Ericsson | gunnar.hedby@ericsson.com | Rel-6 | Paolo |  |  |  |
| 1522 | 423.3 | Definition of radio resource management functionality |  | 473d? | 2003-11-03 A | 2005-08-24 A | 100% | 2003-11-03 | 2005-08-24 | 473d? | finish no earlier than 2005-09-02 | GP,G2 | 3784h | 3784h | SPSHAGB-RRM | Ericsson | gunnar.hedby@ericsson.com | Rel-6 | Paolo |  |  |  |

Notes:
- 1501: Marked as stopped 12/2008
- 1511: Approved TSG#24. Marked as closed 12/2008 (was marked 20% complete)
- 1512: Approved TSG#24. TR 33.978 Approved at TSG SA #27
- 1513: Created at TSG#27 as 100 % complete
- 1515: Feasibility Study
- 1516: Completed
- 1517: Completed
- 1518: Marked as closed 12/2008 (was marked 90% complete)
- 1519: Replaces SCSAGB- Originally Started Nov 2003 as GP-030443
- 1520: Replaces SCSAGB-Stage2
- 1521: Replaces SCSAGB-PSH
- 1522: Replaces SCSAGB-RRM

| ID | WBS | Task | Type | Duration | Start | Finish | Complete | Baseline start | Baseline finish | Baseline duration | Total slack | Constraint | Resources | Work | Actual work | Text1 | Text6 | Text3 | Text8 | Text4 | Text5 | Text12 |
| --- | --- | --- | --- | --- | --- | --- | --- | --- | --- | --- | --- | --- | --- | --- | --- | --- | --- | --- | --- | --- | --- | --- |
| 1523 | 424 | **small Technical Enhancements and Improvements for Rel-6** |  | 503d? | 2006-06-02 A | 2008-05-06 A | 100% | 2006-06-02 | 2008-05-06 | 503d? |  |  | All | 4024h | 4024h | TEI6 | Rel-6 |  |  |  |  |  |
| 1524 | 424.1 | Small Technical Enhancements and Improvements for Rel-6 Conformance Testing |  | 503d? | 2006-06-02 A | 2008-05-06 A | 100% | 2006-06-02 | 2008-05-06 | 503d? |  | start no earlier than 2006-06-02 | R5 | 4024h | 4024h | TEI6_Test | Rel-6 | 34.108,34.121-1/2,34.122,34.123-1/2/3 | Ingbert |  |  |  |
| 1525 | 425 | Deleted - Study of Feature Interactions Requirements | milestone | 0d? | 2004-10-01 A | 2004-10-01 A | 100% | 2004-10-01 | 2004-10-01 | 0d? |  | finish no earlier than 2004-10-01 | S1 |  |  | FINTER | Rel-6 |  | Alain |  |  |  |
| 1526 | 426 | Deleted (moved to Rel7) - Enhancements of VGCS in public networks for communication of public authority officials |  | 7d? | 2005-08-24 A | 2005-09-02 A | 100% | 2005-08-24 | 2005-09-02 | 7d? |  | start no earlier than 2005-08-24 | GP,G2 | 56h | 56h | EVGCS | Rel-6 | 44.018, 44.068, 48.008 | Paolo | Siemens | kenneth.isaacs@roke.co.uk | GP-26 |
| 1527 | 427 | **Deleted - Support of Conversational Services in A/Gb mode via the PS domain** |  | 64d? | 2003-11-21 A | 2004-02-19 A | 100% | 2003-11-21 | 2004-02-19 | 64d? |  |  | GP | 512h | 512h | SCSAGB | Rel-6 |  | Paolo | Ericsson | David Bladsjö (david.bladsjo@ericsson.com) |  |
| 1528 | 427.1 | Delete - Creation of a TR | milestone | 0d? | 2003-11-21 A | 2003-11-21 A | 100% | 2003-11-21 | 2003-11-21 | 0d? |  | start no earlier than 2003-11-21 | GP |  |  | SCSAGB-TR | Rel-6 |  | Paolo | Ericsson | David Bladsjö (david.bladsjo@ericsson.com) | GP-17 |
| 1529 | 427.2 | Delete - Stage 2 | milestone | 0d? | 2003-11-21 A | 2003-11-21 A | 100% | 2003-11-21 | 2003-11-21 | 0d? |  | finish no earlier than 2003-11-21 | GP |  |  | SCSAGB-Stage2 | Rel-6 |  | Paolo | Ericsson | David Bladsjö (david.bladsjo@ericsson.com) | GP-17 |
| 1530 | 427.3 | Delete - Radio Channel Support | milestone | 0d? | 2003-11-21 A | 2003-11-21 A | 100% | 2003-11-21 | 2003-11-21 | 0d? |  | finish no earlier than 2003-11-21 | GP |  |  | SCSAGB-RCS | Rel-6 |  | Paolo | Ericsson | David Bladsjö (david.bladsjo@ericsson.com) | GP-17 |
| 1531 | 427.4 | Delete - Definition of radio resource management functionality | milestone | 0d? | 2003-11-21 A | 2003-11-21 A | 100% | 2003-11-21 | 2003-11-21 | 0d? |  | finish no earlier than 2003-11-21 | GP,G2 |  |  | SCSAGB-RRM | Rel-6 |  | Paolo | Ericsson | David Bladsjö (david.bladsjo@ericsson.com) | GP-17 |
| 1532 | 427.5 | Delete, replaced by 50561 - PS Handover |  | 64d | 2003-11-21 A | 2004-02-19 A | 100% | 2003-11-21 | 2004-02-19 | 64d |  | start no earlier than 2003-11-21 | GP,GP, N1 | 512h | 512h | SCSAGB-PSH | Rel-6 |  | Paolo | Ericsson | David Bladsjö (david.bladsjo@ericsson.com) | GP-18 |
| 1533 | 427.6 | Delete - Modifications to FLO | milestone | 0d? | 2003-11-21 A | 2003-11-21 A | 100% | 2003-11-21 | 2003-11-21 | 0d? |  | finish no earlier than 2003-11-21 | GP,G2 |  |  | SCSAGB-FLO | Rel-6 |  | Paolo | Ericsson | David Bladsjö (david.bladsjo@ericsson.com) | RP-29 |
| 1534 | 428 | Deleted - Rel-6 Evolutions of the transport in the UTRAN | milestone | 0d | 2003-12-31 A | 2003-12-31 A | 100% | 2003-12-31 | 2003-12-31 | 0d |  | start no earlier than 2003-12-31 | RP |  |  | ETRAN | Rel-6 |  | Stefania | Alcatel | Francois Courau | RP-22 |
| 1535 | 429 | Release 5 Features |  | 1d? | 2000-01-03 | 2000-01-03 |  | 2000-01-03 | 2000-01-03 | 1d? | 2791d |  | CP,GP, RP,SP,TP | 8h |  |  | Rel-5 |  |  |  |  |  |
| 1536 | 75 | IP transport in the UTRAN |  | 445d | 2000-07-17 A | 2002-03-29 A | 100% | 2000-07-17 | 2002-03-29 | 445d |  | finish no earlier than 2002-03-29 | R3 | 3560h | 3560h | ETRAN-IPtrans | Rel-5 |  | Juha | Alcatel | Nicolas Drevon |  |
| 1537 | 76 | FS on Usage of SUA |  | 205d | 2001-03-12 A | 2001-12-21 A | 100% | 2001-03-12 | 2001-12-21 | 205d |  | finish no earlier than 2001-12-21 | N4 | 1640h | 1640h | SS7IP | Rel-5 |  | Kimmo |  |  |  |
| 1538 | 77 | **High Speed Downlink Packet Access** |  | 570d | 2001-04-02 A | 2003-06-06 A | 100% | 2001-04-02 | 2003-06-06 | 570d |  |  | R2 | 15272h | 15272h | HSDPA | Rel-5 |  | Joern | Motorola | Ravi Kuchibhotla |  |
| 1539 | 77.1 | Physical Layer |  | 257d | 2001-04-05 A | 2002-03-29 A | 100% | 2001-04-05 | 2002-03-29 | 257d |  | finish no earlier than 2002-03-29 | R1 | 2056h | 2056h | HSDPA-Phys |  |  | Patrick | Motorola | Amitava Ghosh |  |
| 1540 | 77.2 | Layer 2 and 3 aspects |  | 257d | 2001-04-05 A | 2002-03-29 A | 100% | 2001-04-05 | 2002-03-29 | 257d |  | finish no earlier than 2002-03-29 | R2 | 2056h | 2056h | HSDPA-L23 |  |  | Joern | Motorola | Ravi Kuchibhotla |  |
| 1541 | 77.3 | Iub/Iur protocol aspects |  | 260d | 2001-04-02 A | 2002-03-29 A | 100% | 2001-04-02 | 2002-03-29 | 260d |  | finish no earlier than 2002-03-29 | R3 | 2080h | 2080h | HSDPA-IubIur |  |  | Juha | Motorola | Mike Diesen |  |
| 1542 | 77.4 | RF Radio Transmission/ Reception, System Performance Requirements and Conformance Testing |  | 565d | 2001-04-09 A | 2003-06-06 A | 100% | 2001-04-09 | 2003-06-06 | 565d |  | finish no earlier than 2003-06-06 | R4 | 4520h | 4520h | HSDPA-RF |  |  | Stefania | Motorola | Howard Benn |  |
| 1543 | 78 | **Rel-5 Improvements of Radio Interface** |  | 535d | 2000-08-14 A | 2002-08-30 A | 100% | 2000-08-14 | 2002-08-30 | 535d |  |  | RP | 30376h | 30376h | RInImp | NA |  | Stefania |  |  |  |
| 1544 | 78.1 | **Base station classification** |  | 480d | 2000-08-14 A | 2002-06-14 A | 100% | 2000-08-14 | 2002-06-14 | 480d |  |  | R4 | 9208h | 9208h | RInImp-BSClass | Rel-5 |  | Stefania | Nokia | antti.toskala@nokia.com |  |
| 1545 | 78.1.1 | TDD Base station classification |  | 410d | 2000-08-14 A | 2002-03-08 A | 100% | 2000-08-14 | 2002-03-08 | 410d |  | finish no earlier than 2002-03-08 | R4 | 3280h | 3280h | RInImp-BSClass-TDD |  |  | Stefania | Nokia | antti.toskala@nokia.com |  |
| 1546 | 78.1.2 | Base Station Classification for 1.28 Mcps TDD option |  | 261d | 2001-06-15 A | 2002-06-14 A | 100% | 2001-06-15 | 2002-06-14 | 261d |  | finish no earlier than 2002-06-14 | R4 | 2088h | 2088h | RInImp-BSClass-LCRTDD |  |  | Stefania | Siemens | Meik.Kottkamp@siemens.com |  |
| 1547 | 78.2 | Enhancement on the DSCH hard split mode |  | 271d | 2001-03-16 A | 2002-03-29 A | 100% | 2001-03-16 | 2002-03-29 | 271d |  | finish no earlier than 2002-03-29 | R1 | 2168h | 2168h | RInImp-DSCHhsp | Rel-5 |  | Patrick | Samsung | Jaeyoel KIM |  |
| 1548 | 78.3 | Hybrid ARQ II/III |  | 355d | 2000-08-21 A | 2001-12-28 A | 100% | 2000-08-21 | 2001-12-28 | 355d |  | finish no earlier than 2001-12-28 | R2 | 2840h | 2840h | RInImp-HARQ | Rel-5 |  | Joern | Siemens | A. Sitte | RP-14 |
| 1549 | 78.4 | FS on USTS |  | 355d | 2000-08-14 A | 2001-12-21 A | 100% | 2000-08-14 | 2001-12-21 | 355d |  | finish no earlier than 2001-12-21 | R1 | 2840h | 2840h | RInImp-USTS | Rel-5 |  | Patrick | SK Telecom | D. Kim |  |
| 1550 | 78.5 | FS on UE antenna efficency test method performance requirements |  | 255d | 2000-09-25 A | 2001-09-14 A | 100% | 2000-09-25 | 2001-09-14 | 255d |  | finish no earlier than 2001-09-14 | R4 | 2040h | 2040h | RInImp-UEAnTM | Rel-5 |  | Stefania | Allgon | O. Edvardsson |  |
| 1551 | 78.6 | FS on the re-introduction of the downlink SIR measurement |  | 200d | 2001-03-12 A | 2001-12-14 A | 100% | 2001-03-12 | 2001-12-14 | 200d |  | finish no earlier than 2001-12-14 | R4 | 1600h | 1600h | RInImp-SIR | Rel-5 |  | Stefania | Ericsson | Torgny.Palenius@ericsson.com |  |
| 1552 | 78.7 | FS on mitigating the effect of CPICH interference at the UE |  | 255d | 2001-03-19 A | 2002-03-08 A | 100% | 2001-03-19 | 2002-03-08 | 255d |  | finish no earlier than 2002-03-08 | R4 | 2040h | 2040h | RInImp-CPICH_Intf | Rel-5 |  | Stefania | Intel | shimon.moshavi@INTEL.COM |  |

Notes:
- 1523: "Joker" WI, to be used for a Rel 6 CR not related to any feature and with very limited impact on the system. Moved in from Stoyan/Testing WP
- 1524: "Joker" WI, to be used for small modifications applicable to Rel 4 conformance testing
- 1525: SP-23 - To be abandoned?
- 1526: Started
- 1529: Started
- 1530: Not started
- 1531: Not started
- 1532: Started
- 1533: Not started
- 1534: Generic feature
- 1537: update WID / 30.11.2001: To CN #14 for approval
- 1540: 30 November: Completion date shifted to March 2002
- 1548: Stopped at RP#14; work on this task was performed as part of High Speed Downlink Packet Access feature

| ID | WBS | Task | Duration | Start | Finish | Complete | Baseline start | Baseline finish | Baseline duration | Constraint | Resources | Work | Actual work | Text8 | Text12 | Text6 | Text1 | Text4 | Text5 | Text3 |
| --- | --- | --- | --- | --- | --- | --- | --- | --- | --- | --- | --- | --- | --- | --- | --- | --- | --- | --- | --- | --- |
| 1553 | 78.8 | **Deleted - Conformance Test Spec. improvements in Radio Interface** | 140d | 2002-02-18 A | 2002-08-30 A | 100% | 2002-02-18 | 2002-08-30 | 140d |  | T1 | 3360h | 3360h | Ingbert | TP-22 |  |  |  |  |  |
| 1554 | 78.8.1 | Deleted - Testing improvement of inter-frequency and inter-system measurement | 140d | 2002-02-18 A | 2002-08-30 A | 100% | 2002-02-18 | 2002-08-30 | 140d | finish no earlier than 2002-08-30 | T1 | 1120h | 1120h | Ingbert | TP-22 | Rel-5 |  |  |  |  |
| 1555 | 78.8.2 | Deleted - Testing Hybrid ARQ II/III | 140d | 2002-02-18 A | 2002-08-30 A | 100% | 2002-02-18 | 2002-08-30 | 140d | finish no earlier than 2002-08-30 | T1 | 1120h | 1120h | Ingbert | TP-22 | Rel-5 |  |  |  |  |
| 1556 | 79 | **Rel-5 RAN improvements** | 772d? | 2001-03-16 A | 2004-03-01 A | 100% | 2001-03-16 | 2004-03-01 | 772d? |  | RP | 39984h | 39984h | Stefania |  | NA | RANimp |  |  |  |
| 1557 | 79.1 | **RRM optimization for Iur and Iub** | 318d | 2001-03-16 A | 2002-06-04 A | 100% | 2001-03-16 | 2002-06-04 | 318d |  | R3 | 8904h | 8904h | Juha |  | Rel-5 | RANimp-RRMopt | Ericsson | Gert-Jan.van.Lieshout@eln.ericsson.se |  |
| 1558 | 79.1.1 | Iur common transport channel efficiency optimisation | 271d | 2001-03-16 A | 2002-03-29 A | 100% | 2001-03-16 | 2002-03-29 | 271d | finish no earlier than 2002-03-29 | R3 | 2168h | 2168h | Juha |  |  | RANimp-RRMopt-ctc | Ericsson | Shahrokh Amirijoo |  |
| 1559 | 79.1.2 | Iur neighbouring cell reporting efficiency optimisation | 271d | 2001-03-16 A | 2002-03-29 A | 100% | 2001-03-16 | 2002-03-29 | 271d | finish no earlier than 2002-03-29 | R3 | 2168h | 2168h | Juha |  |  | RANimp-RRMopt-ncr | Ericsson | Shahrokh Amirijoo |  |
| 1560 | 79.1.3 | FS Introduction of direct transport bearers between SRNC and Node-B | 253d | 2001-06-15 A | 2002-06-04 A | 100% | 2001-06-15 | 2002-06-04 | 253d | finish no earlier than 2002-06-28 | R3 | 2024h | 2024h | Juha |  |  | RAN-imp-RRMopt-DTB | Ericsson | Risto Sepponen |  |
| 1561 | 79.2 | RL Timing Adjustment | 271d | 2001-03-16 A | 2002-03-29 A | 100% | 2001-03-16 | 2002-03-29 | 271d | finish no earlier than 2002-03-29 | R3 | 2168h | 2168h | Juha |  | Rel-5 | RANimp-RLTA | Ericsson | Elena Voltolina |  |
| 1562 | 79.3 | Separation of resource reservation and radio link activation | 271d | 2001-03-16 A | 2002-03-29 A | 100% | 2001-03-16 | 2002-03-29 | 271d | finish no earlier than 2002-03-29 | R3 | 2168h | 2168h | Juha |  | Rel-5 | RANimp-SepRR | Ericsson | Gert-Jan.van.Lieshout@eln.ericsson.se |  |
| 1563 | 79.4 | FS SRNS Relocation Procedure Enhancement | 318d | 2001-06-15 A | 2002-09-03 A | 100% | 2001-06-15 | 2002-09-03 | 318d | finish no earlier than 2002-09-06 | R3 | 2544h | 2544h | Juha |  | Rel-5 | RANimp-SRNS | Nokia | Olivier Guyot |  |
| 1564 | 79.5 | FS Improvement of Radio Resource Management across RNS and RNS/PSS | 201d | 2001-03-16 A | 2001-12-21 A | 100% | 2001-03-16 | 2001-12-21 | 201d | finish no earlier than 2001-12-21 | R3 | 1608h | 1608h | Juha |  | Rel-5 | RANimp-ImpRRM | Nokia | antti.toskala@nokia.com |  |
| 1565 | 79.6 | Re-arrangements of Iub transport bearers | 271d | 2001-03-16 A | 2002-03-29 A | 100% | 2001-03-16 | 2002-03-29 | 271d | finish no earlier than 2002-03-29 | R3 | 2168h | 2168h | Juha |  | Rel-5 | RANimp-TTPS | Nokia | antti.toskala@nokia.com |  |
| 1566 | 79.7 | RAB support enhancement for Rel-5 | 325d | 2001-04-02 A | 2002-06-28 A | 100% | 2001-04-02 | 2002-06-28 | 325d | finish no earlier than 2002-06-28 | R2 | 2600h | 2600h | Joern |  | Rel-5 | RANimp-RABSE5 | Nokia | Juha Mikola |  |
| 1567 | 79.8 | Beamforming requirements for UE | 61d | 2001-09-21 A | 2001-12-14 A | 100% | 2001-09-21 | 2001-12-14 | 61d | finish no earlier than 2001-12-14 | R1 | 488h | 488h | Patrick |  | Rel-5 | RANimp-BFR-UE | Nokia | Jussi Kähtävä (juha.mikola@nokia.com) |  |
| 1568 | 79.9 | Support of Site Selection Diversity Transmission in UTRAN | 123d | 2001-12-14 A | 2002-06-04 A | 100% | 2001-12-14 | 2002-06-04 | 123d | finish no earlier than 2002-06-04 | R1 | 984h | 984h | Patrick |  | Rel-5 | RANimp-SSDT | NEC |  |  |
| 1569 | 79.10 | Node B Synchronisation for 1.28 Mcps TDD | 271d | 2001-03-16 A | 2002-03-29 A | 100% | 2001-03-16 | 2002-03-29 | 271d | finish no earlier than 2002-03-29 | R1 | 2168h | 2168h | Patrick |  | Rel-5 | RANimp-NBSLCR | CATT | Jinling HU |  |
| 1570 | 79.12 | **Deleted - Conformance Test Aspects - RAN Improvements** | 565d? | 2002-01-01 A | 2004-03-01 A | 100% | 2002-01-01 | 2004-03-01 | 565d? |  | T1 | 8008h | 8008h | Ingbert |  | Rel-5 |  |  |  | 0% |
| 1571 | 79.12.1 | Deleted - Testing Radio access bearer support enhancments | 175d | 2002-01-01 A | 2002-09-02 A | 100% | 2002-01-01 | 2002-09-02 | 175d | finish no earlier than 2002-09-02 | T1 | 1400h | 1400h | Ingbert | TP-22 |  |  |  |  |  |
| 1572 | 434.11.2 | Deleted - General changes to TS34.121 and TS34.122 corresponding to release 5 | 261d? | 2003-03-03 A | 2004-03-01 A | 100% | 2003-03-03 | 2004-03-01 | 261d? | finish no earlier than 2004-03-01 | T1 | 2088h | 2088h | Ingbert |  | Rel-5 | RANimp-test |  |  | 34.108, 34.121, 34.122 |
| 1573 | 80 | UTRAN Sharing in Connected Mode | 197d | 2001-12-03 A | 2002-09-03 A | 100% | 2001-12-03 | 2002-09-03 | 197d | finish no earlier than 2002-09-06 | R3 | 1576h | 1576h | Juha |  | Rel-5 | NETSHARE | Ericsson | Martin Israelsson |  |
| 1574 | 81 | **Provisioning of IP-based multimedia services** | 1089d | 2000-01-03 A | 2004-03-03 A | 100% | 2000-01-03 | 2004-03-03 | 1089d |  | S1,S2,S5 | 187156h | 187156h | Alain |  | Rel-5 | IMS | Openwave | Mark Cataldo |  |
| 1575 | 81.1 | **Call control and roaming to support IMS in UMTS** | 641d | 2000-01-03 A | 2002-06-14 A | 100% | 2000-01-03 | 2002-06-14 | 641d |  | S2 | 82528h | 82528h | Maurice |  | Rel-5 | IMS-CCR | Lucent | Liz Daniel |  |
| 1576 | 81.1.1 | Stage 1 | 215d | 2000-02-21 A | 2000-12-15 A | 100% | 2000-02-21 | 2000-12-15 | 215d | finish no earlier than 2000-09-21 | S1 | 1720h | 1720h | Alain |  |  | IMS-CCR | Motorola | Mark Cataldo | 22.228 |
| 1577 | 81.1.2 | Stage 2 (Architecture and Main flows) | 246d | 2000-04-14 A | 2001-03-23 A | 100% | 2000-04-14 | 2001-03-23 | 246d | finish no earlier than 2001-03-23 | S2 | 1968h | 1968h | Maurice |  |  | IMS-CCR | Lucent | Liz Daniel | 23.228 |
| 1578 | 81.1.3 | Impact on MM/CC/SM | 400d | 2000-08-28 A | 2002-03-08 A | 100% | 2000-08-28 | 2002-03-08 | 400d | finish no earlier than 2002-03-08 | N1 | 3200h | 3200h | Frederic |  |  | IMS-CCR-IWMM | Lucent | Keith Drage (drage@alcatel-lucent.com) |  |

Notes:
- 1553: Marked as stopped 12/2008
- 1554: start/finish dates set...Marked as stopped 12/2008
- 1555: start/finish dates set...Marked as stopped 12/2008
- 1560: FS was closed and introduction of WI not agreed at RAN #16
- 1564: FS was closed and WI was introduced at RAN #14
- 1566: RFC 3095 context relocation
- 1568: RP-020356
- 1570: Marked as stopped 12/2008
- 1571: duration set to 6 months (was 0)...Marked as stopped 12/2008
- 1572: Marked as stopped 12/2008
- 1573: Formerly 'Shared Network support in connected mode', renamed at RAN #16.
- 1574: S1 WI proposed S1-000290 / TR22.976, WI Rapporteur, Mark Cataldo, Motorola
- 1576: Issues include e.g.: Roaming requirements, Requirements on supplementary services, Interworking requirements
- 1577: Issues include e.g.: Mobile IP, RAB selection principles, Optimized VoIP bearer mechanisms, SIP multimedia protocol
- 1578: Per 26/2-02: This is understood to be the PCO & TFT CRs which CN1 provides to TSGN #15 for approval. If this is correct understanding, then the task is 100 % complete.

| ID | WBS | Task | Duration | Start | Finish | Complete | Baseline start | Baseline finish | Baseline duration | Constraint | Resources | Work | Actual work | Text1 | Text3 | Text4 | Text5 | Text8 | Text6 |
| --- | --- | --- | --- | --- | --- | --- | --- | --- | --- | --- | --- | --- | --- | --- | --- | --- | --- | --- | --- |
| 1579 | 81.1.4 | **SIP Call Control protocol for the IMS** | 641d | 2000-01-03 A | 2002-06-14 A | 100% | 2000-01-03 | 2002-06-14 | 641d |  | N1 | 70808h | 70808h | IMS-CCR | 24.228, 24.229, 23.218 | Lucent | Keith Drage (drage@alcatel-lucent.com) | Frederic |  |
| 1580 | 81.1.4.1 | IMS signalling flows | 385d | 2000-10-02 A | 2002-03-22 A | 100% | 2000-10-02 | 2002-03-22 | 385d | finish no earlier than 2002-03-22 | N1 | 3080h | 3080h | IMS-CCR | 24.228 |  |  | Frederic |  |
| 1581 | 81.1.4.2 | IMS stage 3 | 385d | 2000-10-02 A | 2002-03-22 A | 100% | 2000-10-02 | 2002-03-22 | 385d | finish no earlier than 2002-03-22 | N1 | 3080h | 3080h | IMS-CCR | 24.229 |  |  | Frederic |  |
| 1582 | 81.1.4.3 | IMS Session Handling; stage 2 | 385d | 2000-10-02 A | 2002-03-22 A | 100% | 2000-10-02 | 2002-03-22 | 385d | finish no earlier than 2002-03-22 | N1 | 3080h | 3080h | IMS-CCR | 23.218 |  |  | Frederic |  |
| 1583 | 81.1.4.4 | **Main IETF dependencies** | 636d | 2000-01-03 A | 2002-06-07 A | 100% | 2000-01-03 | 2002-06-07 | 636d |  | NP | 45400h | 45400h |  |  |  |  | Kimmo |  |
| 1584 | 81.1.4.4.1 | IETF: RFC 3261 (Session Initiation Protocol) | 346d | 2000-11-24 A | 2002-03-22 A | 100% | 2000-11-24 | 2002-03-22 | 346d | finish no earlier than 2002-03-22 | N1 | 2768h | 2768h |  |  |  |  | Frederic |  |
| 1585 | 81.1.4.4.2 | IETF: RFC 3262 (Reliability of provisional responses) | 346d | 2000-11-24 A | 2002-03-22 A | 100% | 2000-11-24 | 2002-03-22 | 346d | finish no earlier than 2002-03-22 | N1 | 2768h | 2768h |  |  |  |  | Frederic |  |
| 1586 | 81.1.4.4.3 | IETF: RFC 3312 (Without COMET)(Integration of resource management and SIP) | 382d | 2000-11-24 A | 2002-05-13 A | 100% | 2000-11-24 | 2002-05-13 | 382d | finish no earlier than 2002-05-13 | N1 | 3056h | 3056h |  |  |  |  | Frederic |  |
| 1587 | 81.1.4.4.4 | IETF: RFC 3323 (SIP extensions for caller identity and privacy) | 382d | 2000-11-24 A | 2002-05-13 A | 100% | 2000-11-24 | 2002-05-13 | 382d | finish no earlier than 2002-05-13 | N1 | 3056h | 3056h |  |  |  |  | Frederic |  |
| 1588 | 81.1.4.4.5 | IETF: RFC 3313 (SIP extensions for media authorization) | 382d | 2000-11-24 A | 2002-05-13 A | 100% | 2000-11-24 | 2002-05-13 | 382d | finish no earlier than 2002-05-13 | N1 | 3056h | 3056h |  |  |  |  | Frederic |  |
| 1589 | 81.1.4.4.6 | IETF: RFC 3265 (specific event notification) | 346d | 2000-11-24 A | 2002-03-22 A | 100% | 2000-11-24 | 2002-03-22 | 346d | finish no earlier than 2002-03-22 | N1 | 2768h | 2768h |  |  |  |  | Frederic |  |
| 1590 | 81.1.4.4.7 | IETF: RFC editor Queue (refer method) | 401d | 2000-11-24 A | 2002-06-07 A | 100% | 2000-11-24 | 2002-06-07 | 401d | finish no earlier than 2002-06-07 | N1 | 3208h | 3208h |  |  |  |  | Frederic |  |
| 1591 | 81.1.4.4.8 | IETF: RFC editor Queue (DHCP options for SIP servers) | 382d | 2000-11-24 A | 2002-05-13 A | 100% | 2000-11-24 | 2002-05-13 | 382d | finish no earlier than 2002-05-13 | N1 | 3056h | 3056h |  |  |  |  | Frederic |  |
| 1592 | 81.1.4.4.10 | IETF: RFC 3267 (AMR and AMR WB RTP and SDP) | 346d | 2000-11-24 A | 2002-03-22 A | 100% | 2000-11-24 | 2002-03-22 | 346d | finish no earlier than 2002-03-22 | N1 | 2768h | 2768h |  |  |  |  | Frederic |  |
| 1593 | 81.1.4.4.11 | IETF: RFC 3266 (IPv6 support within SDP) | 581d | 2000-01-03 A | 2002-03-22 A | 100% | 2000-01-03 | 2002-03-22 | 581d | finish no earlier than 2002-03-22 | N1 | 4640h | 4640h |  |  |  |  | Frederic |  |
| 1594 | 81.1.4.4.12 | IETF: RFC 3311 (The Update method) | 382d | 2000-11-24 A | 2002-05-13 A | 100% | 2000-11-24 | 2002-05-13 | 382d | finish no earlier than 2002-05-13 | N1 | 3056h | 3056h |  |  |  |  | Frederic |  |
| 1595 | 81.1.4.4.13 | IETF: RFC 3324 (Network Asserted Identity) | 382d | 2000-11-24 A | 2002-05-13 A | 100% | 2000-11-24 | 2002-05-13 | 382d | finish no earlier than 2002-05-13 | N1 | 3056h | 3056h |  |  |  |  | Frederic |  |
| 1596 | 81.1.4.4.14 | IETF: RFC editor Queue (Various 3GPP Private Extensions) | 382d | 2000-11-24 A | 2002-05-13 A | 100% | 2000-11-24 | 2002-05-13 | 382d | finish no earlier than 2002-05-13 | N1 | 3056h | 3056h |  |  |  |  | Frederic |  |
| 1597 | 81.1.4.5 | **Addressing** | 380d | 2000-10-09 A | 2002-03-22 A | 100% | 2000-10-09 | 2002-03-22 | 380d |  | S2 | 7744h | 7744h |  |  |  |  | Maurice |  |
| 1598 | 81.1.4.5.1 | Architectural issues | 235d | 2000-10-09 A | 2001-08-31 A | 100% | 2000-10-09 | 2001-08-31 | 235d | finish no earlier than 2001-03-16 | S2 | 1880h | 1880h |  |  |  |  | Maurice |  |
| 1599 | 81.1.4.5.2 | Impact on HSS | 353d | 2000-11-15 A | 2002-03-22 A | 100% | 2000-11-15 | 2002-03-22 | 353d | finish no earlier than 2002-03-22 | N4 | 2824h | 2824h |  |  |  |  | Kimmo |  |
| 1600 | 81.1.4.6 | **Service Examples (Work stopped)** | 304d | 2001-04-17 A | 2002-06-14 A | 100% | 2001-04-17 | 2002-06-14 | 304d |  | S1 | 4864h | 4864h | IMS-Sex | 22.928 | Motorola | Mark Cataldo | Alain |  |
| 1601 | 81.1.4.6.1 | IMS Framework Report (work stopped) | 304d | 2001-04-17 A | 2002-06-14 A | 100% | 2001-04-17 | 2002-06-14 | 304d | finish no earlier than 2002-06-14 | S1 | 2432h | 2432h | IMS-FrWk | 22.941 | SBC | Randolph Wohlert (rwohlert@tri.sbc.com) | Alain |  |
| 1602 | 81.2 | **Access Security for IMS** | 190d | 2001-10-08 A | 2002-06-28 A | 100% | 2001-10-08 | 2002-06-28 | 190d |  | S3 | 4120h | 4120h | IMS-ASEC |  | Ericsson | krister.boman@emw.ericsson.se | Dionisio | Rel-5 |
| 1603 | 81.2.2 | IMS impacts on UICC (ISIM application) | 185d | 2001-10-08 A | 2002-06-21 A | 100% | 2001-10-08 | 2002-06-21 | 185d | finish no earlier than 2002-06-21 | T3 | 1480h | 1480h |  |  | Vodafone | Jeremy Norris |  |  |
| 1604 | 81.2.3 | SIP extensions for Integrity protection | 140d | 2001-12-17 A | 2002-06-28 A | 100% | 2001-12-17 | 2002-06-28 | 140d | finish no earlier than 2002-06-28 | N1 | 1120h | 1120h |  |  |  |  | Frederic |  |
| 1605 | 81.3 | Security Aspects of Requirement for Network Configuration Independence | 130d | 2001-07-02 A | 2001-12-28 A | 100% | 2001-07-02 | 2001-12-28 | 130d | finish no earlier than 2001-12-28 | S3 | 1040h | 1040h | SEC1-NCI |  | AT&T Wireless | hugh.shieh@attws.com | Dionisio | Rel-5 |
| 1606 | 81.4 | Lawful interception | 410d | 2000-09-04 A | 2002-03-29 A | 100% | 2000-09-04 | 2002-03-29 | 410d | finish no earlier than 2002-03-29 | S3 | 3280h | 3280h | IMS-LI |  | Reg TP | berthold.wilhelm@regtp.de | Dionisio | Rel-5 |
| 1607 | 81.5 | Charging and OAM&P for IMS | 383d | 2000-12-25 A | 2002-06-12 A | 100% | 2000-12-25 | 2002-06-12 | 383d | finish no earlier than 2002-06-12 | S5 | 3064h | 3064h | IMS-OAM | 32-series | VoiceStream, Motorola |  | Dionisio | Rel-5 |

Notes:
- 1579: TSGN_10 approved the change:CN1 - SA2 SIP joint meeting spotted one more place for improvement: work tasks with ID 1998 and 1278 are actually subtasks under of single CN1 WT. One WI has been approved for the CN1 WT with title "SIP Call Control protocol...
- 1580: TS 24.228...
- 1581: TS 24.229...
- 1582: TS 23.218...
- 1599: 17th May, KK: This is cover by 29.228 & 29228. Work complete.
- 1602: TS33.203 will be presented for info at SA#14 and is scheduled for approval at SA#15. Dependencies on IETF exist. Approved SA#15
- 1604: Per 26/2-02: CN1 is not aware of any requirements and is not doing anything on this task.
- 1605: Incorporated into IMS access security TS (33.203) which will be presented for info at SA#14 and is scheduled for approval at SA#15.Editors notes removed SA#16&17
- 1606: Rel-5 33.106 and 33.107 approved at SA#12.Revised WID including new Rel-5 specification (33.108) scheduled for approval at SA#14. 33.108 approved SA#16. CR at SA#17

| ID | WBS | Task | Duration | Start | Finish | Complete | Baseline start | Baseline finish | Baseline duration | Constraint | Resources | Work | Actual work | Text1 | Text3 | Text4 | Text5 | Text6 | Text8 |
| --- | --- | --- | --- | --- | --- | --- | --- | --- | --- | --- | --- | --- | --- | --- | --- | --- | --- | --- | --- |
| 1608 | 81.6 | **Multimedia codecs and protocols for conversational PS services** | 568d | 2000-07-26 A | 2002-09-27 A | 100% | 2000-07-26 | 2002-09-27 | 568d |  | S4 | 15640h | 15640h | IMS-CODEC | 26.235, 26.236 | Toshiba, Nokia | B. Aronson (Toshiba), pasi.s.ojala@nokia.com | Rel-5 | Paolo |
| 1609 | 81.6.1 | Codecs | 427d | 2000-07-26 A | 2002-03-14 A | 100% | 2000-07-26 | 2002-03-14 | 427d | finish no earlier than 2001-03-21 | S4 | 3416h | 3416h |  | 26.235, 26.236 |  |  |  | Paolo |
| 1610 | 81.6.2 | Transport protocols | 1d | 2002-03-12 A | 2002-03-12 A | 100% | 2002-03-12 | 2002-03-12 | 1d | finish no earlier than 2002-03-12 | S4 | 8h | 8h | IMS-CODEC | 26.236 | Nokia | P. Ojala | Rel-5 | Paolo |
| 1611 | 81.6.4 | recommendation for QoS parameter values for various media types | 195d | 2001-12-31 A | 2002-09-27 A | 100% | 2001-12-31 | 2002-09-27 | 195d | finish no earlier than 2002-09-27 | S4 | 1560h | 1560h |  |  |  |  |  | Paolo |
| 1612 | 81.6.5 | IETF: RFC 3310 (HTTP Digest Authentication using AKA) | 382d | 2000-11-24 A | 2002-05-13 A | 100% | 2000-11-24 | 2002-05-13 | 382d | finish no earlier than 2002-05-13 | N1 | 3056h | 3056h |  |  |  |  |  | Frederic |
| 1613 | 81.6.6 | IETF: RFC 3329 (Security mechanism agreement for SIP connections) | 382d | 2000-11-24 A | 2002-05-13 A | 100% | 2000-11-24 | 2002-05-13 | 382d | finish no earlier than 2002-05-13 | N1 | 3056h | 3056h |  |  |  |  |  | Frederic |
| 1614 | 81.7 | **SIP message compression** | 185d | 2001-09-24 A | 2002-06-07 A | 100% | 2001-09-24 | 2002-06-07 | 185d |  | S2 | 3128h | 3128h |  |  |  |  | Rel-5 | Maurice |
| 1615 | 81.7.1 | Stage 2 | 25d | 2001-09-24 A | 2001-10-26 A | 100% | 2001-09-24 | 2001-10-26 | 25d | finish no earlier than 2001-10-26 | S2 | 200h | 200h |  |  |  |  |  | Maurice |
| 1616 | 81.7.2 | Compression signalling | 181d | 2001-09-28 A | 2002-06-07 A | 100% | 2001-09-28 | 2002-06-07 | 181d | finish no earlier than 2002-06-07 | N1 | 1448h | 1448h |  |  |  |  |  | Frederic |
| 1617 | 81.8 | **Stage 3 description of IMS interfaces** | 383d | 2001-03-14 A | 2002-08-30 A | 100% | 2001-03-14 | 2002-08-30 | 383d |  | NP | 29531.6h | 29531.6h |  |  |  |  | Rel-5 | Kimmo |
| 1618 | 81.8.1 | Cx interface (HSS to CSCF) | 135.95d | 2001-03-14 A | 2002-06-07 A | 100% | 2001-03-14 | 2002-06-07 | 135.95d | finish no earlier than 2002-06-07 | N4 | 1087.58h | 1087.58h |  |  |  |  |  | Kimmo |
| 1619 | 81.8.2 | Mp interface (MRFC - MRFP) enhancements | 258d | 2001-03-14 A | 2002-03-08 A | 100% | 2001-03-14 | 2002-03-08 | 258d | finish no earlier than 2002-06-07 | N4 | 2064h | 2064h |  |  |  |  |  | Kimmo |
| 1620 | 81.8.3 | Mw interface (CSCF to P-CSCF) | 323d | 2001-03-14 A | 2002-06-07 A | 100% | 2001-03-14 | 2002-06-07 | 323d | finish no earlier than 2002-06-07 | N1 | 2584h | 2584h |  |  |  |  |  | Frederic |
| 1621 | 81.8.4 | Mr interface (CSCF to MRF) | 273d | 2001-03-14 A | 2002-03-29 A | 100% | 2001-03-14 | 2002-03-29 | 273d | finish no earlier than 2002-03-29 | N1 | 2184h | 2184h |  |  |  |  |  | Frederic |
| 1622 | 81.8.5 | Dx interface (I-CSCF to SLF) | 323d | 2001-03-14 A | 2002-06-07 A | 100% | 2001-03-14 | 2002-06-07 | 323d | finish no earlier than 2002-06-07 | N4 | 2584h | 2584h |  |  |  |  |  | Kimmo |
| 1623 | 81.8.6 | Go interface (GGSN to PCF) | 323d | 2001-03-14 A | 2002-06-07 A | 100% | 2001-03-14 | 2002-06-07 | 323d | finish no earlier than 2002-06-07 | N3 | 2584h | 2584h |  |  |  |  |  | Gwiho |
| 1624 | 81.8.7 | ISC (IMS Service Control) Interface | 323d | 2001-03-14 A | 2002-06-07 A | 100% | 2001-03-14 | 2002-06-07 | 323d | finish no earlier than 2002-06-07 | N1 | 2584h | 2584h |  |  |  |  |  | Frederic |
| 1625 | 81.8.8 | Sh interface (HSS to AS) | 82d | 2002-02-14 A | 2002-06-07 A | 100% | 2002-02-14 | 2002-06-07 | 82d | finish no earlier than 2002-06-07 | N4 | 656h | 656h |  |  |  |  |  | Kimmo |
| 1626 | 81.8.9 | Si interface (HSS to IM-SSF) | 162.5d | 2002-01-16 A | 2002-08-30 A | 100% | 2002-01-16 | 2002-08-30 | 162.5d | finish no earlier than 2002-06-07 | N4 | 1300h | 1300h |  |  |  |  |  | Kimmo |
| 1627 | 81.8.10 | Gm interface (UE to CSCF) | 323d | 2001-03-14 A | 2002-06-07 A | 100% | 2001-03-14 | 2002-06-07 | 323d | finish no earlier than 2002-06-07 | N1 | 2584h | 2584h |  |  |  |  |  | Frederic |
| 1628 | 81.8.11 | Mi interface (CSCF to BGCF) | 323d | 2001-03-14 A | 2002-06-07 A | 100% | 2001-03-14 | 2002-06-07 | 323d | finish no earlier than 2002-06-07 | N1 | 2584h | 2584h |  |  |  |  |  | Frederic |
| 1629 | 81.8.12 | Mj interface (BGCF to MGCF) | 323d | 2001-03-14 A | 2002-06-07 A | 100% | 2001-03-14 | 2002-06-07 | 323d | finish no earlier than 2002-06-07 | N1 | 2584h | 2584h |  |  |  |  |  | Frederic |
| 1630 | 81.8.13 | Mk interface (BGCF to BGCF) | 323d | 2001-03-14 A | 2002-06-07 A | 100% | 2001-03-14 | 2002-06-07 | 323d | finish no earlier than 2002-06-07 | N1 | 2584h | 2584h |  |  |  |  |  | Frederic |
| 1631 | 81.9 | Support of VHE/OSA by entities and protocols of the IMS (e.g. CSCF) | 186d | 2001-09-21 A | 2002-06-07 A | 100% | 2001-09-21 | 2002-06-07 | 186d | finish no earlier than 2002-06-07 | N5 | 1488h | 1488h | IMS-ONOSA | 29.198, 29.998 | Ericsson | Ard.Jan.Moerdijk@eln.ericsson.se | Rel-5 | Kimmo |

Notes:
- 1618: DAB 12/12/01 to 75% / CN4 14/02/02 to 79% / 17th May work complete. 3GPP TSs 29.228 and 29.229 will be sent for proval in CN#16
- 1619: [DAB 08-03-02] - No work required in CN4
- 1622: CN4#11 30/11/01: No inputs received in CN4 / 14/02/02 Completed(introduced in 29.228)
- 1623: [DAB - 23/05/03] - 100 % complete
- 1625: CN4#11 30/11/01: No inputs received in CN4 / CN4#12bis 14/02/02: WID approved / 17th May 100% complete. 3GPP TS 29.329 will be sent for approval in CN#16
- 1626: SA16: Part of Rel5 only if completed in September 02. Marked as closed 12/2008 (was marked 72% complete)

| ID | WBS | Task | Duration | Start | Finish | Predecessors | Complete | Baseline start | Baseline finish | Baseline duration | Constraint | Resources | Work | Actual work | Text1 | Text4 | Text5 | Text6 | Text8 | Text12 | Text3 |
| --- | --- | --- | --- | --- | --- | --- | --- | --- | --- | --- | --- | --- | --- | --- | --- | --- | --- | --- | --- | --- | --- |
| 1632 | 81.10 | **CAMEL control of IMS services** | 365d | 2001-04-16 A | 2002-09-06 A |  | 100% | 2001-04-16 | 2002-09-06 | 365d |  | N2 | 9952h | 9952h | IMS-CAMEL | Lucent | Angelica Remoquillo | Rel-5 | Kimmo |  |  |
| 1633 | 81.10.1 | Stage2 work 'general' | 365d | 2001-04-16 A | 2002-09-06 A |  | 100% | 2001-04-16 | 2002-09-06 | 365d | finish no earlier than 2002-09-06 | N2 | 2920h | 2920h |  |  |  |  | Kimmo |  |  |
| 1634 | 81.10.2 | Stage3 work 'CAP' | 175d | 2002-01-07 A | 2002-09-06 A |  | 100% | 2002-01-07 | 2002-09-06 | 175d | finish no earlier than 2002-09-06 | N2 | 1400h | 1400h |  |  |  |  | Kimmo |  |  |
| 1635 | 81.10.3 | Stage2 work 'Si interface' | 175d | 2002-01-07 A | 2002-09-06 A |  | 100% | 2002-01-07 | 2002-09-06 | 175d | finish no earlier than 2002-09-06 | N2 | 1400h | 1400h |  |  |  |  | Kimmo |  |  |
| 1636 | 81.10.4 | Stage3 work 'Si interface' | 82d | 2002-02-14 A | 2002-06-07 A |  | 100% | 2002-02-14 | 2002-06-07 | 82d | finish no earlier than 2002-06-07 | N4 | 656h | 656h |  |  |  |  | Kimmo |  |  |
| 1637 | 81.10.5 | Deleted - SDM issues for CAMEL control of IMS | 82d | 2002-02-14 A | 2002-06-07 A |  | 100% | 2002-02-14 | 2002-06-07 | 82d | finish no earlier than 2002-06-07 | N4 | 656h | 656h |  |  |  |  | Kimmo | NP-21 |  |
| 1638 | 81.11 | Pre-pay/real-time charging in IMS | 196d | 2001-06-15 A | 2002-03-15 A |  | 100% | 2001-06-15 | 2002-03-15 | 196d | finish no earlier than 2002-03-15 | S1 | 1568h | 1568h |  |  |  | Rel-5 | Alain |  |  |
| 1639 | 81.12 | **Charging** | 289d | 2001-08-06 A | 2002-09-12 A |  | 100% | 2001-08-06 | 2002-09-12 | 289d |  | S2,S5 | 6632h | 6632h | OAM-CH | T-Mobile | karl-heinz.nenner@t-mobile.de | Rel-5 | Dionisio |  | 32.2xy |
| 1640 | 81.12.1 | Charging Implications of IMS architecture | 75d | 2001-08-06 A | 2001-11-16 A |  | 100% | 2001-08-06 | 2001-11-16 | 75d | finish no earlier than 2001-11-16 | S2 | 600h | 600h |  |  |  | Rel-5 | Maurice |  |  |
| 1641 | 81.12.2 | Charging management for IMS (off-line & on-line) | 214d | 2001-11-19 A | 2002-09-12 A | 1640 | 100% | 2001-11-19 | 2002-09-12 | 214d | finish no earlier than 2002-09-12 | S5 | 1712h | 1712h | OAM-CH |  |  | Rel-5 | Dionisio |  |  |
| 1642 | 86.1.6.10 | Billing, accounting and call detail record aspects | 251d | 2001-09-27 A | 2002-09-12 A |  | 100% | 2001-09-27 | 2002-09-12 | 251d | finish no earlier than 2002-09-12 | S5 | 2008h | 2008h | OAM-CH | T-Mobile | Karl-Heinz.Nenner@T-MOBILE.DE | Rel-5 | Dionisio |  | 32.2xy |
| 1643 | 81.13 | **Other IETF depencies** | 401d | 2000-11-24 A | 2002-06-07 A |  | 100% | 2000-11-24 | 2002-06-07 | 401d |  | NP | 9624h | 9624h |  |  |  | Rel-5 |  |  |  |
| 1644 | 81.13.1 | IETF: draft-ietf-aaa-diameter - should be CN4 | 401d | 2000-11-24 A | 2002-06-07 A |  | 100% | 2000-11-24 | 2002-06-07 | 401d | finish no earlier than 2002-06-07 | NP | 3208h | 3208h |  |  |  |  |  |  |  |
| 1645 | 81.13.2 | IETF: draft-johansson-aaa-diameter-mm-app - should be CN4 | 401d | 2000-11-24 A | 2002-06-07 A |  | 100% | 2000-11-24 | 2002-06-07 | 401d | finish no earlier than 2002-06-07 | NP | 3208h | 3208h |  |  |  |  |  |  |  |
| 1646 | 81.15 | Conformance Test Aspects - Provisioning of IMS | 205d | 2002-03-18 A | 2002-12-27 A |  | 100% | 2002-03-18 | 2002-12-27 | 205d | finish no earlier than 2002-12-27 | T1 | 1640h | 1640h | IMS-TEST |  |  |  | Ingbert |  |  |
| 1647 | 81.16 | Testing of support for IMS - prose | 270d | 2002-09-18 A | 2003-09-30 A |  | 100% | 2002-09-18 | 2003-09-30 | 270d | finish no earlier than 2003-09-30 | T1 | 2160h | 2160h |  | Anritsu | dan.fox@eu.anritsu.com | Rel-5 | Ingbert |  | 34.108, 34.123 |
| 1648 | 81.17 | Testing of support for IMS - TTCN | 381d | 2002-09-18 A | 2004-03-03 A |  | 100% | 2002-09-18 | 2004-03-03 | 381d | finish no earlier than 2004-03-03 | T1 | 3048h | 3048h |  | Anritsu | dan.fox@eu.anritsu.com | Rel-5 | Ingbert |  | 34.108, 34.123 |
| 1649 | 82 | **Extended Transparent End-to-End PS Streaming Service** | 313d? | 2002-01-03 A | 2003-03-17 A |  | 100% | 2002-01-03 | 2003-03-17 | 313d? |  | S4 | 6224h | 6224h | PSS-E | Ericsson | olle.franceschi@ericsson.com | Rel-5 | Paolo |  | 26.233, 26.234 |
| 1650 | 82.1 | **Stage 1** | 86d? | 2002-11-18 A | 2003-03-17 A |  | 100% | 2002-11-18 | 2003-03-17 | 86d? |  | S1 | 1376h | 1376h |  | Vodafone | stephen.wolak@vodafone.com |  | Alain |  | 22.233 |
| 1651 | 437.1.1 | Interaction with other services | 86d? | 2002-11-18 A | 2003-03-17 A |  | 100% | 2002-11-18 | 2003-03-17 | 86d? | finish no earlier than 2003-03-17 | S1 | 688h | 688h |  | Vodafone | stephen.wolak@vodafone.com |  | Alain |  | 22.233 |
| 1652 | 82.2 | Stage 2 (version Rel5 of TS 26.234) | 51d | 2002-01-03 A | 2002-03-14 A |  | 100% | 2002-01-03 | 2002-03-14 | 51d | finish no earlier than 2002-03-26 | S4 | 408h | 408h |  |  |  |  | Paolo |  | 26.234 |
| 1653 | 82.3 | RTP usage model | 242d | 2002-01-03 A | 2002-12-06 A |  | 100% | 2002-01-03 | 2002-12-06 | 242d | finish no earlier than 2002-12-06 | S4 | 1936h | 1936h |  |  |  |  | Paolo |  | 26.937 |
| 1654 | 83 | **Rel-5 OSA enhancements** | 955d | 1999-04-27 A | 2002-12-20 A |  | 100% | 1999-04-27 | 2002-12-20 | 955d |  | S1 | 62480h | 62480h | OSA1 | Siemens | Joerg Swetina (joerg.swetina@nw.neclab.eu) | Rel-5 | Alain |  | 22.127, 23.127, 29.198-x, 29.998-x |
| 1655 | 83.1 | General Stage 2 for Rel5 | 194d | 2001-09-11 A | 2002-06-07 A |  | 100% | 2001-09-11 | 2002-06-07 | 194d |  | S2 | 1232h | 1232h |  |  |  | Rel-5 | Maurice |  |  |

Notes:
- 1632: SA16: Part of Rel5 only if Si completed in September 02
- 1633: DAB 12.12.01 split into cn4 and cn2 parts
- 1634: DAB 12.12.01 split into cn4 and cn2 parts
- 1635: DAB 12.12.01 split into cn4 and cn2 parts
- 1636: [DAB 08-03-02] - UID 12004 is MASTER of UID 14998 / 17 May need to be recearch possible impact on 23.008 & 23.016, changes to 29.002 are done.
- 1637: [DAB 08-03-02] - No activity on this in CN4. Marked as stopped 12/2008
- 1638: Marked as closed 12/2008 (was marked 60% complete)
- 1639: Changed Rapp email
- 1643: Was introduced at SA#13 by Ileana Leuca (exact position in the WP and related WG have to be defined)
- 1644: Marked as closed 12/2008 (was marked 90% complete)
- 1645: Marked as closed 12/2008 (was marked 50% complete)
- 1646: The task is a building block, individual work items are being considered but are constrained by lack of supporting companies. Marked as stopped 12/2008
- 1647: Marked as stopped 12/2008
- 1648: Marked as stopped 12/2008
- 1650: 2nd resp SA4
- 1651: 2nd resp SA4. Marked as closed 12/2008 (was marked 65% complete)
- 1652: 2nd resp SA2
- 1653: Marked as closed 12/2008 (was marked 90% complete)
- 1655: Marked as closed 12/2008 (was marked 47% complete)

| ID | WBS | Task | Duration | Start | Finish | Predecessors | Complete | Baseline start | Baseline finish | Baseline duration | Constraint | Resources | Work | Actual work | Text1 | Text6 | Text8 | Text3 | Text4 | Text5 |
| --- | --- | --- | --- | --- | --- | --- | --- | --- | --- | --- | --- | --- | --- | --- | --- | --- | --- | --- | --- | --- |
| 1656 | 83.2 | **OSA APIs for Multimedia Call Control** | 499d | 2000-07-11 A | 2002-06-07 A |  | 100% | 2000-07-11 | 2002-06-07 | 499d |  | S2 | 5960h | 5960h | OSA1-CSCF | Rel-5 | Maurice |  |  |  |
| 1657 | 83.2.1 | Stage 1 | 438d | 2000-07-11 A | 2002-03-14 A |  | 100% | 2000-07-11 | 2002-03-14 | 438d | finish no earlier than 2002-03-14 | S1 | 3504h | 3504h |  |  | Alain | 22.127 | Siemens | Manfred.leitgeb@siemens.at |
| 1658 | 83.2.2 | (Multimedia) Call Control - Stages 2 and 3 | 194d | 2001-09-11 A | 2002-06-07 A |  | 100% | 2001-09-11 | 2002-06-07 | 194d | finish no earlier than 2002-06-07 | N5 | 1552h | 1552h |  |  | Kimmo | 29.198-04 |  |  |
| 1659 | 83.3 | Generic user interaction - Stage 3 | 194d | 2001-09-11 A | 2002-06-07 A |  | 100% | 2001-09-11 | 2002-06-07 | 194d | finish no earlier than 2002-06-07 | N5 | 1552h | 1552h |  | Rel-5 | Kimmo | 29.198-05 |  |  |
| 1660 | 83.4 | Charging - Stage 3 | 194d | 2001-09-11 A | 2002-06-07 A |  | 100% | 2001-09-11 | 2002-06-07 | 194d | finish no earlier than 2002-06-07 | N5 | 1552h | 1552h |  | Rel-5 | Kimmo | 29.198-12 |  |  |
| 1661 | 83.5 | Call Control Service Mapping; Multiparty Call Control SIP - Stage 3 | 194d | 2001-09-11 A | 2002-06-07 A |  | 100% | 2001-09-11 | 2002-06-07 | 194d | finish no earlier than 2002-06-07 | N5 | 1552h | 1552h |  | Rel-5 | Kimmo | 29.998-04-4 |  |  |
| 1662 | 83.6 | WSDL APIs for SOAP/HTTP - Stage 3 | 455d | 2000-09-11 A | 2002-06-07 A |  | 100% | 2000-09-11 | 2002-06-07 | 455d | finish no earlier than 2002-06-07 | N5 | 3640h | 3640h |  | Rel-5 | Kimmo | 29.198, 29.998 |  |  |
| 1663 | 83.7 | **OSA security** | 639d | 2000-07-11 A | 2002-12-20 A |  | 100% | 2000-07-11 | 2002-12-20 | 639d |  | S3 | 15000h | 15000h | OSA1-SEC | Rel-5 | Dionisio |  | BT | colin.blanchard@bt.com |
| 1664 | 83.7.1 | Stage 1 | 349d | 2000-07-11 A | 2001-11-09 A |  | 100% | 2000-07-11 | 2001-11-09 | 349d | finish no earlier than 2001-11-09 | S1 | 2792h | 2792h |  |  | Alain | 22.127 | Siemens | Manfred.leitgeb@siemens.at |
| 1665 | 83.7.2 | Stage 3 | 430d | 2000-10-23 A | 2002-06-14 A |  | 100% | 2000-10-23 | 2002-06-14 | 430d | finish no earlier than 2002-06-14 | S3 | 3440h | 3440h |  |  | Dionisio | ??? |  |  |
| 1666 | 83.7.3 | security related SCF(s) definition | 186d | 2001-09-21 A | 2002-06-07 A |  | 100% | 2001-09-21 | 2002-06-07 | 186d | finish no earlier than 2002-06-07 | N5 | 1488h | 1488h |  |  | Kimmo | 29.198, 29.998 | Ericsson | Ard.Jan.Moerdijk@eln.ericsson.se |
| 1667 | 83.7.4 | (possibly) changes required from supporting platforms, e.g. gsmSCF, HLR | 69d | 2000-09-11 A | 2000-12-14 A |  | 100% | 2000-09-11 | 2000-12-14 | 69d | finish no earlier than 2000-12-14 | S3 | 552h | 552h |  |  | Dionisio | ??? |  |  |
| 1668 | 438.7.5 | Security (moved from Rel-6) | 202d | 2002-03-14 A | 2002-12-20 A |  | 100% | 2002-03-14 | 2002-12-20 | 202d | finish no earlier than 2002-12-20 | S3 | 1616h | 1616h |  |  | Dionisio |  |  |  |
| 1669 | 83.8 | **Interactions OSA - e-commerce** | 815d | 1999-04-27 A | 2002-06-07 A |  | 100% | 1999-04-27 | 2002-06-07 | 815d |  | S2 | 6152h | 6152h | OSA1-ECOM | Rel-5 | Maurice |  |  |  |
| 1670 | 83.8.1 | Stage 1 | 439d | 1999-04-27 A | 2000-12-28 A |  | 100% | 1999-04-27 | 2000-12-28 | 439d | finish no earlier than 2000-12-28 | S1 | 3504h | 3504h |  |  | Alain | 22.127 | Siemens | Joerg Swetina (joerg.swetina@nw.neclab.eu) |
| 1671 | 83.8.2 | Stages 2 and 3 | 186d | 2001-09-21 A | 2002-06-07 A |  | 100% | 2001-09-21 | 2002-06-07 | 186d | finish no earlier than 2002-06-07 | N5 | 1488h | 1488h |  |  | Kimmo | 29.198, 29.998 | Ericsson | Ard.Jan.Moerdijk@eln.ericsson.se |
| 1672 | 83.9 | Policy Management - Stage 3 | 194d | 2001-09-11 A | 2002-06-07 A |  | 100% | 2001-09-11 | 2002-06-07 | 194d | finish no earlier than 2002-06-07 | N5 | 1552h | 1552h |  | Rel-5 | Kimmo | 29.198-13 |  |  |
| 1673 | 83.10 | Presence and Availability Management (PAM) - Stage 3 | 194d | 2001-09-11 A | 2002-06-07 A |  | 100% | 2001-09-11 | 2002-06-07 | 194d | finish no earlier than 2002-06-07 | N5 | 1552h | 1552h |  | Rel-5 | Kimmo | 29.198-14 |  |  |
| 1674 | 83.11 | **CHECK STATUS - LCS - OSA interfaces** | 455d | 2000-09-11 A | 2002-06-07 A |  | 100% | 2000-09-11 | 2002-06-07 | 455d |  | S1 | 5656h | 5656h | OSA1-LCSI | Rel-5 | Alain |  | Siemens | Joerg Swetina (joerg.swetina@nw.neclab.eu) |
| 1675 | 83.11.1 | Stage 1 | 65d | 2000-09-11 A | 2000-12-08 A |  | 100% | 2000-09-11 | 2000-12-08 | 65d | finish no earlier than 2000-12-08 | S1 | 520h | 520h |  |  | Alain | 22.127 | Siemens | Joerg Swetina (joerg.swetina@nw.neclab.eu) |
| 1676 | 83.11.2 | Stage 2 | 1d | 2000-12-11 A | 2000-12-11 A | 1675 | 100% | 2000-12-11 | 2000-12-11 | 1d | finish no earlier than 2000-12-11 | S2 | 8h | 8h |  |  | Maurice | 23.127 | Ericsson | Christophe GOURRAUD |
| 1677 | 83.11.3 | Stage 3 | 186d | 2001-09-21 A | 2002-06-07 A | 1676 | 100% | 2001-09-21 | 2002-06-07 | 186d | finish no earlier than 2002-06-07 | N5 | 1488h | 1488h |  |  | Kimmo | 29.198, 29.998 | Ericsson | Ard.Jan.Moerdijk@eln.ericsson.se |
| 1678 | 438.12 | Access to User Profile | 145d | 2001-06-01 A | 2001-12-20 A |  | 100% | 2001-06-01 | 2001-12-20 | 145d | finish no earlier than 2001-12-20 | S1 | 1160h | 1160h | OSA2-UP | Rel-5 | Alain |  |  |  |
| 1679 | 438.13 | **Retrieval of Terminal capabilities** | 634d | 2000-07-11 A | 2002-12-13 A |  | 100% | 2000-07-11 | 2002-12-13 | 634d |  | S2 | 10808h | 10808h | OSA2-TC | Rel-5 | Maurice |  |  |  |
| 1680 | 438.13.1 | Stage 1 | 132d | 2000-07-11 A | 2001-01-10 A |  | 100% | 2000-07-11 | 2001-01-10 | 132d | finish no earlier than 2001-01-10 | S1 | 1056h | 1056h |  | Rel-5 | Alain | 22.127 | Siemens | Joerg Swetina (joerg.swetina@nw.neclab.eu) |
| 1681 | 438.13.2 | Stages 2 and 3 | 321d | 2001-09-21 A | 2002-12-13 A | 1680 | 100% | 2001-09-21 | 2002-12-13 | 321d | finish no earlier than 2002-12-13 | N5 | 2568h | 2568h |  | Rel-5 | Kimmo | 29.198, 29.998 | Ericsson | Ard.Jan.Moerdijk@eln.ericsson.se |
| 1682 | 438.13.3 | Provisionning of the terminal capabilities | 445d | 2001-04-02 A | 2002-12-13 A |  | 100% | 2001-04-02 | 2002-12-13 | 445d | finish no earlier than 2002-12-13 | T2 | 3560h | 3560h |  | Rel-5 |  | 23.057 |  |  |

Notes:
- 1656: For Rel5 even if completed by March
- 1663: CR to correct security specifications in 29.198 scheduled for approval at CN#15
- 1665: Marked as closed 12/2008 (was marked 80% complete)
- 1668: Contribution at S3#25
- 1670: Marked as closed 12/2008 (was marked 95% complete)
- 1674: az: CN#13 - changed to Rel5
- 1676: az 24/05/01: Rel4 completion 90->100%.
- 1682: According to T2 SWG1 M. Cataldo this is automatically supported by the MExE support of UAProf therefore 100% complete

| ID | WBS | Task | Duration | Start | Finish | Predecessors | Complete | Baseline start | Baseline finish | Baseline duration | Constraint | Resources | Work | Actual work | Text1 | Text4 | Text5 | Text6 | Text8 | Text3 |
| --- | --- | --- | --- | --- | --- | --- | --- | --- | --- | --- | --- | --- | --- | --- | --- | --- | --- | --- | --- | --- |
| 1683 | 84 | **CAMEL phase 4** | 625d | 2000-04-17 A | 2002-09-06 A |  | 100% | 2000-04-17 | 2002-09-06 | 625d |  | S1 | 41104h | 41104h | CAMEL4 | Nokia | keijo.palviainen@nokia.com | Rel-5 | Alain |  |
| 1684 | 84.1 | Service requirements | 565d | 2000-04-17 A | 2002-06-14 A |  | 100% | 2000-04-17 | 2002-06-14 | 565d | finish no earlier than 2002-06-14 | S1 | 4520h | 4520h |  |  |  |  | Alain |  |
| 1685 | 84.2 | Call Party Handling | 500d | 2000-07-10 A | 2002-06-07 A |  | 100% | 2000-07-10 | 2002-06-07 | 500d | finish no earlier than 2002-06-07 | N2 | 4000h | 4000h | CAMEL4-CPH |  |  |  | Kimmo |  |
| 1686 | 84.3 | Mid call procedure for MO and MT calls | 495d | 2000-07-17 A | 2002-06-07 A |  | 100% | 2000-07-17 | 2002-06-07 | 495d | finish no earlier than 2002-06-07 | N2 | 3960h | 3960h | CAMEL4-MCP |  |  |  | Kimmo |  |
| 1687 | 84.4 | Interactions with Optimal Routing | 430d | 2000-07-17 A | 2002-03-08 A |  | 100% | 2000-07-17 | 2002-03-08 | 430d | finish no earlier than 2002-03-08 | N2 | 3440h | 3440h | CAMEL4-IOR |  |  |  | Kimmo |  |
| 1688 | 84.5 | Inclusion of flexible tone injection | 430d | 2000-07-17 A | 2002-03-08 A |  | 100% | 2000-07-17 | 2002-03-08 | 430d | finish no earlier than 2002-03-08 | N2 | 3440h | 3440h | CAMEL4-IFTI |  |  |  | Kimmo |  |
| 1689 | 84.6 | CSE control over MT SMS | 430d | 2000-07-17 A | 2002-03-08 A |  | 100% | 2000-07-17 | 2002-03-08 | 430d | finish no earlier than 2002-03-08 | N2 | 3440h | 3440h | CAMEL4-CCSMS |  |  |  | Kimmo |  |
| 1690 | 84.7 | Notification of GPRS mobility management to CSE | 331d | 2001-03-02 A | 2002-06-07 A |  | 100% | 2001-03-02 | 2002-06-07 | 331d | finish no earlier than 2002-06-07 | N2 | 2648h | 2648h | CAMEL4-NMM |  |  |  | Kimmo |  |
| 1691 | 84.8 | Provision of location information of called subscriber | 266d | 2001-03-02 A | 2002-03-08 A |  | 100% | 2001-03-02 | 2002-03-08 | 266d | finish no earlier than 2002-03-08 | N2 | 2128h | 2128h | CAMEL4-LOCB |  |  |  | Kimmo |  |
| 1692 | 84.9 | Inclusion of ODB data in the CSE_HLR interface | 175d | 2001-07-09 A | 2002-03-08 A |  | 100% | 2001-07-09 | 2002-03-08 | 175d | finish no earlier than 2002-03-08 | N2 | 1400h | 1400h | CAMEL4-ODB |  |  |  | Kimmo |  |
| 1693 | 84.10 | Location information during an ongoing call (Handover DP) | 280d | 2001-05-14 A | 2002-06-07 A |  | 100% | 2001-05-14 | 2002-06-07 | 280d | finish no earlier than 2002-06-07 | N2 | 2240h | 2240h | CAMEL4-HODP |  |  |  | Kimmo |  |
| 1694 | 84.11 | GPRS Any Time Interrogation | 240d | 2001-07-09 A | 2002-06-07 A |  | 100% | 2001-07-09 | 2002-06-07 | 240d | finish no earlier than 2002-06-07 | N2 | 1920h | 1920h | CAMEL4-ATI |  |  |  | Kimmo |  |
| 1695 | 84.12 | Transfer of IMEI (with SW version) to CSE | 240d | 2001-07-09 A | 2002-06-07 A |  | 100% | 2001-07-09 | 2002-06-07 | 240d | finish no earlier than 2002-06-07 | N2 | 1920h | 1920h | CAMEL4-ATI |  |  |  | Kimmo |  |
| 1696 | 84.13 | Handling of partial implementations of CAMEL4 | 131d | 2002-03-08 A | 2002-09-06 A |  | 100% | 2002-03-08 | 2002-09-06 | 131d | finish no earlier than 2002-06-07 | N2 | 1048h | 1048h | CAMEL4-SUB |  |  |  | Kimmo |  |
| 1697 | 85 | **Rel-5 MExE enhancements** | 250d | 2001-03-26 A | 2002-03-08 A |  | 100% | 2001-03-26 | 2002-03-08 | 250d |  | T2 | 2880h | 2880h | MEXE5 |  |  | Rel-5 | Kimmo |  |
| 1698 | 85.1 | MExE Rel-5 Improvements and Investigations | 110d | 2001-03-26 A | 2002-03-08 A |  | 100% | 2001-03-26 | 2002-03-08 | 110d | finish no earlier than 2001-12-17 | T2 | 880h | 880h | MEXE5-ENHANC | Motorola | Mark Cataldo |  |  | 22.057, 23.057 |
| 1699 | 86 | **Wideband Telephony Service - AMR** | 1036d | 2000-01-01 A | 2003-12-19 A |  | 100% | 2000-01-01 | 2003-12-19 | 1036d |  | S4 | 81496h | 81496h | AMRWB | Siemens | Imre.Varga@mch.siemens.de | Rel-5 | Paolo |  |
| 1700 | 86.1 | **Specification** | 636d | 2000-01-01 A | 2002-06-07 A |  | 100% | 2000-01-01 | 2002-06-07 | 636d |  | S4 | 19984h | 19984h |  |  |  | Rel-5 | Paolo |  |
| 1701 | 86.1.1 | Stage 1 | 125d | 2001-10-01 A | 2002-03-22 A |  | 100% | 2001-10-01 | 2002-03-22 | 125d | finish no earlier than 2002-03-22 | S1 | 1000h | 1000h |  |  |  | Rel-5 | Alain |  |
| 1702 | 86.1.2 | **Stage 2** | 77d | 2000-01-03 A | 2000-04-17 A |  | 100% | 2000-01-03 | 2000-04-17 | 77d |  | S4 | 1232h | 1232h |  |  |  | Rel-5 | Paolo |  |
| 1703 | 86.1.2.1 | Design Constraints | 27d | 2000-01-03 A | 2000-02-07 A |  | 100% | 2000-01-03 | 2000-02-07 | 27d |  | S4 [96.3%] | 208h | 208h |  |  |  | Rel-5 | Paolo |  |
| 1704 | 86.1.2.2 | General Description | 51d | 2000-02-07 A | 2000-04-17 A | 1703 | 100% | 2000-02-07 | 2000-04-17 | 51d | start no earlier than 2000-09-25 | S4 | 408h | 408h |  |  |  | Rel-5 | Paolo |  |
| 1705 | 86.1.3 | Feasibility Study | 26d | 2000-04-28 A | 2000-06-02 A | 1704 | 100% | 2000-04-28 | 2000-06-02 | 26d | finish no earlier than 2000-06-02 | S4 | 208h | 208h |  |  |  | Rel-5 | Paolo | 26.901 |
| 1706 | 86.1.4 | N1 Aspects | 66d | 2001-09-21 A | 2001-12-21 A |  | 100% | 2001-09-21 | 2001-12-21 | 66d | finish no earlier than 2001-12-21 | N1 | 528h | 528h |  |  |  | Rel-5 | Frederic |  |
| 1707 | 86.1.5 | N4 work | 83d | 2002-02-13 A | 2002-06-07 A |  | 100% | 2002-02-13 | 2002-06-07 | 83d | finish no earlier than 2002-06-07 | N4 | 664h | 664h |  |  |  | Rel-5 | Kimmo |  |

Notes:
- 1692: Added on May 29, 2001
- 1696: stage2 and stage3 CRs for approval at CN#17
- 1705: S4,TD SP-000024: TR 26.901 v.4.0.0
- 1706: Some of N1 tasks: Indication of supported codecs by the MS, Bearer cap negociation, codec indication to MS... / One common set of codec negotiation procedures will be specified as in ID1657.
- 1707: CN4#11 30/11/01: No inputs to CN4 at this meeting / 14/02/02 work started 50% reached / 17 May work is done 100%

| ID | WBS | Task | Duration | Start | Finish | Predecessors | Complete | Baseline start | Baseline finish | Baseline duration | Constraint | Resources | Work | Actual work | Text6 | Text8 | Text1 | Text3 | Text12 | Text4 | Text5 |
| --- | --- | --- | --- | --- | --- | --- | --- | --- | --- | --- | --- | --- | --- | --- | --- | --- | --- | --- | --- | --- | --- |
| 1708 | 86.1.6 | **Codec issues** | 636d | 2000-01-03 A | 2002-06-07 A |  | 100% | 2000-01-03 | 2002-06-07 | 636d |  | S4 | 9496h | 9496h | Rel-5 | Paolo |  |  |  |  |  |
| 1709 | 86.1.6.1 | Codec qualification | 86d | 2000-02-02 A | 2000-05-31 A |  | 100% | 2000-02-02 | 2000-05-31 | 86d | finish no earlier than 2000-05-31 | S4 | 688h | 688h | Rel-5 | Paolo |  |  |  |  |  |
| 1710 | 86.1.6.2 | Codec selection tests | 102d | 2000-06-01 A | 2000-10-20 A | 1709 | 100% | 2000-06-01 | 2000-10-20 | 102d | finish no earlier than 2000-10-20 | S4 | 816h | 816h | Rel-5 | Paolo |  |  |  |  |  |
| 1711 | 86.1.6.3 | Codec selection | 5d | 2000-10-23 A | 2000-10-27 A | 1710 | 100% | 2000-10-23 | 2000-10-27 | 5d | finish no earlier than 2000-10-27 | S4 | 40h | 40h | Rel-5 | Paolo |  |  |  |  |  |
| 1712 | 86.1.6.4 | TFO AMR-WB | 63d | 2001-12-18 A | 2002-03-14 A |  | 100% | 2001-12-18 | 2002-03-14 | 63d | finish no earlier than 2002-03-14 | S4 | 504h | 504h | Rel-5 | Paolo | AMRWB-TFO |  |  |  |  |
| 1713 | 86.1.6.5 | Other codec issues (verif., caracterisation) | 441d | 2000-09-29 A | 2002-06-07 A |  | 100% | 2000-09-29 | 2002-06-07 | 441d | finish no earlier than 2002-06-07 | S4 | 3528h | 3528h | Rel-5 | Paolo |  | 26.976 |  |  |  |
| 1714 | 86.1.6.6 | AMR-WB and narrrowband interworking | 121d | 2001-09-27 A | 2002-03-14 A |  | 100% | 2001-09-27 | 2002-03-14 | 121d | finish no earlier than 2002-03-14 | S4 | 968h | 968h | Rel-5 | Paolo | AMRWB-IWG |  |  |  |  |
| 1715 | 86.1.6.7 | Interworking with fixed broadband networks | 121d | 2001-09-27 A | 2002-03-14 A |  | 100% | 2001-09-27 | 2002-03-14 | 121d | finish no earlier than 2002-03-14 | S4 | 968h | 968h | Rel-5 | Paolo |  |  |  |  |  |
| 1716 | 86.1.6.8 | Tones and announcements | 121d | 2001-09-27 A | 2002-03-14 A |  | 100% | 2001-09-27 | 2002-03-14 | 121d | finish no earlier than 2002-03-14 | S4 | 968h | 968h | Rel-5 | Paolo |  |  |  |  |  |
| 1717 | 86.1.6.9 | Deleted - WB Conferencing and WB Voice Group calls | 1d | 2000-01-03 A | 2000-01-03 A |  | 100% | 2000-01-03 | 2000-01-03 | 1d | finish no earlier than 2000-01-03 | S1 | 8h | 8h | Rel-5 | Alain |  |  | SP-07 |  |  |
| 1718 | 86.1.8 | **Conformance tests (CRs to 34 series)** | 74d | 2000-01-01 A | 2000-04-12 A |  | 100% | 2000-01-01 | 2000-04-12 | 74d |  | T1 | 1768h | 1768h | Rel-5 | Ingbert |  |  |  |  |  |
| 1719 | 86.1.8.1 | **Terminal Acoustic Characteristics** | 74d | 2000-01-01 A | 2000-04-12 A |  | 100% | 2000-01-01 | 2000-04-12 | 74d |  | S4 | 1176h | 1176h | Rel-5 | Paolo |  |  |  |  |  |
| 1720 | 86.1.8.1.1 | Definition | 22d | 2000-01-01 A | 2000-01-31 A |  | 100% | 2000-01-01 | 2000-01-31 | 22d | finish no earlier than 2000-01-28 | S4 [95.5%] | 168h | 168h | Rel-5 | Paolo |  | 26.131 |  |  |  |
| 1721 | 86.1.8.1.2 | Test specification | 52d | 2000-02-01 A | 2000-04-12 A | 1720 | 100% | 2000-02-01 | 2000-04-12 | 52d | finish no earlier than 2000-03-13 | S4 | 416h | 416h | Rel-5 | Paolo |  | 26.132 |  |  |  |
| 1722 | 86.2 | Floating-point ANSI-C code for the AMR-WB speech codec | 123d | 2001-09-25 A | 2002-03-14 A |  | 100% | 2001-09-25 | 2002-03-14 | 123d | finish no earlier than 2002-03-14 | S4 | 984h | 984h | Rel-5 | Paolo | AMRWB-FP | 26.204 |  | Nokia | janne.m.vainio@nokia.com |
| 1723 | 86.3 | **Support of AMR-WB in GERAN: GMSK and 8PSK WB FR / HR** | 651d | 2000-01-03 A | 2002-06-28 A |  | 100% | 2000-01-03 | 2002-06-28 | 651d |  | GP | 23488h | 23488h | Rel-5 | Paolo | GAMRWB |  |  |  |  |
| 1724 | 86.3.1 | Channel coding in 45.003 | 591d | 2000-01-03 A | 2002-04-05 A |  | 100% | 2000-01-03 | 2002-04-05 | 591d |  | GP | 4720h | 4720h | Rel-5 | Paolo |  |  |  |  |  |
| 1725 | 86.3.2 | Signalling for the A interface | 391d | 2000-01-03 A | 2001-06-29 A |  | 100% | 2000-01-03 | 2001-06-29 | 391d | finish no earlier than 2001-06-29 | GP | 3120h | 3120h | Rel-5 | Paolo |  |  |  |  |  |
| 1726 | 86.3.3 | Signalling for Iu | 651d | 2000-01-03 A | 2002-06-28 A |  | 100% | 2000-01-03 | 2002-06-28 | 651d | finish no earlier than 2002-06-28 | GP | 5200h | 5200h | Rel-5 | Paolo |  |  |  |  |  |
| 1727 | 86.3.4 | Receiver performance in TS 45.005 | 325d | 2001-04-02 A | 2002-06-28 A |  | 100% | 2001-04-02 | 2002-06-28 | 325d | finish no earlier than 2002-06-28 | GP | 2600h | 2600h | Rel-5 | Paolo |  |  |  |  |  |
| 1728 | 86.3.5 | Link Adaptation in 45.009 | 330d | 2001-03-26 A | 2002-06-28 A |  | 100% | 2001-03-26 | 2002-06-28 | 330d | finish no earlier than 2002-06-28 | GP | 2640h | 2640h | Rel-5 | Paolo |  |  |  |  |  |
| 1729 | 86.4 | **GERAN MS conformance test for AMR-WB** | 1036d | 2000-01-03 A | 2003-12-19 A |  | 100% | 2000-01-03 | 2003-12-19 | 1036d |  | GP | 16568h | 16568h | Rel-5 | Paolo |  |  |  |  |  |
| 1730 | 86.4.1 | Deleted - MS test | 1036d | 2000-01-03 A | 2003-12-19 A |  | 100% | 2000-01-03 | 2003-12-19 | 1036d | finish no earlier than 2003-12-19 | GP | 8280h | 8280h | Rel-5 | Paolo |  |  | GP-17 |  |  |
| 1731 | 86.5 | **GERAN BTS conformance test for AMR-WB** | 762d | 2000-01-03 A | 2002-12-02 A |  | 100% | 2000-01-03 | 2002-12-02 | 762d |  | GP | 12184h | 12184h | Rel-5 | Paolo |  |  |  |  |  |
| 1732 | 86.5.1 | BTS test | 762d | 2000-01-03 A | 2002-12-02 A |  | 100% | 2000-01-03 | 2002-12-02 | 762d | finish no earlier than 2002-12-02 | GP | 6088h | 6088h | Rel-5 | Paolo |  |  |  |  |  |

Notes:
- 1713: ANSI C-Code , Test Sequences, Speech Transcoding Functions, Error Concealment of lost frames, Source Controlled Bit-Rate Operation, Voice Activity Detector, Frame Structure
- 1724: 50098 -> 50298
- 1729: Not started 02/2003. Marked as stopped 12/2008
- 1730: Marked as stopped 12/2008

| ID | WBS | Task | Duration | Start | Finish | Complete | Baseline start | Baseline finish | Baseline duration | Constraint | Resources | Work | Actual work | Text1 | Text6 | Text8 | Text3 | Text4 | Text5 |
| --- | --- | --- | --- | --- | --- | --- | --- | --- | --- | --- | --- | --- | --- | --- | --- | --- | --- | --- | --- |
| 1733 | 11 | **Terminal interfaces** | 223d | 2001-05-14 A | 2002-03-20 A | 100% | 2001-05-14 | 2002-03-20 | 223d |  | T2 | 3568h | 3568h | TI | Rel-5 | Kimmo |  |  |  |
| 1734 | 87 | Terminal local model enhancements | 223d | 2001-05-14 A | 2002-03-20 A | 100% | 2001-05-14 | 2002-03-20 | 223d | finish no earlier than 2002-03-20 | T2 | 1784h | 1784h | TLM5 | Rel-5 |  | 23.227 |  |  |
| 1735 | 88 | **Rel-5 Location Services enhancements** | 845d | 2000-04-03 A | 2003-06-27 A | 100% | 2000-04-03 | 2003-06-27 | 845d |  | S2,S5 | 86804h | 86804h | LCS1 | Rel-5 | Maurice |  | Nokia | Jan Kall |
| 1736 | 88.1 | **UE positioning** | 315d | 2001-01-15 A | 2002-03-29 A | 100% | 2001-01-15 | 2002-03-29 | 315d |  | RP | 5560h | 5560h | LCS1-UEpos | NA | Stefania |  |  |  |
| 1737 | 88.1.1 | UE positioning enhancements for 1.28 Mcps TDD | 255d | 2001-04-09 A | 2002-03-29 A | 100% | 2001-04-09 | 2002-03-29 | 255d | finish no earlier than 2002-03-29 | R2 | 2040h | 2040h | LCS-128Pos | Rel-5 | Joern |  | CATT | Xiaohua Mei |
| 1738 | 88.1.2 | Open SMLC-SRNC Interface within the UTRAN to support A-GPS Positioning | 195d | 2001-01-15 A | 2001-10-12 A | 100% | 2001-01-15 | 2001-10-12 | 195d |  | R2 | 1560h | 1560h | LCS-INTF | Rel-5 | Joern |  | Qualcomm | Kirk Burroughs |
| 1739 | 88.2 | **Event based and Periodic LCS** | 535d | 2000-05-22 A | 2002-06-07 A | 100% | 2000-05-22 | 2002-06-07 | 535d |  | S1 | 6288h | 6288h | LCS1-EBP | Rel-5 | Alain |  |  |  |
| 1740 | 88.2.1 | Stage 1 | 130d | 2000-05-22 A | 2000-11-17 A | 100% | 2000-05-22 | 2000-11-17 | 130d | finish no earlier than 2000-07-21 | S1 | 1040h | 1040h |  |  | Alain | 22.071 | Pacific Bell Wireless | Randolph Wohlert (rwohlert@tri.sbc.com) |
| 1741 | 88.2.2 | Stage 2 specification | 60d | 2000-11-06 A | 2001-01-26 A | 100% | 2000-11-06 | 2001-01-26 | 60d | finish no earlier than 2001-01-26 | S2 | 480h | 480h |  |  | Maurice |  |  |  |
| 1742 | 88.2.3 | Impact on MAP | 61d | 2002-03-15 A | 2002-06-07 A | 100% | 2002-03-15 | 2002-06-07 | 61d | finish no earlier than 2002-06-07 | N4 | 488h | 488h |  |  | Kimmo |  |  |  |
| 1743 | 88.3 | **Location Services for GERAN in A/Gb Mode** | 485d | 2000-04-03 A | 2002-02-08 A | 100% | 2000-04-03 | 2002-02-08 | 485d |  | GP | 14760h | 14760h | LCS-GERAN | Rel-5 | Paolo |  |  |  |
| 1744 | 88.3.1 | GERAN LCS Stage 2 (first release) | 485d | 2000-04-03 A | 2002-02-08 A | 100% | 2000-04-03 | 2002-02-08 | 485d | finish no earlier than 2002-02-08 | GP,S2,G1,G2 | 3880h | 3880h |  |  | Paolo |  |  |  |
| 1745 | 88.3.2 | Gb interface support for LCS | 370d | 2000-04-03 A | 2001-08-31 A | 100% | 2000-04-03 | 2001-08-31 | 370d | finish no earlier than 2001-08-31 | GP | 2960h | 2960h |  |  | Paolo |  |  |  |
| 1746 | 88.3.3 | L3 protocol support for LCS | 305d | 2000-04-03 A | 2001-06-01 A | 100% | 2000-04-03 | 2001-06-01 | 305d | finish no earlier than 2001-06-01 | GP | 2440h | 2440h |  |  | Paolo |  |  |  |
| 1747 | 88.3.4 | Stage 3 specifications | 305d | 2000-04-03 A | 2001-06-01 A | 100% | 2000-04-03 | 2001-06-01 | 305d | finish no earlier than 2001-06-01 | GP | 2440h | 2440h |  |  | Paolo |  |  |  |
| 1748 | 88.4 | **Location Services for GERAN in Iu Mode** | 585d | 2000-04-03 A | 2002-06-28 A | 100% | 2000-04-03 | 2002-06-28 | 585d |  | GP | 20996h | 20996h |  | Rel-5 | Paolo |  |  |  |
| 1749 | 88.4.1 | GERAN LCS Stage 2 | 585d | 2000-04-03 A | 2002-06-28 A | 100% | 2000-04-03 | 2002-06-28 | 585d | finish no earlier than 2002-06-28 | GP,R2,R3,S2,G1,G2 | 4680h | 4680h |  |  | Paolo |  |  |  |
| 1750 | 88.4.2 | Iu-ps interface support for LCS | 585d | 2000-04-03 A | 2002-06-28 A | 100% | 2000-04-03 | 2002-06-28 | 585d | finish no earlier than 2002-06-28 | GP,R2,R3,S2,G1,G2 | 4680h | 4680h |  |  | Paolo |  |  |  |
| 1751 | 88.4.3 | Iu-cs interface support for LCS | 585d | 2000-04-03 A | 2002-06-28 A | 100% | 2000-04-03 | 2002-06-28 | 585d | finish no earlier than 2002-06-28 | GP,R2,R3,S2,G1,G2 | 4680h | 4680h |  |  | Paolo |  |  |  |
| 1752 | 88.4.4 | Iur-g interface support for LCS | 62.5d | 2002-01-23 A | 2002-04-19 A | 100% | 2002-01-23 | 2002-04-19 | 62.5d | finish no earlier than 2002-04-19 | GP,R2,R3,S2,G1,G2 | 500h | 500h |  |  | Paolo |  |  |  |
| 1753 | 88.4.5 | RRC protocol support for LCS | 75d | 2001-08-20 A | 2001-11-30 A | 100% | 2001-08-20 | 2001-11-30 | 75d | finish no earlier than 2001-11-30 | GP,R2,R3,S2,G1,G2 | 600h | 600h |  |  | Paolo |  |  |  |
| 1754 | 88.4.6 | Additional impacts on Broadcast of LCS data on packet channels | 77.5d | 2001-08-20 A | 2001-12-05 A | 100% | 2001-08-20 | 2001-12-05 | 77.5d | finish no earlier than 2001-12-05 | GP,R2,R3,S2,G1,G2 | 620h | 620h |  |  | Paolo |  |  |  |
| 1755 | 88.4.7 | Stage 3 specifications | 69.5d | 2002-03-25 A | 2002-06-28 A | 100% | 2002-03-25 | 2002-06-28 | 69.5d | finish no earlier than 2002-06-28 | GP,R2,R3,S2,G1,G2 | 556h | 556h |  |  | Paolo |  |  |  |
| 1756 | 88.5 | **GERAN MS Conformance test for LCS** | 280d | 2002-06-03 A | 2003-06-27 A | 100% | 2002-06-03 | 2003-06-27 | 280d |  | GP | 6720h | 6720h | LCS-GERAN-MSconf |  | Paolo |  |  |  |
| 1757 | 88.5.1 | Develop LCS MS test case work plan (Release 98/99/4) | 280d | 2002-06-03 A | 2003-06-27 A | 100% | 2002-06-03 | 2003-06-27 | 280d | finish no earlier than 2003-06-27 | G4,G5 | 2240h | 2240h |  |  | Paolo |  |  |  |
| 1758 | 88.5.2 | Develop LCS MS test cases | 280d | 2002-06-03 A | 2003-06-27 A | 100% | 2002-06-03 | 2003-06-27 | 280d | finish no earlier than 2003-06-27 | G4,G5 | 2240h | 2240h |  |  | Paolo |  |  |  |

Notes:
- 1738: Finished at RP#13
- 1740: Evaluate Event based and Periodic LCS to be included in R00, corresponding Stage 1 description
- 1741: Marked as closed 12/2008 (was marked 51% complete)
- 1742: Possible impact on UTRAN of LCS quality level request / 17 May No stage 2 for event-based & periodic LCS. Work 100% completefor current stage 2
- 1752: FFS
- 1756: On-going
- 1757: Marked as closed 12/2008 (was marked 60% complete)
- 1758: Marked as closed 12/2008 (was marked 60% complete)

| ID | WBS | Task | Duration | Start | Finish | Predecessors | Complete | Baseline start | Baseline finish | Baseline duration | Constraint | Resources | Work | Actual work | Text1 | Text8 | Text12 | Text6 | Text3 | Text4 | Text5 |
| --- | --- | --- | --- | --- | --- | --- | --- | --- | --- | --- | --- | --- | --- | --- | --- | --- | --- | --- | --- | --- | --- |
| 1759 | 88.6 | **Deleted - GERAN BTS Conformance test for LCS** | 280d | 2002-06-03 A | 2003-06-27 A |  | 100% | 2002-06-03 | 2003-06-27 | 280d |  | GP | 6720h | 6720h | LCS-GERAN-BTSconf | Paolo | GP-15 |  |  |  |  |
| 1760 | 88.6.1 | Deleted - Develop LCS BTS test case work plan (Release 98/99/4) | 280d | 2002-06-03 A | 2003-06-27 A |  | 100% | 2002-06-03 | 2003-06-27 | 280d | finish no earlier than 2003-06-27 | G4,G5 | 2240h | 2240h |  | Paolo | GP-15 |  |  |  |  |
| 1761 | 88.6.2 | Deleted - Develop LCS BTS test cases | 280d | 2002-06-03 A | 2003-06-27 A |  | 100% | 2002-06-03 | 2003-06-27 | 280d | finish no earlier than 2003-06-27 | G4,G5 | 2240h | 2240h |  | Paolo | GP-15 |  |  |  |  |
| 1762 | 88.7 | LCS interoperation stage 2 aspects | 480d | 2000-08-28 A | 2002-06-28 A |  | 100% | 2000-08-28 | 2002-06-28 | 480d |  | S2 | 3840h | 3840h |  | Maurice |  |  |  |  |  |
| 1763 | 88.8 | **LCS interoperability aspects to GERAN** | 480d | 2000-08-28 A | 2002-06-28 A |  | 100% | 2000-08-28 | 2002-06-28 | 480d |  | GP,S5 | 7680h | 7680h | LCS-GERAN | Paolo |  | Rel-5 |  |  |  |
| 1764 | 88.8.1 | Co-ordinated development of GSM LCS Phase 2 and UMTS LCS, S2 and GERAN | 480d | 2000-08-28 A | 2002-06-28 A |  | 100% | 2000-08-28 | 2002-06-28 | 480d | finish no earlier than 2002-06-28 | GP,S2,S5,R2,R3,G2,G1 | 3840h | 3840h | LCS-GERAN | Paolo |  | Rel-5 |  |  |  |
| 1765 | 88.9 | FS on LCS support in the IMS | 90d | 2001-02-12 A | 2002-01-18 A |  | 100% | 2001-02-12 | 2002-01-18 | 90d | start no earlier than 2001-02-12 | S1 | 720h | 720h |  | Alain |  |  |  |  |  |
| 1766 | 88.10 | Charging and OAM&P for LCS enhancements | 201d | 2001-09-21 A | 2002-06-28 A |  | 100% | 2001-09-21 | 2002-06-28 | 201d | finish no earlier than 2002-06-28 | S5 | 1608h | 1608h | LCS1-OAM | Dionisio |  | Rel-5 | 32-series | VoiceStream, Motorola |  |
| 1767 | 88.11 | New security aspects of LCS (not identified) | 446d | 2000-04-14 A | 2001-12-28 A |  | 100% | 2000-04-14 | 2001-12-28 | 446d | finish no earlier than 2001-12-28 | S3 | 3568h | 3568h | LCS1-SEC | Dionisio |  | Rel-5 |  | Nokia | valtteri.niemi@nokia.com |
| 1768 | 88.12 | Specification for the Le Interface | 45d | 2002-01-14 A | 2002-03-15 A |  | 100% | 2002-01-14 | 2002-03-15 | 45d | start no earlier than 2002-01-14 | S2 | 360h | 360h | LCS1-Le | Maurice |  | Rel-5 |  |  |  |
| 1769 | 88.13 | Deleted - CHECK STATUS - Inter-GMLC interface | 153d | 2002-05-30 A | 2002-12-30 A |  | 100% | 2002-05-30 | 2002-12-30 | 153d | finish no earlier than 2002-12-30 | S2 | 1224h | 1224h |  | Maurice | SP-10 |  |  |  |  |
| 1770 | 89 | **Rel-5 Security enhancements** | 615d | 2000-02-21 A | 2002-06-28 A |  | 100% | 2000-02-21 | 2002-06-28 | 615d |  | S3 | 29974.9h | 29974.9h | SEC1 | Dionisio |  | Rel-5 |  | Vodafone | Peter.Howard@vodafone.com |
| 1771 | 89.1 | **Network domain security** | 615d | 2000-02-21 A | 2002-06-28 A |  | 100% | 2000-02-21 | 2002-06-28 | 615d |  | S3 | 25054.9h | 25054.9h | SEC1-NDS | Dionisio |  | Rel-5 |  | Telenor | Geir-myrdahl.koien@telenor.com |
| 1772 | 89.1.1 | **Deleted -Control plane protection in core network (e.g., GTP, CAP, MAP/IP, provided by IPsec)** | 541d | 2000-05-12 A | 2002-06-07 A |  | 100% | 2000-05-12 | 2002-06-07 | 541d |  | S3 | 7118.9h | 7118.9h |  | Dionisio | SP-16 |  |  |  |  |
| 1773 | 89.1.1.1 | Deleted - Main aspects | 290d | 2000-05-12 A | 2001-06-21 A |  | 100% | 2000-05-12 | 2001-06-21 | 290d | finish no earlier than 2001-06-21 | S3 | 2320h | 2320h |  | Dionisio | SP-12 |  |  |  |  |
| 1774 | 89.1.1.2 | Deleted -Integration of GTP signalling security architecture | 191d | 2001-09-14 A | 2002-06-07 A |  | 100% | 2001-09-14 | 2002-06-07 | 191d | finish no earlier than 2002-06-07 | N4 | 1528h | 1528h |  | Kimmo | NP-16 |  |  |  |  |
| 1775 | 89.1.2 | **Deleted -User plane protection in core network (e.g., provided by IPsec)** | 615d | 2000-02-21 A | 2002-06-28 A |  | 100% | 2000-02-21 | 2002-06-28 | 615d |  | S3 | 9360h | 9360h |  | Dionisio | SP-16 |  |  |  |  |
| 1776 | 89.1.2.1 | Deleted -Main aspects | 349d | 2000-02-21 A | 2001-06-21 A |  | 100% | 2000-02-21 | 2001-06-21 | 349d | finish no earlier than 2001-06-21 | S3 | 2792h | 2792h |  | Dionisio | SP-12 |  |  |  |  |
| 1777 | 89.1.2.2 | Deleted -Integration of GTP signalling security architecture | 206d | 2001-09-14 A | 2002-06-28 A |  | 100% | 2001-09-14 | 2002-06-28 | 206d | finish no earlier than 2002-06-28 | N4 | 1648h | 1648h |  | Kimmo | NP-16 |  |  |  |  |
| 1778 | 89.1.3 | IP network layer security (NDS/IP) | 457d | 2000-06-15 A | 2002-03-15 A |  | 100% | 2000-06-15 | 2002-03-15 | 457d | finish no earlier than 2002-03-15 | S3 | 3656h | 3656h | SEC1-NDS-IP | Dionisio |  |  | 33.210 | Telenor | Geir-myrdahl.koien@telenor.com |
| 1779 | 90 | **Intra Domain Connection of RAN Nodes to Multiple CN Nodes** | 455d | 2000-10-02 A | 2002-06-28 A |  | 100% | 2000-10-02 | 2002-06-28 | 455d |  | S2 | 15136h | 15136h | IUFLEX | Alain |  | Rel-5 | 23.236 | Ericsson | stephen.terrill@ericsson.com |
| 1780 | 90.1 | Overall System Architecture | 188d | 2001-01-03 A | 2001-09-21 A |  | 100% | 2001-01-03 | 2001-09-21 | 188d | finish no earlier than 2001-06-01 | S2 | 1504h | 1504h |  | Maurice |  |  |  |  |  |
| 1781 | 90.2 | Stage 3: RAN node selecting CN node | 130d | 2001-09-24 A | 2002-03-22 A | 1780 | 100% | 2001-09-24 | 2002-03-22 | 130d | finish no earlier than 2002-03-22 | R3 | 1040h | 1040h |  | Juha |  |  |  | Vodafone | Brendan.McWilliams@gb.vodafone.co.uk |
| 1782 | 90.3 | N1 work | 205d | 2001-09-17 A | 2002-06-28 A |  | 100% | 2001-09-17 | 2002-06-28 | 205d | start no earlier than 2001-09-17 | N1 | 1640h | 1640h |  | Frederic |  |  | 24.008 and check 29.018 |  |  |
| 1783 | 90.4 | N4 work | 375d | 2000-10-02 A | 2002-03-08 A |  | 100% | 2000-10-02 | 2002-03-08 | 375d | finish no earlier than 2002-03-15 | N4 | 3000h | 3000h |  | Kimmo |  |  |  |  |  |

Notes:
- 1759: Not started 02/3003. Marked as stopped 12/2008
- 1760: Marked as stopped 12/2008
- 1761: Marked as stopped 12/2008
- 1762: Marked as closed 12/2008 (was marked 17% complete)
- 1765: Marked as closed 12/2008 (was marked 75% complete)
- 1767: 14/09/00: WI may need to be split to improve on this date. S3#17 15% complete. No progress since S3#17
- 1769: Marked as stopped 12/2008
- 1770: Added BB UE authentication and rapporteur added. TO BE DELETED
- 1771: S3#17: All due in Rel5. (WI Update at S3#18). Replaced by NDS-IP and NDS-MAP. TO BE DELETED OR MOVED TO HISTORY FILE
- 1772: Marked as stopped 12/2008
- 1773: TO BE DELETED. Marked as stopped 12/2008
- 1774: Waiting for input from SA3!.... Marked as stopped 12/2008
- 1775: TO BE DELETED. Marked as stopped 12/2008
- 1776: ??
- 1777: 14/02/2002 requirements are not clear/not received...Marked as closed 12/2008 (was marked 95 complete)
- 1778: 2002/12: All IPsec RFCs are stable STD Track RFCs. WID updated SA#17
- 1779: No clear indication on the end date. Put to Rel5 by AS.
- 1781: Not identified
- 1783: DAB 12.12.01 - % complete to 66% / 14/02/02 Work completed

| ID | WBS | Task | Duration | Start | Finish | Complete | Baseline start | Baseline finish | Baseline duration | Constraint | Resources | Work | Actual work | Text1 | Text4 | Text5 | Text6 | Text8 | Text12 | Text3 |
| --- | --- | --- | --- | --- | --- | --- | --- | --- | --- | --- | --- | --- | --- | --- | --- | --- | --- | --- | --- | --- |
| 1784 | 90.5 | **GERAN work for Intra Domain Connection of RAN Nodes to Multiple CN Nodes** | 101d | 2002-02-08 A | 2002-06-28 A | 100% | 2002-02-08 | 2002-06-28 | 101d |  | GP | 4848h | 4848h | IDCRAN-GERAN | Ericsson | ingemar.backlund@era.ericsson.se | Rel-5 | Paolo |  |  |
| 1785 | 90.5.1 | Stage 2 (changes to ) | 101d | 2002-02-08 A | 2002-06-28 A | 100% | 2002-02-08 | 2002-06-28 | 101d | finish no earlier than 2002-06-28 | G1 | 808h | 808h |  |  |  |  |  |  |  |
| 1786 | 90.5.2 | 43.051 Introduction of support for IDNNS in GERAN Iu mode | 101d | 2002-02-08 A | 2002-06-28 A | 100% | 2002-02-08 | 2002-06-28 | 101d | finish no earlier than 2002-06-28 | G1 | 808h | 808h |  |  |  |  |  |  |  |
| 1787 | 90.5.3 | Stage 3 (changes to ) | 101d | 2002-02-08 A | 2002-06-28 A | 100% | 2002-02-08 | 2002-06-28 | 101d | finish no earlier than 2002-06-28 | G2 | 808h | 808h |  |  |  |  | Gert |  |  |
| 1788 | 90.5.4 | 48.016 Use of Gb interface concepts when a network applies IDNNS | 101d | 2002-02-08 A | 2002-06-28 A | 100% | 2002-02-08 | 2002-06-28 | 101d | finish no earlier than 2002-06-28 | G2 | 808h | 808h |  |  |  |  | Gert |  |  |
| 1789 | 90.5.5 | 48.018 Include MSC/VLR identity in CS IMSI paging | 101d | 2002-02-08 A | 2002-06-28 A | 100% | 2002-02-08 | 2002-06-28 | 101d | finish no earlier than 2002-06-28 | G2 | 808h | 808h |  |  |  |  | Gert |  |  |
| 1790 | 91 | **Deleted - GERAN improvements 3 (new transport layer on interface A)** | 446d | 2001-04-06 A | 2002-12-20 A | 100% | 2001-04-06 | 2002-12-20 | 446d |  | GP | 14272h | 14272h | GEIMP3 |  |  | Rel-5 | Paolo |  |  |
| 1791 | 91.1 | **Deleted - Evolution of the transport for A** | 446d | 2001-04-06 A | 2002-12-20 A | 100% | 2001-04-06 | 2002-12-20 | 446d |  | GP | 10704h | 10704h | GEIMP3-EtA |  |  |  | Paolo | GP-12 |  |
| 1792 | 91.1.1 | Deleted - Definition of a new A/Ater interface Transport Layer option based on the Iu Interface Transport Layer | 446d | 2001-04-06 A | 2002-12-20 A | 100% | 2001-04-06 | 2002-12-20 | 446d | finish no earlier than 2002-12-20 | GP | 3568h | 3568h |  |  |  |  | Paolo | GP-12 |  |
| 1793 | 91.1.2 | Deleted - Adaptation of the Layer 3 BSSMAP procedures as required | 446d | 2001-04-06 A | 2002-12-20 A | 100% | 2001-04-06 | 2002-12-20 | 446d | finish no earlier than 2002-12-20 | GP | 3568h | 3568h |  |  |  |  | Paolo | GP-12 |  |
| 1794 | 92 | **Rel-5 Charging and OAM&P** | 264d | 2001-09-10 A | 2002-09-12 A | 100% | 2001-09-10 | 2002-09-12 | 264d |  | S5 | 9976h | 9976h | OAM | VoiceStream, Motorola |  | Rel-5 | Dionisio |  | 32-series |
| 1795 | 92.1 | Rel5 Principles, high level Requirements and Architecture | 205d | 2001-09-17 A | 2002-06-28 A | 100% | 2001-09-17 | 2002-06-28 | 205d | finish no earlier than 2002-06-28 | S5 | 1640h | 1640h | OAM-AR/PR | Motorola |  | Rel-5 | Dionisio |  | 32.101, 32.102 |
| 1796 | 92.2 | Rel5 Performance Management | 259d | 2001-09-17 A | 2002-09-12 A | 100% | 2001-09-17 | 2002-09-12 | 259d | finish no earlier than 2002-09-12 | S5 | 2072h | 2072h | OAM-PM | Nortel |  | Rel-5 | Dionisio |  | 32.4xy, 52.402 |
| 1797 | 92.3 | Rel5 Charging Management | 264d | 2001-09-10 A | 2002-09-12 A | 100% | 2001-09-10 | 2002-09-12 | 264d | finish no earlier than 2002-09-12 | S5 | 2112h | 2112h | OAM-CH | T-Mobile | Karl-Heinz.Nenner@T-MOBILE.DE | Rel-5 | Dionisio |  | 32.2xy |
| 1798 | 92.4 | Rel5 Network Infrastructure Management | 255d | 2001-09-21 A | 2002-09-12 A | 100% | 2001-09-21 | 2002-09-12 | 255d | finish no earlier than 2002-09-12 | S5 | 2040h | 2040h | OAM-NIM | Ericsson | thomas.tovinger@ericsson.com | Rel-5 | Dionisio |  | 32.6xy, 32.3xy |
| 1799 | 93 | **GERAN enhancements for streaming services 1 (RLC enhancements)** | 430d | 2000-11-06 A | 2002-06-28 A | 100% | 2000-11-06 | 2002-06-28 | 430d |  | GP | 8944h | 8944h |  |  |  | Rel-5 | Paolo |  |  |
| 1800 | 93.1 | Concept | 258d | 2000-11-06 A | 2001-10-31 A | 100% | 2000-11-06 | 2001-10-31 | 258d | finish no earlier than 2001-10-31 | GP | 2064h | 2064h |  |  |  |  | Paolo |  |  |
| 1801 | 93.2 | RLC protocol enhancement (SDU Discard) | 430d | 2000-11-06 A | 2002-06-28 A | 100% | 2000-11-06 | 2002-06-28 | 430d | finish no earlier than 2002-06-28 | GP | 3440h | 3440h |  |  |  |  | Paolo |  |  |
| 1802 | 94 | **GERAN enhancements for streaming services 2 (usage of ECSD)** | 430d | 2000-11-06 A | 2002-06-28 A | 100% | 2000-11-06 | 2002-06-28 | 430d |  | GP | 19840h | 19840h |  | Ericsson | Frank Muller | Rel-5 | Paolo |  |  |
| 1803 | 94.1 | Usage of ECSD Concept | 380d | 2000-11-06 A | 2002-04-19 A | 100% | 2000-11-06 | 2002-04-19 | 380d | finish no earlier than 2002-04-19 | GP | 3040h | 3040h |  |  |  |  | Paolo |  |  |
| 1804 | 94.2 | Stage 2 | 380d | 2000-11-06 A | 2002-04-19 A | 100% | 2000-11-06 | 2002-04-19 | 380d | finish no earlier than 2002-04-19 | GP | 3040h | 3040h |  |  |  |  | Paolo |  |  |
| 1805 | 94.3 | Stage 3 | 430d | 2000-11-06 A | 2002-06-28 A | 100% | 2000-11-06 | 2002-06-28 | 430d | finish no earlier than 2002-06-28 | GP | 3440h | 3440h |  |  |  |  | Paolo |  |  |
| 1806 | 94.4 | RLC PDU formats | 430d | 2000-11-06 A | 2002-06-28 A | 100% | 2000-11-06 | 2002-06-28 | 430d | finish no earlier than 2002-06-28 | GP | 3440h | 3440h |  |  |  |  | Paolo |  |  |
| 1807 | 94.5 | MAC header | 430d | 2000-11-06 A | 2002-06-28 A | 100% | 2000-11-06 | 2002-06-28 | 430d | finish no earlier than 2002-06-28 | GP | 3440h | 3440h |  |  |  |  | Paolo |  |  |

Notes:
- 1784: Accept changes Gb over IP
- 1788: Closed, accept changes for Gb over IP
- 1790: TERMINATED - NOT STANDARDIZED. Marked as stopped 12/2008
- 1791: TERMINATED - NOT STANDARDIZED. Marked as stopped 12/2008
- 1792: TERMINATED - NOT STANDARDIZED. Marked as stopped 12/2008
- 1793: TERMINATED - NOT STANDARDIZED. Marked as stopped 12/2008
- 1802: AWS, Nokia, Ericsson, Nortel, Siemens, Motorola, Vodafone

| ID | WBS | Task | Duration | Start | Finish | Predecessors | Complete | Baseline start | Baseline finish | Baseline duration | Constraint | Resources | Work | Actual work | Text1 | Text4 | Text5 | Text6 | Text8 |
| --- | --- | --- | --- | --- | --- | --- | --- | --- | --- | --- | --- | --- | --- | --- | --- | --- | --- | --- | --- |
| 1808 | 95 | **GERAN/UTRAN interface evolution 1 (evolution of Iu PS)** | 476d | 2000-09-01 A | 2002-06-28 A |  | 100% | 2000-09-01 | 2002-06-28 | 476d |  | GP,R3 | 10688h | 10688h | GERUEV1 | SBC | Marc Grant | Rel-5 | Paolo |
| 1809 | 95.1 | **Evolution of Iu ps** | 476d | 2000-09-01 A | 2002-06-28 A |  | 100% | 2000-09-01 | 2002-06-28 | 476d |  | GP,R3 | 7248h | 7248h | GERUEV1-IuPS |  |  |  | Paolo |
| 1810 | 95.1.1 | Identification of GERAN requirements on Iu ps | 326d | 2000-09-01 A | 2001-11-30 A |  | 100% | 2000-09-01 | 2001-11-30 | 326d | finish no earlier than 2001-11-30 | GP,R3 | 2608h | 2608h |  |  |  |  | Paolo |
| 1811 | 95.1.2 | Update of specifications | 150d | 2001-12-03 A | 2002-06-28 A | 1810 | 100% | 2001-12-03 | 2002-06-28 | 150d | finish no earlier than 2002-06-28 | GP,R3 | 1200h | 1200h |  |  |  |  | Paolo |
| 1812 | 96 | **GERAN/UTRAN interface evolution 2 (evolution of Iu CS)** | 476d | 2000-09-01 A | 2002-06-28 A |  | 100% | 2000-09-01 | 2002-06-28 | 476d |  | GP,R3 | 12816h | 12816h | GERUEV2 |  |  | Rel-5 | Paolo |
| 1813 | 96.1 | **Evolution of Iu cs** | 476d | 2000-09-01 A | 2002-06-28 A |  | 100% | 2000-09-01 | 2002-06-28 | 476d |  | GP,R3 | 10016h | 10016h | GERUEV2-IuCS | Lucent | Krishna Balachandran |  | Paolo |
| 1814 | 96.1.1 | Identification of GERAN requirements on Iu cs | 426d | 2000-09-01 A | 2002-06-24 A |  | 100% | 2000-09-01 | 2002-06-24 | 426d | finish no earlier than 2002-04-19 | GP,R3 | 3408h | 3408h |  |  |  |  | Paolo |
| 1815 | 96.1.2 | Update of specifications | 476d | 2000-09-01 A | 2002-06-28 A |  | 100% | 2000-09-01 | 2002-06-28 | 476d | finish no earlier than 2002-06-28 | GP,R3 | 3808h | 3808h |  |  |  |  | Paolo |
| 1816 | 97 | **End to End QoS for PS Domain including IMS** | 480d | 2000-08-28 A | 2002-06-28 A |  | 100% | 2000-08-28 | 2002-06-28 | 480d |  | S2 | 9856h | 9856h | E2EQoS | Ericsson | Johnson.oyama@era.ericcson.se | Rel-5 | Maurice |
| 1817 | 97.1 | E2E QoSConcept and Architecture | 178d | 2001-01-03 A | 2001-09-07 A |  | 100% | 2001-01-03 | 2001-09-07 | 178d | finish no earlier than 2001-09-07 | S2 | 1424h | 1424h |  |  |  |  | Maurice |
| 1818 | 97.2 | E2E QoS interworking | 465d | 2000-08-28 A | 2002-06-07 A |  | 100% | 2000-08-28 | 2002-06-07 | 465d | finish no earlier than 2002-06-07 | N3 | 3720h | 3720h | E2EQoS-IW | Lucent | Daisuke Yokota (yokota@lucent.com) |  | Gwiho |
| 1819 | 97.3 | QoS Management (Provisioning and Monitoring) | 201d | 2001-09-21 A | 2002-06-28 A |  | 100% | 2001-09-21 | 2002-06-28 | 201d | finish no earlier than 2002-06-28 | S5 | 1608h | 1608h | E2EQoS-OAM | VoiceStream, Motorola |  | Rel-5 | Dionisio |
| 1820 | 98 | **Messaging enhancements Rel-5** | 467d | 2001-06-15 A | 2003-03-31 A |  | 100% | 2001-06-15 | 2003-03-31 | 467d |  | T2 | 19000h | 19000h | MESS5 |  |  | Rel-5 | Kimmo |
| 1821 | 98.1 | **Multimedia Messaging (MMS) enhancements** | 467d | 2001-06-15 A | 2003-03-31 A |  | 100% | 2001-06-15 | 2003-03-31 | 467d |  | T2 | 11688h | 11688h | MESS5-MMS | Siemens | Josef.Laumen@SAL.SIEMENS.DE |  | Alain |
| 1822 | 98.1.1 | Definition of service requirements | 196d | 2001-06-15 A | 2002-03-15 A |  | 100% | 2001-06-15 | 2002-03-15 | 196d | finish no earlier than 2002-03-15 | S1 | 1568h | 1568h | MESS5-SR | Siemens | Josef.Laumen@SAL.SIEMENS.DE | Rel-5 |  |
| 1823 | 98.1.2 | Technical realization | 256d | 2001-06-15 A | 2002-06-07 A |  | 100% | 2001-06-15 | 2002-06-07 | 256d | finish no earlier than 2002-06-07 | T2 | 2048h | 2048h |  | Siemens | Josef.Laumen@SAL.SIEMENS.DE |  |  |
| 1824 | 98.1.3 | WAP Forum dependency: MM1 stage 3 | 467d | 2001-06-15 A | 2003-03-31 A |  | 100% | 2001-06-15 | 2003-03-31 | 467d | finish no earlier than 2003-03-31 | T2 | 3736h | 3736h |  |  |  |  |  |
| 1825 | 98.1.4 | MMS formats and codecs | 75d | 2001-12-03 A | 2002-03-15 A |  | 100% | 2001-12-03 | 2002-03-15 | 75d | finish no earlier than 2002-03-15 | S4 | 600h | 600h |  |  |  |  | Paolo |
| 1826 | 98.2 | **Enhanced Messaging Service (EMS) enhancements** | 191d | 2001-06-15 A | 2002-03-08 A |  | 100% | 2001-06-15 | 2002-03-08 | 191d |  | T2 | 3584h | 3584h | MESS5-EMS | Ericsson | Alan.Baldwin@EML.ERICSSON.SE |  |  |
| 1827 | 98.2.1 | Definition of service requirements | 66d | 2001-06-15 A | 2001-09-14 A |  | 100% | 2001-06-15 | 2001-09-14 | 66d | finish no earlier than 2001-09-14 | S1 | 528h | 528h |  | Ericsson | Alan.Baldwin@EML.ERICSSON.SE |  | Alain |
| 1828 | 98.2.2 | Technical realization | 191d | 2001-06-15 A | 2002-03-08 A |  | 100% | 2001-06-15 | 2002-03-08 | 191d | finish no earlier than 2002-03-08 | T2 | 1528h | 1528h |  | Ericsson | Alan.Baldwin@EML.ERICSSON.SE |  |  |
| 1829 | 99 | **GERAN Inter BSC NACC improvements over the Gb Interface** | 215d | 2001-09-03 A | 2002-06-28 A |  | 100% | 2001-09-03 | 2002-06-28 | 215d |  | GP | 8200h | 8200h | GERNACC |  |  | Rel-5 | Paolo |
| 1830 | 99.1 | **Modification of core network protocols for GERAN Inter BSC NACC over Gb Interface** | 165d | 2001-09-03 A | 2002-04-19 A |  | 100% | 2001-09-03 | 2002-04-19 | 165d |  | N4,S2 | 4064h | 4064h | GERNACC-Cnmod |  |  |  | Kimmo |
| 1831 | 99.1.1 | Stage 2 - Concept | 43d | 2001-09-03 A | 2001-10-31 A |  | 100% | 2001-09-03 | 2001-10-31 | 43d | finish no earlier than 2001-10-31 | N4,S2 | 344h | 344h |  |  |  |  | Kimmo |
| 1832 | 99.1.2 | Stage 2 - 23.060 change - Definition of Inter BSC NACC | 165d | 2001-09-03 A | 2002-04-19 A |  | 100% | 2001-09-03 | 2002-04-19 | 165d | finish no earlier than 2002-04-19 | N4,S2 | 1320h | 1320h |  |  |  |  | Kimmo |
| 1833 | 99.1.3 | Stage 3 (changes to TS 29.060) | 135d | 2001-09-03 A | 2002-03-08 A |  | 100% | 2001-09-03 | 2002-03-08 | 135d | finish no earlier than 2002-03-08 | N4 | 1080h | 1080h |  |  |  |  | Kimmo |

Notes:
- 1808: SBC, Motorola, Nokia, Ericsson, Nortel
- 1813: Lucent, Ericsson, AWS, Nortel
- 1817: Text3: 23.207
- 1818: [DAB - 30/07/02] - % complete to 95% (if we exclude Diffserv). Marked as closed 12/2008 (was marked 95% complete) / Text3: 29.208, 29.207, 27.060, 29.061, 24.008, 24.228, , 24.229, 29.060, 29.163
- 1819: Text3: 32-series
- 1820: support of UAProf, so this in my opinion is 100% complete
- 1822: Text3: 22.140
- 1823: stage 3 MM7 is missing / Text3: 23.140
- 1824: Marked as closed 12/2008 (was marked 80% complete)
- 1825: Text3: 26.140
- 1826: Text3: 23.040
- 1828: Text3: 23.040
- 1833: IP 30/11/01: Input awaited from GERAN2 to CN4 / 17 May Work complete 100%

| ID | WBS | Task | Duration | Start | Finish | Complete | Baseline start | Baseline finish | Baseline duration | Constraint | Resources | Work | Actual work | Text1 | Text8 | Text6 | Text12 | Text3 | Text4 | Text5 |
| --- | --- | --- | --- | --- | --- | --- | --- | --- | --- | --- | --- | --- | --- | --- | --- | --- | --- | --- | --- | --- |
| 1834 | 99.2 | **Modification of Gb protocols for GERAN Inter BSC NACC over Gb Interface** | 151d | 2001-11-30 A | 2002-06-28 A | 100% | 2001-11-30 | 2002-06-28 | 151d |  | GP | 2416h | 2416h | GERNACC-Gbmod | Paolo |  |  |  |  |  |
| 1835 | 99.2.1 | Stage 3 (changes to TS 48.018) | 151d | 2001-11-30 A | 2002-06-28 A | 100% | 2001-11-30 | 2002-06-28 | 151d | finish no earlier than 2002-06-28 | GP | 1208h | 1208h |  | Paolo |  |  |  |  |  |
| 1836 | 100 | **Enhanced Power Control** | 540d | 2001-11-26 A | 2003-12-19 A | 100% | 2001-11-26 | 2003-12-19 | 540d |  | GP | 12840h | 12840h | EPC | Paolo | Rel-5 |  |  |  |  |
| 1837 | 100.1 | Realization of Enhanced power control and signaling support | 5d | 2001-11-26 A | 2001-11-30 A | 100% | 2001-11-26 | 2001-11-30 | 5d | finish no earlier than 2001-11-30 | GP | 40h | 40h |  | Paolo |  |  |  |  |  |
| 1838 | 100.2 | Deleted - GERAN MS Conformance test for Enhanced Power Control | 530d | 2001-12-10 A | 2003-12-19 A | 100% | 2001-12-10 | 2003-12-19 | 530d | finish no earlier than 2003-12-19 | GP | 4240h | 4240h |  | Paolo |  | GP-17 |  |  |  |
| 1839 | 100.3 | Deleted - GERAN BTS Conformance test for Enhanced Power Control | 530d | 2001-12-10 A | 2003-12-19 A | 100% | 2001-12-10 | 2003-12-19 | 530d | finish no earlier than 2003-12-19 | GP | 4240h | 4240h |  | Paolo |  | GP-17 |  |  |  |
| 1840 | 101 | **8PSK AMR HR** | 530d | 2001-12-10 A | 2003-12-19 A | 100% | 2001-12-10 | 2003-12-19 | 530d |  | GP | 21080h | 21080h | 8PSK-AH | Paolo | Rel-5 |  |  |  |  |
| 1841 | 101.1 | **Definition of channel coding, performance requirements and signaling support** | 145d | 2001-12-10 A | 2002-06-28 A | 100% | 2001-12-10 | 2002-06-28 | 145d |  | GP | 10440h | 10440h |  | Paolo |  |  |  |  |  |
| 1842 | 101.1.1 | Concept | 145d | 2001-12-10 A | 2002-06-28 A | 100% | 2001-12-10 | 2002-06-28 | 145d | finish no earlier than 2002-06-28 | GP | 1160h | 1160h |  | Paolo |  |  |  |  |  |
| 1843 | 101.1.2 | Changes to 44.018 | 145d | 2001-12-10 A | 2002-06-28 A | 100% | 2001-12-10 | 2002-06-28 | 145d | finish no earlier than 2002-06-28 | G2 | 1160h | 1160h |  | Gert |  |  |  |  |  |
| 1844 | 101.1.3 | Changes to 45.001 | 145d | 2001-12-10 A | 2002-06-28 A | 100% | 2001-12-10 | 2002-06-28 | 145d | finish no earlier than 2002-06-28 | G1 | 1160h | 1160h |  |  |  |  |  |  |  |
| 1845 | 101.1.4 | Changes to 45.002 | 145d | 2001-12-10 A | 2002-06-28 A | 100% | 2001-12-10 | 2002-06-28 | 145d | finish no earlier than 2002-06-28 | G1 | 1160h | 1160h |  |  |  |  |  |  |  |
| 1846 | 101.1.5 | Changes to 45.003 | 145d | 2001-12-10 A | 2002-06-28 A | 100% | 2001-12-10 | 2002-06-28 | 145d | finish no earlier than 2002-06-28 | G1 | 1160h | 1160h |  |  |  |  |  |  |  |
| 1847 | 101.1.6 | Changes to 45.005 | 145d | 2001-12-10 A | 2002-06-28 A | 100% | 2001-12-10 | 2002-06-28 | 145d | finish no earlier than 2002-06-28 | G1 | 1160h | 1160h |  |  |  |  |  |  |  |
| 1848 | 101.1.7 | Changes to 24.008 | 145d | 2001-12-10 A | 2002-06-28 A | 100% | 2001-12-10 | 2002-06-28 | 145d | finish no earlier than 2002-06-28 | G2 | 1160h | 1160h |  | Gert |  |  |  |  |  |
| 1849 | 101.1.8 | Changes to 48.058 | 145d | 2001-12-10 A | 2002-06-28 A | 100% | 2001-12-10 | 2002-06-28 | 145d | finish no earlier than 2002-06-28 | G2 | 1160h | 1160h |  | Gert |  |  |  |  |  |
| 1850 | 101.2 | GERAN MS Conformance test for 8PSK HR | 530d | 2001-12-10 A | 2003-12-19 A | 100% | 2001-12-10 | 2003-12-19 | 530d | finish no earlier than 2003-12-19 | GP | 4240h | 4240h |  | Paolo |  |  |  |  |  |
| 1851 | 101.3 | GERAN BTS Conformance test for 8PSK HR | 270d | 2001-12-10 A | 2002-12-20 A | 100% | 2001-12-10 | 2002-12-20 | 270d | finish no earlier than 2002-12-20 | GP | 2160h | 2160h |  | Paolo |  |  |  |  |  |
| 1852 | 102 | Service Change and UDI Fallback | 175d | 2001-10-08 A | 2002-06-07 A | 100% | 2001-10-08 | 2002-06-07 | 175d | finish no earlier than 2002-06-07 | N3 | 1400h | 1400h | SCUDIF | Gwiho | Rel-5 |  | 29.007, 27.001, 24.008 | Ericsson | Rune.Werner.Wiik@ericsson.no |
| 1853 | 103 | **Rel-5 USIM toolkit enhancements** | 865d | 2000-06-05 A | 2003-09-26 A | 100% | 2000-06-05 | 2003-09-26 | 865d |  | T3 | 24352h | 24352h | USAT1 | Xavier | Rel-5 |  |  |  |  |
| 1854 | 103.1 | Deleted - Test specification for USIM toolkit security mechanims | 349d | 2002-05-28 A | 2003-09-26 A | 100% | 2002-05-28 | 2003-09-26 | 349d | finish no earlier than 2003-09-26 | T3 | 2792h | 2792h |  |  | Rel-5 | TP-21 |  | Gemplus | Sophie Viallet |
| 1855 | 103.2 | **Protocol Standardisation of a SIM Toolkit Interpreter** | 688d | 2000-06-05 A | 2003-01-22 A | 100% | 2000-06-05 | 2003-01-22 | 688d |  | T3 | 12512h | 12512h | USAT1-Interpr |  | Rel-5 |  | 27.103 | G & D | Michael Meyer |
| 1856 | 103.2.1 | Stage 1 | 205d | 2000-06-05 A | 2001-03-16 A | 100% | 2000-06-05 | 2001-03-16 | 205d | finish no earlier than 2001-03-16 | T3 | 1640h | 1640h |  |  |  |  |  |  |  |
| 1857 | 103.2.2 | Stage 2 and 3 | 308d | 2001-01-03 A | 2002-03-08 A | 100% | 2001-01-03 | 2002-03-08 | 308d | finish no earlier than 2002-03-08 | T3 | 2464h | 2464h |  |  |  |  |  |  |  |
| 1858 | 103.2.3 | Test specification | 363d | 2001-09-03 A | 2003-01-22 A | 100% | 2001-09-03 | 2003-01-22 | 363d | finish no earlier than 2003-01-22 | T3 | 2904h | 2904h |  |  |  |  |  | Gemplus | Gérald MAUNIER |

Notes:
- 1837: Completed 11/2001
- 1838: Not started. Marked as stopped 12/2008
- 1839: Not started. Marked as stopped 12/2008
- 1840: Completed for Rel-5
- 1850: Marked as stopped 12/2008
- 1852: [DAB - 23/05/03] - 100 % complete some issues with CAMEL
- 1854: Marked as stopped 12/2008
- 1855: 28/5/2001: T3-19 proposed that since the stage 2 and 3 will not be presented to TP-12 for approval as expected, the WI will be moved to rel-5, with completion expected at TP-13.
- 1856: 5/10/2001: Stage one comepeted at TP-12.
- 1857: 5/10/2001: TS 31.112 and 31.113 approved at TP-13. TS 31.114 to be presented to TP-14.
- 1858: 5/10/2001: Work started on test specification. Marked as closed 12/2008 (was marked 12% complete)

| ID | WBS | Task | Duration | Start | Finish | Complete | Baseline start | Baseline finish | Baseline duration | Constraint | Resources | Work | Actual work | Text1 | Text6 | Text4 | Text5 | Text8 | Text12 |
| --- | --- | --- | --- | --- | --- | --- | --- | --- | --- | --- | --- | --- | --- | --- | --- | --- | --- | --- | --- |
| 1859 | 103.4 | **(U)SIM API** | 133d | 2002-03-20 A | 2002-09-20 A | 100% | 2002-03-20 | 2002-09-20 | 133d |  | T3 | 2128h | 2128h | USAT1-API | NA |  |  |  |  |
| 1860 | 103.4.1 | Java API Test specification | 133d | 2002-03-20 A | 2002-09-20 A | 100% | 2002-03-20 | 2002-09-20 | 133d | finish no earlier than 2002-09-20 | T3 | 1064h | 1064h |  |  | Microelectrónica Española | Mario Pérez |  |  |
| 1861 | 104 | **small Technical Enhancements and Improvements for Rel5** | 2349d? | 2000-01-03 A | 2008-12-31 A | 100% | 2000-01-03 | 2008-12-31 | 2349d? |  | All | 18784h | 18784h | TEI5 | Rel-5 |  |  |  |  |
| 1862 | 459.1 | Small Technical Enhancements and Improvements for Rel-5 Conformance Testing | 2349d? | 2000-01-03 A | 2008-12-31 A | 100% | 2000-01-03 | 2008-12-31 | 2349d? | finish no earlier than 2008-12-31 | R5 | 18784h | 18784h | TEI5_Test | Rel-5 |  |  | Ingbert |  |
| 1863 | 105 | Deleted - Technical Report on UE Functionality Split | 87d | 2000-01-03 A | 2000-05-01 A | 100% | 2000-01-03 | 2000-05-01 | 87d |  | S1 [98.9%] | 688h | 688h | UESPLIT | Rel-5 | Motorola | sanjay.gupta@motorola.com | Alain | SP-08 |
| 1864 | 106 | **User Equipment Management** | 267d | 2001-06-21 A | 2002-06-28 A | 100% | 2001-06-21 | 2002-06-28 | 267d |  | S5 | 3752h | 3752h | UEM | Rel-5 | Vodafone | john.mudge@vf.vodafone.co.uk | Dionisio |  |
| 1865 | 106.1 | FS on User Equipment (UE) Management | 267d | 2001-06-21 A | 2002-06-28 A | 100% | 2001-06-21 | 2002-06-28 | 267d | finish no earlier than 2002-06-28 | S5 | 2136h | 2136h | OAM-UEM | Rel-5 | Vodafone | john.mudge@vf.vodafone.co.uk | Dionisio |  |
| 1866 | 107 | **Flow control supporting an MS with multiple data flows with different QoS over the Gb interface** | 50d | 2002-06-24 A | 2002-08-30 A | 100% | 2002-06-24 | 2002-08-30 | 50d |  | GP | 1288h | 1288h | FlowCon | Rel-5 | Ericsson | ingemar.backlund@era.ericsson.se | Paolo |  |
| 1867 | 107.1 | **Update of stage 2 specifications** | 50d | 2002-06-24 A | 2002-08-30 A | 100% | 2002-06-24 | 2002-08-30 | 50d |  | GP | 808h | 808h |  |  |  |  | Paolo |  |
| 1868 | 107.1.1 | Concept document 23.060 (changes to) | 46d | 2002-06-28 A | 2002-08-30 A | 100% | 2002-06-28 | 2002-08-30 | 46d | finish no earlier than 2002-08-30 | S2 | 368h | 368h |  |  |  |  | Maurice |  |
| 1869 | 107.1.2 | Flow Control | 5d | 2002-06-24 A | 2002-06-28 A | 100% | 2002-06-24 | 2002-06-28 | 5d | finish no earlier than 2002-06-28 | GP | 40h | 40h |  |  |  |  | Paolo |  |
| 1870 | 107.2 | **Modification of BSSGP protocol** | 5d | 2002-06-24 A | 2002-06-28 A | 100% | 2002-06-24 | 2002-06-28 | 5d |  | GP | 80h | 80h |  |  | Ericsson | ingemar.backlund@era.ericsson.se | Paolo |  |
| 1871 | 107.2.1 | Stage 3 (changes to 48.018) | 5d | 2002-06-24 A | 2002-06-28 A | 100% | 2002-06-24 | 2002-06-28 | 5d | finish no earlier than 2002-06-28 | G2 | 40h | 40h |  |  |  |  | Gert |  |
| 1872 | 108 | **Multiple TBF in A/Gb mode** | 421d | 2002-04-19 A | 2003-11-28 A | 100% | 2002-04-19 | 2003-11-28 | 421d |  | GP | 17480h | 17480h | MULTBF | Rel-5 | Ericsson | gunnar.mildh@era.ericsson.se | Paolo |  |
| 1873 | 108.1 | **Multiple TBF in A/Gb mode** | 351d | 2002-04-19 A | 2003-08-22 A | 100% | 2002-04-19 | 2003-08-22 | 351d |  | GP | 8112h | 8112h | MULTBF-Agbmode |  |  |  | Paolo |  |
| 1874 | 108.1.1 | Multiple TBF Concept paper | 351d | 2002-04-19 A | 2003-08-22 A | 100% | 2002-04-19 | 2003-08-22 | 351d | finish no earlier than 2003-08-22 | GP | 2808h | 2808h |  |  |  |  | Paolo |  |
| 1875 | 108.1.2 | Deleted - Multiple TBF Stage 2 (43.064) CRs | 156d | 2002-04-19 A | 2002-11-22 A | 100% | 2002-04-19 | 2002-11-22 | 156d | finish no earlier than 2002-11-22 | G1 | 1248h | 1248h |  |  |  |  |  | GP-12 |
| 1876 | 108.1.3 | Deleted - Multiple TBF Stage 3 (44.060) CRs | 156d | 2002-04-19 A | 2002-11-22 A | 100% | 2002-04-19 | 2002-11-22 | 156d | finish no earlier than 2002-11-22 | G2 | 1248h | 1248h |  |  |  |  | Gert | GP-12 |
| 1877 | 108.2 | **Deleted - Multiple TBF in A/Gb mode – MS testing** | 375d | 2002-06-24 A | 2003-11-28 A | 100% | 2002-06-24 | 2003-11-28 | 375d |  | GP | 6000h | 6000h |  |  | Ericsson | ingemar.backlund@era.ericsson.se | Paolo | GP-17 |
| 1878 | 108.2.1 | Deleted - MS conformance tests | 375d | 2002-06-24 A | 2003-11-28 A | 100% | 2002-06-24 | 2003-11-28 | 375d | finish no earlier than 2003-11-28 | G4 | 3000h | 3000h |  |  |  |  | Paolo | GP-17 |
| 1879 | 109 | **Alignment of 3G functional split and Iu** | 922d | 2000-06-08 A | 2003-12-19 A | 100% | 2000-06-08 | 2003-12-19 | 922d |  | GP | 126664h | 126664h | GER3GAL | Rel-5 | Ericsson | Frank Muller | Paolo |  |
| 1880 | 109.1 | **GERAN user / control plane** | 540d | 2000-08-07 A | 2002-08-30 A | 100% | 2000-08-07 | 2002-08-30 | 540d |  | GP | 36232h | 36232h | GER3GAL-GUCOPL |  | Ericsson | Frank Muller | Paolo |  |
| 1881 | 109.1.1 | **Alignment with UMTS bearer concept** | 540d | 2000-08-07 A | 2002-08-30 A | 100% | 2000-08-07 | 2002-08-30 | 540d |  | GP | 24952h | 24952h |  |  |  |  | Paolo |  |
| 1882 | 109.1.1.1 | Enhanced power control | 1d | 2001-08-31 A | 2001-08-31 A | 100% | 2001-08-31 | 2001-08-31 | 1d | finish no earlier than 2001-08-31 | GP | 8h | 8h |  |  |  |  | Paolo |  |
| 1883 | 109.1.1.2 | Stage 2 | 235d | 2000-08-07 A | 2001-06-29 A | 100% | 2000-08-07 | 2001-06-29 | 235d | finish no earlier than 2001-06-29 | GP | 1880h | 1880h |  |  |  |  | Paolo |  |
| 1884 | 109.1.1.3 | Adoption of the UTRAN PDCP | 295d | 2000-11-06 A | 2001-12-21 A | 100% | 2000-11-06 | 2001-12-21 | 295d | finish no earlier than 2001-12-21 | GP | 2360h | 2360h |  |  |  |  | Paolo |  |
| 1885 | 109.1.1.4 | Development of RLC / MAC | 261d | 2001-08-31 A | 2002-08-30 A | 100% | 2001-08-31 | 2002-08-30 | 261d | finish no earlier than 2002-08-30 | GP | 2088h | 2088h |  |  |  |  | Paolo |  |
| 1886 | 109.1.1.5 | Development of GERAN RRC | 266d | 2001-06-22 A | 2002-06-28 A | 100% | 2001-06-22 | 2002-06-28 | 266d | finish no earlier than 2002-06-28 | GP | 2128h | 2128h |  |  |  |  | Paolo |  |
| 1887 | 109.1.1.6 | Ciphering and integrity protection concept paper | 166d | 2001-08-31 A | 2002-04-19 A | 100% | 2001-08-31 | 2002-04-19 | 166d | finish no earlier than 2002-04-19 | GP | 1328h | 1328h |  |  |  |  | Paolo |  |
| 1888 | 109.1.1.7 | Multiple TBF or equivalent Concept paper | 116d | 2001-08-31 A | 2002-02-08 A | 100% | 2001-08-31 | 2002-02-08 | 116d | finish no earlier than 2002-02-08 | GP | 928h | 928h |  |  |  |  | Paolo |  |
| 1889 | 109.1.1.8 | Paging concept | 166d | 2001-08-31 A | 2002-04-19 A | 100% | 2001-08-31 | 2002-04-19 | 166d | finish no earlier than 2002-04-19 | GP | 1328h | 1328h |  |  |  |  | Paolo |  |
| 1890 | 109.1.1.9 | Dedicated Physical subchannels, includes traffic and control channels | 66d | 2001-08-31 A | 2001-11-30 A | 100% | 2001-08-31 | 2001-11-30 | 66d | finish no earlier than 2001-11-30 | GP | 528h | 528h |  |  |  |  | Paolo |  |
| 1891 | 109.1.1.10 | Iu support and broadcast concept | 166d | 2001-08-31 A | 2002-04-19 A | 100% | 2001-08-31 | 2002-04-19 | 166d | finish no earlier than 2002-04-19 | GP | 1328h | 1328h |  |  |  |  | Paolo |  |
| 1892 | 109.1.1.11 | Impact of using RLC instead of LAPDm concept | 116d | 2001-08-31 A | 2002-02-08 A | 100% | 2001-08-31 | 2002-02-08 | 116d | finish no earlier than 2002-02-08 | GP | 928h | 928h |  |  |  |  | Paolo |  |
| 1893 | 109.1.1.12 | Contention resolution, mobile station identity, and access concept | 66d | 2001-08-31 A | 2001-11-30 A | 100% | 2001-08-31 | 2001-11-30 | 66d | finish no earlier than 2001-11-30 | GP | 528h | 528h |  |  |  |  | Paolo |  |
| 1894 | 109.1.1.13 | PDCP concept | 166d | 2001-08-31 A | 2002-04-19 A | 100% | 2001-08-31 | 2002-04-19 | 166d | finish no earlier than 2002-04-19 | GP | 1328h | 1328h |  |  |  |  | Paolo |  |
| 1895 | 109.1.1.14 | Downlink delayed TBF release | 261d | 2001-08-31 A | 2002-08-30 A | 100% | 2001-08-31 | 2002-08-30 | 261d | finish no earlier than 2002-08-30 | GP | 2088h | 2088h |  |  |  |  | Paolo |  |
| 1896 | 109.1.1.15 | Add transparent RLC Concept | 116d | 2001-08-31 A | 2002-02-08 A | 100% | 2001-08-31 | 2002-02-08 | 116d | finish no earlier than 2002-02-08 | GP | 928h | 928h |  |  |  |  | Paolo |  |
| 1897 | 109.1.1.16 | Handover concept | 116d | 2001-08-31 A | 2002-02-08 A | 100% | 2001-08-31 | 2002-02-08 | 116d | finish no earlier than 2002-02-08 | GP | 928h | 928h |  |  |  |  | Paolo |  |

Notes:
- 1859: 8/3/2001: test spec is based on R99 core spec, so deleted from Workplan
- 1861: "Joker" WI, to be used for a Rel 5 CR not related to any feature and with very limited impact on the system
- 1862: "Joker" WI, to be used for small modifications applicable to Rel 5 conformance testing. Moved in from Stoyan/testing WP. / Text3: 34.108, 34.109, 34.121-1, 34.121-2, 34.122, 34.123-1, 34.123-2, 34.123-3, 34.171, 34.229-1, 34.229-2, 34.229-3
- 1865: Text3: 32.802
- 1866: 50101 -> 50201
- 1867: 50102 -> 50202
- 1869: 50103 -> 50203
- 1873: Marked as closed 12/2008 (was marked 26% complete)
- 1874: Marked as closed 12/2008 (was marked 50% complete)
- 1875: Marked as stopped 12/2008
- 1876: Marked as stopped 12/2008
- 1877: 08/08: duplicate UID_50106=-> 50206. Marked as stopped 12/2008
- 1878: Not started. Marked as stopped 12/2008
- 1879: AWS, Nokia, Ericsson, Nortel, Siemens, Vodafone
- 1880: AWS, Nokia, Ericsson, Nortel, Siemens, Vodafone
- 1884: Responsible is GERAN; RAN WG2 help may be needed.

| ID | WBS | Task | Duration | Start | Finish | Complete | Baseline start | Baseline finish | Baseline duration | Constraint | Resources | Work | Actual work | Text8 | Text1 | Text4 | Text5 |
| --- | --- | --- | --- | --- | --- | --- | --- | --- | --- | --- | --- | --- | --- | --- | --- | --- | --- |
| 1898 | 109.1.2 | **Physical layer alignment with UMTS bearer concept** | 280d | 2000-11-06 A | 2001-11-30 A | 100% | 2000-11-06 | 2001-11-30 | 280d |  | GP | 6960h | 6960h | Paolo |  |  |  |
| 1899 | 109.1.2.1 | PDTCH/TCH in 45.003 | 155d | 2000-11-06 A | 2001-06-08 A | 100% | 2000-11-06 | 2001-06-08 | 155d | finish no earlier than 2001-06-08 | GP | 1240h | 1240h | Paolo |  |  |  |
| 1900 | 109.1.2.2 | Control channels in 45.003 | 155d | 2000-11-06 A | 2001-06-08 A | 100% | 2000-11-06 | 2001-06-08 | 155d | finish no earlier than 2001-06-08 | GP | 1240h | 1240h | Paolo |  |  |  |
| 1901 | 109.1.2.3 | Receiver performance in 45.005 for PDTCH/TCH and control channels | 280d | 2000-11-06 A | 2001-11-30 A | 100% | 2000-11-06 | 2001-11-30 | 280d | finish no earlier than 2001-11-30 | GP | 2240h | 2240h | Paolo |  |  |  |
| 1902 | 109.2 | **Iu rg interface** | 430d | 2000-11-06 A | 2002-06-28 A | 100% | 2000-11-06 | 2002-06-28 | 430d |  | GP,RP | 39560h | 39560h | Paolo | GER3GAL-Iurg | Ericsson | Frank Muller |
| 1903 | 109.2.1 | **Inter BSS interface** | 430d | 2000-11-06 A | 2002-06-28 A | 100% | 2000-11-06 | 2002-06-28 | 430d |  | GP,RP | 20640h | 20640h | Paolo |  |  |  |
| 1904 | 109.2.1.1 | Identification of requirements | 430d | 2000-11-06 A | 2002-06-28 A | 100% | 2000-11-06 | 2002-06-28 | 430d | finish no earlier than 2002-06-28 | GP | 3440h | 3440h | Paolo |  |  |  |
| 1905 | 109.2.1.2 | Stage 2 | 430d | 2000-11-06 A | 2002-06-28 A | 100% | 2000-11-06 | 2002-06-28 | 430d | finish no earlier than 2002-06-28 | GP | 3440h | 3440h | Paolo |  |  |  |
| 1906 | 109.2.1.3 | Adoption of relevant parts from Iur | 430d | 2000-11-06 A | 2002-06-28 A | 100% | 2000-11-06 | 2002-06-28 | 430d | finish no earlier than 2002-06-28 | GP | 3440h | 3440h | Paolo |  |  |  |
| 1907 | 109.2.1.4 | Complementation with GERAN specifics | 430d | 2000-11-06 A | 2002-06-28 A | 100% | 2000-11-06 | 2002-06-28 | 430d | finish no earlier than 2002-06-28 | GP | 3440h | 3440h | Paolo |  |  |  |
| 1908 | 109.2.1.5 | Stage 3 | 430d | 2000-11-06 A | 2002-06-28 A | 100% | 2000-11-06 | 2002-06-28 | 430d | finish no earlier than 2002-06-28 | GP | 3440h | 3440h | Paolo |  |  |  |
| 1909 | 109.2.2 | **Inter BSS-RNS interface** | 430d | 2000-11-06 A | 2002-06-28 A | 100% | 2000-11-06 | 2002-06-28 | 430d |  | GP,RP | 15480h | 15480h | Paolo |  |  |  |
| 1910 | 109.2.2.1 | Identification of requirements | 430d | 2000-11-06 A | 2002-06-28 A | 100% | 2000-11-06 | 2002-06-28 | 430d | start no earlier than 2000-11-06 | GP,R3 | 3440h | 3440h | Paolo |  |  |  |
| 1911 | 109.2.2.2 | Stage 2 | 430d | 2000-11-06 A | 2002-06-28 A | 100% | 2000-11-06 | 2002-06-28 | 430d | finish no earlier than 2002-06-28 | GP,R3 | 3440h | 3440h | Paolo |  |  |  |
| 1912 | 109.2.2.3 | Adoption of relevant parts from Iur | 430d | 2000-11-06 A | 2002-06-28 A | 100% | 2000-11-06 | 2002-06-28 | 430d | finish no earlier than 2002-06-28 | GP,R3 | 3440h | 3440h | Paolo |  |  |  |
| 1913 | 109.2.2.4 | Complementation with GERAN specifics | 107.5d | 2002-01-30 A | 2002-06-28 A | 100% | 2002-01-30 | 2002-06-28 | 107.5d | finish no earlier than 2002-06-28 | GP,R3 | 860h | 860h | Paolo |  |  |  |
| 1914 | 109.2.2.5 | Stage 3 | 107.5d | 2002-01-30 A | 2002-06-28 A | 100% | 2002-01-30 | 2002-06-28 | 107.5d | finish no earlier than 2002-06-28 | GP,R3 | 860h | 860h | Paolo |  |  |  |
| 1915 | 109.3 | **Voice over GERAN PS and CS concept** | 430d | 2000-11-06 A | 2002-06-28 A | 100% | 2000-11-06 | 2002-06-28 | 430d |  | GP,R3 | 18520h | 18520h | Paolo |  |  |  |
| 1916 | 109.3.1 | Architecture for A, Iu cs and Iu ps | 430d | 2000-11-06 A | 2002-06-28 A | 100% | 2000-11-06 | 2002-06-28 | 430d | finish no earlier than 2002-06-28 | GP,R3 | 3440h | 3440h | Paolo |  |  |  |
| 1917 | 109.3.2 | Transcoder position/operation | 115d | 2000-11-06 A | 2001-04-13 A | 100% | 2000-11-06 | 2001-04-13 | 115d | finish no earlier than 2001-04-13 | GP | 920h | 920h | Paolo |  |  |  |
| 1918 | 109.3.3 | Handover | 430d | 2000-11-06 A | 2002-06-28 A | 100% | 2000-11-06 | 2002-06-28 | 430d | finish no earlier than 2002-06-28 | GP,R3 | 3440h | 3440h | Paolo |  |  |  |
| 1919 | 109.3.4 | RTP payload | 430d | 2000-11-06 A | 2002-06-28 A | 100% | 2000-11-06 | 2002-06-28 | 430d | finish no earlier than 2002-06-28 | GP,R3 | 3440h | 3440h | Paolo |  |  |  |
| 1920 | 109.3.5 | Codec renegotiation concept | 365d | 2000-11-06 A | 2002-03-29 A | 100% | 2000-11-06 | 2002-03-29 | 365d | finish no earlier than 2002-03-29 | GP,R3 | 2920h | 2920h | Paolo |  |  |  |
| 1921 | 109.3.6 | LA | 115d | 2000-11-06 A | 2001-04-13 A | 100% | 2000-11-06 | 2001-04-13 | 115d | finish no earlier than 2001-04-13 | GP | 920h | 920h | Paolo |  |  |  |

Notes:
- 1902: AWS, Nokia, Ericsson, Nortel, Siemens, Vodafone

| ID | WBS | Task | Duration | Start | Finish | Complete | Baseline start | Baseline finish | Baseline duration | Total slack | Constraint | Resources | Work | Actual work | Text8 | Text12 | Text1 | Text4 | Text5 | Text6 |
| --- | --- | --- | --- | --- | --- | --- | --- | --- | --- | --- | --- | --- | --- | --- | --- | --- | --- | --- | --- | --- |
| 1922 | 109.4 | **Deleted - GERAN MS Conformance test for GERAN interface evolution** | 660d | 2001-06-11 A | 2003-12-19 A | 100% | 2001-06-11 | 2003-12-19 | 660d |  |  | GP | 10560h | 10560h | Paolo | GP-17 |  |  |  |  |
| 1923 | 109.4.1 | Deleted - MS test | 660d | 2001-06-11 A | 2003-12-19 A | 100% | 2001-06-11 | 2003-12-19 | 660d |  | finish no earlier than 2003-12-19 | GP | 5280h | 5280h | Paolo | GP-17 |  |  |  |  |
| 1924 | 109.5 | **GERAN BSS Conformance test for GERAN interface evolution** | 922d | 2000-06-08 A | 2003-12-19 A | 100% | 2000-06-08 | 2003-12-19 | 922d |  |  | GP | 14752h | 14752h | Paolo |  |  |  |  |  |
| 1925 | 109.5.1 | Deleted - BSS test | 922d | 2000-06-08 A | 2003-12-19 A | 100% | 2000-06-08 | 2003-12-19 | 922d |  | finish no earlier than 2003-12-19 | GP | 7376h | 7376h | Paolo | GP-17 |  |  |  |  |
| 1926 | 110 | **GERAN support for IMS** | 690d | 2000-05-01 A | 2002-12-20 A | 100% | 2000-05-01 | 2002-12-20 | 690d |  |  | GP | 39198.4h | 39198.4h | Paolo |  | GERIMS | Nokia | Shkumbin Hamiti | Rel-5 |
| 1927 | 110.1 | **GERAN Header adaptation** | 690d | 2000-05-01 A | 2002-12-20 A | 100% | 2000-05-01 | 2002-12-20 | 690d |  |  | GP,S2,RP | 12302.8h | 12302.8h | Paolo |  | GERIMS-HEADAPT | Nokia | Shkumbin Hamiti |  |
| 1928 | 110.1.1 | Definition of compression and removal modes for PDCP protocol | 15.05d | 2000-05-01 A | 2000-06-09 A | 100% | 2000-05-01 | 2000-06-09 | 15.05d |  | finish no earlier than 2000-09-01 | GP,S2,RP | 120.4h | 120.4h | Paolo |  |  |  |  |  |
| 1929 | 110.1.2 | Conceptual description in stage 2 | 393d | 2000-05-01 A | 2001-10-31 A | 100% | 2000-05-01 | 2001-10-31 | 393d |  | finish no earlier than 2001-10-31 | GP,S2,RP | 3144h | 3144h | Paolo |  |  |  |  |  |
| 1930 | 110.1.3 | Necessary changes on stage 3 regarding header removal | 439.8d | 2000-11-06 A | 2002-12-20 A | 100% | 2000-11-06 | 2002-12-20 | 439.8d |  | finish no earlier than 2002-12-20 | GP,S2,RP | 3518.4h | 3518.4h | Paolo |  |  |  |  |  |
| 1931 | 110.2 | **Deleted - GERAN Radio access bearer design for IMS** | 430d | 2000-11-06 A | 2002-06-28 A | 100% | 2000-11-06 | 2002-06-28 | 430d |  |  | GP,S2,RP | 9287.6h | 9287.6h | Paolo | GP-10 | GERIMS-RABDES | Nokia | Shkumbin Hamiti |  |
| 1932 | 110.2.1 | **Deleted - MuM control signalling for conversational multimedia services** | 430d | 2000-11-06 A | 2002-06-28 A | 100% | 2000-11-06 | 2002-06-28 | 430d |  |  | GP,S2,RP | 5847.6h | 5847.6h | Paolo | GP-10 |  |  |  |  |
| 1933 | 110.2.1.1 | Deleted - Identification of requirements | 330d | 2000-11-06 A | 2002-02-08 A | 100% | 2000-11-06 | 2002-02-08 | 330d |  | finish no earlier than 2002-02-08 | GP,S2,RP | 2640h | 2640h | Paolo | GP-08 |  |  |  |  |
| 1934 | 110.2.1.2 | Deleted - Necessary modifications due to SIP | 40d | 2002-05-06 A | 2002-06-28 A | 100% | 2002-05-06 | 2002-06-28 | 40d |  | finish no earlier than 2002-06-28 | GP,S2,RP | 320h | 320h | Paolo | GP-10 |  |  |  |  |
| 1935 | 110.3 | **Deleted - GERAN MS Conformance test for support of IMS** | 400d | 2001-06-11 A | 2002-12-20 A | 100% | 2001-06-11 | 2002-12-20 | 400d |  |  | GP | 6400h | 6400h | Paolo | GP-12 | GERIMS-MSconf | Nokia | Shkumbin Hamiti |  |
| 1936 | 110.3.1 | Deleted - MS test | 400d | 2001-06-11 A | 2002-12-20 A | 100% | 2001-06-11 | 2002-12-20 | 400d |  | finish no earlier than 2002-12-20 | G4 | 3200h | 3200h | Paolo | GP-12 |  |  |  |  |
| 1937 | 110.4 | **Deleted - GERAN BTS Conformance test for support of IMS** | 400d | 2001-06-11 A | 2002-12-20 A | 100% | 2001-06-11 | 2002-12-20 | 400d |  |  | GP | 6400h | 6400h | Paolo | GP-12 | GERIMS-BTSconf | Nokia | Shkumbin Hamiti |  |
| 1938 | 110.4.1 | Deleted - BTS test | 400d | 2001-06-11 A | 2002-12-20 A | 100% | 2001-06-11 | 2002-12-20 | 400d |  | finish no earlier than 2002-12-20 | G3new | 3200h | 3200h | Ingbert | GP-12 |  |  |  |  |
| 1939 | 466 | MS Conformance Testing of Dual Transfer Mode | 65d? | 2002-11-11 A | 2003-02-07 A | 100% | 2002-11-11 | 2003-02-07 | 65d? |  | finish no earlier than 2003-02-07 | G4,G5 | 520h | 520h | Paolo |  | MSCTDTM | Vodafone | Dave Fox | NA |
| 1940 | 467 | **Handling of early UEs** | 911d? | 2000-01-03 A | 2003-06-27 A | 100% | 2000-01-03 | 2003-06-27 | 911d? |  |  | S2 | 4480h | 4480h | Maurice |  | LATE_UE |  |  | Rel-5 |
| 1941 | 467.1 | Feasibility Study | 50d? | 2002-10-07 A | 2002-12-13 A | 100% | 2002-10-07 | 2002-12-13 | 50d? |  | finish no earlier than 2002-12-13 | S2 | 400h | 400h | Maurice |  |  |  |  |  |
| 1942 | 467.2 | Stage 2 | 125d? | 2003-01-06 A | 2003-06-27 A | 100% | 2003-01-06 | 2003-06-27 | 125d? |  | start no earlier than 2003-01-06 | S2 | 1000h | 1000h | Maurice |  |  |  |  |  |
| 1943 | 467.3 | FS for the Early Mobile Handling in UTRAN | 195d | 2002-09-09 A | 2003-06-06 A | 100% | 2002-09-09 | 2003-06-06 | 195d |  | finish no earlier than 2003-06-06 | R2 | 1560h | 1560h | Joern |  | FSEarlyUE | Vodafone | Alan Law | Rel-5 |
| 1944 | 467.4 | Note: Stage 3 RAN part not shown | 1d | 2000-01-03 A | 2000-01-03 A | 100% | 2000-01-03 | 2000-01-03 | 1d |  |  |  |  |  |  |  |  |  |  |  |
| 1945 | 468 | Release 4 Features | 1d? | 2000-01-03 | 2000-01-03 |  | 2000-01-03 | 2000-01-03 | 1d? | 2791d |  | CP,GP, RP,SP,TP | 8h |  |  |  |  |  |  | Rel-4 |

Notes:
- 1922: Not started. Marked as stopped 12/2008
- 1923: Not started. Marked as stopped 12/2008
- 1924: Not started. Marked as stopped 12/2008
- 1925: Not started. Marked as stopped 12/2008
- 1926: AWS, Nokia, Ericsson, Nortel, Siemens, Motorola
- 1927: AWS, Nokia, Ericsson, Nortel, Siemens, Motorola
- 1931: TERMINATED - NOT STANDARDIZED. Marked as stopped 12/2008
- 1932: TERMINATED - NOT STANDARDIZED. Marked as stopped 12/2008
- 1933: TERMINATED - NOT STANDARDIZED
- 1934: TERMINATED - NOT STANDARDIZED
- 1935: TERMINATED - NOT STANDARDIZED. Marked as stopped 12/2008
- 1936: TERMINATED - NOT STANDARDIZED. Marked as stopped 12/2008
- 1937: TERMINATED - NOT STANDARDIZED. Marked as stopped 12/2008
- 1938: TERMINATED - NOT STANDARDIZED. Marked as stopped 12/2008
- 1939: Needed to complete DTM (R99)

| ID | WBS | Task | Duration | Start | Finish | Predecessors | Complete | Baseline start | Baseline finish | Baseline duration | Constraint | Resources | Work | Actual work | Text1 | Text6 | Text8 | Text3 | Text12 | Text4 | Text5 |
| --- | --- | --- | --- | --- | --- | --- | --- | --- | --- | --- | --- | --- | --- | --- | --- | --- | --- | --- | --- | --- | --- |
| 1946 | 15 | **Miscelleneous UE Conformance Testing Activities** | 958d | 2001-04-02 A | 2004-12-01 A |  | 100% | 2001-04-02 | 2004-12-01 | 958d |  | T1 | 36360h | 36360h | MISTST1 | NA | Ingbert |  |  |  |  |
| 1947 | 15.1 | Optimisation of Test Time, RF Aspects (FDD) | 508d | 2001-09-24 A | 2003-09-03 A |  | 100% | 2001-09-24 | 2003-09-03 | 508d | finish no earlier than 2003-09-03 | T1 | 4064h | 4064h | MISTST1-OpFDD | Rel Indep | Ingbert | 34.121 |  |  |  |
| 1948 | 15.2 | Optimisation of Test Time, RF Aspects (TDD) | 508d | 2001-09-24 A | 2003-09-03 A |  | 100% | 2001-09-24 | 2003-09-03 | 508d | finish no earlier than 2003-09-03 | T1 | 4064h | 4064h | MISTST1-OpTDD | Rel Indep | Ingbert | 34.122 |  |  |  |
| 1949 | 15.3 | Extensions to R99 Test cases | 139.4w | 2001-04-02 A | 2003-12-02 A |  | 100% | 2001-04-02 | 2003-12-02 | 139.4w | finish no earlier than 2003-12-02 | T1 | 5576h | 5576h | MISTST1-Ext |  | Ingbert | 34.123 p 1,2 |  |  |  |
| 1950 | 15.4 | Extension to R99 Test cases - TTCN | 439d | 2002-06-28 A | 2004-03-03 A |  | 100% | 2002-06-28 | 2004-03-03 | 439d | finish no earlier than 2004-03-03 | T1 | 3512h | 3512h |  |  | Ingbert |  |  |  |  |
| 1951 | 15.5 | Creation of R99 TCs for TDD - prose | 719d | 2001-10-01 A | 2004-07-01 A |  | 100% | 2001-10-01 | 2004-07-01 | 719d | finish no earlier than 2004-07-01 | T1 | 5752h | 5752h | MISTST1-TDD |  | Ingbert | 34.123-1 |  |  |  |
| 1952 | 15.6 | Deleted - Creation of R99 TCs for TDD - TTCN | 587d | 2002-09-03 A | 2004-12-01 A |  | 100% | 2002-09-03 | 2004-12-01 | 587d | finish no earlier than 2004-12-01 | T1 | 4696h | 4696h |  |  | Ingbert |  | TP-26 |  |  |
| 1953 | 15.7 | Deleted - Review all other work items for impact on new or exiting 34 series specs. | 25.8w | 2002-07-02 A | 2002-12-27 A |  | 100% | 2002-07-02 | 2002-12-27 | 25.8w | finish no earlier than 2002-12-27 | T1 | 1032h | 1032h | MISTST1 |  | Ingbert | 34.121,122,123,125 | TP-18 |  |  |
| 1954 | 46 | **Facsimile** | 89d | 2000-02-22 A | 2000-06-23 A |  | 100% | 2000-02-22 | 2000-06-23 | 89d |  | S1 | 4376h | 4376h | FAX | Rel-4 | Alain |  |  |  |  |
| 1955 | 46.1 | **Real Time Fax** | 89d | 2000-02-22 A | 2000-06-23 A |  | 100% | 2000-02-22 | 2000-06-23 | 89d |  | S2 | 3664h | 3664h | FAX-RT |  | Maurice |  |  |  |  |
| 1956 | 46.1.1 | Terminal capabilities, AT commands | 89d | 2000-02-22 A | 2000-06-23 A |  | 100% | 2000-02-22 | 2000-06-23 | 89d | finish no earlier than 2000-06-23 | T2 | 712h | 712h |  |  |  | 21.904, 27.007 |  |  |  |
| 1957 | 46.1.2 | Signalling aspects (e.g. ICM) | 89d | 2000-02-22 A | 2000-06-23 A |  | 100% | 2000-02-22 | 2000-06-23 | 89d | start no earlier than 2000-02-22 | N1 | 712h | 712h |  |  | Frederic |  |  |  |  |
| 1958 | 46.1.3 | Service provision | 89d | 2000-02-22 A | 2000-06-23 A |  | 100% | 2000-02-22 | 2000-06-23 | 89d | finish no earlier than 2000-06-23 | N3 | 712h | 712h |  |  | Gwiho | 23.146 |  |  |  |
| 1959 | 46.1.4 | Review whether service/stage 1 aspects need to be aligned | 51d | 2000-04-14 A | 2000-06-23 A |  | 100% | 2000-04-14 | 2000-06-23 | 51d | finish no earlier than 2000-12-14 | S1 | 408h | 408h |  |  | Alain |  |  |  |  |
| 1960 | 46.1.5 | Review whether architecture/stage 2 aspects need to be aligned | 51d | 2000-04-14 A | 2000-06-23 A |  | 100% | 2000-04-14 | 2000-06-23 | 51d | finish no earlier than 2000-12-14 | S2 | 408h | 408h |  |  | Maurice |  |  |  |  |
| 1961 | 47 | Transparent End-to-End PS mobile streaming application | 253d | 2000-04-03 A | 2001-03-21 A |  | 100% | 2000-04-03 | 2001-03-21 | 253d | finish no earlier than 2000-12-29 | S4 | 2024h | 2024h | PSTREAM | Rel-4 | Paolo | 26.233, 26.234 |  |  |  |
| 1962 | 48 | **Multimedia Messaging** | 277d | 2000-02-22 A | 2001-03-14 A |  | 100% | 2000-02-22 | 2001-03-14 | 277d |  | T2 | 12208h | 12208h | MMS | Rel-4 | Kimmo | 22.140, 23.140 |  | Siemens | Josef.Laumen@SAL.SIEMENS.DE |
| 1963 | 48.1 | Definition of service requirements | 72d | 2000-02-22 A | 2000-05-31 A |  | 100% | 2000-02-22 | 2000-05-31 | 72d | start no earlier than 2000-02-22 | S1 | 576h | 576h | MMS |  | Alain |  |  |  |  |
| 1964 | 48.2 | Review of definition of service requirements | 205d | 2000-06-01 A | 2001-03-14 A | 1963 | 100% | 2000-06-01 | 2001-03-14 | 205d | finish no earlier than 2000-09-08 | T2 | 1640h | 1640h |  |  |  | 22.140, 23.140 |  | Siemens |  |
| 1965 | 48.3 | **Technical Realisation** | 243d | 2000-04-10 A | 2001-03-14 A |  | 100% | 2000-04-10 | 2001-03-14 | 243d |  | T2 | 7776h | 7776h |  |  |  | 22.140, 23.140 |  | Siemens | Josef.Laumen@SAL.SIEMENS.DE |
| 1966 | 48.3.1 | Review of definition of reference Achitecture model | 243d | 2000-04-10 A | 2001-03-14 A |  | 100% | 2000-04-10 | 2001-03-14 | 243d | finish no earlier than 2001-03-14 | T2 | 1944h | 1944h |  |  |  | 22.140, 23.140 |  | Siemens | Josef.Laumen@SAL.SIEMENS.DE |
| 1967 | 48.3.2 | "Fulfill Requirements of Stage 1" | 243d | 2000-04-10 A | 2001-03-14 A |  | 100% | 2000-04-10 | 2001-03-14 | 243d | finish no earlier than 2001-03-14 | T2 | 1944h | 1944h |  |  |  | 22.140, 23.140 |  | Siemens | Josef.Laumen@SAL.SIEMENS.DE |
| 1968 | 48.3.3 | Definition of MMS primitives in Stage 2 | 243d | 2000-04-10 A | 2001-03-14 A |  | 100% | 2000-04-10 | 2001-03-14 | 243d | finish no earlier than 2001-03-14 | T2 | 1944h | 1944h |  |  |  | 22.140, 23.140 |  | Siemens | Josef.Laumen@SAL.SIEMENS.DE |
| 1969 | 49 | **Transcoder-Free Operation** | 326d | 2000-01-03 A | 2001-03-30 A |  | 100% | 2000-01-03 | 2001-03-30 | 326d |  | N4 | 13056h | 13056h | TrFO | Rel-4 | Kimmo |  |  |  |  |
| 1970 | 49.1 | **OoBTC solution** | 326d | 2000-01-03 A | 2001-03-30 A |  | 100% | 2000-01-03 | 2001-03-30 | 326d |  | N4 | 8448h | 8448h | TRFO-OOBTC |  | Kimmo |  |  | NEC | Toshiyuki Tamura (tamurato@aj.jp.nec.com) |
| 1971 | 49.1.1 | implementation in UTRAN | 145d | 2000-09-11 A | 2001-03-30 A |  | 100% | 2000-09-11 | 2001-03-30 | 145d | finish no earlier than 2001-03-30 | R3 | 1160h | 1160h | TRFO-OOBTC-UTRAN |  | Juha | 25.401, 25.410, 25.413, 25.415, 23.153 |  | Siemens | Alexander Vesely |
| 1972 | 49.1.2 | Impact on architecture, Principles and Terminology | 211d | 2000-01-03 A | 2000-10-20 A |  | 100% | 2000-01-03 | 2000-10-20 | 211d | finish no earlier than 2000-10-20 | S2 | 1680h | 1680h |  |  | Maurice |  |  |  |  |
| 1973 | 49.1.3 | Codec Negotiation between UE and MSC | 125d | 2000-08-14 A | 2001-02-02 A |  | 100% | 2000-08-14 | 2001-02-02 | 125d | finish no earlier than 2001-02-02 | N1 | 1000h | 1000h |  |  | Frederic | 24.008, 23.009, 23.108, (29.002) |  | Motorola | Andrew Howell |
| 1974 | 49.1.4 | Codec Negotiation inter MSC | 125d | 2000-07-03 A | 2000-12-22 A |  | 100% | 2000-07-03 | 2000-12-22 | 125d | finish no earlier than 2000-12-22 | N4 | 1000h | 1000h |  |  | Kimmo |  |  |  |  |
| 1975 | 49.1.5 | Bearer establishment inter MSC | 125d | 2000-07-03 A | 2000-12-22 A |  | 100% | 2000-07-03 | 2000-12-22 | 125d | finish no earlier than 2000-12-22 | N4 | 1000h | 1000h |  |  | Kimmo | 23.153 |  |  |  |

Notes:
- 1947: It is believed that the current R99 test spec. can be optimised for faster overall test times. Marked as stopped 12/2008 (was 70% complete)
- 1948: It is believed that the current R99 test spec. can be optimised for faster overall test times
- 1949: Further test coverage of the R99 specification to cover supplementry services. Marked as stopped 12/2008 (was 70% complete)
- 1950: Marked as closed 12/2008 (was marked 50% complete)
- 1951: Marked as closed 12/2008 (was marked 50% complete)
- 1952: Marked as stopped 12/2008
- 1953: Marked as stopped 12/2008
- 1955: postponed from R99 to R00, SP-000169
- 1967: e.g. minimum set of media formats, media format conversion, personalization of MMS.
- 1969: Lead given to CN4 from CN / [DAB 28/11/00]
- 1971: moved according to NP-000575
- 1972: e.g. study cascading TrFO/TFO/TrFO
- 1973: the link to NP-000085has been deleted because refering to a R99 status sheet / One common set of codec negotiation procedures will be specified as in ID1656.
- 1974: Bearer establishment inter MSC. TS 23.153 R99 part complete. capabilities moved to annex + list of open issues
- 1975: Bearer establishment inter MSC. TS 23.153 R99 part complete. capabilities moved to annex. / See NP-000127 / Open issues: / Handling of Conference Calls; / Handling of Multi Party Supplementary Services; / Handling of Handover UMTS to GSM; / Handling of Sending a ...

| ID | WBS | Task | Duration | Start | Finish | Complete | Baseline start | Baseline finish | Baseline duration | Constraint | Resources | Work | Actual work | Text1 | Text8 | Text6 | Text4 | Text5 |
| --- | --- | --- | --- | --- | --- | --- | --- | --- | --- | --- | --- | --- | --- | --- | --- | --- | --- | --- |
| 1976 | 49.2 | **Speech Transcoder: Location and Control at the UMTS Core Network Border** | 125d | 2000-04-10 A | 2000-09-29 A | 100% | 2000-04-10 | 2000-09-29 | 125d |  | S2 | 2000h | 2000h | TRFO-STLC | Maurice |  |  |  |
| 1977 | 49.2.1 | Transcoder at Edge | 125d | 2000-04-10 A | 2000-09-29 A | 100% | 2000-04-10 | 2000-09-29 | 125d | finish no earlier than 2000-09-29 | NP | 1000h | 1000h |  |  |  |  |  |
| 1978 | 50 | **GERAN improvements 1 (Gb over IP)** | 225d | 2000-05-09 A | 2001-03-19 A | 100% | 2000-05-09 | 2001-03-19 | 225d |  | GP | 6472h | 6472h | GEIMP1 | Paolo | Rel-4 |  |  |
| 1979 | 50.1 | **Gb over IP (Ip-fication of Gb)** | 225d | 2000-05-09 A | 2001-03-19 A | 100% | 2000-05-09 | 2001-03-19 | 225d |  | GP | 4672h | 4672h | GbIP | Paolo |  |  |  |
| 1980 | 50.1.1 | Concept | 134d | 2000-05-09 A | 2000-11-10 A | 100% | 2000-05-09 | 2000-11-10 | 134d |  | GP | 1072h | 1072h |  | Paolo |  |  |  |
| 1981 | 50.1.2 | Changes to 08.16, 08.18 | 225d | 2000-05-09 A | 2001-03-19 A | 100% | 2000-05-09 | 2001-03-19 | 225d |  | GP | 1800h | 1800h |  | Paolo |  |  |  |
| 1982 | 51 | **GERAN improvements 2 (NACC)** | 677d | 2000-11-06 A | 2003-06-10 A | 100% | 2000-11-06 | 2003-06-10 | 677d |  | GP | 19224h | 19224h | GEIMP2 | Paolo | Rel-4 |  |  |
| 1983 | 51.1 | **Gb enhancements** | 155d | 2000-11-06 A | 2001-06-08 A | 100% | 2000-11-06 | 2001-06-08 | 155d |  | GP | 7440h | 7440h | Gben | Paolo |  |  |  |
| 1984 | 51.1.1 | **Intra BSC NACC (Network Assisted Cell Change)** | 155d | 2000-11-06 A | 2001-06-08 A | 100% | 2000-11-06 | 2001-06-08 | 155d |  | GP | 6200h | 6200h |  | Paolo |  |  |  |
| 1985 | 51.1.1.1 | Concept | 155d | 2000-11-06 A | 2001-06-08 A | 100% | 2000-11-06 | 2001-06-08 | 155d | finish no earlier than 2001-06-08 | GP | 1240h | 1240h |  | Paolo |  |  |  |
| 1986 | 51.1.1.2 | Changes in 03.64 | 155d | 2000-11-06 A | 2001-06-08 A | 100% | 2000-11-06 | 2001-06-08 | 155d | finish no earlier than 2001-06-08 | GP | 1240h | 1240h |  | Paolo |  |  |  |
| 1987 | 51.1.1.3 | Changes in 04.60 | 155d | 2000-11-06 A | 2001-06-08 A | 100% | 2000-11-06 | 2001-06-08 | 155d | finish no earlier than 2001-06-08 | GP | 1240h | 1240h |  | Paolo |  |  |  |
| 1988 | 51.1.1.4 | Changes in 44.008 | 155d | 2000-11-06 A | 2001-06-08 A | 100% | 2000-11-06 | 2001-06-08 | 155d | finish no earlier than 2001-06-08 | GP | 1240h | 1240h |  | Paolo |  |  |  |
| 1989 | 51.3 | **MS conformance test for Intra BSC NACC** | 398d | 2001-11-30 A | 2003-06-10 A | 100% | 2001-11-30 | 2003-06-10 | 398d |  | GP | 6368h | 6368h | GEIMP2-Msconf | Paolo |  |  |  |
| 1990 | 51.3.1 | Changes in 51.010 | 398d | 2001-11-30 A | 2003-06-10 A | 100% | 2001-11-30 | 2003-06-10 | 398d | finish no earlier than 2003-12-19 | G5,G4 | 3184h | 3184h |  | Paolo |  |  |  |
| 1991 | 52 | **GERAN improvements 4 (Delayed TBF)** | 105d | 2001-01-15 A | 2001-06-08 A | 100% | 2001-01-15 | 2001-06-08 | 105d |  | GP | 3960h | 3960h | GEIMP4 | Paolo | Rel-4 |  |  |
| 1992 | 52.1 | **Gb enhancements 2** | 105d | 2001-01-15 A | 2001-06-08 A | 100% | 2001-01-15 | 2001-06-08 | 105d |  | GP | 3120h | 3120h | GEIMP4-Gben2 | Paolo |  |  |  |
| 1993 | 52.1.1 | stage 2 | 105d | 2001-01-15 A | 2001-06-08 A | 100% | 2001-01-15 | 2001-06-08 | 105d | finish no earlier than 2001-06-08 | GP | 840h | 840h |  | Paolo |  |  |  |
| 1994 | 52.1.2 | **Stage 3 (changes in 44.060)** | 60d | 2001-01-15 A | 2001-04-06 A | 100% | 2001-01-15 | 2001-04-06 | 60d |  | G2 | 1440h | 1440h |  | Gert |  |  |  |
| 1995 | 52.1.2.1 | Definition of enhanced countdown procedure | 60d | 2001-01-15 A | 2001-04-06 A | 100% | 2001-01-15 | 2001-04-06 | 60d | finish no earlier than 2001-04-06 | G2 | 480h | 480h |  | Gert |  |  |  |
| 1996 | 52.1.2.2 | Definition of enhanced TBF release procedure | 60d | 2001-01-15 A | 2001-04-06 A | 100% | 2001-01-15 | 2001-04-06 | 60d | finish no earlier than 2001-04-06 | G2 | 480h | 480h |  | Gert |  |  |  |
| 1997 | 52.1.2.3 | Definition of USF=FREE type polling mechanism on PDCH | 60d | 2001-01-15 A | 2001-04-06 A | 100% | 2001-01-15 | 2001-04-06 | 60d | finish no earlier than 2001-04-06 | G2 | 480h | 480h |  | Gert |  |  |  |
| 1998 | 53 | **Low Chip Rate TDD option** | 880d | 2000-07-19 A | 2003-12-02 A | 100% | 2000-07-19 | 2003-12-02 | 880d |  | R1 | 25872h | 25872h | LCRTDD | Patrick | Rel-4 | CWTS | G. Yang |
| 1999 | 53.1 | Physical layer | 183d | 2000-07-19 A | 2001-03-30 A | 100% | 2000-07-19 | 2001-03-30 | 183d | finish no earlier than 2001-03-30 | R1 | 1464h | 1464h | LCRTDD-Phys | Patrick |  | CWTS | G. Yang |
| 2000 | 53.2 | Layer 2 and layer 3 protocol aspects | 183d | 2000-07-19 A | 2001-03-30 A | 100% | 2000-07-19 | 2001-03-30 | 183d | finish no earlier than 2001-03-30 | R2 | 1464h | 1464h | LCRTDD-L23 | Joern |  | CWTS | Y. Liu |
| 2001 | 53.3 | RF radio transmission/reception, system performance requirements and conformance testing | 165d | 2000-08-14 A | 2001-03-30 A | 100% | 2000-08-14 | 2001-03-30 | 165d | finish no earlier than 2001-03-30 | R4 | 1320h | 1320h | LCRTDD-RF | Stefania |  | CWTS | D. Zhang |
| 2002 | 53.4 | UE radio access capability | 165d | 2000-08-14 A | 2001-03-30 A | 100% | 2000-08-14 | 2001-03-30 | 165d | finish no earlier than 2001-03-30 | R2 | 1320h | 1320h | LCRTDD-UErac | Joern |  | CWTS | Y. Liu |
| 2003 | 53.5 | Iub/Iur protocol aspects | 165d | 2000-08-14 A | 2001-03-30 A | 100% | 2000-08-14 | 2001-03-30 | 165d | finish no earlier than 2001-03-30 | R3 | 1320h | 1320h | LCRTDD-IubIur | Juha |  | CWTS | Y. Liu |

Notes:
- 1976: WI description and Tdoc S2-99352 / Speech Transcoder: Location and Control at the UMTS Core Network Border
- 1977: WI description and Tdoc S2-99352...
- 1989: Started
- 1990: az 05/08: duplicated UID_50099 => 50299. Marked as closed 12/2008 (was marked 50% complete)

| ID | WBS | Task | Duration | Start | Finish | Predecessors | Complete | Baseline start | Baseline finish | Baseline duration | Constraint | Resources | Work | Actual work | Text8 | Text3 | Text12 | Text1 | Text4 | Text5 | Text6 |
| --- | --- | --- | --- | --- | --- | --- | --- | --- | --- | --- | --- | --- | --- | --- | --- | --- | --- | --- | --- | --- | --- |
| 2004 | 53.6 | **Low chiprate TDD interworking with GERAN** | 101d | 2000-09-01 A | 2001-01-19 A | 2003 | 100% | 2000-09-01 | 2001-01-19 | 101d |  |  |  |  | Paolo |  |  |  |  |  |  |
| 2005 | 53.6.1 | Handover and Cell Selection / Reselection to UTRA 1.28 Mcps TDD | 101d | 2000-09-01 A | 2001-01-19 A |  | 100% | 2000-09-01 | 2001-01-19 | 101d | finish no earlier than 2001-01-19 |  |  |  |  |  |  |  |  |  |  |
| 2006 | 53.8 | **Conformance Test Aspects - Low Chip Rate TDD** | 577d | 2001-09-17 A | 2003-12-02 A | 2004 | 100% | 2001-09-17 | 2003-12-02 | 577d |  | T1 | 12088h | 12088h | Ingbert | 0% |  |  |  |  |  |
| 2007 | 53.8.1 | Testing Layer 2 and layer 3 protocol aspects | 468d | 2001-09-17 A | 2003-07-02 A |  | 100% | 2001-09-17 | 2003-07-02 | 468d | finish no earlier than 2003-07-02 | T1 | 3744h | 3744h | Ingbert | 34.123-1, 34.123-2 |  |  |  |  |  |
| 2008 | 53.8.2 | Deleted - Testing Layer 2 and layer 3 protocol aspects - TTCN | 261d | 2002-12-03 A | 2003-12-02 A |  | 100% | 2002-12-03 | 2003-12-02 | 261d | finish no earlier than 2003-12-02 | T1 | 2088h | 2088h | Ingbert | 34.123-3 | TP-22 |  |  |  |  |
| 2009 | 53.8.3 | Testing RF Radio Transmission and Reception | 205d | 2001-09-17 A | 2002-06-28 A |  | 100% | 2001-09-17 | 2002-06-28 | 205d | finish no earlier than 2002-06-28 | T1 | 1640h | 1640h | Ingbert |  |  |  |  |  |  |
| 2010 | 54 | **Enable bearer independent CS architecture** | 566d | 2000-01-03 A | 2002-03-01 A |  | 100% | 2000-01-03 | 2002-03-01 | 566d |  | S2 | 20192h | 20192h | Maurice |  |  | CSSPLIT | Siemens | Alexander Milinski | Rel-4 |
| 2011 | 54.1 | **Enable bearer-independent call control** | 425d | 2000-01-03 A | 2001-08-16 A |  | 100% | 2000-01-03 | 2001-08-16 | 425d |  | N4 | 12344h | 12344h | Kimmo |  |  |  | Ericsson | Heinz-Peter.Keutmann@eed.ericsson.se |  |
| 2012 | 54.1.1 | Architecture and Stage 2 description | 181d | 2000-01-03 A | 2000-09-08 A |  | 100% | 2000-01-03 | 2000-09-08 | 181d | finish no earlier than 2000-09-08 | S2 [99.4%] | 1440h | 1440h | Maurice | 23.002 |  |  |  |  |  |
| 2013 | 54.1.2 | Standardisation of protocols (control & user planes) over Nb interface | 64d | 2001-01-02 A | 2001-03-30 A |  | 100% | 2001-01-02 | 2001-03-30 | 64d | finish no earlier than 2001-03-30 | N3 | 512h | 512h | Gwiho |  |  |  |  |  |  |
| 2014 | 54.1.3 | Standardisation of protocols over reference points between MSC server and Gateway MSC server | 130d | 2000-09-25 A | 2001-03-23 A |  | 100% | 2000-09-25 | 2001-03-23 | 130d | finish no earlier than 2001-03-23 | N4 | 1040h | 1040h | Kimmo |  |  |  |  |  |  |
| 2015 | 54.1.4 | Standardisation of detailed stage 2 description | 180d | 2000-07-17 A | 2001-03-23 A |  | 100% | 2000-07-17 | 2001-03-23 | 180d | finish no earlier than 2001-03-23 | N4 | 1440h | 1440h | Kimmo |  |  |  |  |  |  |
| 2016 | 54.1.5 | **Bearer control between MSC server and MGW** | 250d | 2000-09-01 A | 2001-08-16 A |  | 100% | 2000-09-01 | 2001-08-16 | 250d |  | N4 | 4512h | 4512h | Kimmo |  |  |  |  |  |  |
| 2017 | 54.1.5.1 | stage 3 - protocol issues | 250d | 2000-09-01 A | 2001-08-16 A |  | 100% | 2000-09-01 | 2001-08-16 | 250d | finish no earlier than 2001-08-16 | N4 | 2000h | 2000h | Kimmo |  |  |  |  |  |  |
| 2018 | 54.1.5.2 | stage 3 - parameter value issues | 64d | 2001-01-02 A | 2001-03-30 A |  | 100% | 2001-01-02 | 2001-03-30 | 64d | finish no earlier than 2001-03-30 | N3 | 512h | 512h | Gwiho |  |  |  |  |  |  |
| 2019 | 54.2 | Lawful interception | 155d | 2000-08-21 A | 2001-03-23 A |  | 100% | 2000-08-21 | 2001-03-23 | 155d | finish no earlier than 2001-03-23 | S3 | 1240h | 1240h | Dionisio |  |  |  |  |  |  |
| 2020 | 54.4 | Deleted - Conformance Test Aspects - Enable bearer independent CS architecture | 260d | 2001-03-05 A | 2002-03-01 A |  | 100% | 2001-03-05 | 2002-03-01 | 260d |  | T1 | 2080h | 2080h | Ingbert |  | TP-15 | CSSPLIT-TEST |  |  |  |
| 2021 | 55 | **MExE enhancements Rel-4** | 511d | 2000-01-03 A | 2001-12-14 A |  | 100% | 2000-01-03 | 2001-12-14 | 511d |  | T2 | 19032h | 19032h | Kimmo |  |  | MEXE |  |  | Rel-4 |
| 2022 | 55.1 | **MExE Security Analysis Activity** | 474d | 2000-02-22 A | 2001-12-14 A |  | 100% | 2000-02-22 | 2001-12-14 | 474d |  | S3 | 8464h | 8464h | Dionisio |  |  | MEXE-SEC | BT | colin.blanchard@bt.com |  |
| 2023 | 55.1.1 | Stage 3 | 370d | 2000-07-17 A | 2001-12-14 A |  | 100% | 2000-07-17 | 2001-12-14 | 370d | finish no earlier than 2001-12-14 | S3 | 2960h | 2960h | Dionisio |  |  | MEXE1-SEC |  |  |  |
| 2024 | 55.1.2 | Terminal aspects | 214d | 2000-02-22 A | 2000-12-15 A |  | 100% | 2000-02-22 | 2000-12-15 | 214d | finish no earlier than 2000-12-15 | T2 | 1712h | 1712h |  |  |  |  |  |  |  |
| 2025 | 55.2 | **MExE Rel4 Improvements and Investigations** | 251d | 2000-01-03 A | 2000-12-15 A |  | 100% | 2000-01-03 | 2000-12-15 | 251d |  | T2 | 6480h | 6480h |  | 22.057, 23.057 |  | MEXE-ENHANC | Motorola | Mark Cataldo |  |
| 2026 | 55.2.1 | 3rd MExE classmark | 251d | 2000-01-03 A | 2000-12-15 A |  | 100% | 2000-01-03 | 2000-12-15 | 251d | finish no earlier than 2000-12-15 | T2 | 2000h | 2000h |  | 22.057, 23.057 |  |  | Motorola | Mark Cataldo |  |
| 2027 | 55.2.2 | FS on Secure download mechanism and capabilities to support SDR concepts | 225d | 2000-02-07 A | 2000-12-15 A |  | 100% | 2000-02-07 | 2000-12-15 | 225d | finish no earlier than 2000-12-15 | T2 | 1800h | 1800h |  | 22.057, 23.057 |  |  | Motorola | Mark Cataldo |  |
| 2028 | 55.2.3 | FS on Support of MP3/MPEG4 content | 225d | 2000-02-07 A | 2000-12-15 A |  | 100% | 2000-02-07 | 2000-12-15 | 225d | finish no earlier than 2000-12-15 | T2 | 1800h | 1800h |  | 22.057, 23.057 |  |  | Motorola | Mark Cataldo |  |

Notes:
- 2007: Marked as closed 12/2008 (was marked 60% complete)
- 2008: Marked as stopped 12/2008
- 2009: duration set to 6 months (was 0), finish date set
- 2011: DAB 12.12.01 should be 100% hence closed
- 2012: R00 stage 2 at least 80 % complete in TSGS #8 21.-23.6.2000
- 2019: Requirements capture: S3#14 (Aug 00), Feature specification: S3#15 (Sep 00), Definition of architecture. Should be included in general LI work mentioned above.
- 2020: Marked as stopped 12/2008
- 2022: Presentation to S3 of threats and countermeasures analysis: S3#15, Feature specification: S3#16. S3#18: WID updated
- 2023: Analysis undertaken by T2. No additional analysis needed for Rel-4
- 2026: Additional features for MExE R2000

| ID | WBS | Task | Duration | Start | Finish | Complete | Baseline start | Baseline finish | Baseline duration | Constraint | Resources | Work | Actual work | Text1 | Text6 | Text8 | Text3 | Text4 | Text5 |
| --- | --- | --- | --- | --- | --- | --- | --- | --- | --- | --- | --- | --- | --- | --- | --- | --- | --- | --- | --- |
| 2029 | 56 | **Tandem Free aspects for 3G and between 2G and 3G systems** | 344d | 2000-02-22 A | 2001-06-15 A | 100% | 2000-02-22 | 2001-06-15 | 344d |  | S4 | 9696h | 9696h | TFO | Rel-4 | Paolo |  |  |  |
| 2030 | 56.1 | **Tandem Free AMR** | 344d | 2000-02-22 A | 2001-06-15 A | 100% | 2000-02-22 | 2001-06-15 | 344d |  | S4 | 6944h | 6944h | TFO-AMR |  | Paolo |  |  |  |
| 2031 | 56.1.1 | Specification | 284d | 2000-02-22 A | 2001-03-23 A | 100% | 2000-02-22 | 2001-03-23 | 284d | start no earlier than 2000-02-22 | S4 | 2272h | 2272h |  |  | Paolo | 28.062 |  |  |
| 2032 | 56.1.2 | **Impact on:** | 115d | 2001-01-08 A | 2001-06-15 A | 100% | 2001-01-08 | 2001-06-15 | 115d |  | NP | 1920h | 1920h |  |  | Kimmo |  |  |  |
| 2033 | 56.1.2.1 | CN | 60d | 2001-03-26 A | 2001-06-15 A | 100% | 2001-03-26 | 2001-06-15 | 60d | finish no earlier than 2001-06-15 | NP | 480h | 480h |  |  | Kimmo |  |  |  |
| 2034 | 56.1.2.2 | GERAN | 65d | 2001-01-08 A | 2001-04-06 A | 100% | 2001-01-08 | 2001-04-06 | 65d | finish no earlier than 2001-04-06 | GP | 520h | 520h |  |  | Paolo |  |  |  |
| 2035 | 57 | **Advanced Speech Call Items enhancements_REL-4** | 334d | 2000-12-03 A | 2002-03-14 A | 100% | 2000-12-03 | 2002-03-14 | 334d |  | N1 | 5925.6h | 5925.6h | ASCI | Rel-4 | Frederic |  | Nortel | sonia.garapaty@nortelnetworks.com |
| 2036 | 57.1 | Stage 2 | 326.7d | 2000-12-03 A | 2002-03-14 A | 100% | 2000-12-03 | 2002-03-14 | 326.7d | finish no earlier than 2002-03-14 | N4 | 2613.6h | 2613.6h |  |  | Kimmo | 23.067, 24.067 | Sagem | Vivien Perlic |
| 2037 | 57.2 | Stages 2 and 3 on A interface | 80d | 2000-12-03 A | 2001-03-23 A | 100% | 2000-12-03 | 2001-03-23 | 80d | finish no earlier than 2001-03-23 | N1 | 640h | 640h |  |  | Frederic | 44.068, 44.069, 24.008 | Nortel | sonia.garapaty@nortelnetworks.com |
| 2038 | 58 | **700 MHz spectrum support** | 776d | 2000-01-03 A | 2002-12-20 A | 100% | 2000-01-03 | 2002-12-20 | 776d |  | GP | 25016h | 25016h | 700SS | Rel-4 | Paolo |  |  |  |
| 2039 | 58.1 | **GERAN support for the 700 MHz band** | 276d | 2000-01-03 A | 2001-01-19 A | 100% | 2000-01-03 | 2001-01-19 | 276d |  | GP | 8808h | 8808h |  |  | Paolo |  |  |  |
| 2040 | 58.1.1 | Signalling support | 276d | 2000-01-03 A | 2001-01-19 A | 100% | 2000-01-03 | 2001-01-19 | 276d | finish no earlier than 2001-01-19 | GP | 2200h | 2200h |  |  | Paolo |  |  |  |
| 2041 | 58.1.2 | Physical layer definitions | 276d | 2000-01-03 A | 2001-01-19 A | 100% | 2000-01-03 | 2001-01-19 | 276d | finish no earlier than 2001-01-19 | GP | 2200h | 2200h |  |  | Paolo |  |  |  |
| 2042 | 58.1.3 | Receiver performance and RF budget | 276d | 2000-01-03 A | 2001-01-19 A | 100% | 2000-01-03 | 2001-01-19 | 276d | finish no earlier than 2001-01-19 | GP | 2200h | 2200h |  |  | Paolo |  |  |  |
| 2043 | 58.2 | **GERAN MS Conformance test for 700 MHz band** | 175d | 2001-04-02 A | 2001-11-30 A | 100% | 2001-04-02 | 2001-11-30 | 175d |  | GP | 2800h | 2800h |  |  | Paolo |  |  |  |
| 2044 | 58.2.1 | MS test | 175d | 2001-04-02 A | 2001-11-30 A | 100% | 2001-04-02 | 2001-11-30 | 175d | finish no earlier than 2001-11-30 | GP | 1400h | 1400h |  |  | Paolo |  |  |  |
| 2045 | 58.3 | **GERAN BTS Conformance test for 700 MHz band** | 450d | 2001-04-02 A | 2002-12-20 A | 100% | 2001-04-02 | 2002-12-20 | 450d |  | GP | 7200h | 7200h |  |  | Paolo |  |  |  |
| 2046 | 58.3.1 | BTS test | 450d | 2001-04-02 A | 2002-12-20 A | 100% | 2001-04-02 | 2002-12-20 | 450d | finish no earlier than 2002-12-20 | GP | 3600h | 3600h |  |  | Paolo |  |  |  |
| 2047 | 59 | Operator Determined Barring for Packet Oriented Services | 208d | 2000-06-01 A | 2001-03-19 A | 100% | 2000-06-01 | 2001-03-19 | 208d | finish no earlier than 2001-03-19 | NP | 1664h | 1664h | ODB | Rel-4 |  |  | NEC | Toshiyuki Tamura (tamurato@aj.jp.nec.com) |
| 2048 | 60 | **UMTS QoS Architecture for PS Domain** | 759d | 2000-01-03 A | 2002-11-27 A | 100% | 2000-01-03 | 2002-11-27 | 759d |  | S2 | 41312h | 41312h | QoSPS | Rel-4 | Maurice |  | Ericsson | Ina.widegren@era.ericsson.se |
| 2049 | 60.1 | Architecture | 153d | 2000-06-05 A | 2001-01-03 A | 100% | 2000-06-05 | 2001-01-03 | 153d | finish no earlier than 2001-01-03 | S2 | 1224h | 1224h |  |  | Maurice | 23.107 |  |  |
| 2050 | 60.2 | Charging and OAM&P for QoS Management | 201d | 2001-09-21 A | 2002-06-28 A | 100% | 2001-09-21 | 2002-06-28 | 201d | finish no earlier than 2002-06-28 | S5 | 1608h | 1608h | QoSPS-OAM | Rel-4 | Dionisio | 32-series | VoiceStream, Motorola |  |
| 2051 | 60.3 | **RAB Quality of Service (re)Negotiation over Iu** | 155d | 2000-08-21 A | 2001-03-23 A | 100% | 2000-08-21 | 2001-03-23 | 155d |  | R3 | 3648h | 3648h | QoSPS-MAPEND-RABQoS |  | Juha | 25.413 | Ericsson | A. Molander |
| 2052 | 60.3.1 | RAB Quality of Service Negotiation over Iu | 155d | 2000-08-21 A | 2001-03-23 A | 100% | 2000-08-21 | 2001-03-23 | 155d | finish no earlier than 2001-03-23 | R3 | 1240h | 1240h | QoSPS-MAPEND-RABQoS-Negot |  | Juha |  | Ericsson | A. Molander |
| 2053 | 60.3.2 | RAB Quality of Service Negotiation over Iu during relocation | 16d | 2001-03-02 A | 2001-03-23 A | 100% | 2001-03-02 | 2001-03-23 | 16d | start no earlier than 2001-03-02 | R3 | 128h | 128h | QoSPS-MAPEND-RABQoS-NegotReloc |  | Juha |  |  |  |
| 2054 | 60.3.3 | RAB Quality of Service Re-Negotiation over Iu | 130d | 2000-09-25 A | 2001-03-23 A | 100% | 2000-09-25 | 2001-03-23 | 130d | finish no earlier than 2001-03-23 | R3 | 1040h | 1040h | QoSPS-MAPEND-RABQoS-ReNegot |  | Juha |  | Motorola | S. Irwin |

Notes:
- 2029: RAN and CN to verify no problems for GSM terminals roaming in 3G R99
- 2030: RAN and CN to verify UMTS_AMR_2 support
- 2032: "Implementation" changed to "Impact on:" by A. Sultan (for better wording)
- 2033: RAN and CN to verify UMTS_AMR_2 support
- 2034: End date Modified from June to March to have it in Rel4
- 2035: Approved in TSGN_10
- 2036: CN4#11 30/11/02: no inputs received in CN4
- 2047: Completed WI missing from the P-plan Added for tracking

| ID | WBS | Task | Duration | Start | Finish | Complete | Baseline start | Baseline finish | Baseline duration | Constraint | Resources | Work | Actual work | Text1 | Text8 | Text12 | Text4 | Text5 | Text3 | Text6 |
| --- | --- | --- | --- | --- | --- | --- | --- | --- | --- | --- | --- | --- | --- | --- | --- | --- | --- | --- | --- | --- |
| 2055 | 60.4 | **GERAN QoS Aspects - Handovers: maintenance of real-time QoS while moving between cells in the PLMN including inter-SGSN and SRNS relocation or possibly other mechanisms** | 501d | 2000-01-03 A | 2001-11-30 A | 100% | 2000-01-03 | 2001-11-30 | 501d |  | GP | 14456h | 14456h | GERQoS | Paolo |  |  |  |  |  |
| 2056 | 60.4.1 | **Handover Concept for the PS domain** | 501d | 2000-01-03 A | 2001-11-30 A | 100% | 2000-01-03 | 2001-11-30 | 501d |  | GP | 10448h | 10448h |  | Paolo |  |  |  |  |  |
| 2057 | 60.4.1.1 | Stable RT handover report 25.936 including header removal | 14d | 2000-01-03 A | 2000-01-19 A | 100% | 2000-01-03 | 2000-01-19 | 14d | start no earlier than 2000-01-03 | GP [92.9%] | 104h | 104h |  | Paolo |  |  |  |  |  |
| 2058 | 60.4.1.2 | Update of stage 2 | 293d | 2000-01-03 A | 2001-02-13 A | 100% | 2000-01-03 | 2001-02-13 | 293d | finish no earlier than 2001-02-13 | GP | 2336h | 2336h |  | Paolo |  |  |  |  |  |
| 2059 | 60.4.1.3 | Update of relevant stage 3 specs -> RRC | 501d | 2000-01-03 A | 2001-11-30 A | 100% | 2000-01-03 | 2001-11-30 | 501d | finish no earlier than 2001-11-30 | G2 | 4000h | 4000h |  | Gert |  |  |  |  |  |
| 2060 | 60.5 | **Deleted - GERAN MS Conformance test for inter-system and intra-system Packet data real-time Handover** | 324d | 2001-08-31 A | 2002-11-27 A | 100% | 2001-08-31 | 2002-11-27 | 324d |  | G4,R3 | 12960h | 12960h | GERQoS-Mstest | Paolo | GP-12 |  |  |  |  |
| 2061 | 60.5.1 | **Deleted - Handover for the PS domain** | 324d | 2001-08-31 A | 2002-11-27 A | 100% | 2001-08-31 | 2002-11-27 | 324d |  | G4,R3 | 10368h | 10368h |  | Paolo | GP-12 |  |  |  |  |
| 2062 | 60.5.1.1 | Deleted - Stable RT handover report 25.936 including header removal | 324d | 2001-08-31 A | 2002-11-27 A | 100% | 2001-08-31 | 2002-11-27 | 324d | finish no earlier than 2002-11-27 | G4,R3 | 2592h | 2592h |  | Paolo | GP-12 |  |  |  |  |
| 2063 | 60.5.1.2 | Deleted - Update of stage 2 | 324d | 2001-08-31 A | 2002-11-27 A | 100% | 2001-08-31 | 2002-11-27 | 324d | finish no earlier than 2002-11-27 | G4,R3 | 2592h | 2592h |  | Paolo | GP-12 |  |  |  |  |
| 2064 | 60.5.1.3 | Deleted - Update of relevant stage 3 specs | 324d | 2001-08-31 A | 2002-11-27 A | 100% | 2001-08-31 | 2002-11-27 | 324d | finish no earlier than 2002-11-27 | G4,R3 | 2592h | 2592h |  | Paolo | GP-12 |  |  |  |  |
| 2065 | 60.6 | PS-domain handover for real-time services | 155d | 2000-08-28 A | 2001-03-30 A | 100% | 2000-08-28 | 2001-03-30 | 155d | finish no earlier than 2001-03-30 | R3 | 1240h | 1240h | QoSPS-PSdoRTS | Juha |  | Nokia | A. Lansisalmi |  |  |
| 2066 | 60.7 | Deleted - RAB QoS Renegotiation at Relocation | 58d | 2001-01-03 A | 2001-03-23 A | 100% | 2001-01-03 | 2001-03-23 | 58d | finish no earlier than 2001-03-23 | R3 | 464h | 464h |  | Juha | RP-11 |  |  | 25.851, 25.946 |  |
| 2067 | 61 | **small Technical Enhancements and Improvements for Rel4** | 2178d? | 2000-01-03 A | 2008-05-06 A | 100% | 2000-01-03 | 2008-05-06 | 2178d? |  | All | 4024h | 4024h | TEI4 |  |  |  |  |  | Rel-4 |
| 2068 | 485.1 | Small Technical Enhancements and Improvements for Rel-4 Conformance Testing | 504d? | 2000-01-03 A | 2008-05-06 A | 100% | 2000-01-03 | 2008-05-06 | 504d? | finish no earlier than 2008-12-31 | R5 | 4024h | 4024h | TEI4_Test | Ingbert |  |  |  |  | Rel-4 |
| 2069 | 62 | **Rel-4 Evolutions of the transport in the UTRAN** | 525d | 2000-08-21 A | 2002-08-23 A | 100% | 2000-08-21 | 2002-08-23 | 525d |  | RP | 8600h | 8600h | ETRAN | Stefania |  | Alcatel | Francois Courau |  | NA |
| 2070 | 62.1 | QoS optimisation for AAL2 connections over Iub and Iur interfaces | 160d | 2000-08-21 A | 2001-03-30 A | 100% | 2000-08-21 | 2001-03-30 | 160d | finish no earlier than 2001-03-30 | R3 | 1280h | 1280h | ETRAN-QoSAAL2 | Juha |  | Japan Telecom | T. Yoshimura |  | Rel-4 |
| 2071 | 62.2 | Transport bearer modification procedure on Iub, Iur, and Iu | 130d | 2000-10-02 A | 2001-03-30 A | 100% | 2000-10-02 | 2001-03-30 | 130d | finish no earlier than 2001-03-30 | R3 | 1040h | 1040h | ETRAN-MigrMod | Juha |  | Japan Telecom | T. Yoshimura |  | Rel-4 |
| 2072 | 62.3 | **Conformance Test Aspects of Rel-4 evolutions of the transport in UTRAN** | 130d | 2002-02-25 A | 2002-08-23 A | 100% | 2002-02-25 | 2002-08-23 | 130d |  | T1 | 2080h | 2080h |  | Ingbert |  |  |  |  |  |
| 2073 | 62.3.1 | Testing RAB support enhancements | 130d | 2002-02-25 A | 2002-08-23 A | 100% | 2002-02-25 | 2002-08-23 | 130d | finish no earlier than 2002-08-23 | T1 | 1040h | 1040h | CT-RABS? | Ingbert |  |  |  | 34.108, 34. 121, 34.122, 34.123 p 1,2, 34.123 pt 3 |  |
| 2074 | 63 | **Rel-4 Evolutions of the transport in the CN** | 215d | 2000-05-29 A | 2001-03-23 A | 100% | 2000-05-29 | 2001-03-23 | 215d |  | N4 | 7968h | 7968h | CNTRSP | Kimmo |  |  |  |  | NA |
| 2075 | 63.1 | **IP Transport of CN protocols (e.g., CAP, MAP)** | 77d | 2000-12-07 A | 2001-03-23 A | 100% | 2000-12-07 | 2001-03-23 | 77d |  | N4 | 2808h | 2808h | SS7IP | Kimmo |  |  |  |  | Rel-4 |
| 2076 | 63.1.1 | **Stage 3** | 77d | 2000-12-07 A | 2001-03-23 A | 100% | 2000-12-07 | 2001-03-23 | 77d |  | N4 | 2192h | 2192h |  | Kimmo |  |  |  |  |  |
| 2077 | 63.1.1.1 | CAP | 77d | 2000-12-07 A | 2001-03-23 A | 100% | 2000-12-07 | 2001-03-23 | 77d | finish no earlier than 2001-03-23 | N2 | 616h | 616h |  | Kimmo |  |  |  |  |  |
| 2078 | 63.1.1.2 | MAP | 77d | 2000-12-07 A | 2001-03-23 A | 100% | 2000-12-07 | 2001-03-23 | 77d | finish no earlier than 2001-03-23 | N4 | 616h | 616h |  | Kimmo |  |  |  |  |  |
| 2079 | 63.1.1.3 | BSSAP+ | 43d | 2001-01-15 A | 2001-03-14 A | 100% | 2001-01-15 | 2001-03-14 | 43d | finish no earlier than 2001-03-14 | N1 | 344h | 344h | SS7IP-BSSAP+ | Frederic |  |  |  |  |  |

Notes:
- 2060: Still exist? To be clarified by GERAN4/5. Marked as stopped 12/2008
- 2061: Marked as stopped 12/2008
- 2062: Marked as stopped 12/2008
- 2063: Marked as stopped 12/2008
- 2064: Marked as stopped 12/2008
- 2066: Marked as stopped 12/2008
- 2067: "Joker" WI, to be used for a Rel 4 CR not related to any feature and with very limited impact on the system
- 2068: "Joker" WI, to be used for small modifications applicable to Rel 4 conformance testing. Moved in from the Stoyan/Testing WP
- 2073: Marked as stopped 12/2008
- 2074: WI formulation assigned to N4
- 2075: AS: corrected to Rel4 as stated at SA#10

| ID | WBS | Task | Duration | Start | Finish | Complete | Baseline start | Baseline finish | Baseline duration | Constraint | Resources | Work | Actual work | Text4 | Text5 | Text6 | Text8 | Text1 | Text12 | Text3 |
| --- | --- | --- | --- | --- | --- | --- | --- | --- | --- | --- | --- | --- | --- | --- | --- | --- | --- | --- | --- | --- |
| 2080 | 63.2 | **FS on Transport and control separation in the PS CN domain** | 215d | 2000-05-29 A | 2001-03-23 A | 100% | 2000-05-29 | 2001-03-23 | 215d |  | S2 | 3440h | 3440h | Ericsson | Juan-Antonio.Ibanez@eed.ericsson.se | Rel-4 | Maurice |  |  |  |
| 2081 | 63.2.1 | Architectural impacts | 215d | 2000-05-29 A | 2001-03-23 A | 100% | 2000-05-29 | 2001-03-23 | 215d | finish no earlier than 2001-03-23 | S2 | 1720h | 1720h |  |  |  | Maurice |  |  |  |
| 2082 | 64 | **Rel-4 Improvements of Radio Interface** | 700d | 2000-07-10 A | 2003-03-14 A | 100% | 2000-07-10 | 2003-03-14 | 700d |  | RP | 28624h | 28624h |  |  | NA | Stefania | RInImp |  |  |
| 2083 | 64.1 | UTRA repeater specification (master) | 183d | 2000-07-10 A | 2001-03-21 A | 100% | 2000-07-10 | 2001-03-21 | 183d | finish no earlier than 2001-03-21 | R4 | 1464h | 1464h | Mikom, Allgon | T. Kummetz, Mikom; Alf Ahlström, Allgon | Rel-4 | Stefania | RInImp-REP |  |  |
| 2084 | 64.2 | DSCH power control improvement in soft handover | 140d | 2000-09-11 A | 2001-03-23 A | 100% | 2000-09-11 | 2001-03-23 | 140d | finish no earlier than 2001-03-23 | R1 | 1120h | 1120h | Nokia | antti.toskala@nokia.com | Rel-4 | Patrick | RInImp-DSCHsho |  |  |
| 2085 | 64.3 | UMTS 1800 | 320d | 2000-09-25 A | 2001-12-14 A | 100% | 2000-09-25 | 2001-12-14 | 320d | finish no earlier than 2001-12-14 | R4 | 2560h | 2560h | Motorola | Howard Benn | Rel indep | Stefania | RInImp-UMTS18 |  |  |
| 2086 | 64.4 | UMTS 1900 | 195d | 2001-03-19 A | 2001-12-14 A | 100% | 2001-03-19 | 2001-12-14 | 195d | finish no earlier than 2001-12-14 | R4 | 1560h | 1560h | Motorola | Howard Benn | Rel indep | Stefania | RInImp-UMTS19 |  |  |
| 2087 | 64.5 | FS on High Speed downlink packet access | 155d | 2000-08-21 A | 2001-03-23 A | 100% | 2000-08-21 | 2001-03-23 | 155d | finish no earlier than 2001-03-23 | R2 | 1240h | 1240h | Motorola | A. Ghosh |  | Joern | RInImp-HSDPA |  |  |
| 2088 | 64.6 | FS on improved common DL channel for Cell-FACH state | 340d | 2000-09-11 A | 2001-12-28 A | 100% | 2000-09-11 | 2001-12-28 | 340d | finish no earlier than 2001-12-28 | R2 | 2720h | 2720h | GBT | J. Kwak |  | Joern | RInImp-DLCFACH | RP-14 |  |
| 2089 | 64.7 | **Conformance Test Spec. Rel-4 improvements in Radio Interface** | 375d | 2001-10-08 A | 2003-03-14 A | 100% | 2001-10-08 | 2003-03-14 | 375d |  | T1 | 12360h | 12360h |  |  |  | Ingbert |  |  |  |
| 2090 | 64.7.1 | Deleted - Testing Improved usage of downlink resource in FDD for CCTrCHs of dedicated type | 140d | 2002-02-18 A | 2002-08-30 A | 100% | 2002-02-18 | 2002-08-30 | 140d | finish no earlier than 2002-08-30 | T1 | 1120h | 1120h |  |  |  | Ingbert |  | TP-17 |  |
| 2091 | 64.7.2 | Deleted - Testing Terminal Power saving features | 140d | 2002-02-18 A | 2002-08-30 A | 100% | 2002-02-18 | 2002-08-30 | 140d | finish no earlier than 2002-08-30 | T1 | 1120h | 1120h |  |  |  | Ingbert |  | TP-17 |  |
| 2092 | 64.7.3 | Deleted - Testing DSCH power control improvement in soft handover | 140d | 2002-02-18 A | 2002-08-30 A | 100% | 2002-02-18 | 2002-08-30 | 140d | finish no earlier than 2002-08-30 | T1 | 1120h | 1120h |  |  | Rel-4 | Ingbert |  | TP-17 |  |
| 2093 | 64.7.4 | Testing UMTS 1800 | 180d | 2001-10-08 A | 2002-06-14 A | 100% | 2001-10-08 | 2002-06-14 | 180d | finish no earlier than 2002-06-14 | T1 | 1440h | 1440h |  |  | Rel indep | Ingbert |  |  | 34.108, 34,121, 34.122, 34.123-1 |
| 2094 | 64.7.5 | Testing UMTS 1900 | 180d | 2001-10-08 A | 2002-06-14 A | 100% | 2001-10-08 | 2002-06-14 | 180d | finish no earlier than 2002-06-14 | T1 | 1440h | 1440h |  |  | Rel indep | Ingbert |  |  | 34.108, 34,121, 34.122, 34.123-1 |
| 2095 | 64.7.6 | Testing UMTS 1800 - TTCN | 195d | 2002-06-17 A | 2003-03-14 A | 100% | 2002-06-17 | 2003-03-14 | 195d | finish no earlier than 2003-03-14 | T1 | 1560h | 1560h |  |  | Rel indep | Ingbert |  |  | 34.123-3 |
| 2096 | 64.7.7 | Testing UMTS 1900 - TTCN | 195d | 2002-06-17 A | 2003-03-14 A | 100% | 2002-06-17 | 2003-03-14 | 195d | finish no earlier than 2003-03-14 | T1 | 1560h | 1560h |  |  | Rel indep | Ingbert |  |  | 34.123-3 |
| 2097 | 65 | **Rel-4 RAN improvements** | 938d? | 2000-08-14 A | 2004-03-17 A | 100% | 2000-08-14 | 2004-03-17 | 938d? |  | RP | 29336h | 29336h |  |  | NA | Stefania | RANimp |  |  |
| 2098 | 65.1 | Node B synchronisation for TDD | 160d | 2000-08-14 A | 2001-03-23 A | 100% | 2000-08-14 | 2001-03-23 | 160d | finish no earlier than 2001-03-23 | R1 | 1280h | 1280h | Siemens | S. Oestreich | Rel-4 | Patrick | RANimp-NBsync |  |  |
| 2099 | 65.2 | RAB support enhancement for Rel-4 | 155d | 2000-08-21 A | 2001-03-23 A | 100% | 2000-08-21 | 2001-03-23 | 155d | finish no earlier than 2001-03-23 | R2 | 1240h | 1240h | Ericsson | M. Israelsson, A. Krishnarajah | Rel-4 | Joern | RANimp-RABSE |  |  |
| 2100 | 65.4 | **Deleted - Conformance Test Aspects - Rel-4 RAN Improvements** | 577d? | 2002-01-01 A | 2004-03-17 A | 100% | 2002-01-01 | 2004-03-17 | 577d? |  | T1 | 19312h | 19312h |  |  |  | Ingbert |  |  | 0% |
| 2101 | 65.4.1 | Deleted - Testing Radio access bearer support enhancments | 175d | 2002-01-01 A | 2002-09-02 A | 100% | 2002-01-01 | 2002-09-02 | 175d | finish no earlier than 2002-09-02 | T1 | 1400h | 1400h |  |  |  | Ingbert |  | TP-17 |  |
| 2102 | 65.4.2 | Deleted - Testing RAB support enhancements-Robust Header Compression | 332d | 2002-05-28 A | 2003-09-03 A | 100% | 2002-05-28 | 2003-09-03 | 332d | finish no earlier than 2003-09-03 | T1 | 2656h | 2656h |  |  | Rel-4 | Ingbert | RABimp-RoCH | TP-21 | 34.123-1, -2 |
| 2103 | 65.4.3 | Deleted - Testing RAB support enhancements-Robust Header Compression - TTCN | 472d | 2002-05-28 A | 2004-03-17 A | 100% | 2002-05-28 | 2004-03-17 | 472d | finish no earlier than 2004-03-17 | T1 | 3776h | 3776h |  |  | Rel-4 | Ingbert |  | TP-23 | 34.123-3 |
| 2104 | 65.4.4 | Testing of Extended Robut Header Compression | 270d | 2002-09-18 A | 2003-09-30 A | 100% | 2002-09-18 | 2003-09-30 | 270d | finish no earlier than 2003-09-30 | T1 | 2160h | 2160h |  |  | Rel-4 | Ingbert | Ext-RoHC |  | 34.123-1, -2 |
| 2105 | 65.4.5 | Deleted - Testing of Extended Robut Header Compression - TTCN | 325d | 2002-09-18 A | 2003-12-16 A | 100% | 2002-09-18 | 2003-12-16 | 325d | finish no earlier than 2003-12-16 | T1 | 2600h | 2600h |  |  | Rel-4 | Ingbert |  | TP-22 | 34.123-3 |
| 2106 | 489.3.6 | Deleted - General changes to TS34.121 corresponding to release 4 | 263d? | 2003-03-03 A | 2004-03-03 A | 100% | 2003-03-03 | 2004-03-03 | 263d? | finish no earlier than 2004-03-03 | T1 | 2104h | 2104h |  |  | Rel-4 | Ingbert | RANimp-test | TP-23 | 34.108, 34.121 |

Notes:
- 2080: Rel4 added
- 2088: Stopped at RP#14
- 2090: Marked as stopped 12/2008
- 2091: Marked as stopped 12/2008
- 2092: Marked as stopped 12/2008
- 2093: finish date set
- 2094: finish date set
- 2095: finish date set
- 2096: finish date set
- 2099: 29 Nov 2000: split into ROHC and non-ROHC part; 5 Mar 2001: splitting off of ROHC for Rel-4 agreed by R2
- 2100: Marked as stopped 12/2008
- 2101: Marked as stopped 12/2008
- 2102: UID changed. Marked as stopped 12/2008
- 2103: UID changed. Marked as stopped 12/2008
- 2104: Marked as closed 12/2008 (was marked 15% complete)
- 2105: Marked as stopped 12/2008
- 2106: Marked as stopped 12/2008

| ID | WBS | Task | Duration | Start | Finish | Complete | Baseline start | Baseline finish | Baseline duration | Constraint | Resources | Work | Actual work | Text1 | Text4 | Text6 | Text8 | Text12 | Text3 | Text5 |
| --- | --- | --- | --- | --- | --- | --- | --- | --- | --- | --- | --- | --- | --- | --- | --- | --- | --- | --- | --- | --- |
| 2107 | 66 | **Rel-4 Emergency call enhancements** | 628d | 2000-01-03 A | 2002-05-28 A | 100% | 2000-01-03 | 2002-05-28 | 628d |  | N1 | 7936h | 7936h | EMC1 | Ericsson | NA | Frederic |  |  |  |
| 2108 | 66.1 | **For CS based calls** | 628d | 2000-01-03 A | 2002-05-28 A | 100% | 2000-01-03 | 2002-05-28 | 628d |  | N1 | 3600h | 3600h | EMC1-CS | Ericsson | Rel-4 | Frederic |  |  |  |
| 2109 | 66.1.1 | Distinction in CS domain of emergency call types to different emergency services | 40d | 2000-05-01 A | 2000-06-23 A | 100% | 2000-05-01 | 2000-06-23 | 40d | finish no earlier than 2000-06-23 | S1 | 320h | 320h |  |  | Rel-4 | Alain |  |  |  |
| 2110 | 66.1.2 | Distinction in CS domain of emergency calls to different emergency types | 22d | 2000-08-24 A | 2000-09-22 A | 100% | 2000-08-24 | 2000-09-22 | 22d | finish no earlier than 2000-09-22 | N1 | 176h | 176h |  |  | Rel-4 | Frederic |  |  |  |
| 2111 | 66.1.3 | Deleted - Conformance Test Aspects - Emergency call enhancements | 151d | 2000-01-03 A | 2000-07-28 A | 100% | 2000-01-03 | 2000-07-28 | 151d |  | T1 [99.3%] | 1200h | 1200h |  |  |  | Ingbert | TP-08 |  |  |
| 2112 | 66.1.4 | Testing CS based emergency calls | 67d | 2002-02-25 A | 2002-05-28 A | 100% | 2002-02-25 | 2002-05-28 | 67d | finish no earlier than 2002-05-28 | T1 | 536h | 536h |  |  |  | Ingbert |  | 34.123-1 |  |
| 2113 | 66.1.5 | Testing CS based emergency calls - TTCN | 134d | 2001-11-22 A | 2002-05-28 A | 100% | 2001-11-22 | 2002-05-28 | 134d | finish no earlier than 2002-05-28 | T1 | 1072h | 1072h |  |  |  | Ingbert |  | 34.123-3 |  |
| 2114 | 67 | **Rel-4 Terminal interfaces** | 315d | 2000-01-03 A | 2001-03-15 A | 100% | 2000-01-03 | 2001-03-15 | 315d |  | T2 | 14296h | 14296h | TI |  | NA | Kimmo |  |  |  |
| 2115 | 67.1 | **AT commands enhancements** | 314d | 2000-01-03 A | 2001-03-14 A | 100% | 2000-01-03 | 2001-03-14 | 314d |  | T2 | 5016h | 5016h | TI-ATC |  | Rel-4 |  |  | 27.007 |  |
| 2116 | 67.1.1 | Specification of AT commands for new services | 314d | 2000-01-03 A | 2001-03-14 A | 100% | 2000-01-03 | 2001-03-14 | 314d | finish no earlier than 2001-03-14 | T2 | 2504h | 2504h |  |  |  |  |  | 27.007 |  |
| 2117 | 67.2 | **Wide Area Data Synchronisation** | 314d | 2000-01-03 A | 2001-03-14 A | 100% | 2000-01-03 | 2001-03-14 | 314d |  | T2 | 5016h | 5016h | TI-WADS |  | NA |  |  |  |  |
| 2118 | 67.2.1 | Continues evolution of Synchronisation protocol | 314d | 2000-01-03 A | 2001-03-14 A | 100% | 2000-01-03 | 2001-03-14 | 314d | finish no earlier than 2001-03-14 | T2 | 2504h | 2504h | TI-SYNC-EVOL |  | Rel-4 |  |  | 27.903, 27.103 |  |
| 2119 | 67.3 | Terminal local model | 218d | 2000-05-16 A | 2001-03-15 A | 100% | 2000-05-16 | 2001-03-15 | 218d | finish no earlier than 2001-03-15 | T2 | 1744h | 1744h | TLM | Ericsson | Rel-4 |  |  | 23.227 | Olga.Tome@ECS.ERICSSON.SE |
| 2120 | 68 | **Rel-4 Location Services enhancements** | 455d | 2000-04-03 A | 2001-12-28 A | 100% | 2000-04-03 | 2001-12-28 | 455d |  | S2 | 26799.2h | 26799.2h | LCS1 | Nokia | NA | Maurice |  |  | Jan Kall |
| 2121 | 68.1 | CBS interactions | 455d | 2000-04-03 A | 2001-12-28 A | 100% | 2000-04-03 | 2001-12-28 | 455d | finish no earlier than 2001-12-28 | T2 | 3640h | 3640h | LCS1-CBS |  | Rel-4 |  |  | 23.041 |  |
| 2122 | 68.2 | LCS support in the CS domain | 180d | 2000-05-15 A | 2001-01-19 A | 100% | 2000-05-15 | 2001-01-19 | 180d | finish no earlier than 2001-01-19 | S2 | 1440h | 1440h | LCS1-CS |  | Rel-4 | Maurice |  |  |  |
| 2123 | 68.3 | **LCS support in the PS domain** | 435d | 2000-05-01 A | 2001-12-28 A | 100% | 2000-05-01 | 2001-12-28 | 435d |  | S2 | 13560h | 13560h | LCS1-PS |  | Rel-4 | Maurice |  |  |  |
| 2124 | 68.3.1 | Stage 1 | 40d | 2000-07-03 A | 2000-08-25 A | 100% | 2000-07-03 | 2000-08-25 | 40d | start no earlier than 2000-07-03 | S1 | 320h | 320h |  | Pacific Bell Wireless |  | Alain |  | 22.071 | Randolph Wohlert (rwohlert@tri.sbc.com) |
| 2125 | 68.3.2 | Stage 2 | 190d | 2000-05-01 A | 2001-01-19 A | 100% | 2000-05-01 | 2001-01-19 | 190d | finish no earlier than 2001-01-19 | S2 | 1520h | 1520h |  |  |  | Maurice |  | 23.271 |  |
| 2126 | 68.3.3 | **Stage 3** | 355d | 2000-08-21 A | 2001-12-28 A | 100% | 2000-08-21 | 2001-12-28 | 355d |  | N1 | 8240h | 8240h |  |  |  | Frederic |  |  |  |
| 2127 | 68.3.3.1 | Layer 3 LCS signaling UE (MS) -SGSN (UMTS PS and and GSM-GPRS) | 355d | 2000-08-21 A | 2001-12-28 A | 100% | 2000-08-21 | 2001-12-28 | 355d | finish no earlier than 2001-12-28 | N1 | 2840h | 2840h |  | Nokia |  | Frederic |  |  | Janne Muhonen |
| 2128 | 68.3.3.2 | MAP impacts of LCS | 160d | 2000-08-21 A | 2001-03-30 A | 100% | 2000-08-21 | 2001-03-30 | 160d | finish no earlier than 2001-03-30 | N4 | 1280h | 1280h |  |  |  | Kimmo |  |  |  |
| 2129 | 68.3.3.3 | GTP signaling for LCS | 160d | 2000-08-21 A | 2001-03-30 A | 100% | 2000-08-21 | 2001-03-30 | 160d | finish no earlier than 2001-03-30 | N4 | 1280h | 1280h |  |  |  | Kimmo |  |  |  |
| 2130 | 68.4 | **UE positioning Rel-4** | 260d | 2000-04-03 A | 2001-03-30 A | 100% | 2000-04-03 | 2001-03-30 | 260d |  | RP | 4591.2h | 4591.2h | LCS1-UEpos |  | NA | Stefania |  |  |  |
| 2131 | 68.4.1 | Iub/Iur interfaces for methods Rel 99 | 233.9d | 2000-04-03 A | 2001-03-30 A | 100% | 2000-04-03 | 2001-03-30 | 233.9d | finish no earlier than 2001-03-30 | R3 | 1871.2h | 1871.2h | LCS1-UEpos-IubIur | Ericsson | Rel-4 | Juha |  |  | Yun-Chao Hu |
| 2132 | 68.4.2 | UE positioning enhancements - IPDL for TDD | 150d | 2000-08-28 A | 2001-03-23 A | 100% | 2000-08-28 | 2001-03-23 | 150d | finish no earlier than 2001-03-23 | R2 | 1200h | 1200h | LCS1-UEpos-enh | Siemens | Rel-4 | Joern |  |  | M. Beckmann |

Notes:
- 2108: WI approved in TSG_10 / CN1#15: ID 2101 REMOVE-Emergency call recalling capability enhancement, no contributions
- 2110: Calls to different emergency services such as ambulance, fire brigade, police, etc. can be routed to respective different emergency centres. / NP-000447 is the stage 3 changes for CS call control protocol.
- 2111: UID changed. Marked as stopped 12/2008
- 2116: goal not completely achieved because of missing input
- 2117: AS: Rel5 changed to Rel4 according to SA#10 decision, milestone on testing added
- 2122: Only MAP impact foreseen so far. To be further split if needed.
- 2124: To be also considered: External LCS client identity, and Privacy options when PDP-context and when no PDP-context is established
- 2125: AS: 23.271 completed at SA#10
- 2128: Missing work task
- 2130: UID changed
- 2131: 27/11: WG corrected; rapporteur corrected
- 2132: 5 Mar 2001: splitting off of IPDL for TDD for Rel-4 agreed by R2

| ID | WBS | Task | Duration | Start | Finish | Complete | Remaining | Baseline start | Baseline finish | Baseline duration | Total slack | Constraint | Resources | Work | Actual work | Text1 | Text6 | Text8 | Text3 | Text4 | Text5 | Text12 |
| --- | --- | --- | --- | --- | --- | --- | --- | --- | --- | --- | --- | --- | --- | --- | --- | --- | --- | --- | --- | --- | --- | --- |
| 2133 | 69 | **Rel-4 UICC/(U)SIM enhancements and interworking** | 175d | 2000-07-24 A | 2001-03-23 A | 100% |  | 2000-07-24 | 2001-03-23 | 175d |  |  | T3 | 2800h | 2800h | UICC1 | NA | Xavier |  |  |  |  |
| 2134 | 69.1 | Common PCN Handset Specification (CPHS) | 175d | 2000-07-24 A | 2001-03-23 A | 100% |  | 2000-07-24 | 2001-03-23 | 175d |  | finish no earlier than 2001-03-23 | T3 | 1400h | 1400h | UICC1-CPHS | Rel-4 |  | 27.103 | One2One |  |  |
| 2135 | 70 | **Rel-4 (U)SIM toolkit enhancements** | 210d | 2000-06-05 A | 2001-03-23 A | 100% |  | 2000-06-05 | 2001-03-23 | 210d |  |  | T3 | 3360h | 3360h | USAT1 | NA | Xavier |  |  |  |  |
| 2136 | 70.1 | USAT local link | 210d | 2000-06-05 A | 2001-03-23 A | 100% |  | 2000-06-05 | 2001-03-23 | 210d |  | finish no earlier than 2001-03-23 | T3 | 1680h | 1680h | USAT1-LocLnk | Rel-4 |  |  | Gemplus | Jean-Francois Rubon |  |
| 2137 | 71 | **Rel-4 Security enhancements** | 576d | 2000-01-03 A | 2002-03-15 A | 100% |  | 2000-01-03 | 2002-03-15 | 576d |  |  | S3 | 24152h | 24152h | SEC1 | NA | Dionisio |  | Vodafone | Peter.Howard@vodafone.com |  |
| 2138 | 71.1 | Evolution of GSM CS algorithms (e.g. A5/3 development and deployment) | 272d | 2000-01-03 A | 2001-01-15 A | 100% |  | 2000-01-03 | 2001-01-15 | 272d |  | finish no earlier than 2001-01-15 | S3 | 2168h | 2168h | SEC1-CSALGO1 | Rel-4 | Dionisio |  |  |  |  |
| 2139 | 71.2 | **Evolution of GSM PS algorithms (e.g. GEA 2 deployment)** | 219d | 2000-02-22 A | 2000-12-22 A | 100% |  | 2000-02-22 | 2000-12-22 | 219d |  |  | S3 | 6024h | 6024h | SEC1-PSALGO1 | Rel-4 | Dionisio |  |  |  |  |
| 2140 | 71.2.1 | Main aspects | 199d | 2000-02-22 A | 2000-11-24 A | 100% |  | 2000-02-22 | 2000-11-24 | 199d |  | finish no earlier than 2000-11-24 | S3 | 1592h | 1592h |  |  | Dionisio |  |  |  |  |
| 2141 | 71.2.2 | Impact on GTP | 200d | 2000-03-20 A | 2000-12-22 A | 100% |  | 2000-03-20 | 2000-12-22 | 200d |  | finish no earlier than 2000-12-22 | N4 | 1600h | 1600h |  |  | Kimmo |  |  |  |  |
| 2142 | 71.2.3 | GEA capability indication in MS CM | 135d | 2000-06-19 A | 2000-12-22 A | 100% |  | 2000-06-19 | 2000-12-22 | 135d |  | finish no earlier than 2000-12-22 | N1 | 1080h | 1080h | SEC1-PSALGO1-GEACAP |  | Frederic |  | Vodafone Airtouch | Duncan Mills |  |
| 2143 | 71.3 | **Deleted - MAP application layer security** | 576d | 2000-01-03 A | 2002-03-15 A | 100% |  | 2000-01-03 | 2002-03-15 | 576d |  |  | S3 | 11352h | 11352h | SEC1-MAPAL | Rel-4 | Dionisio |  |  |  | SP-15 |
| 2144 | 71.3.1 | Deleted - Main aspects | 199d | 2000-02-21 A | 2001-03-29 A | 100% |  | 2000-02-21 | 2001-03-29 | 199d |  | start no earlier than 2000-02-21 | S3 | 1592h | 1592h |  |  | Dionisio |  |  |  | SP-11 |
| 2145 | 71.3.2 | Deleted - Other stage 3 aspects | 199d | 2000-02-22 A | 2000-11-24 A | 100% |  | 2000-02-22 | 2000-11-24 | 199d |  | finish no earlier than 2000-11-24 | N4 | 1592h | 1592h |  |  | Kimmo |  |  |  | CP-10 |
| 2146 | 71.3.3 | Deleted - CHECK STATUS - Visibility and Configurability of security | 576d | 2000-01-03 A | 2002-03-15 A | 100% |  | 2000-01-03 | 2002-03-15 | 576d |  | finish no earlier than 2002-03-15 | S3 | 4600h | 4600h | SEC1-VCS | Rel-5 | Dionisio |  | France Telecom | Sebastien.nguyenngoc@rd.francetelecom.com | SP-15 |
| 2147 | 72 | **Rel-4 Charging and OAM&P** | 221d | 2000-12-01 A | 2001-10-05 A | 100% |  | 2000-12-01 | 2001-10-05 | 221d |  |  | S5 | 10472h | 10472h | OAM | Rel-4 | Dionisio | 32-series | VoiceStream, Motorola |  |  |
| 2148 | 72.1 | Rel4 Principles, high level Requirements and Architecture | 145d | 2000-12-01 A | 2001-06-21 A | 100% |  | 2000-12-01 | 2001-06-21 | 145d |  | finish no earlier than 2001-06-21 | S5 | 1160h | 1160h | OAM-AR/PR | Rel-4 | Dionisio | 32.101, 32.102 | Motorola, Telia | Michael.Truss@MOTOROLA.COM; Tommy.R.Berggren@TELIA.SE |  |
| 2149 | 72.2 | Rel4 Performance Management | 216d | 2000-12-01 A | 2001-09-28 A | 100% |  | 2000-12-01 | 2001-09-28 | 216d |  | finish no earlier than 2001-06-21 | S5 | 1728h | 1728h |  | Rel-4 | Dionisio | 32.4xy, 52.402 | T-Mobile | karl-heinz.nenner@t-mobile.de |  |
| 2150 | 72.3 | Fault Management | 221d | 2000-12-01 A | 2001-10-05 A | 100% |  | 2000-12-01 | 2001-10-05 | 221d |  | finish no earlier than 2001-06-21 | S5 | 1768h | 1768h |  | Rel-4 | Dionisio | 32.111-1/4 | Lucent |  |  |
| 2151 | 72.4 | Configuration Management | 145d | 2000-12-01 A | 2001-06-21 A | 100% |  | 2000-12-01 | 2001-06-21 | 145d |  | finish no earlier than 2001-06-21 | S5 | 1160h | 1160h | OAM-CM | Rel-4 | Dionisio | 32.106-1/8 | Ericsson | thomas.tovinger@ericsson.com |  |
| 2152 | 72.5 | Rel4 Charging Management | 216d | 2000-12-01 A | 2001-09-28 A | 100% |  | 2000-12-01 | 2001-09-28 | 216d |  | finish no earlier than 2001-06-21 | S5 | 1728h | 1728h | OAM-CH | Rel-4 | Dionisio | 32.2xy (Charging) | T-Mobile | karl-heinz.nenner@t-mobile.de |  |
| 2153 | 72.6 | UTRAN Operations and Maintenance procedures | 145d | 2000-12-01 A | 2001-06-21 A | 100% |  | 2000-12-01 | 2001-06-21 | 145d |  | finish no earlier than 2001-06-21 | S5 | 1160h | 1160h | UOAM | Rel-4 | Dionisio | 32.800 | Mannesmann Mobilfunk | bert.boden@d2mannesmann.de |  |
| 2154 | 73 | **Global Text Telephony** | 2537d? | 2000-01-03 A | 2009-09-18 | 20% | 2023.4d? | 2000-01-03 | 2009-09-18 | 2537d? | 255d |  | S1,S2,S4,R5 | 26144h | 5848h | GTT | Rel Indep | Maurice |  | Ericsson | gunnar.hellstrom@omnitor.se |  |
| 2155 | 73.1 | Stage 1 | 188d | 2000-04-05 A | 2000-12-22 A | 100% |  | 2000-04-05 | 2000-12-22 | 188d |  | finish no earlier than 2000-12-22 | S1 | 1504h | 1504h | GTT | Rel Indep | Alain | 22.976, 22.226 |  |  |  |
| 2156 | 73.2 | Stage 2 | 206d | 2000-01-03 A | 2000-10-13 A | 100% |  | 2000-01-03 | 2000-10-13 | 206d |  |  | S2 | 1640h | 1640h | GTT | Rel Indep | Maurice | 23.226 |  |  |  |

Notes:
- 2134: 28/5/2001: CRs approved at TP-11. WI complete.
- 2136: 25/5/2001:CR was approved at TP-11. WI is complete
- 2137: Added BB UE authentication and rapporteur added. TO BE DELETED
- 2138: Algorithm development go-ahead at SA3#21. Scheduled for completion in August 2002?. Approved SA#17. DELETE ENTRY FROM REL-4?
- 2139: A5/3 development will consider new GEA algorithm based on Kasumi.
- 2140: Complete TSG#09 (09/2000). S3#17: Proposed for deletion. TO BE DELETED
- 2143: TO DELETE: REPLACED BY NDS-MAP and NDS-IP. TO BE DELETED, but replacement NDS-MAP was missing. Completed Auto Key Management -> Rel-6. Marked as stopped 12/2008
- 2144: UID changed. Marked as stopped 12/2008
- 2145: UID changed. Marked as stopped 12/2008
- 2146: CR approved at SA3#21 awaiting comments from CN1. Marked as stopped 12/2008
- 2147: az: WID appr.SA#13.
- 2149: Changed Rapp email
- 2152: Changed Rapp email
- 2154: SP-000162 agreed WI. Rapporteur / Gunnar Hellström, Ericsson Radio Systems AB, / email: gunnar.hellstrom@omnitor.se tel: +46 708 204 288

| ID | WBS | Task | Duration | Start | Finish | Complete | Baseline start | Baseline finish | Baseline duration | Total slack | Constraint | Resources | Work | Actual work | Text1 | Text6 | Text8 | Text3 |
| --- | --- | --- | --- | --- | --- | --- | --- | --- | --- | --- | --- | --- | --- | --- | --- | --- | --- | --- |
| 2157 | 73.3 | **Specification of Cellular Text telephone Modem** | 136d | 2000-09-11 A | 2001-03-19 A | 100% | 2000-09-11 | 2001-03-19 | 136d |  |  | S4 | 2704h | 2704h | GTT-CTM | Rel Indep | Paolo |  |
| 2158 | 73.3.1 | General description and C-code | 66d | 2000-09-11 A | 2000-12-11 A | 100% | 2000-09-11 | 2000-12-11 | 66d |  | finish no earlier than 2000-12-11 | S4 | 528h | 528h | GTT-CTM | Rel Indep | Paolo | 26.226, 26.230 |
| 2159 | 73.3.2 | Minimum Performance requirements | 136d | 2000-09-11 A | 2001-03-19 A | 100% | 2000-09-11 | 2001-03-19 | 136d |  | finish no earlier than 2001-03-19 | S4 | 1088h | 1088h | GTT-CTM | Rel Indep | Paolo | 26.231 |
| 2160 | 73.5 | Conformance Test Aspects - Global Text Telephony | 2348d? | 2000-09-21 | 2009-09-18 |  | 2000-09-21 | 2009-09-18 | 2348d? | 255d | finish no earlier than 2009-09-18 | R5 |  |  | GTT_Test | Rel Indep | Ingbert | 34.125 |
